# 3GPP_Release-2000

Schedule from MS Project, 1998-12-07 to 2014-09-17, A marks actual dates.

## Calendars

- Standard: Mon-Fri 08:00-12:00, 13:00-17:00; Sat-Sun off. Exceptions (off unless hours are given): 2000-01-15 08:00-12:00, 13:00-17:00, 2009-05-30 08:00-12:00, 13:00-17:00, 2011-08-27 to 2011-08-28 08:00-12:00, 13:00-17:00, 2011-09-24 08:00-12:00, 13:00-17:00, 2012-06-02 08:00-12:00, 13:00-17:00, 2012-09-01 08:00-12:00, 13:00-17:00.

## Resources

| Resource |
| --- |
| NP |
| N1 |
| N2 |
| N3 |
| N4 |
| N5 |
| TP |
| T1 |
| T2 |
| T3 |
| RP |
| R1 |
| R2 |
| R3 |
| R4 |
| SP |
| S1 |
| S2 |
| S3 |
| S4 |
| S5 |
| PCG |
| GP |
| No |
| CN4 |
| ? |
| WG G2 |
| G2 |
| G1 |
| G4 |
| G3 |
| All |
| Generic |
| MLST |
| G5 |
| S3, G2 |
| WG T2 |
| GP,G1 |
| G4,G5 |
| OMA |
| GP-G2 |
| Yes |
| GP, |
| N4, |
| GP, N1 |
| CT5 |
| C5 |
| C1 |
| C4 |
| C3 |
| C6 |
| G1, |
| 4 |
| ct |
| c,s,r |
| CT,RAN,SA |
| G2, |
| G1, G3 |
| CT6 |
| CT1 |
| CT1, CT3, CT4 |
| C1, C3, C4 |
| CP |
| R5 |
| C |
| Rel-8 |
| GP, G2 |
| R1,R4 |
| S5,C1 |
| CT,RAN,SA,GERAN |
| S3,C1,C4 |
| 5 |
| S1,C1,C3,C4,S5 |
| S1,C1,C3,C5 |
| S1,C1,C3,C4 |
| S1,S5 |
| S2,S3 |
| RAN,SA |
| RP,S5 |
| S2,CT |
| S1,CT |
| S1,CT,GERAN |
| S1,C5 |
| S3,CT |
| S4,CT |
| C1,SA |
| S1,S2 |
| S1,S4 |
| S2,S2,S3,CT |
| S2,S3,CT |
| S1,CT,GX |
| S1,S4,CT |
| S2,S2,S3,S5,CT |
| S1,S2,CT |
| S1,S2,S3,CT |
| S1,S2,S3,S5CT |
| S1,S2,S3,S5,CT |
| S2,S5,CT |
| S4,S3 |
| S1,C1 |
| CP,C1 |
| C1,C3 |
| C1,C3,C4 |
| S1,S5,CT |
| C4,C3 |
| CP,RAN,SA,GERAN |
| S1,S2,S3,S5,CP |
| S2,S3,CP |
| S2,CP |
| S1,CP,GX |
| S1,CP |
| S1,S4,CP |
| S1,S2,CP |
| S1,S2,S3,CP |
| S2,S5,CP |
| S3,CP |
| S1,S5,CP |
| RAN,SA,GERAN |
| S1,S2,S3,S5,C1,C3,C4,C6 |
| S2,S3,C1,C3,C4 |
| S2,C4 |
| S2,C1,C3,C4 |
| S2,C1,C4 |
| S2,S3,C1,C4 |
| S1,C1,C4,G2 |
| C1,C4 |
| S1,C1,C3 |
| S1,S4,C1,C3,C4 |
| S1,S2,S3,C1,C3,C4 |
| S2,S5,C3 |
| S1,S2,C1,C4 |
| S2,C1 |
| S2,C1,C3 |
| S3,C1,C3,C4 |
| S1,S5,C1,C3,C4 |
| S2,C3,C4 |
| C3,C1 |
| R2,R4 |
| R2,R5 |
| RP,R5 |
| RP,S5,R5 |
| R1,R5 |
| S1,C1,R5 |
| S1,C1,S4,R5 |
| GERAN |
| G3new |
| G1, G3new |
| C4,C1,C3 |
| R1.R4 |
| R1, R4 |
| R2,R3 |
| C3,C4 |
| S4,C3 |
| S4,C3,C1,C4 |
| S1,S2,C1 |
| S1,S2<C1,C3,C4 |
| S1,S2,C1,C3,C4 |
| S5,C1,C3,C4 |
| GP,C4 |
| C4,C1 |
| S2,S1 |
| RP,SP,GP |
| RP,SP,CP,GP |
| CP,GP,RP,SP |
| GP,C4,S4 |
| S1,C1,C4 |
| S1,S2,C3,C1 |
| R2,R4,R3 |
| CP,GP, RP,SP |
| S2,S1,C1,S5 |
| S2,S1,C1 |
| S1,C1,S4 |
| S1,S2,GP,C4,R2 |
| S1,GP,R2 |
| S1,C6 |
| S1,S2,C1,S4 |
| S2,S3,S5,C1,C3,C4 |
| S2,S5,C1 |
| S2,S3,S5 |
| CP,GP, RP,SP,TP |
| S2,C4,C1 |
| S1,C1,C4,S3 |
| S2,S5 |
| S3,C1 |
| S3,C4 |
| S1,C4 |
| S2,S5,C3,C1 |
| S2,S1,S5,C1,C4 |
| S1,R1,C3 |
| S1,C1,R2 |
| S2,S1,C1,C4 |
| S1,C1,C6 |
| GP,S4,C4,C1,C3 |
| C3,C1,C4 |
| S1,C4,C1 |
| S1,S3 |
| S1,S2,S5,C3,C4 |
| R4,G1 |
| G1,R4 |
| RP,GP |
| R4,GP |
| R3,R2 |
| C6,RP,SP |
| R5,C6 |
| CP,RP,SP |
| RP,SP,CP |
| R3,S5 |
| S1,S2,RP |
| S1,S2,S5,RP |
| S2,S1,RP |
| Rel-9 |
| S3,C6 |
| S1,S2,S3,S5,RP |
| S2,S1,S3 |
| S1,S2,S3 |
| S1,S2,S3,S5 |
| C6,R5 |
| S1,S2,RP,GP |
| S1,S2,S4,S5,RP,GP |
| GP,G2 |
| GP,GP, N1 |
| GP,S2,G1,G2 |
| GP,R2,R3,S2,G1,G2 |
| GP,S2,S5,R2,R3,G2,G1 |
| GP,R3 |
| N4,S2 |
| GP,RP |
| GP,S2,RP |
| G5,G4 |
| G4,R3 |
| S2,R2,R4 |
| S1,S2,R2,R4 |
| GP,S5 |
| S1,S2,S5 |
| R4,R5 |
| R4,R2,R3,R5 |
| S2,S5,N4,RP |
| S1,S2,S3,S5,NP |
| S2,S4,S5 |
| T2,S1,S4,S5 |
| SP,RP |
| S2,RP |
| S1,S2,CP,G2 |
| CP,SP |
| S1,G2 |
| SP,CP |
| S1,S2,S5,C3 |
| S1,C1,S3 |
| G1,G3new |
| C4, C3, C1C4 |
| C4,C3,C1 |
| S1,S2,S3,S5,R2,R3,R4 |
| S1,S2,S3,R2 |
| S2,S3,S5,C4,R2 |
| S1,S5,C1 |
| S1,S2,S3,C1,C3,C4,R2 |
| Ggp |
| S3,S2,C1,C4,G2 G3new |
| R1,R2,R3,R4 |
| R4,R1,R2,R3 |
| R4,R2,R3 |
| S1,C1,C4,R2 |
| R4,R2 |
| S2,C4,R2,R4 |
| S2,C4,R2 |
| S2,S3,S5,C3,C4,R2 |
| S1,S2,S4,T2 |
| S1,S2,S4 |
| S1,S2,S4,R5 |
| S3,S2,C1,C4,G2,G3new |
| GP,C1 |
| S1,S5,C4 |
| S1,S2,S3,S5,R2,R3,R4,GP |
| GP,C4,C3,C1 |
| SMG9 |
| SMG1 |
| SMG2 |
| N3,R5 |
| N1, N2, N4, G1, G2, R3, S1, SMG2 |
| S1,SMG1 |
| SMG1,N4 |
| N1,C1,N4,S1,T2,G2,SMG1,SMG2,SMG3,SMG7,SMG9 |
| SMG1,N2 |
| S1,S2,N2,N4 |
| N4,N2 |
| G1,G2 |
| G1,G2,C1 |
| G1,G2,N1 |
| SMG2, SMG1, SMG3, SMG4, SMG7, SMG9, SMG10, G1, G2, G3, N1, N3, T2 |
| SMG2,G1 |
| S1,G1,G2 |
| SMG1,N1,G1,G2 |
| G2,G1 |
| G1,G2,G3,S1,S2,SMG1,SMG2,SMG7,N1,N2,N3,N4,T2 |
| 23.003, 23.008, 29.060 |
| S1, S2, SMG1, SMG2, SMG12, G2, N1, N2, N4 |
| S1,S2,SMG1,SMG2,SMG12,G2,N1,N2,N4 |
| S1,SMG2,N1,N2,N4 |
| SMG1,T2 |
| S1,N1,N2,N4 |
| S1,S2,N5 |
| SMG2,SMG7,G2,T2 |
| S3,N1,N2,N3 |
| S3,N1,N2,N4 |
| SMG9,T3 |
| SMG2,SMG3,SMG7,G2,N2 |
| SMG2,N1,G1,G2 |
| S1,N2 |
| N1,N3 |
| S2,N1 |
| N1,N2,N4 |
| N2,N1,N4 |
| N2,N4 |
| S1,T3 |
| T2,N3 |
| S3,N2 |
| T2,S1 |
| S1,N4 |
| SMG1,SMG2,SMG7 |
| N1,S1,T1 |
| SMG1,SMG3 |
| N4,S2,N1 |
| S1,S2,SMG1,SMG2,SMG7,G1,G2,G3,N1,N2,N3,N4,T2 |
| SMG1,N3 |
| S1,N3 |
| CP,SP,SMG |
| CP,SP,TP,GP,SMG |
| NP,SP,TP,GP,SMG |
| NP,GP, RP,SP,TP |
| SMG2,SMG1,SMG3,SMG4,SMG7,SMG9,SMG10,G1,G2,G3,N1,N3,T2 |
| S1,N2,N4 |
| S1,S2,S3,C1,C3,C4,R2,R3 |
| R2,R3,R1,R4 |
| R2,R3,R4 |
| R2,R1,R3,R4 |
| S2,C4,R2,R3,R4 |
| S2,C4,R2,R1,R3,R4 |
| S2,S3,S5,C3,C4,R2,R3,R4 |
| R1,R2,R4 |
| R3,R1,R4 |
| S2, |
| S2,G2, |
| S1,S2,G2, |
| S1,S2,G2,R2,R3, |
| S1,S2,C4,G2,R2,R3 |
| S1,S2,N4,G2,R2,R3 |
| S1,S2,SMG1,SMG2,SMG12,G2,N1,N2,N4,R2,R3 |
| S1,SMG1,T2 |
| S1,SMG1,S2 |
| S1,N4,N2 |
| T2,N1,N3 |
| S3,N2,N4 |
| SMG1,SMG2,SMG3,SMG7,SMG9,N1,C1,N4,S1,T2,G2 |
| SMG1,N2,N4 |
| S2,T2,N1,N2,N4 |
| S1,T2 |
| S1,S2,C4 |
| S1,S2,N4,RP |
| S2,N4 |
| S1,S2,N3,N4,RP |
| S1,S2,SMG1,SMG2,SMG12,T2,G2,N1,N2,N4,R2,R3 |
| S1,T2,N1,N3 |
| S1,S2,SMG1,SMG2,SMG12,T2,G2,N1,N2,N3,N4,R2,R3 |
| S1,S2,S3,SMG1,SMG2,SMG12,G2,N1,N2,N4,R2,R3 |
| S1,S2,SMG,G1,G2,G3,N1,N2,N3,N4,T2 |
| S1,S2,SMG,T2,G2,N1,N2,N3,N4,R2,R3 |
| S1,S3,SMG,G1,G2,G3,N1,N2,N3,N4,T2 |
| S1,S3,T2,N2,N4 |
| S1,S2,SMG,T2,G1,G2,G3,N1,N2,N3,N4 |
| G2,S2 |
| T1,R5 |
| R5,T1 |
| S1,S2,S4,T1,R5 |
| S1,S2,S4,S5,T1,RP,GP |
| S1,S2,S3,S5,R2,R3,R4,GP,C1 |
| S1,S2,S3,SMG1,SMG2,SMG12,N1,N2,N4,R2,R3 |
| S1,S2,SMG,T2,N1,N2,N3,N4,R2,R3 |
| NP,SP,TP,SMG |
| S1,S2,SMG,T2,N1,N2,N3,N4 |
| SMG,N1 |
| SMG |
| S1,S2,SMG1,SMG2,SMG7,N1,N2,N3,N4,T2 |
| SMG2,SMG1,SMG3,SMG4,SMG7,SMG9,SMG10,N1,N3,T2 |
| S1,SMG |
| SMG2,SMG7,T2 |
| SMG2,S2 |
| N1,N2,N4,R3,S1,SMG |
| SMG2,SMG3,SMG7,N2 |
| SMG1,SMG2,SMG3,SMG7,SMG9,N1,C1,N4,S1,T2 |
| S1,S2,SMG,N3,N4,RP |
| S1,S2,S4,SMG,N3,N4,RP |
| S2,C1,C4,R2,R1,R3,R4 |
| R2,S2,S4 |
| G3new,R5 |
| GP,R4 |
| S2,S4,R2 |
| SP,GP |
| RP,SP |
| S2,S1,S3,S5 |
| S3,S1 |
| N4,N1,N2,S2 |
| S2,G1,G2,R2,R3 |
| S2,G1,G2 |
| G1,G2,R2,R3 |
| N4,T3 |
| S3,S2,N1,N4,T3,OMA |
| T2,S1,S4,S5,OMA |
| S2,N3 |
| S4,S1 |
| N4,N3,S1 |
| R5,G3new |
| R4,R2,R1 |
| S2,R2 |
| C3, C4,C1 |
| S3,C1,C4,C3 |
| C1,C4,C3 |
| S2,C1,C4,C3 |
| R3,R5 |
| S1,S2,C3 |
| R1,R2 |
| S3,C1,C4,G2,G3new |
| R1,R3 |
| GP,N1 |
| R1,R2,R3 |
| R3,R2,R4 |
| R4,R3 |
| S1,S2,R2,R3 |
| S1,S2,S3,C1,C3,C4,R2,R3,R5 |
| S2,S1,S5 |
| C4, C1 |
| C3, C1, C4 |
| S2,S1,S3,S5,C4,C1 |
| S2,C3,C1,C4 |
| S2,S1,S5,C3 |
| GP,S2,C1 |
| GP,S2,C1,G2 |
| G2,S2,C1 |
| v |
| G3new,G1,G2 |
| G1,G2,C1,G3new |
| S2,S1,S5,C1,C3 |
| C1,C3,C4,R5 |
| R2,R1 |
| S1<S2,N1,R2,R5 |
| S1,S2,N1,R2,R5 |
| S2,R5 |
| S1,S2,S5,R5 |
| S2,C1,C4,R2,R1,R3,R4,R5 |
| S1,S2,S3,S5,NP,R5 |
| S1,S2,S4,S5,RP,R5,GP |
| S1,S2,S3,S5,C1,C6,R2,R3,R4 |
| S1,S2,S3,S5,C1,C6,R2,R3,R4,GP |
| S4,R2 |
| S1,S2,C1,C4,G2 |
| S4,C3,C4 |
| S5,C1,C4 |
| S2,C4,C3,C1 |
| C4, C3, C1 |
| S2,S4,R2,C4,C3,C1 |
| GP1,GP2 |
| GP,GP1,GP2 |
| GP,G1,G2 |
| G2,R3 |
| S1,S2,S3,C1,C3,C4,G2 |
| GP,G1,C1 |
| S1,S2,C4,C3,C1 |
| - |
| GP,G1,G2,G3new |
| S1,S2,S3,C1,C3,C4,G2,R2,R3 |
| S1,S2,C1,C3,C4,G2,R2,R3 |
| C1,C6 |
| GP,G2,C4 |
| S2,C3 |
| R5,R4 |
| C4,GP,G2 |
| S1,S2,C1,C4,G2,R2,R3 |
| R1,R2,R4,S3 |
| S2,S5,C3,C1,C4 |
| S2,S4,C4,C3,C1 |
| S2,S4 |
| S3,S1,S2 |
| S1,S2,S3,C1,R2 |
| S3,S1,S2,C1,R2 |
| S2,C3,S5 |
| S1,S2,C1,C4,C3,G2,R2,R3 |
| S5,C4 |
| S2,S1,C3 |
| C1,C4,C3,C6 |
| S1,S2,C1,C4,C3,C6,G2,R2,R3 |
| R1,R2,R4,S3,C4,C6 |
| R4,R1,R4,R1,R2,R3,R3 |
| S2,R3,R2 |
| S1,S2,S5,CP |
| S1,S3,CP |
| C6,C1 |
| R4,R2,R1,R3 |
| R3,R1,R2 |
| R1,R4,R2,R3 |
| S2,C4,C1,C3 |
| R3,R1,R2,R4 |
| C4,S1 |
| S2,S5,R3,GP, |
| S2,S5,R3,GP |
| S1,S2,S3,S5,C1,C3,C4 |
| S2,S3,S5,C1,C3,C4,C6 |
| S5,S1 |
| 03.06.2011 |
| CT1 CT3, CT4 |
| CT3, |
| CT4 |
| CT3 |
| GP,G2,G1 |
| S5,S1,C1 |
| SP,RP,CP |
| SP,CP,GP,RP |
| R1,R2,R4,R3 |
| R4,R2,R5 |
| R2,R4,R5 |
| R1,R2,R4,S2,S3,C4,C6 |
| C1-IETF |
| S4-IETF |
| C1-IETF, C3-IETF, C4-IETF |
| S3-IETF |
| C4-IETF |
| C1-IETF, C3-IETF |
| S2,S4,C1,R2 |
| S2,S4,C3,C4 |
| S2,S4,C1,C3,R2 |
| S1,S2,C1,IETF |
| S4,IETF |
| C1,C4,IETF |
| S2,S4,C1,C3,R2,IETF |
| S3,C1,C4,C3,IETF |
| S3,C4,IETF |
| C1,IETF |
| S1,S2,S3,S5,C1,C3,C4,C6,IETF |
| S2,S3,C1,C4,IETF |
| S1,S2,C1,C3,C4,IETF |
| C1,C3,C4,IETF |
| S1,S5,C1,C3,C4,IETF |
| C1,C3,IETF |
| S2,C1,C3,C4,IETF |
| S2,S4,C3,C4,IETF |
| S5,C1,C4,IETF |
| S5,C1,C3,C4,IETF |
| S2,S3,S5,C1,C3,C4,IETF |
| S2,IETF |
| S3,C1,C3,C4,IETF |
| S2,S3,C1,C3,C4,IETF |
| S3,S2 |
| S3,S2,C1 |
| S3,S1,S2,C1 |
| S2,S5,N3 |
| S1,S2,S3,S5,N1,N3,N4,T3 |
| S5,N4,R3 |
| S1,S2,S5,C1,C4,C3,C6,G2,R2,R3 |
| S2,N1,N4,R3,GP |
| T2,S3 |
| S3,N4,N1 |
| S2,N3,N4 |
| S3,T2 |
| S2,S1,S3,S5,RP,GP |
| S1,S2,S3,S5,R5 |
| S1,S2,S3,S5,NP,T3,T1,R5 |
| S3,T3 |
| GP,S3 |
| S1,S2,S3,S4,S5,RP,R5,GP |
| N1,N4 |
| S1,S2,S3,S4,N1,N3,N4,OMA |
| S2,C1,C3,C4,G2,R2,R3 |
| S1,C4,C3 |
| S2,S1,C1,C4,IETF |
| C1,C3,C4,C6 |
| C4,C1,C6 |
| S1,S2,S3,C1,C3,C4,C6 |
| S2,S1,C1,C3,C4 |
| S1,S2,C1,C3 |
| C1.IETF |
| C1-IETF,C4-IETF |
| G1,C1 |
| G1,S2,C4 |
| G2,S2,C4 |
| R1,R2,R3,R4,R5 |
| R2,R4,R3,R5 |
| R3,R2,R5 |
| R2,R3,C1,C6 |
| S1,S2,S3,C1,C3,C4,C6,R2,R3 |
| R4,R1 |
| S2,S4,C4,C3,C1,IETF |
| S2,C4,C3 |
| S3.C4,C1 |
| G2,C4 |
| R4,G1,G3new |
| C4,G2 |
| S3,C4,C1 |
| R2,R3,R5 |
| R1,R2,R4,R5 |
| S1,S2,S3,S5,C1,C6,R2,R3,R4,R5,GP |
| S1,C1,C4,R2,R5 |
| S2,S3,S5,C3,C4,R2,R3,R4,R5 |
| R2,R1,R3,R4,R5 |
| S3-IETF, C1-IETF |
| S3-IETF,C1-IETF |
| C1-IETF,C3-IETF |
| S2-IETF |
| S2,S1,C1,C3,C4,IETF |
| 25.101, 25.104, 25.141, 25.317 |
| S1,G2,S2,C1 |
| S1,C1,C4,R2,R3,R5 |
| S5,S2 |
| S4,C3,C4,IETF |
| S4,S3,C3,C4,IETF |
| S4,S3,C3,C4 |
| S4,S3,IETF |
| S1,S2,S3,S5,C1,C3,C4,C6,R2,R3 |
| C1,C4,C6 |
| S1,S2,S5,C1,C4,C6,G2,R2,R3 |
| GP,G1,C1,G3new |
| S2,S5,C1,C3 |
| C4,C3,G2 |
| S2,S1,S5,C3,C1,C4 |
| C3,C4,C1 |
| S2,S1,S5,C3,C4,C1 |
| RAN1 |
| RAN2 |
| RAN3 |
| RAN4 |
| R4,R2,R3, |
| Feasibility Study on LTE Device to Device Communications – Radio Aspects |
| SMG1,SMG2,SMG3,SMG7,SMG9,N1,N4,S1,T2 |
| C3-IETF, C4-IETF |
| S3-IETF,C1-IETF,C3-IETF |
| C3-IETF |
| C3,IETF |
| S2,C1,C4,C3,IETF |
| S1,S2,S3,C1,C3,C4,R2,R3,R5,IETF |
| C1-IETF,C3-IETF,C4-IETF |
| C4,C1,C3,IETF |
| S2,C4,C1,C3,IETF |
| C1,C4,C3,IETF |
| S2,S1,T2,N1,N4,R3,R2 |
| S2,S1,S2,S1,N1,N4 |
| S2,S1,N1,N4 |
| S2,R2,G1 |
| S2,S1,S3,S5,N4,R2,R3,GP |
| S1,S2,N4 |
| S2,OMA |
| S2,N4,OMA |
| S2,S5,N4,R2,R4 |
| S2,S5,N4,R2,R4,OMA |
| GP,R2 |
| S1,S2,GP,R2 |
| G1,G3 |
| S1,G2,R2 |
| S2,S5,N4,R2,R4,R5,OMA |
| SR5 |
| S3,C4,C1,R5 |
| S3,S1,C1 |
| S2,C4,C3,G2 |
| SP,CP,RP |
| S3,R5 |
| GP,G2,G3new |
| S1,S2,S3,S4,S5,N1,N3,RP,R5,GP |
| S1,S2,S3,S4,S5,N1,N3,RP,R5,T1,GP |
| S1,S2,S3,S4,S5,N1,N3,RP,R5,T1,GP,G2,G3new |
| S1,S2,S3,S4,S5,N1,N3,R2,R4,R5,T1,GP,G2,G3new |
| S1,S2,S5,C1,C4,C6,G2,R2,R3,G3new |
| SP,CP,RP,GP |
| G2,G1,G3new |
| G2,G1,C1,G3new |
| RAN |
| R |
| S2,S1,S3,S5,R2 |
| S2,S1,S3,S5,R2,R3 |
| S1,S2,S5,C1,C4,C6,G2,R2,R3,R5,G3new |
| C1,C4,R5,IETF |
| C1,R5 |
| R3,R1 |
| R3,GP |
| S3,IETF |

## Schedule

| ID | WBS | Task | Type | Duration | Start | Finish | Complete | Remaining | Baseline start | Baseline finish | Baseline duration | Total slack | Constraint | Resources | Work | Actual work | Text6 | Text1 | Text2 | Text4 | Text5 | Text7 | Text8 | Text11 |
| --- | --- | --- | --- | --- | --- | --- | --- | --- | --- | --- | --- | --- | --- | --- | --- | --- | --- | --- | --- | --- | --- | --- | --- | --- |
| 1 | 1 | Version 2012 Sep 30 | milestone | 0d? | 2000-01-03 | 2000-01-03 |  |  | 2000-01-03 | 2000-01-03 | 0d? | 3845d | finish no earlier than 2000-01-03 | - |  |  |  |  |  |  |  |  |  |  |
| 2 | 2 | Rel-11 Stage 1 frozen 09/2011 | milestone | 0d? | 1998-12-07 | 1998-12-07 |  |  | 1998-12-07 | 1998-12-07 | 0d? | 4125d | finish no earlier than 1998-12-07 | - |  |  |  |  |  |  |  |  |  |  |
| 3 | 3 | Rel-11 Stage 2 frozen 03/2012 | milestone | 0d? | 1998-12-07 | 1998-12-07 |  |  | 1998-12-07 | 1998-12-07 | 0d? | 4125d | finish no earlier than 1998-12-07 | - |  |  |  |  |  |  |  |  |  |  |
| 4 | 4 | Rel-11 Stage 3 frozen 09/2012 | milestone | 0d? | 1998-12-07 | 1998-12-07 |  |  | 1998-12-07 | 1998-12-07 | 0d? | 4125d | finish no earlier than 1998-12-07 | - |  |  |  |  |  |  |  |  |  |  |
| 5 | 5 | Rel-12 Stage 1 freeze 03/2013 |  | 1d? | 2000-01-03 | 2000-01-03 |  |  | 2000-01-03 | 2000-01-03 | 1d? | 3844d |  | - | 8h |  |  |  |  |  |  |  |  |  |
| 6 | 6 | Rel-12 Stage 2 freeze 12/2013 |  | 1d? | 2000-01-03 | 2000-01-03 |  |  | 2000-01-03 | 2000-01-03 | 1d? | 3844d |  | - | 8h |  |  |  |  |  |  |  |  |  |
| 7 | 7 | Rel-12 Stage 3 freeze 06/2014 |  | 1d? | 2000-01-03 | 2000-01-03 |  |  | 2000-01-03 | 2000-01-03 | 1d? | 3844d |  | - | 8h |  |  |  |  |  |  |  |  |  |
| 8 | 8 | Gantt: dark blue=done; light blue=to be done; grey: previous values; black=summary | milestone | 0d? | 1998-12-07 | 1998-12-07 |  |  | 1998-12-07 | 1998-12-07 | 0d? | 4125d | finish no earlier than 1998-12-07 | - |  |  |  |  |  |  |  |  |  |  |
| 9 | 9 | Release 12 Features |  | 646d? | 2011-09-24 | 2014-03-12 |  |  | 2011-09-24 | 2014-03-12 | 646d? | 135d | finish no earlier than 2014-03-12 | SP,CP,RP,GP | 5168h |  | Rel-12 |  |  |  |  |  |  |  |
| 10 | 10 | **SIPTO Service Continuity of IP Data Session** |  | 262d? | 2010-09-23 A | 2011-09-21 A | 100% |  | 2010-09-23 | 2011-09-21 | 262d? |  |  | S1 | 4176h | 4176h | Rel-12 | SIPTO_SC | PCG-25 | Vodafone | mona.mustapha@vodafone.com | SP-49 | Alain |  |
| 11 | 10.1 | Stage 1 for SIPTO Service Continuity of IP Data Session |  | 262d? | 2010-09-23 A | 2011-09-21 A | 100% |  | 2010-09-23 | 2011-09-21 | 262d? |  | finish no earlier than 2011-09-21 | S1 | 2080h | 2080h | Rel-12 | SIPTO_SC | PCG-25 | Vodafone | mona.mustapha@vodafone.com | SP-49 | Alain |  |
| 12 | 11 | **Interworking between Mobile Operators using the Evolved Packet System and Data Application Providers** |  | 725d? | 2010-12-16 A | 2013-09-18 | 34% | 476.34d? | 2010-12-16 | 2013-09-18 | 725d? | 260d |  | S1,S2 | 15872h | 4681.82h | Rel-12 | MOSAP | PCG-26 | Cisco | Vojislav Vucetic (vvucetic@cisco.com) | SP-50 | Alain |  |
| 13 | 11.1 | Stage 1 for MOSAP |  | 202d? | 2010-12-16 A | 2011-09-21 A | 100% |  | 2010-12-16 | 2011-09-21 | 202d? |  | finish no earlier than 2011-09-21 | S1 | 1600h | 1600h | Rel-12 | MOSAP | PCG-26 | Cisco | Vojislav Vucetic (vvucetic@cisco.com) | SP-50 | Alain |  |
| 14 | 11.2 | TR on Stage 2 for MOSAP |  | 461d? | 2011-06-06 A | 2013-03-06 | 50% | 230.5d? | 2011-06-06 | 2013-03-06 | 461d? | 400d | finish no earlier than 2013-03-06 | S2 | 3688h | 1844h | Rel-12 | MOSAP | PCG-27 | Intel | chang.hong.shan@intel.com | SP-52 | Maurice |  |
| 15 | 11.3 | Stage 2 for MOSAP |  | 598d? | 2011-06-13 | 2013-09-18 |  |  | 2011-06-13 | 2013-09-18 | 598d? | 260d | finish no earlier than 2013-09-18 | S2 | 4784h |  | Rel-12 | MOSAP | PCG-27 | Intel | chang.hong.shan@intel.com | SP-52 | Maurice |  |
| 16 | 12 | **IMS Network-Independent Public User Identities** |  | 275d? | 2011-06-08 A | 2012-06-20 A | 100% |  | 2011-06-08 | 2012-06-20 | 275d? |  |  | S1 | 4390.4h | 4390.4h | Rel-12 | INIPUI | PCG-27 | Vodafone | mona.mustapha@vodafone.com | SP-52 | Alain |  |
| 17 | 12.1 | Stage 1 for IMS Network-Independent Public User Identities |  | 275d? | 2011-06-08 A | 2012-06-20 A | 100% |  | 2011-06-08 | 2012-06-20 | 275d? |  | finish no earlier than 2012-06-20 | S1 | 2190.4h | 2190.4h | Rel-12 | INIPUI | PCG-27 | Vodafone | mona.mustapha@vodafone.com | SP-52 | Alain |  |
| 18 | 13 | **IMS-based Telepresence** |  | 197d? | 2011-09-22 A | 2012-06-20 A | 100% |  | 2011-09-22 | 2012-06-20 | 197d? |  |  | S1 | 3145.86h | 3145.86h | Rel-12 | IMS_TELEP | PCG-27 | Orange | bruno.tossou@orange-ftgroup.com | SP-53 |  |  |
| 19 | 13.1 | Stage 1 for IMS-based Telepresence |  | 197d? | 2011-09-22 A | 2012-06-20 A | 100% |  | 2011-09-22 | 2012-06-20 | 197d? |  | finish no earlier than 2012-06-08 | S1 | 1569.86h | 1569.86h | Rel-12 | IMS_TELEP | PCG-27 | Orange | bruno.tossou@orange-ftgroup.com | SP-53 |  |  |
| 20 | 14 | **Service and Media Reachability for Users over Restrictive Firewalls** |  | 198d? | 2011-09-21 A | 2012-06-20 A | 100% |  | 2011-09-21 | 2012-06-20 | 198d? |  |  | S1 | 3161.66h | 3161.66h | Rel-12 | SMURFs | PCG-27 | Vodafone | mona.mustapha@vodafone.com | SP-53 |  |  |
| 21 | 14.1 | Stage 1 for Service and Media Reachability for Users over Restrictive Firewalls |  | 198d? | 2011-09-21 A | 2012-06-20 A | 100% |  | 2011-09-21 | 2012-06-20 | 198d? |  | finish no earlier than 2012-06-08 | S1 | 1577.66h | 1577.66h | Rel-12 | SMURFs | PCG-27 | Vodafone | mona.mustapha@vodafone.com | SP-53 |  |  |
| 22 | 15 | **Advanced IP Interconnection of Services (IPXS) for national interconnect** |  | 139d? | 2012-03-06 A | 2012-09-12 A | 100% |  | 2012-03-06 | 2012-09-12 | 139d? |  |  | S1 | 2208h | 2208h | Rel-12 | IPXSNAT | PCG-28 | KPN | toon.norp@tno.nl | SP-55 |  | S1-122331 |
| 23 | 15.1 | Stage 1 for Advanced IP Interconnection of Services (IPXS) for national interconnect |  | 139d? | 2012-03-06 A | 2012-09-12 A | 100% |  | 2012-03-06 | 2012-09-12 | 139d? |  | finish no earlier than 2012-09-12 | S1 | 1096h | 1096h | Rel-12 | IPXSNAT | PCG-28 | KPN | toon.norp@tno.nl | SP-55 |  | S1-122331 |
| 24 | 16 | **Integration of Single Sign-On (SSO) frameworks with 3GPP networks** |  | 137d? | 2012-03-08 A | 2012-09-12 A | 100% |  | 2012-03-08 | 2012-09-12 | 137d? |  |  | S1 | 2184h | 2184h | Rel-12 | SSO_Int | PCG-28 | InterDigital | christopher.wallace@interdigital.com | SP-55 |  | S1-122330 |
| 25 | 16.1 | Stage 1 for Integration of Single Sign-On (SSO) frameworks with 3GPP networks |  | 137d? | 2012-03-08 A | 2012-09-12 A | 100% |  | 2012-03-08 | 2012-09-12 | 137d? |  | finish no earlier than 2012-09-12 | S1 | 1088h | 1088h | Rel-12 | SSO_Int | PCG-28 | InterDigital | christopher.wallace@interdigital.com | SP-55 |  | S1-122330 |

Notes:
- 1: -
- 2: -
- 3: -
- 4: -
- 5: -
- 6: -
- 7: -
- 8: -
- 9: -
- 10: SP#57 moved to Rel-12 (Reason: Stage 2 for requirements in TS 22.101 clause 4.3.5 have not been implemented in Rel-11). Linked to Rel-10 Local IP Access and Selected Internet IP Traffic Offload (LIPA_SIPTO) / Text3: Stage 1
- 11: SP#57 moved to Rel-12. SP#53 completed / Text3: 22.101, 22.220
- 12: SP#56 updated WID SP-110350=>SP-120427
- 13: SP#53 completed / Text3: 22.278
- 14: SP#56 updated WID SP-110350=>SP-120427 / Text3: new TR 23.862
- 15: SP#56 updated WID SP-110350=>SP-120427 / Text3: TBD
- 16: Triggered by Rel-11 TR 22.894 (FS_INIPUI) / Text3: Stage 1
- 17: SP#56 re-completed. Updated WID SP-110381=>SP-120425 (Re-opened & moved to Rel-12 by adding new reqs & removing reqs from Rel-11). SP#53 Rel-11 Stage 1 completed / Text3: 22.115, 22.228
- 18: SP#56 Stage 1 completed
- 19: SP#56 completed / Text3: 22.228
- 20: SP#56 Stage 1 completed
- 21: SP#56 completed / Text3: 22.278
- 22: SP#57 Stage 1 completed. Linked to Rel-11 Feature Advanced IP Interconnection of Services (IPXS) UID_470051.
- 23: SP#57 completed / Text3: 22.228 CR#0161, TBD (CR on IMS interconnect with non-IMS based SIP networks)
- 24: SP#57 Stage 1 completed. Triggered by Rel-12 TR 22.895. Linked to SA3 33.8xy (Study on Security aspects of SSO_Int), 33.914 (SSO application security for common IMS based on SIP Digest), 33.924 (i/w GBA and OpenID), 33.980 (i/w GBA and Liberty Alliance)
- 25: SP#57 completed / Text3: 22.101

| ID | WBS | Task | Duration | Start | Finish | Complete | Remaining | Baseline start | Baseline finish | Baseline duration | Total slack | Constraint | Resources | Work | Actual work | Text1 | Text2 | Text4 | Text5 | Text6 | Text7 | Text11 | Text8 |
| --- | --- | --- | --- | --- | --- | --- | --- | --- | --- | --- | --- | --- | --- | --- | --- | --- | --- | --- | --- | --- | --- | --- | --- |
| 26 | 17 | **Explicit Communication Transfer Blind (ECT Blind) service interactions** | 3d? | 2012-06-18 A | 2012-06-20 A | 100% |  | 2012-06-18 | 2012-06-20 | 3d? |  |  | S1 | 48h | 48h | ECTB | PCG-29 | Orange | Philippe Lottin | Rel-12 | SP-56 | S1-122333 |  |
| 27 | 17.1 | Stage 1 for Explicit Communication Transfer Blind (ECT Blind) service interactions | 3d? | 2012-06-18 A | 2012-06-20 A | 100% |  | 2012-06-18 | 2012-06-20 | 3d? |  | finish no earlier than 2012-06-20 | S1 | 24h | 24h | ECTB | PCG-29 | Orange | Philippe Lottin | Rel-12 | SP-56 | S1-122333 |  |
| 28 | 18 | **Group Communication System Enablers for LTE** | 199d? | 2012-06-18 A | 2013-03-20 | 5% | 189.05d? | 2012-06-18 | 2013-03-20 | 199d? | 390d |  | S1 | 3176h | 158.77h | GCSE_LTE | PCG-29 | Nokia Siemens Networks | Juergen Merkel | Rel-12 | SP-56 | S1-122332 |  |
| 29 | 18.1 | Stage 1 for Group Communication System Enablers for LTE | 198d? | 2012-06-18 A | 2013-03-20 | 5% | 188.1d? | 2012-06-18 | 2013-03-20 | 198d? | 390d | finish no earlier than 2013-03-20 | S1 | 1584h | 79.2h | GCSE_LTE | PCG-29 | Nokia Siemens Networks | Juergen Merkel | Rel-12 | SP-56 | S1-122332 |  |
| 30 | 19 | **IMS access via Digital Video Broadcast - Return Channel via Satellite (DVB-RCS2)** | 162d? | 2012-02-02 A | 2012-09-12 A | 100% |  | 2012-02-02 | 2012-09-12 | 162d? |  |  | S1 | 2584h | 2584h | IMSSat | PCG-29 | KPN | toon.norp@tno.nl | Rel-12 | SP-57 | S1-122454 |  |
| 31 | 19.1 | Stage 1 for IMS access via DVB-RCS2 | 162d? | 2012-02-02 A | 2012-09-12 A | 100% |  | 2012-02-02 | 2012-09-12 | 162d? |  | finish no earlier than 2012-09-12 | S1 | 1288h | 1288h | IMSSat | PCG-29 | KPN | toon.norp@tno.nl | Rel-12 | SP-57 | S1-122454 |  |
| 32 | 20 | **IMS Registration Control** | 164d? | 2012-01-31 A | 2012-09-12 A | 100% |  | 2012-01-31 | 2012-09-12 | 164d? |  |  | S1 | 2616h | 2616h | IMS_RegCon | PCG-29 | China Mobile | lulu@chinamobile.com | Rel-12 | SP-57 | S1-122501 |  |
| 33 | 20.1 | Stage 1 for IMS Registration Control | 164d? | 2012-01-31 A | 2012-09-12 A | 100% |  | 2012-01-31 | 2012-09-12 | 164d? |  | finish no earlier than 2012-09-12 | S1 | 1304h | 1304h | IMS_RegCon | PCG-29 | China Mobile | lulu@chinamobile.com | Rel-12 | SP-57 | S1-122501 |  |
| 34 | 21 | **User Plane Congestion management** | 228d? | 2012-02-01 | 2012-12-12 |  |  | 2012-02-01 | 2012-12-12 | 228d? | 460d |  | S1 | 3648h |  | UPCON | PCG-29 | KDDI | John Visser (xjo-visser@kddi.com) | Rel-12 | SP-57 | S1-122519 |  |
| 35 | 21.1 | Stage 1 for User Plane Congestion management | 228d? | 2012-02-01 | 2012-12-12 |  |  | 2012-02-01 | 2012-12-12 | 228d? | 460d | finish no earlier than 2012-12-12 | S1 | 1824h |  | UPCON | PCG-29 | KDDI | John Visser (xjo-visser@kddi.com) | Rel-12 | SP-57 | S1-122519 |  |
| 36 | 22 | **LIPA Mobility and SIPTO at the Local Network** | 826d? | 2010-10-15 A | 2013-12-06 | 7% | 769.2d? | 2010-10-15 | 2013-12-06 | 826d? | 203d |  | S2,C4,C1 | 53652.4h | 2870.72h | LIMONET | PCG-26 | Huawei | zhufenqin@huawei.com | Rel-12 | SP-50 |  | Maurice |
| 37 | 22.1 | TR on Stage 2 for LIPA Mobility and SIPTO at the Local Network | 580.85d? | 2010-10-15 A | 2013-03-06 | 52% | 278.81d? | 2010-10-15 | 2013-03-06 | 580.85d? | 400d | finish no earlier than 2013-03-06 | S2 | 4646.8h | 2416.34h | LIMONET | PCG-26 | Huawei | zhufenqin@huawei.com | Rel-12 | SP-50 |  | Maurice |
| 38 | 22.2 | BB1: Stage 2 for SIPTO at the Local Network | 580.85d? | 2010-10-19 | 2013-03-06 |  |  | 2010-10-19 | 2013-03-06 | 580.85d? | 400d | finish no earlier than 2013-03-06 | S2 | 4646.8h |  | LIMONET-SIPTO | PCG-26 | Huawei | zhufenqin@huawei.com | Rel-12 | SP-50 |  | Maurice |
| 39 | 22.3 | **BB1: Stage 3 CN aspects of SIPTO at the Local Network** | 581d? | 2011-09-21 | 2013-12-06 |  |  | 2011-09-21 | 2013-12-06 | 581d? | 203d |  | C4,C1 | 13944h |  | LIMONET-SIPTO | PCG-27 | Huawei | caixia.qi@huawei.com | Rel-12 | CP-53 |  |  |
| 40 | 22.3.1 | CT4 part of Stage 3 CN aspects of SIPTO at the Local Network | 581d? | 2011-09-21 | 2013-12-06 |  |  | 2011-09-21 | 2013-12-06 | 581d? | 203d | finish no earlier than 2013-12-06 | C4 | 4648h |  | LIMONET-SIPTO | PCG-27 | Huawei | caixia.qi@huawei.com | Rel-12 | CP-53 |  |  |
| 41 | 22.3.2 | CT1 part of Stage 3 CN aspects of SIPTO at the Local Network | 581d? | 2011-09-21 | 2013-12-06 |  |  | 2011-09-21 | 2013-12-06 | 581d? | 203d | finish no earlier than 2013-12-06 | C1 | 4648h |  | LIMONET-SIPTO | PCG-27 | Huawei | caixia.qi@huawei.com | Rel-12 | CP-53 |  |  |
| 42 | 22.4 | BB2: Stage 2 for stand-alone L-GW and associated Mobility for LIPA and SIPTO at the Local Network | 580.85d? | 2010-10-19 | 2013-03-06 |  |  | 2010-10-19 | 2013-03-06 | 580.85d? | 400d | finish no earlier than 2013-03-06 | S2 | 4646.8h |  | LIMONET-LIPA | PCG-26 | Huawei | zhufenqin@huawei.com | Rel-12 | SP-50 |  | Maurice |
| 43 | 22.5 | **BB2: Stage 3 CN aspects of LIPA Mobility** | 581d? | 2011-09-21 | 2013-12-06 |  |  | 2011-09-21 | 2013-12-06 | 581d? | 203d |  | C1,C4 | 13944h |  | LIMONET-LIPA | PCG-27 | Huawei | christian.herrero@huawei.com | Rel-12 | CP-53 |  |  |
| 44 | 22.5.1 | CT1 part of CN aspects of LIPA Mobility | 581d? | 2011-09-21 | 2013-12-06 |  |  | 2011-09-21 | 2013-12-06 | 581d? | 203d | finish no earlier than 2013-12-06 | C1 | 4648h |  | LIMONET-LIPA | PCG-27 | Huawei | christian.herrero@huawei.com | Rel-12 | CP-53 |  |  |
| 45 | 22.5.2 | CT4 part of CN aspects of LIPA Mobility | 581d? | 2011-09-21 | 2013-12-06 |  |  | 2011-09-21 | 2013-12-06 | 581d? | 203d | finish no earlier than 2013-12-06 | C4 | 4648h |  | LIMONET-LIPA | PCG-27 | Huawei | christian.herrero@huawei.com | Rel-12 | CP-53 |  |  |
| 46 | 22.6 | **Postponed - RAN aspects of LIPA Mobility and SIPTO at the Local Network** | 326d? | 2012-09-07 | 2013-12-06 |  |  | 2012-09-07 | 2013-12-06 | 326d? | 203d |  | R3,R2 | 5216h |  | LIMONET-RAN | PCG-29 | Huawei | zheng.zhou@huawei.com | Rel-12 | RP-57 |  |  |
| 47 | 22.6.1 | Core part: RAN aspects of LIPA Mobility and SIPTO at the Local Network | 326d? | 2012-09-07 | 2013-12-06 |  |  | 2012-09-07 | 2013-12-06 | 326d? | 203d | finish no earlier than 2013-12-06 | R3,R2 | 2608h |  | LIMONET-RAN-Core | PCG-29 | Huawei | zheng.zhou@huawei.com | Rel-12 | RP-57 |  |  |
| 48 | 23 | **Operator Policies for IP Interface Selection** | 516d? | 2011-03-23 A | 2013-03-06 | 25% | 386.62d? | 2011-03-23 | 2013-03-06 | 516d? | 400d |  | S2 | 12328h | 3091.02h | OPIIS | PCG-26 | LG Electronics | taehyeon.kim@lge.com | Rel-12 | SP-51 |  | Maurice |
| 49 | 23.1 | TR on Stage 2 for Operator Policies for IP Interface Selection | 514d? | 2011-03-23 A | 2013-03-06 | 50% | 257d? | 2011-03-23 | 2013-03-06 | 514d? | 400d | finish no earlier than 2013-03-06 | S2 | 4112h | 2056h | OPIIS | PCG-26 | LG Electronics | taehyeon.kim@lge.com | Rel-12 | SP-51 |  | Maurice |
| 50 | 23.2 | Stage 2 for Operator Policies for IP Interface Selection | 511d? | 2011-03-30 | 2013-03-06 |  |  | 2011-03-30 | 2013-03-06 | 511d? | 400d | finish no earlier than 2013-03-06 | S2 | 4088h |  | OPIIS | PCG-26 | LG Electronics | taehyeon.kim@lge.com | Rel-12 | SP-51 |  | Maurice |

Notes:
- 26: SP#56 WID approved & Stage 1 completed
- 27: SP#56 new WID approved & work completed. Clarify the service interactions between ECT Blind and other MMTEL Supplementary Services / Text3: 22.173
- 28: Linked to Rel-12 FS_ProSe TR 22.803 Study on Proximity-based Services. External requirements: NIST, MESA, APCO Global Alliance, TCCA. Specify 3GPP system enablers to support group communication over LTE for Public Safety.
- 29: SA#56 SP-120421 LS Reply to ETSI TETRA (S1-121247/TETRA(12)000036r1) to inform Approval of this WID / Text3: new TS 22.468
- 30: SP#57 Stage 1 completed. Integrate Satcom access with IMS. Specify DVB-RCS2 as an IP Connectivity Access Network for IMS
- 31: SP#57 completed. Definition of DVB-RCS2 as a non-3GPP IP Connectivity Access Network for IMS / Text3: 22.228
- 32: SP#57 Stage 1 completed. Specify for fixed line the requirement of controlling user registration to IMS based on network information related to user location (e.g. IP address, DSLAM information)
- 33: SP#57 completed / Text3: 22.228
- 34: Triggered by Rel-12 TR 22.805 Study on User Plane Congestion management (FS_UPCON)
- 35: Convert TR 22.805 clause 6 consolidated requirements to normative requirements in 22.101 / Text3: 22.101
- 36: Linked to UID_450035 Local IP Access and Selected IP Traffic Offload (LIPA_SIPTO)
- 37: - / Text3: new TR 23.859
- 38: - / Text3: 23.060, 23.401
- 39: - / Text3: Stage 3
- 40: - / Text3: 29.002, 29.060, 29.272, 29.274, 29.275, 29.281, 29.282, 29.303, 29.305
- 41: - / Text3: 24.008, 24.301
- 42: - / Text3: 23.060, 23.401
- 43: - / Text3: Stage 3
- 44: - / Text3: 24.008, 24.301
- 45: - / Text3: 29.060, 29.274, 29.281, 29.303, 29.002, 29.272, 29.275, 29.282, 29.305
- 46: Stage 3 / Text3: UTRA, LTE
- 47: - / Text3: 25.401, 25.413, 25.423, 25.467, 25.469, 36.300, 36.413, 36.423
- 48: SP#56 updated WID SP-110222=>SP-120260 (removed impacted specs. Completrion 12/12=>03/13). Linked to Rel-10 IFOM IP Flow Mobility and seamless WLAN offload (non-seamless WLAN offload aspects) & Rel-11 LIMONET (support traffic offload at local network) / Text3: Stage 2
- 49: SP#56 updated WID SP-110222=>SP-120260. Completion 12/12=>03/13 / Text3: new TR 23.853
- 50: SP#56 updated WID SP-110222=>SP-120260 (removed impacted specs). Completion 12/12=>03/13 / Text3: TBD

| ID | WBS | Task | Duration | Start | Finish | Complete | Remaining | Baseline start | Baseline finish | Baseline duration | Total slack | Constraint | Resources | Work | Actual work | Text1 | Text2 | Text3 | Text4 | Text5 | Text6 | Text7 | Text8 | Text11 |
| --- | --- | --- | --- | --- | --- | --- | --- | --- | --- | --- | --- | --- | --- | --- | --- | --- | --- | --- | --- | --- | --- | --- | --- | --- |
| 51 | 24 | **Short Message Service (SMS) submit and delivery without MSISDN in IMS** | 461d? | 2011-06-08 A | 2013-03-06 | 37% | 289.27d? | 2011-06-08 | 2013-03-06 | 461d? | 400d |  | S2 | 10552.3h | 3926.63h | SMSMI | PCG-27 | Stage 2 | Nokia Siemens Networks | curt.wong@nsn.com | Rel-12 | SP-52 | Maurice |  |
| 52 | 24.1 | TR on Stage 2 for SMS submit and delivery without MSISDN in IMS | 400d? | 2011-06-08 A | 2012-12-12 | 80% | 80d? | 2011-06-08 | 2012-12-12 | 400d? | 460d | finish no earlier than 2012-12-12 | S2 | 3192.32h | 2552.76h | SMSMI | PCG-27 | new TR 23.863 | Nokia Siemens Networks | curt.wong@nsn.com | Rel-12 | SP-52 | Maurice |  |
| 53 | 24.2 | Stage 2 for SMS submit and delivery without MSISDN in IMS | 459d? | 2011-06-10 | 2013-03-06 |  |  | 2011-06-10 | 2013-03-06 | 459d? | 400d | finish no earlier than 2013-03-06 | S2 | 3672h |  | SMSMI | PCG-27 | 23.204, 23.682 | Nokia Siemens Networks | curt.wong@nsn.com | Rel-12 | SP-52 | Maurice |  |
| 54 | 25 | **Machine-Type and other mobile data applications Communications enhancements** | 1050d? | 2009-12-10 A | 2013-12-11 | 18% | 856.3d? | 2009-12-10 | 2013-12-11 | 1050d? | 200d |  | S2,S1,S3,S5 | 41768h | 7699.02h | MTCe | PCG-29 |  | Intel | Puneet Jain | Rel-12 | SP-56 |  | S1-122520 |
| 55 | 25.1 | **Support for Interworking with M2M Service Enablement** | 189d? | 2012-06-18 A | 2013-03-06 | 50% | 94d? | 2012-06-18 | 2013-03-06 | 189d? | 400d |  | S1 | 3016h | 1512h | MTCe-SIMSE | PCG-29 |  | KPN | toon.norp@tno.nl | Rel-12 | SP-56 |  | S1-122334 |
| 56 | 25.1.1 | Stage 1 for Support for Interworking with M2M Service Enablement | 189d? | 2012-06-18 A | 2013-03-06 | 50% | 94d? | 2012-06-18 | 2013-03-06 | 189d? | 400d | finish no earlier than 2013-03-06 | S1 | 1504h | 752h | MTCe-SIMSE | PCG-29 | 22.368 | KPN | toon.norp@tno.nl | Rel-12 | SP-56 |  | S1-122334 |
| 57 | 25.2 | Machine-Type and other mobile data applications Communications – Service Requirement Maintenance | 126d? | 2012-09-12 | 2013-03-06 |  |  | 2012-09-12 | 2013-03-06 | 126d? | 400d | finish no earlier than 2013-03-06 | S1 | 1008h |  | MTCe-SRM | PCG-29 | 22.101, 22.368 | KPN | toon.norp@tno.nl | Rel-12 | SP-57 |  | S1-122520 |
| 58 | 25.3 | TR on Security aspects of Machine-Type Communications | 989d? | 2009-12-10 A | 2013-09-18 | 50% | 494.5d? | 2009-12-10 | 2013-09-18 | 989d? | 260d | finish no earlier than 2013-09-18 | S3 | 7912h | 3956h | NIMTC | PCG-29 | new TR 33.868 | Samsung | Rajavelsamy R (rajvel@samsung.com) | Rel-12 | SP-56 |  | SP-120331 |
| 59 | 25.4 | Security and Privacy aspects for Machine-Type and other mobile data applications Communications enhancements (Stage 2) | 388d? | 2012-06-19 | 2013-12-11 |  |  | 2012-06-19 | 2013-12-11 | 388d? | 200d | finish no earlier than 2013-12-11 | S3 | 3104h |  | MTCe | PCG-29 | new TS 33.xyz | Samsung | Rajavelsamy R (rajvel@samsung.com) | Rel-12 | SP-56 |  |  |
| 60 | 25.5 | TR on Stage 2 for Machine-Type and other mobile data applications Communications enhancements | 328d? | 2012-06-18 A | 2013-09-18 | 2% | 321.44d? | 2012-06-18 | 2013-09-18 | 328d? | 260d | finish no earlier than 2013-09-18 | S2 | 2624h | 52.48h | MTCe-TR | PCG-29 | new TR 23.887 | Intel | Puneet Jain | Rel-12 | SP-56 |  |  |
| 61 | 25.6 | BB1: Small Data and Device Triggering Enhancements (SDDTE) | 328d? | 2012-06-18 A | 2013-09-17 | 10% | 295.2d? | 2012-06-18 | 2013-09-17 | 328d? | 261d | start no earlier than 2012-06-18 | S2 | 2624h | 262.4h | MTCe-SDDTE | PCG-29 | 23.682 | Intel | Puneet Jain | Rel-12 | SP-56 |  |  |
| 62 | 25.7 | BB2: Monitoring Enhancements (MONTE) | 328d? | 2012-06-18 A | 2013-09-17 | 2% | 321.44d? | 2012-06-18 | 2013-09-17 | 328d? | 261d | start no earlier than 2012-06-18 | S2 | 2624h | 52.48h | MTCe-MONTE | PCG-29 | 23.682 | Intel | Puneet Jain | Rel-12 | SP-56 |  |  |
| 63 | 25.8 | BB3: UE Power Consumptions Optimizations (UEPCOP) | 328d? | 2012-06-18 A | 2013-09-17 | 2% | 321.44d? | 2012-06-18 | 2013-09-17 | 328d? | 261d | start no earlier than 2012-06-18 | S2 | 2624h | 52.48h | MTCe-UEPCOP | PCG-29 | 23.060, 23.401, 23.682 | Ericsson | Peter Hedman | Rel-12 | SP-56 |  |  |
| 64 | 25.9 | BB4: Group based MTC feature (GROUP) | 327d? | 2012-06-20 A | 2013-09-18 | 10% | 294.3d? | 2012-06-20 | 2013-09-18 | 327d? | 260d | finish no earlier than 2013-09-18 | S2,S5 | 2616h | 261.6h | MTCe-GROUP | PCG-29 | 23.682 | KPN | Annemieke Kips | Rel-12 | SP-56 |  |  |
| 65 | 25.10 | **Postponed - RAN aspects of Machine-Type and other mobile data applications Communications enhancements** | 326d? | 2012-09-07 | 2013-12-06 |  |  | 2012-09-07 | 2013-12-06 | 326d? | 203d |  | R2,R3 | 5216h |  | MTCe-RAN | PCG-29 | UTRA, LTE | ZTE | sergio.parolari@zteitaly.com | Rel-12 | RP-57 |  |  |
| 66 | 25.10.1 | Postponed - Core part: RAN aspects of Machine-Type and other mobile data applications Communications enhancements | 326d? | 2012-09-07 | 2013-12-06 |  |  | 2012-09-07 | 2013-12-06 | 326d? | 203d | finish no earlier than 2013-12-06 | R2,R3 | 2608h |  | MTCe-RAN-Core | PCG-29 | 25.331, 25.413, 36.300, 36.331, 36.413, new TR 37.8xy | ZTE | sergio.parolari@zteitaly.com | Rel-12 | RP-57 |  |  |
| 67 | 26 | **Policy and Charging Control for supporting fixed broadband access networks** | 974d? | 2010-03-26 A | 2013-12-11 | 24% | 736.88d? | 2010-03-26 | 2013-12-11 | 974d? | 200d |  | S2,S1,S5 | 35280h | 8570.77h | P4C | PCG-29 | Stage 2 | Huawei | marco.spini@huawei.com | Rel-12 | SP-56 |  |  |
| 68 | 26.1 | Stage 1 for Policy and Charging Support for Fixed Mobile Convergence | 3d? | 2012-09-10 A | 2012-09-12 A | 100% |  | 2012-09-10 | 2012-09-12 | 3d? |  | finish no earlier than 2012-09-12 | S1 | 24h | 24h | P4C-FMC | PCG-29 | 22.278 | Huawei | amar.deol@huawei.com | Rel-12 | SP-57 |  |  |
| 69 | 26.2 | TR on Stage 2 on Support for fixed broadband access networks convergence | 263d? | 2012-06-20 A | 2013-06-20 | 5% | 249.85d? | 2012-06-20 | 2013-06-20 | 263d? | 324d | finish no earlier than 2013-06-19 | S2,S5 | 2104h | 105.2h | P4C | PCG-29 | new TR 23.896 | Huawei | marco.spini@huawei.com | Rel-12 | SP-56 |  |  |
| 70 | 26.3 | BB1: Policy and Charging Control for supporting traffic from fixed terminals and NSWO traffic from 3GPP UEs in fixed broadband access networks (P4C-F) | 387d? | 2012-06-20 A | 2013-12-11 | 15% | 327.8d? | 2012-06-20 | 2013-12-11 | 387d? | 200d | finish no earlier than 2013-12-11 | S2,S5 | 3088h | 465.6h | P4C-F | PCG-29 | 23.139, 23.203 | Huawei | marco.spini@huawei.com | Rel-12 | SP-56 |  |  |
| 71 | 26.4 | TR on Stage 2 for Support for BBF Accesses Interworking (was Rel-11 TR on Stage 2 for BBAI UID_470022) | 849d? | 2010-03-26 A | 2013-06-19 | 80% | 169.6d? | 2010-03-26 | 2013-06-19 | 849d? | 325d | finish no earlier than 2013-06-19 | S2 | 6784h | 5427.2h | P4C-TI | PCG-24 | new TR 23.839 | Ericsson | marco.spini@huawei.com | Rel-12 | SP-47 |  |  |
| 72 | 26.5 | BB2: Policy and Charging Control for 3GPP UEs connected to BroadBand Forum access network as Trusted network in Interworking scenario (P4C-TI) | 387d? | 2012-06-20 A | 2013-12-11 | 15% | 327.8d? | 2012-06-20 | 2013-12-11 | 387d? | 200d | finish no earlier than 2013-12-11 | S2,S5 | 3088h | 465.6h | P4C-TI | PCG-29 | 23.139, 23.203 | Alcatel-Lucent | konstantin.livanos@alcatel-lucent.com | Rel-12 | SP-56 |  |  |
| 73 | 26.6 | BB3: Policy and Charging Control for 3GPP UEs connected to fixed broadband access network via S2b and S2c reference points for EPC routed traffic (P4C-S2bc) | 388d? | 2012-06-19 | 2013-12-11 |  |  | 2012-06-19 | 2013-12-11 | 388d? | 200d | finish no earlier than 2013-12-11 | S2 | 3104h |  | P4C-S2bc | PCG-29 | 23.139, 23.203 | ZTE | Tricci So (tso@zteusa.com) | Rel-12 | SP-56 |  |  |
| 74 | 26.7 | BB4: Policy and Charging Control for EPC routed traffic over fixed broadband access networks of 3GPP UEs connected via H(e)NB in convergent scenarios (P4C-HeNB) | 388d? | 2012-06-19 | 2013-12-11 |  |  | 2012-06-19 | 2013-12-11 | 388d? | 200d | finish no earlier than 2013-12-11 | S2 | 3104h |  | P4C-HeNB | PCG-29 | 23.139, 23.203 | NEC | Stefan.Schmid@neclab.eu | Rel-12 | SP-56 |  |  |
| 75 | 26.8 | BB5: Policy and Charging Control for supporting Layer 2 traffic in fixed broadband access network (P4C-FL2) | 387d? | 2012-06-20 | 2013-12-11 |  |  | 2012-06-20 | 2013-12-11 | 387d? | 200d | start no earlier than 2012-06-20 | S2,S5 | 3096h |  | P4C-FL2 | PCG-29 | 23.139, 23.203 | Huawei | marco.spini@huawei.com | Rel-12 | SP-56 |  |  |
| 76 | 26.9 | BB6: Policy and Charging Control for 3GPP UEs connected to fixed broadband access networks via S2a reference point for EPC routed traffic in convergence (P4C-TC) | 387d? | 2012-06-20 A | 2013-12-11 | 6% | 363.72d? | 2012-06-20 | 2013-12-11 | 387d? | 200d | finish no earlier than 2013-12-11 | S2,S5 | 3096h | 186.24h | P4C-TC | PCG-29 | 23.139, 23.203 | ZTE | Tricci So (tso@zteusa.com) | Rel-12 | SP-56 |  |  |

Notes:
- 51: Linked to Rel-7 SMSIP (Support of SMS over generic 3GPP IP access), Rel-11 SIMTC, Rel-12 TR 22.988 SA1 Study on alternatives to E.164 for MTC
- 52: SP#54 TR 23.863v100 for Information
- 53: -
- 54: SP#57 updated WID SP-120441=>SP-120540. Study and provide Stage 2 specification for the requirements in SA1 TSs 22.368, 22.101
- 55: SP#57 completion 12/12=>03/13. Stage 1. Define requirements for interworking with M2M service enablement layer specified by ETSI TC M2M
- 56: SP#57 completion 12/12=>03/13 (Reason: timing of related work in ETSI TC M2M). External requirements : ETSI TC M2M TS 102 689 (Source of specifications for Service Enablement layer)
- 57: -
- 58: Was Rel-10 UID_460023 (Security for NIMTC). Was Rel-11 UID_490028 (TR on Security aspects of Machine-Type Communications). SP#56 activity transferred to Rel-12 Feature MTCe
- 59: Stage 2
- 60: Study capturing solution alternatives and evaluations for Stage 2 BB1-BB4 meeting requirements in 22.368, 22.101
- 61: -
- 62: -
- 63: -
- 64: Fulfil the group based Rel-11 Stage 1 for System Improvements to Machine Type UID_480130 requirements in TS 22.368 on policing (cl. 7.2.14.2), addressing (cl. 7.2.14.3), charging (cl. 7.1.5)
- 65: Stage 2/3
- 66: -
- 67: Stage 2. Linked to BBF, IETF work.
- 68: SP#57 completed
- 69: TR contains result of study, solutions and evaluations of solutions for BB1, BB3-BB6 (except BB2 that will use TR 23.839)
- 70: -
- 71: TR not Approved in Rel-11 (was TR on Stage 2 for BBAI UID_470022). TR contains result of study, solutions and evaluations of solutions for BB2
- 72: -
- 73: -
- 74: -
- 75: -
- 76: -

| ID | WBS | Task | Duration | Start | Finish | Complete | Remaining | Baseline start | Baseline finish | Baseline duration | Total slack | Constraint | Resources | Work | Actual work | Text1 | Text2 | Text4 | Text6 | Text7 | Text11 | Text9 | Text12 | Text8 |
| --- | --- | --- | --- | --- | --- | --- | --- | --- | --- | --- | --- | --- | --- | --- | --- | --- | --- | --- | --- | --- | --- | --- | --- | --- |
| 77 | 27 | **IMS Business Trunking for IP-PBX in Static Mode of Operation** | 387.1d? | 2011-09-28 A | 2013-03-20 | 19% | 314.68d? | 2011-09-28 | 2013-03-20 | 387.1d? | 390d |  | S2,S1 | 4704h | 873.51h | BusTI | PCG-29 | Deutsche Telekom | Rel-12 | SP-56 |  |  |  |  |
| 78 | 27.1 | TR on IMS Business Trunking for IP-PBX in Static Mode of Operation | 128d? | 2012-06-18 A | 2012-12-12 | 7% | 119.04d? | 2012-06-18 | 2012-12-12 | 128d? | 460d | finish no earlier than 2012-12-12 | S2,S1 | 1024h | 71.68h | BusTI | PCG-29 | Deutsche Telekom | Rel-12 | SP-56 |  |  |  |  |
| 79 | 27.2 | Stage 1 for IMS Business Trunking for IP-PBX in Static Mode of Operation | 64d? | 2011-09-28 A | 2012-09-12 A | 100% |  | 2011-09-28 | 2012-09-12 | 64d? |  | finish no earlier than 2012-08-30 | S1 | 504h | 504h | BusTI | PCG-29 | Deutsche Telekom | Rel-12 | SP-56 | S1-122336 |  |  |  |
| 80 | 27.3 | Stage 2 for IMS Business Trunking for IP-PBX in Static Mode of Operation | 198d? | 2012-06-19 | 2013-03-20 |  |  | 2012-06-19 | 2013-03-20 | 198d? | 390d | finish no earlier than 2013-03-20 | S2 | 1584h |  | BusTI | PCG-29 | Deutsche Telekom | Rel-12 | SP-56 |  |  |  |  |
| 81 | 28 | **WLAN Network Selection for 3GPP Terminals** | 199d? | 2012-06-18 A | 2013-03-20 | 15% | 169.16d? | 2012-06-18 | 2013-03-20 | 199d? | 390d |  | S2,S1 | 3176h | 476.32h | WLAN_NS | PCG-29 | Intel | Rel-12 | SP-56 |  |  |  |  |
| 82 | 28.1 | TR on WLAN Network Selection for 3GPP Terminals | 198d? | 2012-06-18 A | 2013-03-20 | 15% | 168.3d? | 2012-06-18 | 2013-03-20 | 198d? | 390d | finish no earlier than 2013-03-20 | S2,S1 | 1584h | 237.6h | WLAN_NS | PCG-29 | Intel | Rel-12 | SP-56 |  |  |  |  |
| 83 | 29 | Rel-12 Security small Enhancements | 515d? | 2011-03-23 A | 2013-03-05 | 40% | 309d? | 2011-03-23 | 2013-03-05 | 515d? | 401d |  | S3 | 4120h | 1648h | SEC12 | PCG-29 |  | Rel-12 | SP-56 |  |  |  |  |
| 84 | 30 | **Security aspects of Public Warning System** | 456d? | 2011-03-23 A | 2012-12-12 | 91% | 43.26d? | 2011-03-23 | 2012-12-12 | 456d? | 460d |  | S3,S1 | 15152h | 11452h | PWS_Sec | PCG-26 | ST-Ericsson | Rel-12 | SP-51 |  |  |  |  |
| 85 | 30.1 | Stage 1 for Protection against false PWS Warning Notifications | 65d? | 2012-06-15 A | 2012-09-12 A | 100% |  | 2012-06-15 | 2012-09-12 | 65d? |  | finish no earlier than 2012-09-12 | S1 | 512h | 512h | PWS_Sec | PCG-29 | Vodafone | Rel-12 | SP-56 | S1-122335 |  |  |  |
| 86 | 30.2 | SA3 part for Security aspects of Public Warning System | 455d? | 2011-03-23 A | 2012-12-12 | 70% | 136.5d? | 2011-03-23 | 2012-12-12 | 455d? | 460d | finish no earlier than 2012-12-12 | S3 | 3640h | 2548h | PWS_Sec | PCG-26 | ST-Ericsson | Rel-12 | SP-51 |  |  |  |  |
| 87 | 30.3 | Deleted - Stage 1 for Security aspects of Public Warning System | 330d? | 2011-03-23 A | 2012-06-20 A | 100% |  | 2011-03-23 | 2012-06-20 | 330d? |  | start no earlier than 2011-03-23 | S1 | 2640h | 2640h | PWS_Sec | PCG-26 | ST-Ericsson | Rel-12 | SP-51 |  | PCG-29 | SP-56 |  |
| 88 | 30.4 | Deleted - Stage 2 for Security aspects of Public Warning System | 133d? | 2011-03-23 A | 2011-09-21 A | 100% |  | 2011-03-23 | 2011-09-21 | 133d? |  | start no earlier than 2011-03-23 | S2 | 1064h | 1064h | PWS_Sec | PCG-26 | ST-Ericsson | Rel-12 | SP-51 |  | PCG-27 | SP-53 |  |
| 89 | 30.5 | Deleted - CT1 part for Security aspects of Public Warning System | 328d? | 2011-03-25 A | 2012-06-20 A | 100% |  | 2011-03-25 | 2012-06-20 | 328d? |  | finish no earlier than 2012-06-20 | C1 | 2624h | 2624h | PWS_Sec | PCG-26 | ST-Ericsson | Rel-12 | SP-51 |  | PCG-29 | SP-56 |  |
| 90 | 30.6 | Deleted - RAN2 part for Security aspects of Public Warning System | 128d? | 2011-03-25 A | 2011-09-16 A | 100% |  | 2011-03-25 | 2011-09-16 | 128d? |  | start no earlier than 2011-03-25 | R2 | 1024h | 1024h | PWS_Sec | PCG-26 | ST-Ericsson | Rel-12 | SP-51 |  | PCG-27 | RP-53 |  |
| 91 | 31 | Security enhancements for usage of Generic Bootstrapping Architecture (GBA) from the browser (Stage 2) | 457d? | 2011-06-08 A | 2013-03-06 | 85% | 68.4d? | 2011-06-08 | 2013-03-06 | 457d? | 400d | finish no earlier than 2013-03-06 | S3 | 3648h | 3100.8h | Web_GBA | PCG-27 | Nokia | Rel-12 | SP-52 |  |  |  | Dionisio |
| 92 | 32 | Extended IMS media plane security features (Stage 2) | 186d? | 2012-06-20 A | 2013-03-05 | 79% | 39.06d? | 2012-06-20 | 2013-03-05 | 186d? | 401d | start no earlier than 2012-06-20 | S3 | 1488h | 1175.52h | eMEDIASEC | PCG-29 | Vodafone | Rel-12 | SP-56 |  |  |  |  |
| 93 | 33 | Lawful Interception in the 3GPP Rel-12 | 323d? | 2012-09-12 | 2013-12-06 |  |  | 2012-09-12 | 2013-12-06 | 323d? | 203d | finish no earlier than 2013-12-06 | S3 | 2584h |  | LI12 | PCG-29 | PIDS, Alcatel-Lucent | Rel-12 | SP-57 |  |  |  |  |
| 94 | 34 | **Codec for Enhanced Voice Services** | 975d? | 2010-03-25 A | 2013-12-11 | 55% | 438.29d? | 2010-03-25 | 2013-12-11 | 975d? | 200d |  | S4,S1 | 15592h | 8582.86h | EVS_codec | PCG-24 | Huawei | Rel-12 | SP-47 |  |  |  | Paolo |
| 95 | 34.1 | Stage 1 for Codec for Enhanced Voice Services | 1d? | 2010-03-25 A | 2010-03-25 A | 100% |  | 2010-03-25 | 2010-03-25 | 1d? |  | start no earlier than 2010-03-25 | S1 | 8h | 8h | EVS_codec | PCG-24 | Huawei | Rel-12 | SP-47 |  |  |  | Paolo |
| 96 | 34.2 | Stage 2/3 for Codec for Enhanced Voice Services | 973d? | 2010-03-25 A | 2013-12-11 | 55% | 437.85d? | 2010-03-25 | 2013-12-11 | 973d? | 200d | finish no earlier than 2013-12-11 | S4 | 7784h | 4281.2h | EVS_codec | PCG-24 | Huawei | Rel-12 | SP-47 |  |  |  | Paolo |
| 97 | 35 | Coordination of Video Orientation | 135d? | 2012-06-07 A | 2012-12-12 | 40% | 81d? | 2012-06-07 | 2012-12-12 | 135d? | 460d | finish no earlier than 2012-12-12 | S4 | 1080h | 432h | CVO | PCG-29 | Ericsson | Rel-12 | SP-56 |  |  |  |  |
| 98 | 36 | High Efficiency Video Coding | 386d? | 2012-09-12 | 2014-03-05 |  |  | 2012-09-12 | 2014-03-05 | 386d? | 140d | finish no earlier than 2014-03-05 | S4 | 3088h |  | HEVC | PCG-29 | Qualcomm | Rel-12 | SP-57 |  |  |  |  |
| 99 | 37 | **Rel-12 Operations, Administration, Maintenance and Provisioning (OAM&P)** | 587d? | 2012-06-20 A | 2014-09-17 | 4% | 565.84d? | 2012-06-20 | 2014-09-17 | 587d? | 0d |  | S5 | 41016h | 1542.36h | OAM12 | PCG-29 |  | Rel-12 | SP-56 |  |  |  |  |
| 100 | 37.1 | **Rel-12 Self-Organizing Networks (SON) - OAM aspects** | 187d? | 2012-06-20 A | 2013-03-06 | 10% | 168.36d? | 2012-06-20 | 2013-03-06 | 187d? | 400d |  | S5 | 4480h | 446.68h | OAM12-SON | PCG-29 |  | Rel-12 | SP-56 |  |  |  |  |
| 101 | 37.1.1 | Enhanced Network Management (NM) centralized Coverage and Capacity Optimization | 186d? | 2012-06-20 A | 2013-03-06 | 10% | 167.4d? | 2012-06-20 | 2013-03-06 | 186d? | 400d | finish no earlier than 2013-03-06 | S5 | 1488h | 148.8h | SON-NM-CCO | PCG-29 | Ericsson | Rel-12 | SP-56 |  |  |  |  |
| 102 | 37.1.2 | Multi-vendor Plug and Play eNB connection to the network | 187d? | 2012-06-20 A | 2013-03-06 | 10% | 168.4d? | 2012-06-20 | 2013-03-06 | 187d? | 400d | finish no earlier than 2013-03-06 | S5 | 1496h | 148.8h | SON-NM-MUPPET | PCG-29 | Nokia Siemens Networks | Rel-12 | SP-56 |  |  |  |  |
| 103 | 37.2 | Compliance of 3GPP SA5 specifications to the NGMN Top Operational Efficiency (OPE) Recommendations | 327d? | 2012-06-20 | 2013-09-18 |  |  | 2012-06-20 | 2013-09-18 | 327d? | 260d | start no earlier than 2012-06-20 | S5 | 2616h |  | OAM-NGMN_OPE | PCG-29 | Huawei | Rel-12 | SP-56 |  |  |  |  |

Notes:
- 77: SP#57 Stage 1 completed. Linked to Rel-11 IPXS Feature UID_470051 Advanced IP Interconnection of Services. This WI defines a generic framework for interconnecting with any type of IMS based network including IP-PBXs. / Text5: michele.zarri@telekom.com
- 78: Feasibility study on IMS Business Trunking for IP-PBX in Static Mode of Operation / Text3: new TR 23.897 / Text5: michele.zarri@telekom.com
- 79: SP#57 completed. 22.228CR#0171 / Text3: 22.228 / Text5: kurt.bischinger@t-mobile.at
- 80: - / Text3: 23.228 / Text5: michele.zarri@telekom.com
- 81: Linked to Rel-11 IPXS Feature UID_470051 Advanced IP Interconnection of Services. This WI defines a generic framework for interconnecting with any type of IMS based network including IP-PBXs. / Text5: vivek.g.gupta@intel.com
- 82: - / Text3: new TR 23.865 / Text5: vivek.g.gupta@intel.com
- 83: SEC12 is an umbrella Feature for Security related TEI12 type of changes that are not part of any other dedicated feature
- 84: SP#57 Stage 1 completed / Text5: john.mattsson@ericsson.com
- 85: SP#57 completed. Specify reqs to protect against false PWS Warning Notifications (Optional as not all regions/countries require this functionality). WID covers all objectives in SA3 PWS_Sec Feature-level WID replacing the original Stage 1 UID_510154 / Text3: 22.268 / Text5: adrian.neal@vodafone.com
- 86: - / Text3: 33.102, 33.401, 43.020, new (33.269, 33.869) / Text5: john.mattsson@ericsson.com
- 87: Completed in Rel-9 under PWS. SP#55 stopped, Stage 1 requirements removed from Rel-9 onwards (SP-120172). AP 55/1: SA1 to align Stage 1 PWS security for Rel-12. SA1 new WID PWS Security UID_560029. / Text3: 22.268 / Text5: john.mattsson@ericsson.com
- 88: SP#53 work stopped as already done in previous releases / Text3: 23.401 / Text5: john.mattsson@ericsson.com
- 89: TSG#56 work stopped. SP#56 updated WID SP-110223=>SP-120334 (removed all but SA3 impacted specs) / Text3: 23.041 / Text5: mikael.wass@ericsson.com
- 90: RP#53 work stopped as no WI in RAN / Text3: 36.331 / Text5: john.mattsson@ericsson.com
- 91: SP#56 TR 33.823 v100 for Information / Text3: 33.220, 33.222, new TR 33.823 / Text5: Silke.Holtmanns@nokia.com
- 92: SP#57 TR 33.829 v100 for Information. Triggered by Rel-11 TR 33.829 Study on Extended IMS media plane security features (FS_eMEDIASEC) / Text3: 33.328 / Text5: peter.howard@vodafone.com
- 93: Stage 1/2/3. Update LI specifications for Rel-12 architecture and services (e.g. IMS Media security, MTC, IMS enh, EPS enh, Enh Location Reporting, H(e)NB also with LIPA and SIPTO, Mobile Cloud, Network Hardening / Common Criteria, GBA for web Services. / Text3: 33.106, 33.107, 33.108 / Text5: Koen Jaspers (k.b.jaspers@minjus.nl), terry.jacobson@alcatel-lucent.com
- 94: SP#47 Stage 1 completed. Triggered by UID_370045 Study on enhanced voice service requirements for EPS (TR 22.813) / Text5: anisse.taleb@huawei.com
- 95: SP#47 completed. Covered by general requirements in 22.101, 22.001 / Text3: 22.173 / Text5: anisse.taleb@huawei.com
- 96: - / Text3: 26.xyz, 26.xyz, 26.9yz / Text5: anisse.taleb@huawei.com
- 97: SP#57 moved to Rel-12. Resolve backward compatible video orientation mis-alignment issues in MTSI real-time video communication via interaction between MTSI video clients at call setup & during mid-call of the video orientation for correct local rendering / Text3: 26.114, 26.141, 26.234, 26.346 / Text5: frederic.gabin@ericsson.com
- 98: Specify the support of HEVC in 3GPP services (PSS, DASH, MTSI, MMS, MBMS) / Text3: 26.114, 26.140, 26.234, 26.244, 26.247, 26.346, New TR 26.9xy / Text5: Ye-Kui Wang (yekuiw@qualcomm.com)
- 99: OAM12 is an umbrella Feature also for OAM&P related TEI12 type of changes that are not part of any other dedicated feature/WI
- 100: OAM12-SON is an umbrella BB also for SON related TEI12 type of changes that are not part of any other dedicated feature/WI
- 101: - / Text3: 32.103, 32.425, 32.521, 32.522, 32.762, 32.766, new TR 32.836 / Text5: per.elmdahl@ericsson.com
- 102: - / Text3: 32.501, new TS [nm.ij2 (Messages for multi-vendor plug and play, stage 2), nm.ij6 (Messages for multi-vendor plug and play , stage 3)] / Text5: clemens.suerbaum@nsn.com
- 103: Stage 1/2/3. Source of external requirements: NGMN Top OPE Recommendations 1.0 / Text3: 32.101/2/3,32.111-1,32.111-2,32.111-6,32.15x,32.401,32.411,32.412,32.421,32.422,32.423,32.431,32.432,32.436,32.441,32.442,32.446,32.500,32.501,32.502,32.506,32.521,32.522,32.526,32.531,32.532,32.536,32.551,32.691,32.692,32.696,32.762,New TR 32.838 / Text5: christian.toche@huawei.com

| ID | WBS | Task | Duration | Start | Finish | Complete | Remaining | Baseline start | Baseline finish | Baseline duration | Total slack | Constraint | Resources | Work | Actual work | Text1 | Text2 | Text4 | Text5 | Text6 | Text7 | Text8 | Text11 |
| --- | --- | --- | --- | --- | --- | --- | --- | --- | --- | --- | --- | --- | --- | --- | --- | --- | --- | --- | --- | --- | --- | --- | --- |
| 104 | 37.3 | **Compliance of 3GPP SA5 specifications to the NGMN Next Generation Converged Operations Requirements (NGCOR)** | 587d? | 2012-06-20 A | 2014-09-17 | 4% | 563.48d? | 2012-06-20 | 2014-09-17 | 587d? | 0d |  | S5 | 18760h | 752.08h | OAM-NGMN_NGCOR | PCG-29 | Huawei | christian.toche@huawei.com | Rel-12 | SP-56 |  |  |
| 105 | 37.3.1 | TR on Compliance of 3GPP SA5 specifications to the NGMN NGCOR | 587d? | 2012-06-20 A | 2014-09-17 | 5% | 557.65d? | 2012-06-20 | 2014-09-17 | 587d? | 0d | start no earlier than 2012-06-20 | S5 | 4696h | 234.8h | OAM-NGMN_NGCOR | PCG-29 | Huawei | christian.toche@huawei.com | Rel-12 | SP-56 |  |  |
| 106 | 37.3.2 | Converged Management Model Alignment (Phase 2) | 457d? | 2012-06-20 A | 2014-03-19 | 1% | 452.43d? | 2012-06-20 | 2014-03-19 | 457d? | 130d | start no earlier than 2012-06-20 | S5 | 3656h | 36.56h | OAM-MODAL | PCG-29 | Nokia Siemens Networks | olaf.pollakowski@nsn.com | Rel-12 | SP-56 |  |  |
| 107 | 37.3.3 | Converged management Performance Management Interface Definitions | 387d? | 2012-06-20 A | 2013-12-11 | 1% | 383.13d? | 2012-06-20 | 2013-12-11 | 387d? | 200d | start no earlier than 2012-06-20 | S5 | 3096h | 30.96h | OAM-PMID | PCG-29 | China Mobile | liangshuangchun@cmdi.chinamobile.com | Rel-12 | SP-56 |  |  |
| 108 | 37.3.4 | 3GPP Fault Management Solution Profile for NGMN NGCOR | 327d? | 2012-06-20 A | 2013-09-18 | 10% | 294.3d? | 2012-06-20 | 2013-09-18 | 327d? | 260d | start no earlier than 2012-06-20 | S5 | 2616h | 261.6h | OAM-FMSP | PCG-29 | Ericsson | thomas.tovinger@ericsson.com | Rel-12 | SP-56 |  |  |
| 109 | 37.4 | **WLAN Management** | 327d? | 2012-06-20 A | 2013-09-18 | 2% | 321.56d? | 2012-06-20 | 2013-09-18 | 327d? | 260d |  | S5 | 10464h | 174.35h | WLAN-OAM | PCG-29 | Intel | joey.chou@intel.com | Rel-12 | SP-56 |  |  |
| 110 | 37.4.1 | TR on WLAN impacts to Type-2 management interface to the 3GPP Network Manager | 327d? | 2012-06-20 A | 2013-09-18 | 5% | 310.65d? | 2012-06-20 | 2013-09-18 | 327d? | 260d | start no earlier than 2012-06-20 | S5 | 2616h | 130.8h | WLAN-OAM | PCG-29 | Intel | joey.chou@intel.com | Rel-12 | SP-56 |  |  |
| 111 | 37.4.2 | WLAN Network Resource Model for Type-2 interface | 327d? | 2012-06-20 | 2013-09-18 |  |  | 2012-06-20 | 2013-09-18 | 327d? | 260d | start no earlier than 2012-06-20 | S5 | 2616h |  | WLAN-OAM | PCG-29 | Intel | joey.chou@intel.com | Rel-12 | SP-56 |  |  |
| 112 | 37.4.3 | WLAN measurements defined in IEEE and IETF WLAN performance measurements for use on Type-2 interface | 327d? | 2012-06-20 | 2013-09-18 |  |  | 2012-06-20 | 2013-09-18 | 327d? | 260d | start no earlier than 2012-06-20 | S5 | 2616h |  | WLAN-OAM | PCG-29 | Intel | joey.chou@intel.com | Rel-12 | SP-56 |  |  |
| 113 | 38 | Rel-12 Charging Management small Enhancements | 526d? | 2012-09-12 | 2014-09-17 |  |  | 2012-09-12 | 2014-09-17 | 526d? | 0d | finish no earlier than 2014-09-17 | S5 | 4208h |  | CH12 | PCG-29 |  |  | Rel-12 | SP-57 |  |  |
| 114 | 39 | Interworking between a PLMN with WLAN to access the EPC and a PDN (Stage 3) | 326d? | 2012-09-07 | 2013-12-06 |  |  | 2012-09-07 | 2013-12-06 | 326d? | 203d | finish no earlier than 2013-12-06 | C3 | 2608h |  | SAES_WLAN_EPC_intwk | PCG-29 | Huawei | Christian.Herrero@huawei.com | Rel-12 | CP-57 |  |  |
| 115 | 40 | **Introduction of ER-GSM band for GSM-R** | 439d? | 2011-09-16 A | 2013-05-17 | 23% | 337.67d? | 2011-09-16 | 2013-05-17 | 439d? | 348d |  | G1,C1 | 9576h | 1469.07h | RT_ERGSM | PCG-27 | Kapsch Carriercom | thomas.chatelet@kapsch.net | Rel-12 | GP-51 |  |  |
| 116 | 40.1 | GERAN1 part of Introduction of ER-GSM band for GSM-R | 438d? | 2011-09-16 A | 2013-05-17 | 40% | 262.8d? | 2011-09-16 | 2013-05-17 | 438d? | 348d | finish no earlier than 2013-05-17 | G1 | 3496h | 1393.6h | RT_ERGSM | PCG-27 | Kapsch Carriercom | thomas.chatelet@kapsch.net | Rel-12 | GP-51 |  |  |
| 117 | 40.2 | CT1 part of Introduction of ER-GSM band for GSM-R | 321d? | 2011-09-21 | 2012-12-07 |  |  | 2011-09-21 | 2012-12-07 | 321d? | 463d | finish no earlier than 2012-12-07 | C1 | 2568h |  | RT_ERGSM | PCG-27 | Kapsch Carriercom | thomas.chatelet@kapsch.net | Rel-12 | CP-53 |  |  |
| 118 | 41 | **Downlink Multi Carrier GERAN** | 392d? | 2012-08-31 | 2014-02-28 |  |  | 2012-08-31 | 2014-02-28 | 392d? | 143d |  | G2,G1,C1,G3new | 10464h |  | DMCG | PCG-29 | Ericsson | paul.schliwa-bertling@ericsson.com | Rel-12 | GP-55 |  |  |
| 119 | 41.1 | Core part: Downlink Multi Carrier GERAN | 262d? | 2012-08-31 | 2013-08-30 |  |  | 2012-08-31 | 2013-08-30 | 262d? | 273d | finish no earlier than 2013-08-30 | G2,G1 | 2096h |  | DMCG | PCG-29 | Ericsson | paul.schliwa-bertling@ericsson.com | Rel-12 | GP-55 |  |  |
| 120 | 41.2 | CT part: Downlink Multi Carrier GERAN | 262d? | 2012-08-31 | 2013-08-30 |  |  | 2012-08-31 | 2013-08-30 | 262d? | 273d | finish no earlier than 2013-08-30 | C1 | 2096h |  | DMCG | PCG-29 | Ericsson | paul.schliwa-bertling@ericsson.com | Rel-12 | GP-55 |  |  |
| 121 | 41.3 | Test part: Downlink Multi Carrier GERAN | 392d? | 2012-08-31 | 2014-02-28 |  |  | 2012-08-31 | 2014-02-28 | 392d? | 143d | finish no earlier than 2014-02-28 | G3new | 3136h |  | DMCG-MStest | PCG-29 | ST-Ericsson | hakan.e.grunditz@stericsson.com | Rel-12 | GP-55 |  |  |
| 122 | 42 | **Further enhancements to H(e)NB mobility - Part 3 (Stage 2/3)** | 201d? | 2012-09-07 | 2013-06-14 |  |  | 2012-09-07 | 2013-06-14 | 201d? | 328d |  | R3,R2 | 3216h |  | EHNB_enh3 | PCG-29 | Alcatel-Lucent |  | Rel-12 | RP-57 |  |  |
| 123 | 42.1 | Core part: Further enhancements to H(e)NB mobility - Part 3 | 201d? | 2012-09-07 | 2013-06-14 |  |  | 2012-09-07 | 2013-06-14 | 201d? | 328d | finish no earlier than 2013-06-14 | R3,R2 | 1608h |  | EHNB_enh3-Core | PCG-29 | Alcatel-Lucent |  | Rel-12 | RP-57 |  |  |
| 124 | 43 | **Carrier based HetNet ICIC for LTE** | 591d? | 2011-03-18 A | 2013-06-14 | 40% | 354.6d? | 2011-03-18 | 2013-06-14 | 591d? | 328d |  | R3,R1,R2 | 9432h | 3772.77h | LTE_CA_HetNet_ICIC | PCG-26 | Nokia Siemens Networks | krzysztof.kordybach@nsn.com | Rel-12 | RP-51 | Juha |  |
| 125 | 43.1 | Core part: Carrier based HetNet ICIC for LTE | 588d? | 2011-03-18 A | 2013-06-14 | 40% | 352.8d? | 2011-03-18 | 2013-06-14 | 588d? | 328d | finish no earlier than 2013-06-14 | R3,R1,R2 | 4704h | 1881.6h | LTE_CA_HetNet_ICIC-Core | PCG-26 | Nokia Siemens Networks | krzysztof.kordybach@nsn.com | Rel-12 | RP-51 | Juha | RP-121007 |
| 126 | 44 | **LTE in the 1670-1675 MHz Band for US** | 402d? | 2012-03-05 A | 2013-09-13 | 5% | 381.92d? | 2012-03-05 | 2013-09-13 | 402d? | 263d |  | R4,R2,R3 | 9128h | 456.26h | LTE_FDD_1670_US | PCG-28 | LightSquared | Masoud.Olfat@LightSquared.com | Rel-12 | RP-55 |  |  |
| 127 | 44.1 | Core part: LTE in the 1670-1675 MHz Band for US | 337d? | 2012-03-05 A | 2013-06-14 | 5% | 320.15d? | 2012-03-05 | 2013-06-14 | 337d? | 328d | finish no earlier than 2013-06-14 | R4,R2,R3 | 2696h | 134.8h | LTE_FDD_1670_US-Core | PCG-28 | LightSquared | Masoud.Olfat@LightSquared.com | Rel-12 | RP-55 |  | RP-121072 |
| 128 | 44.2 | Perf. part: LTE in the 1670-1675 MHz Band for US | 402d? | 2012-03-05 A | 2013-09-13 | 5% | 381.9d? | 2012-03-05 | 2013-09-13 | 402d? | 263d | finish no earlier than 2013-09-13 | R4 | 3216h | 160.8h | LTE_FDD_1670_US-Perf | PCG-28 | LightSquared | Masoud.Olfat@LightSquared.com | Rel-12 | RP-55 |  | RP-121073 |

Notes:
- 104: Stage 1/2/3. Source of external requirements: NGMN NGCOR v1.3
- 105: - / Text3: new TR 32.837
- 106: Stage 1/2/3. / Text3: 32.101, 32.103, new TS 32.xxx/28.xxx (FMC FNIM Umbrella Operations Model (OIM), new TR (32.839 [Management Specification Tooling Environment], 32.840 [Management Specification Testing Recommendations])
- 107: Stage 1/2/3. / Text3: New TSs (32.PM1 to 32.PM7)
- 108: Stage 1/2/3. / Text3: 32.103 or New TS 28.abc
- 109: -
- 110: - / Text3: New TR 32.841
- 111: - / Text3: new TSs ab.xy1/2/6 WLAN NRM Requirements/Information Service/Solution Set
- 112: SA5 shall not define new WLAN performance measurements / Text3: new TSs ab.xyz (Performance Management; performance measurements for WLAN)
- 113: CH12 is an umbrella Feature also for OAM&P related TEI12 type of changes that are not part of any other dedicated feature/WI
- 114: Linked to Rel-8 Feature SAES: System Architecture Evolution specification - Evolved Packet System (non RAN aspects) UID_320005, Rel-11 Feature S2a Mobility based On GTP and WLAN access to EPC (SaMOG_WLAN) UID_530046 / Text3: 29.061
- 115: GP#55 moved to Rel-12. Use of band 870-876/915-921 MHz for land mobile service on national possibilities/market demand - as per ECC/DEC/(04)06 / Text3: GERAN
- 116: GP#55 moved to Rel-12. Completion 11/12=>05/13. GP#51 approved WID. Introduction of ERGSM band, Performance requirements and Deployment scenarios / Text3: 45.001, 45.005, 45.050
- 117: ERGSM capability indication. GP#55 moved Feature to Rel-12 / Text3: 24.008
- 118: GP#55 approved WID. Linked to Rel-7 Downlink Dual Carrier UID_50579 (Previous work on multiple carriers on the downlink was limited to two). Ref: TR 45.912 Feasibility study for evolved GERAN, TS 43.064 GPRS Stage 2 / Text3: GERAN
- 119: - / Text3: 43.064, 44.018, 44.060, 45.002, 45.005, 45.008
- 120: - / Text3: 24.008
- 121: GP#55 approved WID / Text3: 51.010-1, 51.010-2
- 122: Triggered by FS_EHNB_enh (TR 37.803) / Text3: UTRA, LTE
- 123: Text3: 25.331, 25.413, 25.423, 25.467, 25.469, 25.471, 36.300, 36.331, 36.413, 36.423
- 124: Stage 2/3. RP#57 moved to Rel-12. Updated WID RP-111111=>RP-121198 / Text3: LTE
- 125: RP#57 moved to Rel-12. Updated WID RP-111111=>RP-121198, Completion 09/12=>06/13 / Text3: 36.300, 36.413, 36.420, 36.423
- 126: RP#57 moved to Rel-12. Updated WID RP-120360=>RP-121397 / Text3: LTE
- 127: RP#57 moved to Rel-12. Updated WID RP-120360=>RP-121397. Completion 12/12=>06/13 / Text3: 25.101, 25.104, 25.113, 25.133, 25.306, 25.307, 25.331, 25.461, 25.466, 34.124, 36.101, 36.104, 36.113, 36.124, 36.133, 36.307, new TR 36.832
- 128: RP#57 moved to Rel-12. Updated WID RP-120360=>RP-121397. Completion 03/13=>09/13 / Text3: 25.133, 25.306, 25.307, 25.331, 25.461, 25.466, 34.124, 36.113, 36.124, 36.133, 36.141, 36.307

| ID | WBS | Task | Duration | Start | Finish | Complete | Remaining | Baseline start | Baseline finish | Baseline duration | Total slack | Constraint | Resources | Work | Actual work | Text1 | Text2 | Text4 | Text5 | Text6 | Text7 | Text11 |
| --- | --- | --- | --- | --- | --- | --- | --- | --- | --- | --- | --- | --- | --- | --- | --- | --- | --- | --- | --- | --- | --- | --- |
| 129 | 45 | **LTE in the US Wireless Communications Service (WCS) Band** | 266d? | 2012-09-07 | 2013-09-13 |  |  | 2012-09-07 | 2013-09-13 | 266d? | 263d |  | R4,R2 | 5864h |  | LTE_WCS_band | PCG-29 | AT&T | marc.grant@att.com | Rel-12 | RP-57 |  |
| 130 | 45.1 | Core part: LTE in the US Wireless Communications Service (WCS) Band | 201d? | 2012-09-07 | 2013-06-14 |  |  | 2012-09-07 | 2013-06-14 | 201d? | 328d | finish no earlier than 2013-06-14 | R4,R2 | 1608h |  | LTE_WCS_band-Core | PCG-29 | AT&T | marc.grant@att.com | Rel-12 | RP-57 |  |
| 131 | 45.2 | Perf. part: LTE in the US Wireless Communications Service (WCS) Band | 266d? | 2012-09-07 | 2013-09-13 |  |  | 2012-09-07 | 2013-09-13 | 266d? | 263d | finish no earlier than 2013-09-13 | R4 | 2128h |  | LTE_WCS_band-Perf | PCG-29 | AT&T | marc.grant@att.com | Rel-12 | RP-57 |  |
| 132 | 46 | **Introduction of LTE 450 MHz band in Brazil** | 201d? | 2012-09-07 | 2013-06-14 |  |  | 2012-09-07 | 2013-06-14 | 201d? | 328d |  | R4 | 4824h |  | LTE450_Brazil | PCG-29 | Huawei | Liehai Liu (liuliehai@huawei.com) | Rel-12 | RP-57 |  |
| 133 | 46.1 | Core part: Introduction of LTE 450 MHz band in Brazil | 201d? | 2012-09-07 | 2013-06-14 |  |  | 2012-09-07 | 2013-06-14 | 201d? | 328d | finish no earlier than 2013-06-14 | R4 | 1608h |  | LTE450_Brazil-Core | PCG-29 | Huawei | Liehai Liu (liuliehai@huawei.com) | Rel-12 | RP-57 |  |
| 134 | 46.2 | Perf. part: Introduction of LTE 450 MHz band in Brazil | 201d? | 2012-09-07 | 2013-06-14 |  |  | 2012-09-07 | 2013-06-14 | 201d? | 328d | finish no earlier than 2013-06-14 | R4 | 1608h |  | LTE450_Brazil-Perf | PCG-29 | Huawei | Liehai Liu (liuliehai@huawei.com) | Rel-12 | RP-57 |  |
| 135 | 47 | **Further Downlink MIMO Enhancement for LTE Advanced** | 266d? | 2012-09-07 | 2013-09-13 |  |  | 2012-09-07 | 2013-09-13 | 266d? | 263d |  | R1,R4 | 5864h |  | LTE_eDL_MIMO_enh | PCG-29 | Alcatel-Lucent | Min Zhang (min.hs.zhang@alcatel-lucent.com) | Rel-12 | RP-57 |  |
| 136 | 47.1 | Core part: Further Downlink MIMO Enhancement for LTE Advanced | 201d? | 2012-09-07 | 2013-06-14 |  |  | 2012-09-07 | 2013-06-14 | 201d? | 328d | finish no earlier than 2013-06-14 | R1 | 1608h |  | LTE_eDL_MIMO_enhl-Core | PCG-29 | Alcatel-Lucent | Min Zhang (min.hs.zhang@alcatel-lucent.com) | Rel-12 | RP-57 |  |
| 137 | 47.2 | Perf. part: Further Downlink MIMO Enhancement for LTE Advanced | 266d? | 2012-09-07 | 2013-09-13 |  |  | 2012-09-07 | 2013-09-13 | 266d? | 263d | finish no earlier than 2013-09-13 | R4 | 2128h |  | LTE_eDL_MIMO_enhl-Perf | PCG-29 | Alcatel-Lucent | ren.da@alcatel-lucent.com | Rel-12 | RP-57 |  |
| 138 | 48 | **New Carrier Type for LTE** | 461d? | 2012-09-07 | 2014-06-13 |  |  | 2012-09-07 | 2014-06-13 | 461d? | 68d |  | R1,R2,R4 | 9984h |  | LTE_NCT | PCG-29 | Ericsson | daniel.n.larsson@ericsson.com | Rel-12 | RP-57 |  |
| 139 | 48.1 | Core part: New Carrier Type for LTE | 326d? | 2012-09-07 | 2013-12-06 |  |  | 2012-09-07 | 2013-12-06 | 326d? | 203d | finish no earlier than 2013-12-06 | R1,R2,R4 | 2608h |  | LTE_NCT-Core | PCG-29 | Ericsson | daniel.n.larsson@ericsson.com | Rel-12 | RP-57 |  |
| 140 | 48.2 | Perf. part: New Carrier Type for LTE | 461d? | 2012-09-07 | 2014-06-13 |  |  | 2012-09-07 | 2014-06-13 | 461d? | 68d | finish no earlier than 2014-06-13 | R4 | 3688h |  | LTE_NCT-Perf | PCG-29 | Ericsson | daniel.n.larsson@ericsson.com | Rel-12 | RP-57 |  |
| 141 | 49 | **LTE Advanced intra-band non-contiguous Carrier Aggregation in Band 25** | 583d? | 2011-09-19 A | 2013-12-06 | 35% | 378.96d? | 2011-09-19 | 2013-12-06 | 583d? | 203d |  | R4 | 13496h | 4723.56h | LTE_CA_NC_B25 | PCG-27 | Sprint | George.Cummings@sprint.com | Rel-12 | RP-53 |  |
| 142 | 49.1 | Core part: LTE Advanced intra-band non-contiguous Carrier Aggregation in Band 25 | 522d? | 2011-09-19 A | 2013-09-13 | 35% | 339.3d? | 2011-09-19 | 2013-09-13 | 522d? | 263d | finish no earlier than 2013-09-13 | R4 | 4176h | 1461.6h | LTE_CA_NC_B25-Core | PCG-27 | Sprint | George.Cummings@sprint.com | Rel-12 | RP-53 | RP-121064 |
| 143 | 49.2 | Perf. part: LTE Advanced intra-band non-contiguous Carrier Aggregation in Band 25 | 582d? | 2011-09-19 A | 2013-12-06 | 35% | 378.3d? | 2011-09-19 | 2013-12-06 | 582d? | 203d | finish no earlier than 2013-12-06 | R4 | 4656h | 1629.6h | LTE_CA_NC_B25-Perf | PCG-27 | Sprint | George.Cummings@sprint.com | Rel-12 | RP-53 | RP-121065 |
| 144 | 50 | **LTE Advanced intra-band non-contiguous Carrier Aggregation in Band 3** | 337d? | 2012-03-05 A | 2013-06-14 | 10% | 303.31d? | 2012-03-05 | 2013-06-14 | 337d? | 328d |  | R4 | 8072h | 807.16h | LTE_CA_NC_B3 | PCG-28 | SK Telecom | Haesung PARK | Rel-12 | RP-55 |  |
| 145 | 50.1 | Core part: LTE Advanced intra-band non-contiguous Carrier Aggregation in Band 3 | 336d? | 2012-03-05 A | 2013-06-14 | 20% | 268.8d? | 2012-03-05 | 2013-06-14 | 336d? | 328d | finish no earlier than 2013-06-14 | R4 | 2688h | 537.6h | LTE_CA_NC_B3-Core | PCG-28 | SK Telecom | Haesung PARK | Rel-12 | RP-55 | RP-121066 |
| 146 | 50.2 | Perf. part: LTE Advanced intra-band non-contiguous Carrier Aggregation in Band 3 | 336d? | 2012-03-06 | 2013-06-14 |  |  | 2012-03-06 | 2013-06-14 | 336d? | 328d | finish no earlier than 2013-06-14 | R4 | 2688h |  | LTE_CA_NC_B3-Perf | PCG-28 | SK Telecom | Haesung PARK | Rel-12 | RP-55 | RP-121067 |
| 147 | 51 | **LTE Advanced intra-band Contiguous Carrier Aggregation in Band 1** | 261d? | 2012-06-18 A | 2013-06-14 | 4% | 249.81d? | 2012-06-18 | 2013-06-14 | 261d? | 328d |  | R4 | 5744h | 246.28h | LTE_CA_C_B1 | PCG-29 | KDDI | Masaaki Obara | Rel-12 | RP-56 |  |
| 148 | 51.1 | Core part: LTE Advanced intra-band contiguous Carrier Aggregation in Band 1 | 196d? | 2012-06-18 A | 2013-03-15 | 10% | 176.4d? | 2012-06-18 | 2013-03-15 | 196d? | 393d | finish no earlier than 2013-03-15 | R4 | 1568h | 156.8h | LTE_CA_C_B1-Core | PCG-29 | KDDI | Masaaki Obara | Rel-12 | RP-56 | RP-121068 |
| 149 | 51.2 | Perf. part: LTE Advanced intra-band contiguous Carrier Aggregation in Band 1 | 261d? | 2012-06-18 | 2013-06-14 |  |  | 2012-06-18 | 2013-06-14 | 261d? | 328d | finish no earlier than 2013-06-14 | R4 | 2088h |  | LTE_CA_C_B1-Perf | PCG-29 | KDDI | Masaaki Obara | Rel-12 | RP-56 | RP-121069 |
| 150 | 52 | **LTE Advanced intra-band non-contiguous Carrier Aggregation in Band 4** | 386d? | 2012-06-18 A | 2013-12-06 | 5% | 366.71d? | 2012-06-18 | 2013-12-06 | 386d? | 203d |  | R4 | 9264h | 463.14h | LTE_CA_NC_B4 | PCG-29 | T-Mobile USA | nelson.ueng@t-mobile.com | Rel-12 | RP-56 |  |
| 151 | 52.1 | Core part: LTE Advanced intra-band non-contiguous Carrier Aggregation in Band 4 | 386d? | 2012-06-18 A | 2013-12-06 | 10% | 347.4d? | 2012-06-18 | 2013-12-06 | 386d? | 203d | finish no earlier than 2013-12-06 | R4 | 3088h | 308.8h | LTE_CA_NC_B4-Core | PCG-29 | T-Mobile USA | nelson.ueng@t-mobile.com | Rel-12 | RP-56 | RP-121074 |
| 152 | 52.2 | Perf. part: LTE Advanced intra-band non-contiguous Carrier Aggregation in Band 4 | 386d? | 2012-06-18 | 2013-12-06 |  |  | 2012-06-18 | 2013-12-06 | 386d? | 203d | finish no earlier than 2013-12-06 | R4 | 3088h |  | LTE_CA_NC_B4-Perf | PCG-29 | T-Mobile USA | nelson.ueng@t-mobile.com | Rel-12 | RP-56 | RP-121075 |

Notes:
- 129: Start work when appropriate regional regulatory approval is attained (http://apps.fcc.gov/ecfs/document/view?id=7021923273) / Text3: LTE
- 130: - / Text3: 36.101, 36.104, 36.113, 36.124, 36.133, 36.307, 36.331
- 131: - / Text3: 36.101, 36.133, 36.141
- 132: - / Text3: LTE
- 133: - / Text3: 36.101, 36.104, 36.113, 36.124, 36.133, 37.104, 37.113, 36.307, new TR 36.8xy
- 134: - / Text3: 36.133, 36.141, 37.141
- 135: Stage 3 / Text3: LTE
- 136: - / Text3: 36.211, 36.212, 36.213, 36.331
- 137: - / Text3: 36.101
- 138: Stage 2,3 / Text3: LTE
- 139: - / Text3: 36.101, 36.133, 36.211, 36.212, 36.213, 36.321, 36.331
- 140: - / Text3: 36.101, 36.133
- 141: Stage 3. RP#57 moved to Rel-12. Updated WID RP-120366=>RP-121143 (Since the gain vs added complexity is low for the UL, only DL CA is considered in this WI) / Text3: LTE
- 142: RP#57 updated WID RP-120366=>RP-121143. Completion 06/13=>12/13 / Text3: 36.101, 36.104, 36.133, 36.141, 36.307, new TR 36.841
- 143: RP#57 updated WID RP-120366=>RP-121143. Completion 06/13=>09/13 / Text3: 36.101, 36.104, 36.133, 36.141, 36.307
- 144: Stage 3 / Text3: LTE
- 145: - / Text3: 36.101, 36.104, 36.133, 36.307, new TR 36.8ab
- 146: - / Text3: 36.101, 36.104, 36.133, 36.141, 36.307
- 147: Stage 3 / Text3: LTE
- 148: - / Text3: 36.101, 36.104, 36.133, 36.141, 36.307, new TR 36.8xy
- 149: - / Text3: 36.101, 36.104, 36.133, 36.141, 36.307
- 150: Stage 3 / Text3: LTE
- 151: - / Text3: 36.101, 36.104, 36.133, 36.141, 36.307, new TR 36.833
- 152: - / Text3: 36.101, 36.104, 36.133, 36.141, 36.307

| ID | WBS | Task | Duration | Start | Finish | Complete | Remaining | Baseline start | Baseline finish | Baseline duration | Total slack | Constraint | Resources | Work | Actual work | Text1 | Text2 | Text4 | Text5 | Text6 | Text7 | Text11 |
| --- | --- | --- | --- | --- | --- | --- | --- | --- | --- | --- | --- | --- | --- | --- | --- | --- | --- | --- | --- | --- | --- | --- |
| 153 | 53 | **LTE Advanced intra-band contiguous Carrier Aggregation in Band 3** | 326d? | 2012-09-07 | 2013-12-06 |  |  | 2012-09-07 | 2013-12-06 | 326d? | 203d |  | R4 | 7344h |  | LTE_CA_C_B3 | PCG-29 | China Unicom | Fei CUI (cuifei1@chinaunicom.cn) | Rel-12 | RP-57 |  |
| 154 | 53.1 | Core part: LTE Advanced intra-band contiguous Carrier Aggregation in Band 3 | 266d? | 2012-09-07 | 2013-09-13 |  |  | 2012-09-07 | 2013-09-13 | 266d? | 263d | finish no earlier than 2013-09-13 | R4 | 2128h |  | LTE_CA_C_B3-Core | PCG-29 | China Unicom | Fei CUI (cuifei1@chinaunicom.cn) | Rel-12 | RP-57 |  |
| 155 | 53.2 | Perf. part: LTE Advanced intra-band contiguous Carrier Aggregation in Band 3 | 326d? | 2012-09-07 | 2013-12-06 |  |  | 2012-09-07 | 2013-12-06 | 326d? | 203d | finish no earlier than 2013-12-06 | R4 | 2608h |  | LTE_CA_C_B3-Perf | PCG-29 | China Unicom | Fei CUI (cuifei1@chinaunicom.cn) | Rel-12 | RP-57 |  |
| 156 | 54 | **LTE Advanced inter-band Carrier Aggregation of Band 3 and Band 5 with 2UL** | 337d? | 2012-03-05 A | 2013-06-14 | 10% | 303.25d? | 2012-03-05 | 2013-06-14 | 337d? | 328d |  | R4 | 8080h | 809.19h | LTE_CA_B3_B5_2UL | PCG-28 | SK Telecom | Seungpyo Hong | Rel-12 | RP-55 |  |
| 157 | 54.1 | Core part: LTE Advanced inter-band Carrier Aggregation of Band 3 and Band 5 with 2UL | 337d? | 2012-03-05 A | 2013-06-14 | 20% | 269.6d? | 2012-03-05 | 2013-06-14 | 337d? | 328d | finish no earlier than 2013-06-14 | R4 | 2696h | 539.2h | LTE_CA_B3_B5_2UL-Core | PCG-28 | SK Telecom | Seungpyo Hong | Rel-12 | RP-55 | RP-121056 |
| 158 | 54.2 | Perf. part: LTE Advanced inter-band Carrier Aggregation of Band 3 and Band 5 with 2UL | 336d? | 2012-03-06 | 2013-06-14 |  |  | 2012-03-06 | 2013-06-14 | 336d? | 328d | finish no earlier than 2013-06-14 | R4 | 2688h |  | LTE_CA_B3_B5_2UL-Perf | PCG-28 | SK Telecom | Seungpyo Hong | Rel-12 | RP-55 | RP-121057 |
| 159 | 55 | **LTE Advanced inter-band Carrier Aggregation of Band 2 and Band 4** | 261d? | 2012-06-18 A | 2013-06-14 | 5% | 247.96d? | 2012-06-18 | 2013-06-14 | 261d? | 328d |  | R4 | 6264h | 313.14h | LTE_CA_B2_B4 | PCG-29 | T-Mobile USA | nelson.ueng@t-mobile.com | Rel-12 | RP-56 |  |
| 160 | 55.1 | Core part: LTE Advanced inter-band Carrier Aggregation of Band 2 and Band 4 | 261d? | 2012-06-18 A | 2013-06-14 | 10% | 234.9d? | 2012-06-18 | 2013-06-14 | 261d? | 328d | finish no earlier than 2013-06-14 | R4 | 2088h | 208.8h | LTE_CA_B2_B4-Core | PCG-29 | T-Mobile USA | nelson.ueng@t-mobile.com | Rel-12 | RP-56 | RP-121076 |
| 161 | 55.2 | Perf. part: LTE Advanced inter-band Carrier Aggregation of Band 2 and Band 4 | 261d? | 2012-06-18 | 2013-06-14 |  |  | 2012-06-18 | 2013-06-14 | 261d? | 328d | finish no earlier than 2013-06-14 | R4 | 2088h |  | LTE_CA_B2_B4-Perf | PCG-29 | T-Mobile USA | nelson.ueng@t-mobile.com | Rel-12 | RP-56 | RP-121077 |
| 162 | 56 | **LTE Advanced inter-band Carrier Aggregation of Band 23 and Band 29** | 201d? | 2012-09-07 | 2013-06-14 |  |  | 2012-09-07 | 2013-06-14 | 201d? | 328d |  | R4 | 4824h |  | LTE_CA_B23_B29 | PCG-29 | Dish Network | Mariam Sorond, Dominic Tolli | Rel-12 | RP-57 |  |
| 163 | 56.1 | Core part: LTE Advanced inter-band Carrier Aggregation of Band 23 and Band 29 | 201d? | 2012-09-07 | 2013-06-14 |  |  | 2012-09-07 | 2013-06-14 | 201d? | 328d | finish no earlier than 2013-06-14 | R4 | 1608h |  | LTE_CA_B23_B29-Core | PCG-29 | Dish Network | Mariam Sorond, Dominic Tolli | Rel-12 | RP-57 |  |
| 164 | 56.2 | Perf. part: LTE Advanced inter-band Carrier Aggregation of Band 23 and Band 29 | 201d? | 2012-09-07 | 2013-06-14 |  |  | 2012-09-07 | 2013-06-14 | 201d? | 328d | finish no earlier than 2013-06-14 | R4 | 1608h |  | LTE_CA_B23_B29-Perf | PCG-29 | Dish Network | Mariam Sorond, Dominic Tolli | Rel-12 | RP-57 |  |
| 165 | 57 | **LTE Advanced inter-band Carrier Aggregation of Band 3 and Band 26** | 201d? | 2012-09-07 | 2013-06-14 |  |  | 2012-09-07 | 2013-06-14 | 201d? | 328d |  | R4 | 4824h |  | LTE_CA_B3_B26 | PCG-29 | KT | Chungwoo HWANG (cwhwang@kt.com) | Rel-12 | RP-57 |  |
| 166 | 57.1 | Core part: LTE Advanced inter-band Carrier Aggregation of Band 3 and Band 26 | 201d? | 2012-09-07 | 2013-06-14 |  |  | 2012-09-07 | 2013-06-14 | 201d? | 328d | finish no earlier than 2013-06-14 | R4 | 1608h |  | LTE_CA_B3_B26-Core | PCG-29 | KT | Chungwoo HWANG (cwhwang@kt.com) | Rel-12 | RP-57 |  |
| 167 | 57.2 | Perf. part: LTE Advanced inter-band Carrier Aggregation of Band 3 and Band 26 | 201d? | 2012-09-07 | 2013-06-14 |  |  | 2012-09-07 | 2013-06-14 | 201d? | 328d | finish no earlier than 2013-06-14 | R4 | 1608h |  | LTE_CA_B3_B26-Perf | PCG-29 | KT | Chungwoo HWANG (cwhwang@kt.com) | Rel-12 | RP-57 |  |
| 168 | 58 | **LTE Advanced inter-band Carrier Aggregation of Band 3 and Band 19** | 201d? | 2012-09-07 | 2013-06-14 |  |  | 2012-09-07 | 2013-06-14 | 201d? | 328d |  | R4 | 4824h |  | LTE_CA_B3_B19 | PCG-29 | NTT DOCOMO | Hiromasa Umeda | Rel-12 | RP-57 |  |
| 169 | 58.1 | Core part: LTE Advanced inter-band Carrier Aggregation of Band 3 and Band 19 | 201d? | 2012-09-07 | 2013-06-14 |  |  | 2012-09-07 | 2013-06-14 | 201d? | 328d | finish no earlier than 2013-06-14 | R4 | 1608h |  | LTE_CA_B3_B19-Core | PCG-29 | NTT DOCOMO | Hiromasa Umeda | Rel-12 | RP-57 |  |
| 170 | 58.2 | Perf. part: LTE Advanced inter-band Carrier Aggregation of Band 3 and Band 19 | 201d? | 2012-09-07 | 2013-06-14 |  |  | 2012-09-07 | 2013-06-14 | 201d? | 328d | finish no earlier than 2013-06-14 | R4 | 1608h |  | LTE_CA_B3_B19-Perf | PCG-29 | NTT DOCOMO | Hiromasa Umeda | Rel-12 | RP-57 |  |
| 171 | 59 | **LTE Advanced inter-band Carrier Aggregation of Band 38 and Band 39** | 266d? | 2012-09-07 | 2013-09-13 |  |  | 2012-09-07 | 2013-09-13 | 266d? | 263d |  | R4 | 6384h |  | LTE_CA_B38_B39 | PCG-29 | China Mobile | Pan Qun (panqun@chinamobile.com) | Rel-12 | RP-57 |  |
| 172 | 59.1 | Core part: LTE Advanced inter-band Carrier Aggregation of Band 38 and Band 39 | 266d? | 2012-09-07 | 2013-09-13 |  |  | 2012-09-07 | 2013-09-13 | 266d? | 263d | finish no earlier than 2013-09-13 | R4 | 2128h |  | LTE_CA_B38_B39-Core | PCG-29 | China Mobile | Pan Qun (panqun@chinamobile.com) | Rel-12 | RP-57 |  |
| 173 | 59.2 | Perf. part: LTE Advanced inter-band Carrier Aggregation of Band 38 and Band 39 | 266d? | 2012-09-07 | 2013-09-13 |  |  | 2012-09-07 | 2013-09-13 | 266d? | 263d | finish no earlier than 2013-09-13 | R4 | 2128h |  | LTE_CA_B38_B39-Perf | PCG-29 | China Mobile | Pan Qun (panqun@chinamobile.com) | Rel-12 | RP-57 |  |
| 174 | 60 | **LTE Advanced inter-band Carrier Aggregation of Band 1 and Band 8** | 201d? | 2012-09-07 | 2013-06-14 |  |  | 2012-09-07 | 2013-06-14 | 201d? | 328d |  | R4,R2 | 4824h |  | LTE_CA_B1_B8 | PCG-29 | Softbank Mobile | Kenichi Kihara | Rel-12 | RP-57 |  |
| 175 | 60.1 | Core part: LTE Advanced inter-band Carrier Aggregation of Band 1 and Band 8 | 201d? | 2012-09-07 | 2013-06-14 |  |  | 2012-09-07 | 2013-06-14 | 201d? | 328d | finish no earlier than 2013-06-14 | R4,R2 | 1608h |  | LTE_CA_B1_B8-Core | PCG-29 | Softbank Mobile | Kenichi Kihara | Rel-12 | RP-57 |  |
| 176 | 60.2 | Perf. part: LTE Advanced inter-band Carrier Aggregation of Band 1 and Band 8 | 201d? | 2012-09-07 | 2013-06-14 |  |  | 2012-09-07 | 2013-06-14 | 201d? | 328d | finish no earlier than 2013-06-14 | R4 | 1608h |  | LTE_CA_B1_B8-Perf | PCG-29 | Softbank Mobile | Kenichi Kihara | Rel-12 | RP-57 |  |

Notes:
- 153: Stage 3 / Text3: LTE
- 154: - / Text3: 36.101, 36.104, 36.133, 36.141, 36.307, 37.104, 37.141
- 155: - / Text3: 36.101, 36.104, 36.133, 36.141, 36.307, 37.104, 37.141
- 156: Stage 3. Complementary to 1UL existing Rel-11 WI LTE_CA_B3_B5 UID_530026 / Text3: LTE
- 157: RP#57 completion 03/13=>06/13 / Text3: 36.101, 36.104, 36.133, 36.307, new generic TR 36.85x
- 158: - / Text3: 36.133, 36.141
- 159: Stage 3. RP#57 updated WID RP-120875=>RP-121145 (to include smaller channel bandwidths) / Text3: LTE
- 160: RP#57 updated WID RP-120875=>RP-121145 (to include smaller channel bandwidths) / Text3: 36.101, 36.104, 36.133, 36.141, 36.307, new generic TR 36.85x
- 161: RP#57 updated WID RP-120875=>RP-121145 (to include smaller channel bandwidths) / Text3: 36.101, 36.104, 36.133, 36.141, 36.307
- 162: Stage 3. On hold until Band 29 is introduced in 3GPP specs (Band 29 = LTE_DL_FDD700) / Text3: LTE
- 163: - / Text3: 36.101, 36.104, 36.307, new TR 36.8xy
- 164: - / Text3: 36.133, 36.141
- 165: Stage 3 / Text3: LTE
- 166: - / Text3: 36.101, 36.104, 36.133, 36.307, new TR 36.8xy
- 167: - / Text3: 36.101, 36.104, 36.133, 36.141, 36.307
- 168: Stage 3 / Text3: LTE
- 169: - / Text3: 36.101, 36.104, 36.133, new generic TR 36.85x
- 170: - / Text3: 36.141, 36.307
- 171: Stage 3 / Text3: LTE
- 172: - / Text3: 36.101, 36.104, 36.307, new generic TR 36.85x
- 173: - / Text3: 36.133, 36.141
- 174: Stage 3 / Text3: LTE
- 175: - / Text3: 36.101, 36.104, 36.133, 36.307, 36.331, new generic TR 36.85x
- 176: - / Text3: 36.133, 36.141

| ID | WBS | Task | Duration | Start | Finish | Complete | Remaining | Baseline start | Baseline finish | Baseline duration | Total slack | Constraint | Resources | Work | Actual work | Text1 | Text2 | Text3 | Text4 | Text5 | Text6 | Text7 | Text8 | Text11 |
| --- | --- | --- | --- | --- | --- | --- | --- | --- | --- | --- | --- | --- | --- | --- | --- | --- | --- | --- | --- | --- | --- | --- | --- | --- |
| 177 | 61 | **LTE Advanced inter-band Carrier Aggregation of Band 3 and Band 28** | 201d? | 2012-09-07 | 2013-06-14 |  |  | 2012-09-07 | 2013-06-14 | 201d? | 328d |  | R4 | 4824h |  | LTE_CA_B3_B28 | PCG-29 | LTE | eAccess | FukumotoShiro@eaccess.net | Rel-12 | RP-57 |  |  |
| 178 | 61.1 | Core part: LTE Advanced inter-band Carrier Aggregation of Band 3 and Band 28 | 201d? | 2012-09-07 | 2013-06-14 |  |  | 2012-09-07 | 2013-06-14 | 201d? | 328d | finish no earlier than 2013-06-14 | R4 | 1608h |  | LTE_CA_B3_B28-Core | PCG-29 | 36.101, 36.104, 36.133, new generic TR 36.85x | eAccess | FukumotoShiro@eaccess.net | Rel-12 | RP-57 |  |  |
| 179 | 61.2 | Perf. part: LTE Advanced inter-band Carrier Aggregation of Band 3 and Band 28 | 201d? | 2012-09-07 | 2013-06-14 |  |  | 2012-09-07 | 2013-06-14 | 201d? | 328d | finish no earlier than 2013-06-14 | R4 | 1608h |  | LTE_CA_B3_B28-Perf | PCG-29 | 36.141, 36.307 | eAccess | FukumotoShiro@eaccess.net | Rel-12 | RP-57 |  |  |
| 180 | 62 | (Small) Technical Enhancements and Improvements for Rel-11 | 393d? | 2012-06-21 | 2013-12-20 |  |  | 2012-06-21 | 2013-12-20 | 393d? | 193d | finish no earlier than 2013-12-20 | All | 3144h |  | TEI12 | PCG-29 |  |  |  | Rel-12 | RP-56 |  |  |
| 181 | 63 | Postponed - Enhanced CoMP for LTE | 1d? | 2012-09-07 | 2012-09-07 |  |  | 2012-09-07 | 2012-09-07 | 1d? | 528d | start no earlier than 2012-09-07 | R1 | 8h |  | COMP_LTE_enh | PCG-29 | LTE | Samsung |  | Rel-12 | RP-57 |  |  |
| 182 | 64 | Postponed - Further Enhancements for Diverse Data Applications for LTE | 1d? | 2012-09-07 | 2012-09-07 |  |  | 2012-09-07 | 2012-09-07 | 1d? | 528d | start no earlier than 2012-09-07 | R2 | 8h |  | LTE_eDDA2 | PCG-29 | LTE | Research In Motion |  | Rel-12 | RP-57 |  |  |
| 183 | 65 | Postponed - LTE Coverage Enhancements | 1d? | 2012-09-07 | 2012-09-07 |  |  | 2012-09-07 | 2012-09-07 | 1d? | 528d | start no earlier than 2012-09-07 | R1 | 8h |  | Cov_Enh_LTE | PCG-29 | LTE | China Telecom |  | Rel-12 | RP-57 |  |  |
| 184 | 66 | Postponed - Performance Requirements of 8 Rx Antennas for LTE UL | 1d? | 2012-09-07 | 2012-09-07 |  |  | 2012-09-07 | 2012-09-07 | 1d? | 528d | start no earlier than 2012-09-07 | R4 | 8h |  | LTE_UL_8Rx-Perf | PCG-29 | LTE | China Telecom |  | Rel-12 | RP-57 |  |  |
| 185 | 67 | Postponed - LTE Advanced inter-band Carrier Aggregation of Band 1 and Band 5 with 2UL | 1d? | 2012-09-07 | 2012-09-07 |  |  | 2012-09-07 | 2012-09-07 | 1d? | 528d | start no earlier than 2012-09-07 | R4 | 8h |  | LTE_CA_B1_B5_2UL | PCG-29 | LTE | LG Uplus |  | Rel-12 | RP-57 |  |  |
| 186 | 68 | Postponed - eMBMS enhancements for LTE | 1d? | 2012-09-07 | 2012-09-07 |  |  | 2012-09-07 | 2012-09-07 | 1d? | 528d | start no earlier than 2012-09-07 | R1,R2,R4 | 8h |  | MBMS_LTE_enh2 | PCG-29 | LTE 36.101, 36.104, 36.211, 36.212, 36.213, 36.321, 36.331 | Qualcomm | Hao Xu | Rel-12 | RP-57 |  |  |
| 187 | 69 | Postponed - Proposed Enhancement II of Minimization of Drive Tests for E-UTRAN | 1d? | 2012-09-07 | 2012-09-07 |  |  | 2012-09-07 | 2012-09-07 | 1d? | 528d | start no earlier than 2012-09-07 | R2 | 8h |  | eMDT2_LTE-Core | PCG-29 | LTE | MediaTek |  | Rel-12 | RP-57 |  |  |
| 188 | 70 | Postponed - Hetnet Mobility Enhancements for LTE | 1d? | 2012-09-07 | 2012-09-07 |  |  | 2012-09-07 | 2012-09-07 | 1d? | 528d | start no earlier than 2012-09-07 | R2 | 8h |  | HetNet_eMOB_LTE | PCG-29 | LTE | Alcatel-Lucent |  | Rel-12 | RP-57 |  |  |
| 189 | 71 | Postponed - Further Enhancements to LTE TDD for DL-UL Interference Management and Traffic Adaptation | 1d? | 2012-09-07 | 2012-09-07 |  |  | 2012-09-07 | 2012-09-07 | 1d? | 528d | start no earlier than 2012-09-07 | R1 | 8h |  | LTE_TDD_eIMTA | PCG-29 | LTE | CATT |  | Rel-12 | RP-57 |  |  |
| 190 | 72 | Postponed - Further LTE (UL) Carrier Aggregation Enhancements | 1d? | 2012-09-07 | 2012-09-07 |  |  | 2012-09-07 | 2012-09-07 | 1d? | 528d | start no earlier than 2012-09-07 | R1 | 8h |  | LTE_CA_enh2_UL | PCG-29 | LTE | Nokia |  | Rel-12 | RP-57 |  |  |
| 191 | 73 | Release 12 Studies | 646d? | 2011-09-24 | 2014-03-12 |  |  | 2011-09-24 | 2014-03-12 | 646d? | 135d | finish no earlier than 2014-03-12 | SP | 5168h |  |  |  |  |  |  | Rel-12 |  |  |  |
| 192 | 74 | Study on Alternatives to E.164 for Machine-Type Communications | 513d? | 2010-03-25 A | 2012-03-07 A | 100% |  | 2010-03-25 | 2012-03-07 | 513d? |  | finish no earlier than 2012-03-07 | S1 | 4080h | 4080h | FS_AMTC | PCG-24 | 22.988 | T-Mobile USA | gary.jones@T-Mobile.com | Rel-12 | SP-47 | Alain |  |
| 193 | 75 | Study on enhancements for Machine-Type Communications (MTC) | 716d? | 2010-06-10 A | 2013-03-06 | 45% | 393.8d? | 2010-06-10 | 2013-03-06 | 716d? | 400d | finish no earlier than 2013-03-06 | S1 | 5728h | 2577.6h | FS_MTCe | PCG-25 | 22.888 | Huawei | laurence.meriau@huawei.com | Rel-12 | SP-48 | Alain | S1-122337 |
| 194 | 76 | Study on Integration of Single Sign-On (SSO) frameworks with 3GPP networks | 383d? | 2010-09-23 A | 2012-03-07 A | 100% |  | 2010-09-23 | 2012-03-07 | 383d? |  | finish no earlier than 2011-09-08 | S1 | 3041.15h | 3041.15h | FS_SSO_Int | PCG-25 | 22.895 | InterDigital | christopher.wallace@interdigital.com | Rel-12 | SP-49 | Alain |  |
| 195 | 77 | Study on Continuity of Data Sessions to Local Networks | 262.85d? | 2010-12-16 A | 2011-12-14 A | 100% |  | 2010-12-16 | 2011-12-14 | 262.85d? |  | finish no earlier than 2011-12-14 | S1 | 2084.27h | 2084.27h | FS_CSN | PCG-26 | 22.896 | NEC | joerg.swetina@nw.neclab.eu | Rel-12 | SP-50 | Alain |  |
| 196 | 78 | Study on non-MTC Mobile Data Applications Impacts | 262.77d? | 2010-12-16 A | 2011-12-14 A | 100% |  | 2010-12-16 | 2011-12-14 | 262.77d? |  | finish no earlier than 2011-12-14 | S1 | 2083.59h | 2083.59h | FS_MODAI | PCG-26 | 22.801 | Huawei, China Mobile | Amar Deol (adeol@huawei.com), Gang Li | Rel-12 | SP-50 | Alain |  |
| 197 | 79 | Study on Proximity-based Services | 322d? | 2011-09-22 A | 2012-12-12 | 75% | 80.5d? | 2011-09-22 | 2012-12-12 | 322d? | 460d | finish no earlier than 2012-12-12 | S1 | 2568h | 1924.93h | FS_ProSe | PCG-27 | 22.803 | Qualcomm | Rich Hovey (rhovey@qualcomm.com) | Rel-12 | SP-53 |  | S1-122339 |
| 198 | 80 | Study on User Plane Congestion management | 198d? | 2011-12-14 A | 2012-09-12 A | 100% |  | 2011-12-14 | 2012-09-12 | 198d? |  | finish no earlier than 2012-09-12 | S1 | 1568h | 1568h | FS_UPCON | PCG-28 | 22.805 | KDDI | John Visser (xjo-visser@kddi.com) | Rel-12 | SP-54 |  | S1-122340 |
| 199 | 81 | Study on RAN Sharing Enhancements | 261d? | 2011-12-14 A | 2012-12-12 | 70% | 78.3d? | 2011-12-14 | 2012-12-12 | 261d? | 460d | finish no earlier than 2012-12-12 | S1 | 2088h | 1461.6h | FS_RSE | PCG-28 | 22.852 | NEC | joerg.swetina@nw.neclab.eu | Rel-12 | SP-54 |  | S1-122341 |
| 200 | 82 | Study on Application specific Congestion control for Data Communication | 201d? | 2012-09-12 | 2013-06-19 |  |  | 2012-09-12 | 2013-06-19 | 201d? | 325d | finish no earlier than 2013-06-19 | S1 | 1608h |  | FS_ACDC | PCG-29 | 22.8xy | NTT DOCOMO | Shin-ichi Isobe (isobes@nttdocomo.co.jp) | Rel-12 | SP-57 |  | S1-122521 |

Notes:
- 177: Stage 3
- 178: -
- 179: -
- 180: -
- 181: -
- 182: -
- 183: follow-up WI of FS_Cov_Enh_LTE (RP-120225) completed at RAN #56. WI has core and perf. Part
- 184: WI has perf. part only (as change from 4Rx to 8Rx has no spec impact)
- 185: -
- 186: Stage 2,3
- 187: -
- 188: note: Follow-up WI of SI FS_HetNet_eMOB_LTE that might be completed at RAN #57
- 189: Follow up WI to FS_LTE_TDD_eIMTA completed at RAN#56
- 190: -
- 191: -
- 192: SP#55 completed. Determine an alternative to E.164 for identifying individual devices and route messages between those devices
- 193: SP#56 completion 12/12=>03/13. Study addition of new MTC-related use cases and functionality, and also improvements to the existing requirements in TS 22.368
- 194: SP#55 completed. Linked to SA3 Study on Single Sign On (SSO) Application Security for IMS - based on SIP Digest (UID_480048), SA3 TR 33.924 Extended Identity Management (GBA-IdM) and SA3 TR 33.980 (LibSec)
- 195: SP#54 completed. Linked to SA1 Rel-11 Feature UID_490030 SIPTO Service Continuity of IP Data Session (SIPTO_SC)
- 196: SP#54 completed. Linked to UID_490036 SA2 Rel-11 TR 23.843 Study on Core Network Overload solutions (FS_CNO)
- 197: SP#57 TR 22.803 v100 for Information
- 198: SP#57 completed. Linked to SAPP (Service Awareness and Privacy Policies), FS_UMONC (Study on Usage Monitoring Control Enhancement), QoS_SSL (QoS Control Based on Subscriber Spending Limits)
- 199: SP#57 completion 09/12=>12/12. TR 22.852 v100 for Information. Extend Rel-6 Network Sharing UID_31018 (basic scenarios of network/RAN sharing) to cover more complex scenarios that arise due to recent needs for more dynamic co-operation among operators.
- 200: ACDC is applicable to UTRAN and E-UTRAN

| ID | WBS | Task | Duration | Start | Finish | Complete | Remaining | Baseline start | Baseline finish | Baseline duration | Total slack | Constraint | Resources | Work | Actual work | Text1 | Text2 | Text3 | Text4 | Text5 | Text6 | Text7 | Text8 | Text11 | Text9 | Text12 |
| --- | --- | --- | --- | --- | --- | --- | --- | --- | --- | --- | --- | --- | --- | --- | --- | --- | --- | --- | --- | --- | --- | --- | --- | --- | --- | --- |
| 201 | 83 | **Study on IMS based Peer-to-Peer Content Distribution Services (Stage 2)** | 585d? | 2010-09-23 A | 2012-12-12 | 90% | 57.2d? | 2010-09-23 | 2012-12-12 | 585d? | 460d |  | S2,S1,S3 | 10064h | 6952h | FS_IMS_P2P_CDS | PCG-25 | 23.844 | China Mobile | Yu Qing (yuqing@chinamobile.com) | Rel-12 | SP-49 | Maurice |  |  |  |
| 202 | 83.1 | SA1 part of Study on IMS based Peer-to-Peer Content Distribution Services (Stage 2) | 262d? | 2010-09-23 A | 2011-09-21 A | 100% |  | 2010-09-23 | 2011-09-21 | 262d? |  | finish no earlier than 2011-09-21 | S1 | 2080h | 2080h | FS_IMS_P2P_CDS | PCG-25 | 23.844 | China Mobile | Yu Qing (yuqing@chinamobile.com) | Rel-12 | SP-49 | Maurice |  |  |  |
| 203 | 83.2 | SA2 part of Study on IMS based Peer-to-Peer Content Distribution Services (Stage 2) | 347d? | 2010-09-23 A | 2012-06-20 A | 100% |  | 2010-09-23 | 2012-06-20 | 347d? |  | finish no earlier than 2012-06-08 | S2 | 2776h | 2776h | FS_IMS_P2P_CDS | PCG-25 | 23.844 | China Mobile | Yu Qing (yuqing@chinamobile.com) | Rel-12 | SP-49 | Maurice |  |  |  |
| 204 | 83.3 | SA3 part of Study on IMS based Peer-to-Peer Content Distribution Services (Stage 2) | 66d? | 2012-09-12 | 2012-12-12 |  |  | 2012-09-12 | 2012-12-12 | 66d? | 460d | finish no earlier than 2012-12-12 | S3 | 528h |  | FS_IMS_P2P_CDS | PCG-29 | 33.844 | China Mobile | Zhu Judy(zhuhongru@chinamobile.com) | Rel-12 | SP-57 |  |  |  |  |
| 205 | 84 | Study on Core Network Overload solutions | 844d? | 2010-09-23 A | 2013-12-11 | 35% | 548.6d? | 2010-09-23 | 2013-12-11 | 844d? | 200d | finish no earlier than 2013-12-11 | S2 | 6744h | 2359.31h | FS_CNO | PCG-25 | 23.843 | Huawei | john.kaippallimalil@huawei.com | Rel-12 | SP-49 | Maurice |  |  |  |
| 206 | 85 | Study on System Enhancements for Energy Efficiency | 399d? | 2010-12-16 A | 2012-06-20 A | 100% |  | 2010-12-16 | 2012-06-20 | 399d? |  | finish no earlier than 2012-06-20 | S2 | 3192h | 3192h | FS_SEEE | PCG-26 | 23.866 | Huawei | frank.mademann@huawei.com | Rel-12 | SP-50 | Maurice |  |  |  |
| 207 | 86 | Study on S2a Mobility based On GTP and WLAN access to EPC | 516d? | 2011-03-23 A | 2013-03-06 | 25% | 387.25d? | 2011-03-23 | 2013-03-06 | 516d? | 400d | finish no earlier than 2013-03-06 | S2 | 4085.94h | 1011.59h | FS_SaMOG | PCG-26 | 23.852 | ZTE | Chunhui Zhu (zhu.chunhui@zte.com.cn) | Rel-12 | SP-51 | Maurice |  |  |  |
| 208 | 87 | **Study on Usage Monitoring Control enhancement** | 401d? | 2011-06-08 A | 2012-12-12 | 71% | 117.49d? | 2011-06-08 | 2012-12-12 | 401d? | 460d |  | S2,S1,S5 | 9618.08h | 6780.6h | FS_UMONC | PCG-27 |  | ZTE, Huawei | bi.yifeng@zte.com.cn | Rel-12 | SP-52 | Maurice |  |  |  |
| 209 | 87.1 | SA1 part of Study on Usage Monitoring Control enhancement | 275d? | 2011-06-08 A | 2012-06-20 A | 100% |  | 2011-06-08 | 2012-06-20 | 275d? |  | finish no earlier than 2012-06-20 | S1 | 2176h | 2176h | FS_UMONC | PCG-27 | 23.858 | ZTE | Li.Mian@zte.com.cn | Rel-12 | SP-52 | Maurice | S1-122338 |  |  |
| 210 | 87.2 | SA2 part of Study on Usage Monitoring Control enhancement | 397d? | 2011-06-14 A | 2012-12-12 | 40% | 238.2d? | 2011-06-14 | 2012-12-12 | 397d? | 460d | finish no earlier than 2012-12-12 | S2 | 3146.08h | 1248.48h | FS_UMONC | PCG-27 | 23.858 | ZTE | bi.yifeng@zte.com.cn | Rel-12 | SP-52 | Maurice |  |  |  |
| 211 | 87.3 | Deleted - SA5 part of Study on Usage Monitoring Control enhancement | 141d? | 2011-06-08 A | 2011-12-16 A | 100% |  | 2011-06-08 | 2011-12-16 | 141d? |  | finish no earlier than 2012-09-12 | S5 | 1088h | 1088h | FS_UMONC | PCG-27 | 32.858 | Huawei | Hui Cai (Sarah.Cai@huawei.com) | Rel-12 | SP-52 | Dionisio |  | PCG-29 | SP-57 |
| 212 | 88 | Study on Optimized Offloading to WLAN in 3GPP-RAT mobility | 263d? | 2012-06-18 A | 2013-06-19 | 5% | 249.85d? | 2012-06-18 | 2013-06-19 | 263d? | 325d | finish no earlier than 2013-06-19 | S2 | 2104h | 105.2h | FS_WORM | PCG-29 | 23.890 | RIM | Stefano Faccin (sfaccin@rim.com) | Rel-12 | SP-56 |  |  |  |  |
| 213 | 89 | Study on Application Based Charging | 198d? | 2012-06-18 A | 2013-03-20 | 12% | 174.24d? | 2012-06-18 | 2013-03-20 | 198d? | 390d | finish no earlier than 2013-03-20 | S2 | 1584h | 190.08h | FS_ABC | PCG-29 | 23.800 | Allot Communications | Alla Goldner (agoldner@allot.com) | Rel-12 | SP-56 |  |  |  |  |
| 214 | 90 | **Study on Multi Access PDN connectivity and IP flow Mobility** | 1208.96d? | 2008-08-08 A | 2013-03-19 | 71% | 356.05d? | 2008-08-08 | 2013-03-19 | 1208.96d? | 391d |  | S2,S1 | 12912h | 9104.58h | FS_MAPIM | PCG-21 | 23.861 | Qualcomm | Gerardo Giaretta (gerardog@qualcomm.com) | Rel-12 | SP-41 | Maurice |  |  |  |
| 215 | 90.1 | SA1 part of Study on Multi Access PDN connectivity and IP flow Mobility | 22d? | 2008-08-08 A | 2011-09-21 A | 100% |  | 2008-08-08 | 2011-09-21 | 22d? |  | finish no earlier than 2011-09-21 | S1 | 160h | 160h | FS_MAPIM | PCG-21 | 23.861 | Qualcomm | Gerardo Giaretta (gerardog@qualcomm.com) | Rel-12 | SP-41 | Maurice |  |  |  |
| 216 | 90.2 | SA2 part of Study on Multi Access PDN connectivity and IP flow Mobility | 1180d? | 2008-09-18 A | 2013-03-19 | 70% | 354d? | 2008-09-18 | 2013-03-19 | 1180d? | 391d | finish no earlier than 2012-06-20 | S2 | 9440h | 6608h | FS_MAPIM | PCG-21 | 23.861 | Qualcomm | Gerardo Giaretta (gerardog@qualcomm.com) | Rel-12 | SP-41 | Maurice |  |  |  |
| 217 | 91 | Study on IP Flow Mobility support for S2a and S2b Interfaces | 198d? | 2012-06-18 A | 2013-03-20 | 20% | 158.4d? | 2012-06-18 | 2013-03-20 | 198d? | 390d | finish no earlier than 2013-03-20 | S2 | 1584h | 316.8h | FS_NBIFOM | PCG-29 | 23.861 | ZTE | Tricci So (tso@zteusa.com) | Rel-12 | SP-56 |  |  |  |  |
| 218 | 92 | Study on Extended IMS Media Plane Security features | 657d? | 2010-06-10 A | 2012-12-12 | 79% | 141.13d? | 2010-06-10 | 2012-12-12 | 657d? | 460d | finish no earlier than 2012-12-12 | S3 | 5248h | 4118.96h | FS_eMEDIASEC | PCG-25 | 33.829 | Vodafone | peter.howard@vodafone.com | Rel-12 | SP-48 | Dionisio |  |  |  |
| 219 | 93 | Study on Security aspects of Integration of Single Sign-On (SSO) frameworks with 3GPP networks | 521d? | 2010-12-16 A | 2012-12-12 | 25% | 390.75d? | 2010-12-16 | 2012-12-12 | 521d? | 460d | finish no earlier than 2012-12-12 | S3 | 4168h | 1042h | FS_SSO_Int_Sec | PCG-26 | 33.8xy | Ericsson | vesa.lehtovirta@ericsson.com | Rel-12 | SP-50 | Dionisio |  |  |  |
| 220 | 94 | Study on IMS Firewall Traversal | 391d? | 2011-06-17 A | 2012-12-12 | 70% | 117.3d? | 2011-06-17 | 2012-12-12 | 391d? | 460d | finish no earlier than 2012-12-12 | S3 | 2648h | 2149.6h | FS_iFire | PCG-27 | 33.830 | Acme Packet | Prashant Kumar (PKumar@acmepacket.com) | Rel-12 | SP-53 |  |  |  |  |
| 221 | 95 | Study on Security on spoofed call detection and prevention (Stage 2) | 333d? | 2012-03-07 A | 2013-06-14 | 25% | 249.75d? | 2012-03-07 | 2013-06-14 | 333d? | 328d | finish no earlier than 2013-06-14 | S3 | 2664h | 666h | FS_SPOOF | PCG-28 | 33.8xy | China Mobile | lixiangjun@chinamobile.com | Rel-12 | SP-55 |  |  |  |  |
| 222 | 96 | Study on Security Assurance Methodology for 3GPP Network Elements | 201d? | 2012-09-12 | 2013-06-19 |  |  | 2012-09-12 | 2013-06-19 | 201d? | 325d | finish no earlier than 2013-06-19 | S3 | 1608h |  | FS_SECAM | PCG-29 | 33.8xy | Orange | loic.habermacher@orange.com | Rel-12 | SP-57 |  |  |  |  |
| 223 | 97 | Study on Improved Support for Dynamic Adaptive Streaming over HTTP in 3GPP | 321d? | 2011-12-14 A | 2013-03-06 | 20% | 256.8d? | 2011-12-14 | 2013-03-06 | 321d? | 400d | finish no earlier than 2013-03-06 | S4 | 2568h | 513.6h | FS_IS_DASH | PCG-28 | 26.938 | Qualcomm | c_tstock@qualcomm.com | Rel-12 | RP-54 |  |  |  |  |
| 224 | 98 | Study on version handling | 714d? | 2010-03-25 A | 2012-12-12 | 90% | 71.4d? | 2010-03-25 | 2012-12-12 | 714d? | 460d | finish no earlier than 2012-12-12 | S5 | 5704h | 5132.8h | FS_OAM_VH | PCG-24 | 32.830 | Ericsson | thomas.tovinger@ericsson.com | Rel-12 | SP-47 | Dionisio |  |  |  |
| 225 | 99 | Study on management of Heterogeneous Networks | 649d? | 2011-03-23 A | 2013-09-11 | 40% | 389.4d? | 2011-03-23 | 2013-09-11 | 649d? | 265d | finish no earlier than 2013-09-11 | S5 | 5192h | 2076.8h | FS_OAM_HetNet | PCG-26 | 32.8xy | Ericsson | brendan.hassett@ericsson.com | Rel-12 | SP-51 |  |  |  |  |
| 226 | 100 | Study on OAM aspects of Network Sharing | 266d? | 2011-12-07 A | 2012-12-12 | 30% | 186.2d? | 2011-12-07 | 2012-12-12 | 266d? | 460d | finish no earlier than 2012-12-12 | S5 | 2128h | 638.4h | FS_OAM_SHARE | PCG-28 | 32.851 | Alcatel-Lucent, Huawei | Padma.Sudarsan@alcatel-lucent.com, zoulan@huawei.com | Rel-12 | SP-54 |  |  |  |  |
| 227 | 101 | Study on GERAN improvements for Machine-Type Communications | 648.5d? | 2010-05-24 A | 2012-11-23 | 60% | 259.4d? | 2010-05-24 | 2012-11-23 | 648.5d? | 473d | finish no earlier than 2012-11-23 | G1,G2 | 5188h | 3112.8h | FS_NIMTC_GERAN | PCG-24 | GERAN 43.868 | Ericsson | paul.schliwa-bertling@ericsson.com | Rel-12 | GP-44 | Paolo |  |  |  |
| 228 | 102 | Study on Solutions for GSM/EDGE BTS Energy Saving | 582d? | 2010-09-03 A | 2012-11-23 | 85% | 87.3d? | 2010-09-03 | 2012-11-23 | 582d? | 473d | finish no earlier than 2012-11-23 | G1,G2 | 4656h | 3957.6h | FS_Energy_BTS | PCG-25 | GERAN 45.926 | Nokia Siemens Networks, Vodafone | juergen.hofmann@nsn.com, leo.patanapongpibul@vodafone.com | Rel-12 | GP-47 | Paolo |  |  |  |
| 229 | 103 | Study on Voice services over Adaptive Multi-user channels on One Slot (VAMOS) enhancements | 400d? | 2011-05-20 A | 2012-11-23 | 35% | 260d? | 2011-05-20 | 2012-11-23 | 400d? | 473d | finish no earlier than 2012-11-23 | GP,G2,G1 | 3200h | 1120h | FS_eVAMOS | PCG-27 | GERAN 45.8xy | China Mobile, Huawei | dengjuan@chinamobile.com, Chao Luo (chluo@huawei.com) | Rel-12 | GP-50 | Paolo |  |  |  |
| 230 | 104 | Study on GERAN enhancements for Mobile Data Applications | 521d? | 2011-05-24 A | 2013-05-17 | 40% | 312.6d? | 2011-05-24 | 2013-05-17 | 521d? | 348d | finish no earlier than 2013-05-17 | G2,G1 | 4168h | 1667.2h | FS_GERAN_eMDA | PCG-27 | GERAN 43.802 | Huawei | ming.fang@huawei.com | Rel-12 | GP-50 | Gert |  |  |  |
| 231 | 105 | Study on Inclusion of RF Pattern Matching Technologies as a positioning method in the E-UTRAN | 523d? | 2010-12-10 A | 2012-12-07 | 55% | 235.35d? | 2010-12-10 | 2012-12-07 | 523d? | 463d | finish no earlier than 2012-12-07 | R4 | 4184h | 2301.2h | FS_LCS_LTE_RFPMT | PCG-26 | LTE 36.809 | Polaris Wireless | Scot Gordon (sgordon@polariswireless.com) | Rel-12 | RP-50 | Issam | RP-121084 |  |  |
| 232 | 106 | Study on Provision of low-cost MTC UEs based on LTE | 382d? | 2011-09-19 A | 2013-03-01 | 90% | 38.2d? | 2011-09-19 | 2013-03-01 | 382d? | 403d | finish no earlier than 2013-03-01 | R1,R2,R4 | 3048h | 2742.4h | FS_LC_MTC_LTE | PCG-27 | LTE 36.888 | Vodafone | prakash.bhat@vodafone.com | Rel-12 | RP-53 |  | RP-121086 |  |  |
| 233 | 107 | Study on Mobile Relay for E-UTRA | 657d? | 2009-07-21 A | 2013-06-14 | 80% | 131.4d? | 2009-07-21 | 2013-06-14 | 657d? | 328d | finish no earlier than 2013-06-14 | R3,R1 | 5256h | 4204.8h | FS_LTE_mobRelay | PCG-27 | LTE 36.836 | CATT | Haijing Hu | Rel-12 | RP-53 |  | RP-121087 |  |  |
| 234 | 108 | Study on LTE-HRPD (High Rate Packet Data in 3GPP2) inter-RAT SON | 202d? | 2012-03-02 A | 2012-12-07 | 30% | 141.4d? | 2012-03-02 | 2012-12-07 | 202d? | 463d | finish no earlier than 2012-12-07 | R3 | 1616h | 484.8h | FS_LTE_HRPD_SON | PCG-28 | LTE TR 36.8xy | China Telecom | Wu Jinlian (wujl@gsta.com) | Rel-12 | RP-55 |  | RP-121088 |  |  |
| 235 | 109 | Study on LTE FDD in the bands 1980-2010 MHz and 2170-2200 MHz | 201d? | 2012-09-07 | 2013-06-14 |  |  | 2012-09-07 | 2013-06-14 | 201d? | 328d | finish no earlier than 2013-06-14 | R4 | 1608h |  | FS_LTE_1980_2170_Korea | PCG-29 | LTE TR 36.8xy | KT | Chungwoo Hwang (cwhwang@kt.com) | Rel-12 | RP-57 |  |  |  |  |
| 236 | 110 | Study on Scenarios and Requirements of LTE Small Cell Enhancements | 66d? | 2012-09-07 | 2012-12-07 |  |  | 2012-09-07 | 2012-12-07 | 66d? | 463d | finish no earlier than 2012-12-07 | RP | 528h |  | FS_LTE_SC_enh_req | PCG-29 | LTE TR 36.8xy | China Mobile | Hai TANG (tanghai@chinamobile.com) | Rel-12 | RP-57 |  |  |  |  |
| 237 | 111 | Study on RF and EMC requirements for active Antenna Array System (AAS) Base Station | 322d? | 2011-09-19 A | 2012-12-07 | 65% | 112.7d? | 2011-09-19 | 2012-12-07 | 322d? | 463d | finish no earlier than 2012-12-07 | R4,R1 | 2576h | 1674.4h | FS_AAS_BS_LTE_UTRA | PCG-27 | UTRA, LTE 37.840 | Huawei | Ronnie.zhang@huawei.com | Rel-12 | RP-53 |  | RP-121081 |  |  |
| 238 | 112 | Study on Passive InterModulation (PIM) handling for UTRA and LTE Base Stations | 202d? | 2012-03-05 A | 2012-12-07 | 55% | 90.9d? | 2012-03-05 | 2012-12-07 | 202d? | 463d | finish no earlier than 2012-12-07 | R4,G1 | 1616h | 888.8h | FS_BS_PIM | PCG-28 | UTRA, LTE, GERAN 37.808 | Ericsson | johan.skold@ericsson.com | Rel-12 | RP-55 |  | RP-121082 |  |  |
| 239 | 113 | Study on UMTS Heterogeneous Networks | 201d? | 2012-09-07 | 2013-06-14 |  |  | 2012-09-07 | 2013-06-14 | 201d? | 328d | finish no earlier than 2013-06-14 | R1,R2,R3 | 1608h |  | FS_UTRA_hetnet | PCG-29 | UTRA TR 25.8vw | Huawei | carmela.cozzo@huawei.com | Rel-12 | RP-57 |  |  |  |  |
| 240 | 114 | Postponed - Study on Small Data Transmission Optimization for High Mobility in LTE | 1d? | 2012-09-07 | 2012-09-07 |  |  | 2012-09-07 | 2012-09-07 | 1d? | 528d | start no earlier than 2012-09-07 | R2 | 8h |  | FS_UTRA_ | PCG-29 | LTE TR 36.8xy | China Unicom |  | Rel-12 | RP-57 |  |  |  |  |
| 241 | 115 | Postponed - Study on DCH enhancements | 1d? | 2012-09-07 | 2012-09-07 |  |  | 2012-09-07 | 2012-09-07 | 1d? | 528d | start no earlier than 2012-09-07 | R1 | 8h |  | FS_UTRA_DCHenh | PCG-29 | UTRA TR 25.8vw | Qualcomm |  | Rel-12 | RP-57 |  |  |  |  |
| 242 | 116 | Postponed - Study on LTE and HSDPA Carrier Aggregation | 1d? | 2012-09-07 | 2012-09-07 |  |  | 2012-09-07 | 2012-09-07 | 1d? | 528d | start no earlier than 2012-09-07 | R2 | 8h |  | FS_LTE_HSDPA_CA | PCG-29 | UTRA, LTE TR | Nokia Siemens Networks |  | Rel-12 | RP-57 |  |  |  |  |
| 243 | 117 | Postponed - Study on 3D-channel model for Elevation Beamforming and Massive MIMO studies for LTE | 1d? | 2012-09-07 | 2012-09-07 |  |  | 2012-09-07 | 2012-09-07 | 1d? | 528d | start no earlier than 2012-09-07 | R1 | 8h |  | FS_LTE_ | PCG-29 | LTE TR 36.8xy | Nokia Siemens Networks |  | Rel-12 | RP-57 |  |  |  |  |
| 244 | 118 | Postponed - Study on LTE Downlink Enhancements for Elevation Beamforming | 1d? | 2012-09-07 | 2012-09-07 |  |  | 2012-09-07 | 2012-09-07 | 1d? | 528d | start no earlier than 2012-09-07 | R1 | 8h |  | FS_LTE_ | PCG-29 | LTE TR 36.8xy | Nokia Siemens Networks |  | Rel-12 | RP-57 |  |  |  |  |
| 245 | 119 | Postponed - Study on LTE Device to Device Proximity Discovery | 1d? | 2012-09-07 | 2012-09-07 |  |  | 2012-09-07 | 2012-09-07 | 1d? | 528d | start no earlier than 2012-09-07 | R1,R2,R4 | 8h |  | FS_LTE_D2D_Prox | PCG-29 | LTE TR 36.8xy | Qualcomm | Saurabh Tavildar | Rel-12 | RP-57 |  |  |  |  |
| 246 | 120 | Postponed - Study on HSPA RRM Enhancement | 1d? | 2012-09-07 | 2012-09-07 |  |  | 2012-09-07 | 2012-09-07 | 1d? | 528d | start no earlier than 2012-09-07 | R2 | 8h |  | FS_HSPA_RRMenh | PCG-29 | UTRA TR 25.8vw | China Unicom |  | Rel-12 | RP-57 |  |  |  |  |
| 247 | 121 | Postponed - Study on RAN Enhancements for UMTS/HSPA and LTE Interworking | 1d? | 2012-09-07 | 2012-09-07 |  |  | 2012-09-07 | 2012-09-07 | 1d? | 528d | start no earlier than 2012-09-07 | R3 | 8h |  | FS_HSPA_LTE_interworking | PCG-29 | UTRA, LTE TR | China Unicom |  | Rel-12 | RP-57 |  |  |  |  |
| 248 | 122 | Postponed - Study on next-generation SON for UTRA and LTE | 1d? | 2012-09-07 | 2012-09-07 |  |  | 2012-09-07 | 2012-09-07 | 1d? | 528d | start no earlier than 2012-09-07 | R3 | 8h |  | FS_UTRA_LTE_NG_SON | PCG-29 | UTRA, LTE TR | Nokia Siemens Networks |  | Rel-12 | RP-57 |  |  |  |  |
| 249 | 123 | Postponed - Study on LTE extensions to Minimization of Drive Tests | 1d? | 2012-09-07 | 2012-09-07 |  |  | 2012-09-07 | 2012-09-07 | 1d? | 528d | start no earlier than 2012-09-07 | R2 | 8h |  | FS_LTE_feMDT | PCG-29 | LTE TR 36.8xy | Nokia Siemens Networks |  | Rel-12 | RP-57 |  |  |  |  |
| 250 | 124 | Postponed - Study on Push to talk over Cellular for LTE | 1d? | 2012-09-07 | 2012-09-07 |  |  | 2012-09-07 | 2012-09-07 | 1d? | 528d | start no earlier than 2012-09-07 | R1 | 8h |  | FS_LTE_ | PCG-29 | LTE TR 36.8xy | Alcatel-Lucent |  | Rel-12 | RP-57 |  |  |  |  |
| 251 | 125 | Postponed - Study on WLAN/3GPP Radio Interworking | 1d? | 2012-09-07 | 2012-09-07 |  |  | 2012-09-07 | 2012-09-07 | 1d? | 528d | start no earlier than 2012-09-07 | R2 | 8h |  | FS_UTRA_LTE_ | PCG-29 | UTRA, LTE TR 37.8xy | Intel |  | Rel-12 | RP-57 |  |  |  |  |
| 252 | 126 | Postponed - Study on Further EUL Enhancements | 1d? | 2012-09-07 | 2012-09-07 |  |  | 2012-09-07 | 2012-09-07 | 1d? | 528d | start no earlier than 2012-09-07 | R2 | 8h |  | FS_EDCH_enh | PCG-29 | UTRA TR 25.8vw | Ericsson |  | Rel-12 | RP-57 |  |  |  |  |
| 253 | 127 | Postponed - Study on Further Enhanced Receivers for LTE UEs | 1d? | 2012-09-07 | 2012-09-07 |  |  | 2012-09-07 | 2012-09-07 | 1d? | 528d | start no earlier than 2012-09-07 | R1 | 8h |  | FS_LTE_UE_Rx_enh | PCG-29 | LTE TR 36.8xy | Renesas |  | Rel-12 | RP-57 |  |  |  |  |
| 254 | 128 | Postponed - Study on Full Dimension MIMO for LTE | 1d? | 2012-09-07 | 2012-09-07 |  |  | 2012-09-07 | 2012-09-07 | 1d? | 528d | start no earlier than 2012-09-07 | R1 | 8h |  | FS_LTE_FD_MIMO | PCG-29 | LTE TR 36.8xy | Samsung |  | Rel-12 | RP-57 |  |  |  |  |
| 255 | 129 | Postponed - Study on Enhanced Interference Suppression for LTE | 326d? | 2012-09-07 | 2013-12-06 |  |  | 2012-09-07 | 2013-12-06 | 326d? | 203d | finish no earlier than 2013-12-06 | R1,R2,R4 | 2608h |  | FS_LTE_ISenh | PCG-29 | LTE TR 36.8xy | Broadcom | Amin Mobasher (mobasher@broadcom.com) | Rel-12 | RP-57 |  |  |  |  |
| 256 | 130 | Deleted - Study on UICC/USIM enhancements | 588d? | 2009-12-10 A | 2012-03-07 A | 100% |  | 2009-12-10 | 2012-03-07 | 588d? |  | finish no earlier than 2012-03-07 | S1 | 4704h | 4704h | FS_U2e | PCG-24 | 22.817 | Giesecke & Devrient | ilario.macchi@gi-de.com | Rel-12 | SP-46 | Alain |  | PCG-28 | SP-55 |
| 257 | 131 | Release 11 Features | 708d? | 2010-03-29 A | 2012-12-07 | 85% | 106.2d? | 2010-03-29 | 2012-12-07 | 708d? | 463d | finish no earlier than 2012-12-07 | SP,CP,GP,RP | 5664h | 4814.4h |  |  |  |  |  | Rel-11 |  | All |  |  |  |

Notes:
- 201: SP#57 updated WID SP-100567=>SP-120622 (added new SA3 TR). Triggered by TR 22.906 SA1 Study on IMS based Peer-to-Peer Content Distribution Services UID_450047
- 202: SP#53 completed
- 203: SP#56 completed. TR 23.844v100 for Information and Approval
- 204: SP#57 updated WID SP-100567=>SP-120622 (added new SA3 TR)
- 205: SP#57 updated WID SP-120262=>SP-120490. Linked to CT4 TR 23.857 Study on EPC Nodes Restoration (UID_490014). Anticipated support from CT4 and RAN WGs
- 206: SP#56 completed
- 207: Completion 06/12=>03/13 (for UE impact). Study covers generic non-3GPP access (e.g. WLAN, WIMAX, CDMA/HRPD). Spin-off Feature SaMOG_WLAN. Linked to Rel-8 Support for non-3GPP accesses, Rel-10 SMOG, Rel-11 BBAI
- 208: SP#57 updated WID SP-120258=>SP-120554 (stopped SA5's dedicated TR work)
- 209: SP#56 completed
- 210: SP#57 updated WID SP-120258=>SP-120554
- 211: SP#57 stopped. Updated WID SP-120258=>SP-120554 (stopped SA5's dedicated TR work)
- 212: Linked to UID_350027 SAE for support for non-3GPP accesses (SAES-SA-FP_n3GPP), UID_410043 MAPIM, UID_450041 IFOM, UID_530046 SaMOG
- 213: Linked to Rel-11 Feature UID_500032 Service Awareness and Privacy Policies (SAPP)
- 214: SP#43 TR 23.861v100 for Information. Spin-off Features UID_430035 MAPCON and UID_450041 IFOM. SP#56: Rel-9 draft TR 23.861v130 renamed & progressed under new Study FS_NBIFOM UID_560039
- 215: SP#53 completed
- 216: SP#56: Rel-9 draft TR 23.861v130 renamed & progressed under new Study FS_NBIFOM UID_560039
- 217: SP#56 revives dormant Study on Multi Access PDN connectivity and IP flow Mobility (FS_MAPIM) UID_410043. TR 23.861 title changed from (Multi Access PDN connectivity and IP flow mobility) to (Network based IP flow mobility)
- 218: SP#57 TR 33.829 v100 for Information. Completion 06/12=>12/12. Continuation of Rel-9 Feature UID_430036 IMS Media Plane Security (MEDIASEC). Study solutions and extensions to features and functionality described in TR 33.828 and TS 33.328
- 219: -
- 220: -
- 221: Linked to Rel-11 SPUCI TR 33.838
- 222: Study methodologies for specifying product security assurance and hardening requirements on 3GPP network elements (with associated test cases when feasible)
- 223: Linked to Feature UID_470034 HTTP-based Streaming and Download Services
- 224: SP#57 moved to Rel-12. Completion 09/12=>12/12
- 225: -
- 226: Linked to SP-110433 (LS on Equivalent PLMN identities and MDT) and Network Sharing UID_31018, SA1 22.951 (Service aspects and requirements for network sharing), SA2 23.251 (Network Sharing; Architecture and functional description)
- 227: GP#55 moved to Rel-12. Completion 08/12=>11/12. GP#54 TR 43.868 v100 for Information. GP#44 approved WID
- 228: GP#55 moved to Rel-12. Completion 08/12=>11/12. TR 45.926 v100 for Information. GP#47 approved WID
- 229: GP#55 moved to Rel-12. GP#50 approved WID. Triggered by Rel-8 TR 45.914 Study Multi-User-Reusing One Timeslot (MUROS) UID_50590 and Rel-9 VAMOS UID_420002
- 230: GP#55 moved to Rel-12. Completion 08/12=>05/13. TR 43.802 v100 for Information (mobile coucou). GP#50 approved WID. Triggered by RAN#51 (Mar 2011) WID in RP-110454 (LTE RAN Enhancements for Diverse Data Applications) UID_510031
- 231: RP#57 moved to Rel-12. Linked to Rel-10 WI on Inclusion of RF Pattern Matching Technologies as a positioning method in the UTRAN (LCS_UMTS_RFPMT) UID_460005
- 232: RP#57 moved to Rel-12 (RAN1 to only look at coverage aspects). Updated WID RP-111112=>RP-121441. Completion 12/12=>03/13
- 233: RP#57 moved to Rel-12. Updated WID RP-111377=>RP-121443. Completion 09/12=>06/13
- 234: RP#57 moved to Rel-12
- 235: Study only for Region 3 (so far)
- 236: -
- 237: RP#57 moved to Rel-12. Completion 09/12=>12/12
- 238: RP#57 moved to Rel-12. Completion 09/12=>12/12. Linked to Rel-10 WI on Multi-standard radio Base Station RF requirements for non-contiguous spectrum deployments (MSR_NC) UID_480025
- 239: -
- 240: -
- 241: -
- 242: -
- 243: -
- 244: -
- 245: -
- 246: -
- 247: -
- 248: -
- 249: -
- 250: -
- 251: -
- 252: -
- 253: -
- 254: -
- 256: SP#55 work stopped. Triggered by GSMA Smart SIM and 3GNBK projects, and to evolve from traditional USAT to multimedia USIM toolkit support, particularly to Smart Card Web Server
- 257: -

| ID | WBS | Task | Duration | Start | Finish | Complete | Remaining | Baseline start | Baseline finish | Baseline duration | Total slack | Constraint | Resources | Work | Actual work | Text1 | Text2 | Text4 | Text5 | Text6 | Text7 | Text8 | Text11 | Text9 | Text12 |
| --- | --- | --- | --- | --- | --- | --- | --- | --- | --- | --- | --- | --- | --- | --- | --- | --- | --- | --- | --- | --- | --- | --- | --- | --- | --- |
| 258 | 132 | **Advanced IP Interconnection of Services** | 712d? | 2010-03-25 A | 2012-12-07 | 99% | 9.29d? | 2010-03-25 | 2012-12-07 | 712d? | 463d |  | S1,S2,C1,C3 | 17629.9h | 17484h | IPXS | PCG-24 | Telefónica | chris.friel@O2.com | Rel-11 | SP-47 | Alain |  |  |  |
| 259 | 132.1 | Stage 1 for Advanced IP Interconnection of Services | 392d | 2010-03-25 A | 2011-09-21 A | 100% |  | 2010-03-25 | 2011-09-21 | 392d |  | finish no earlier than 2011-09-21 | S1 | 3120h | 3120h | IPXS | PCG-24 | Telefónica | chris.friel@O2.com | Rel-11 | SP-47 | Alain |  |  |  |
| 260 | 132.2 | Stage 2 for Advanced IP Interconnection of Services | 263d? | 2010-12-16 A | 2011-12-14 A | 100% |  | 2010-12-16 | 2011-12-14 | 263d? |  | finish no earlier than 2012-03-21 | S2 | 2085.91h | 2085.91h | IPXS | PCG-26 | Ericsson | fredrik.lindholm@ericsson.com | Rel-11 | SP-50 | Maurice |  |  |  |
| 261 | 132.3 | **Stage 3 for Advanced IP Interconnection of Services** | 327d? | 2011-09-13 A | 2012-12-07 | 97% | 9.03d? | 2011-09-13 | 2012-12-07 | 327d? | 463d |  | C1,C3 | 6728h | 6656.4h | IPXS | PCG-27 | Ericsson | christer.holmberg@ericsson.com | Rel-11 | CP-53 |  |  |  |  |
| 262 | 132.3.1 | CT1 part of Stage 3 for Advanced IP Interconnection of Services | 324d? | 2011-09-16 A | 2012-12-07 | 95% | 16.2d? | 2011-09-16 | 2012-12-07 | 324d? | 463d | finish no earlier than 2012-12-07 | C1 | 2048h | 2048h | IPXS | PCG-27 | Ericsson | christer.holmberg@ericsson.com | Rel-11 | CP-53 |  | CP-120549 |  |  |
| 263 | 132.3.2 | CT3 part of Stage 3 for Advanced IP Interconnection of Services | 262d? | 2011-09-13 A | 2012-09-07 A | 100% |  | 2011-09-13 | 2012-09-07 | 262d? |  | finish no earlier than 2012-09-07 | C3 | 2088h | 2088h | IPXS | PCG-27 | Ericsson | christer.holmberg@ericsson.com | Rel-11 | CP-53 |  |  |  |  |
| 264 | 133 | **System Improvements to Machine-Type Communications** | 790d? | 2009-12-10 A | 2012-12-12 | 99% | 10.01d? | 2009-12-10 | 2012-12-12 | 790d? | 460d |  | S1,S2,S3,S5,C1,C3,C4,C6,R2,R3 | 87050.8h | 82920.9h | SIMTC | PCG-25 | KPN | toon.norp@tno.nl | Rel-11 | SP-48 | Alain |  |  |  |
| 265 | 133.1 | Stage 1 for SIMTC | 337d? | 2010-06-10 A | 2011-09-21 A | 100% |  | 2010-06-10 | 2011-09-21 | 337d? |  |  | S1 | 2683.46h | 2683.46h | SIMTC | PCG-25 | KPN | toon.norp@tno.nl | Rel-11 | SP-48 | Alain | S1-122342 |  |  |
| 266 | 133.2 | TR on Stage 2 for SIMTC | 593d? | 2010-06-10 A | 2012-09-12 A | 100% |  | 2010-06-10 | 2012-09-12 | 593d? |  | finish no earlier than 2012-09-12 | S2 | 4736h | 4736h | SIMTC | PCG-25 | Intel | puneet.jain@intel.com | Rel-11 | SP-48 | Maurice |  |  |  |
| 267 | 133.3 | **BB1: Stage 2 Reachability Aspects of SIMTC** | 274d? | 2011-06-09 A | 2012-06-20 A | 100% |  | 2011-06-09 | 2012-06-20 | 274d? |  |  | S2 | 10773.1h | 10773.1h | SIMTC-Reach | PCG-27 | Intel | puneet.jain@intel.com | Rel-11 | SP-52 | Maurice |  |  |  |
| 268 | 133.3.1 | Deleted - MTC Feature Control (described in TS 22.368, clause 7.1.1 and 23.888, clause 5.7) | 137d? | 2011-06-10 A | 2011-12-14 A | 100% |  | 2011-06-10 | 2011-12-14 | 137d? |  | finish no earlier than 2011-11-09 | S2 | 1088h | 1088h | SIMTC-Reach | PCG-27 | Intel | puneet.jain@intel.com | Rel-11 | SP-52 | Maurice |  |  |  |
| 269 | 133.3.2 | On-line device trigger | 273d? | 2011-06-09 A | 2012-06-20 A | 100% |  | 2011-06-09 | 2012-06-20 | 273d? |  | finish no earlier than 2012-06-20 | S2 | 2170.29h | 2170.29h | SIMTC-Reach | PCG-27 | Intel | puneet.jain@intel.com | Rel-11 | SP-52 | Maurice |  |  |  |
| 270 | 133.3.3 | MTC Addressing | 138d? | 2011-06-09 A | 2011-12-14 A | 100% |  | 2011-06-09 | 2011-12-14 | 138d? |  | finish no earlier than 2012-03-21 | S2 | 1097.24h | 1097.24h | SIMTC-Reach | PCG-27 | Intel | puneet.jain@intel.com | Rel-11 | SP-52 | Maurice |  |  |  |
| 271 | 133.3.4 | Identifiers – especially removal of MSISDN dependencies in the architecture | 273d? | 2011-06-09 A | 2012-06-20 A | 100% |  | 2011-06-09 | 2012-06-20 | 273d? |  | finish no earlier than 2012-06-20 | S2 | 2169.53h | 2169.53h | SIMTC-Reach | PCG-27 | Intel | puneet.jain@intel.com | Rel-11 | SP-52 | Maurice |  |  |  |
| 272 | 133.3.5 | MSISDN-less / PS-Only | 196d? | 2011-06-13 A | 2012-03-07 A | 100% |  | 2011-06-13 | 2012-03-07 | 196d? |  | finish no earlier than 2012-03-07 | S2 | 1568h | 1568h | SIMTC-Reach | PCG-27 | Intel | puneet.jain@intel.com | Rel-11 | SP-52 | Maurice |  |  |  |
| 273 | 133.3.6 | MTC related interfaces and functional entities to support above features (MTCsp, etc.) | 61d? | 2011-12-14 A | 2012-03-07 A | 100% |  | 2011-12-14 | 2012-03-07 | 61d? |  | finish no earlier than 2012-03-07 | S2 | 488h | 488h | SIMTC-Reach | PCG-28 | Intel | puneet.jain@intel.com | Rel-11 | SP-54 |  |  |  |  |
| 274 | 133.4 | **BB1: Stage 3 (CS+PS) Reachability Aspects of SIMTC** | 323d? | 2011-09-19 A | 2012-12-07 | 97% | 9.48d? | 2011-09-19 | 2012-12-07 | 323d? | 463d |  | C1,C3,C4,C6 | 11296h | 10963.4h | SIMTC-Reach | PCG-27 | Ericsson | mikael.wass@ericsson.com | Rel-11 | CP-53 |  |  |  |  |
| 275 | 133.4.1 | CT1 part of Stage 3 BB1: Reachability Aspects of SIMTC | 257d? | 2011-09-19 A | 2012-09-07 A | 100% |  | 2011-09-19 | 2012-09-07 | 257d? |  | finish no earlier than 2012-09-07 | C1 | 2048h | 2048h | SIMTC-Reach | PCG-27 | Ericsson | mikael.wass@ericsson.com | Rel-11 | CP-53 |  |  |  |  |
| 276 | 133.4.2 | CT3 part of Stage 3 BB1: Reachability Aspects of SIMTC | 257d? | 2011-09-19 A | 2012-09-07 A | 100% |  | 2011-09-19 | 2012-09-07 | 257d? |  | finish no earlier than 2012-09-07 | C3 | 2048h | 2048h | SIMTC-Reach | PCG-27 | Ericsson | mikael.wass@ericsson.com | Rel-11 | CP-53 |  |  |  |  |
| 277 | 133.4.3 | CT4 part of Stage 3 BB1: Reachability Aspects of SIMTC | 322d? | 2011-09-19 A | 2012-12-07 | 90% | 32.1d? | 2011-09-19 | 2012-12-07 | 322d? | 463d | finish no earlier than 2012-12-07 | C4 | 2568h | 2311.2h | SIMTC-Reach | PCG-27 | Ericsson | mikael.wass@ericsson.com | Rel-11 | CP-53 |  | CP-120453 |  |  |
| 278 | 133.4.4 | CT6 part of Stage 3 BB1: Reachability Aspects of SIMTC | 257d? | 2011-09-19 A | 2012-09-07 A | 100% |  | 2011-09-19 | 2012-09-07 | 257d? |  | finish no earlier than 2012-09-07 | C6 | 2048h | 2048h | SIMTC-Reach | PCG-27 | ST Ericsson | Andrzej Winiarski | Rel-11 | CP-53 |  |  |  |  |
| 279 | 133.5 | **Stage 2/3 for CS aspects for SIMTC** | 259d? | 2011-09-16 A | 2012-09-07 A | 100% |  | 2011-09-16 | 2012-09-07 | 259d? |  |  | C4,C1,C6 | 10328h | 10328h | SIMTC-CS | PCG-27 | Ericsson | mikael.wass@ericsson.com | Rel-11 | CP-53 |  |  |  |  |
| 280 | 133.5.1 | Deleted - Stage 2 CS aspects for SIMTC | 258d? | 2011-09-16 A | 2012-09-06 A | 100% |  | 2011-09-16 | 2012-09-06 | 258d? |  | finish no earlier than 2012-09-07 | C4 | 2056h | 2056h | SIMTC-CS | PCG-27 | Ericsson | mikael.wass@ericsson.com | Rel-11 | CP-53 |  |  | PCG-29 | CP-57 |
| 281 | 133.5.2 | **Stage 3 CS aspects for SIMTC** | 259d? | 2011-09-16 A | 2012-09-07 A | 100% |  | 2011-09-16 | 2012-09-07 | 259d? |  |  | C1,C6 | 6200h | 6200h | SIMTC-CS | PCG-27 | Ericsson | mikael.wass@ericsson.com | Rel-11 | CP-53 |  |  |  |  |
| 282 | 133.5.2.1 | CT1 part of Stage 3 CS aspects for SIMTC | 259d? | 2011-09-16 A | 2012-09-07 A | 100% |  | 2011-09-16 | 2012-09-07 | 259d? |  | start no earlier than 2011-09-16 | C1 | 2064h | 2064h | SIMTC-CS | PCG-27 | Ericsson | mikael.wass@ericsson.com | Rel-11 | CP-53 |  |  |  |  |
| 283 | 133.5.2.2 | Deleted - CT6 part of Stage 3 CS aspects for SIMTC | 259d? | 2011-09-16 A | 2012-09-07 A | 100% |  | 2011-09-16 | 2012-09-07 | 259d? |  | start no earlier than 2011-09-16 | C6 | 2064h | 2064h | SIMTC-CS | PCG-27 | Ericsson | mikael.wass@ericsson.com | Rel-11 | CP-53 |  |  | PCG-29 | CP-57 |

Notes:
- 258: SP#53 Stage 1 completed. Triggered by Rel-10 TR 22.893 UID_380083 Study on advanced requirements for IP interconnect (FS_IPXS)
- 259: SP#53 completed / Text3: 22.101, 22.228
- 260: SP#54 completed / Text3: 23.228
- 261: - / Text3: Stage 3
- 262: CP#57 completion 09/12=>12/12 (exception in CP-120549) / Text3: 24.229
- 263: CP#57 completed / Text3: 29.165
- 264: Enhancements to Rel-10 Feature UID_410031 (NIMTC) based on Rel-11 Study on enhancements to MTC
- 265: SP#53 completed. SP#57 added MTC definitions in 21.905 / Text3: 22.368, 21.905 (MTC definitions)
- 266: SP#57 completed. TR 23.888v200 for Approval. Was Rel-10 UID_450028 (TR on Stage 2 for NIMTC) / Text3: new TR 23.888
- 267: SP#56 completed / Text3: 23.221, new 23.368
- 268: SP#54 work stopped
- 269: SP#56 completed / Text3: new 23.682
- 270: SP#54 completed / Text3: 23.221, new 23.682
- 271: SP#56 completed / Text3: new 23.682
- 272: SP#55 completed / Text3: 23.060, 23.272, new 23.682
- 273: SP#55 completed / Text3: new 23.682
- 274: CP#57 updated WID CP-120418=>CP-120617 / Text3: Stage 3
- 275: CP#57 completed / Text3: 23.040, 24.008, 24.301, 24.341, 24.368
- 276: CP#57 completed. TS 29.368 v200 for Approval / Text3: 29.061, new TS 29.368
- 277: CP#57 completion 09/12==>12/12 (exception in CP-120453). TS (29.336, 29.337) v100 for Information + Approval / Text3: 23.003, 23.008, 29.002, 29.060, 29.230, new TS (29.336, 29.337)
- 278: CP#57 completed / Text3: 31.102
- 279: CP#57 completed. Updated WID CP-120418=>CP-120617 / Text3: Stage 2/3
- 280: CP#57 stopped / Text3: 23.012
- 281: CP#57 completed / Text3: Stage 3
- 282: CP#57 completed / Text3: 24.008, 24.301
- 283: CP#57 stopped / Text3: 31.102

| ID | WBS | Task | Duration | Start | Finish | Complete | Remaining | Baseline start | Baseline finish | Baseline duration | Total slack | Constraint | Resources | Work | Actual work | Text1 | Text2 | Text4 | Text5 | Text6 | Text7 | Text11 | Text8 | Text9 | Text12 |
| --- | --- | --- | --- | --- | --- | --- | --- | --- | --- | --- | --- | --- | --- | --- | --- | --- | --- | --- | --- | --- | --- | --- | --- | --- | --- |
| 284 | 133.6 | **Stage 2/3 for SMS in MME architecture option and related PS-only service subscription** | 127d? | 2012-06-15 A | 2012-12-07 | 93% | 8.46d? | 2012-06-15 | 2012-12-07 | 127d? | 463d |  | C1,C4 | 2512h | 2343.55h | SIMTC-PS_Only | PCG-29 | Ericsson | mikael.wass@ericsson.com | Rel-11 | CP-56 |  |  |  |  |
| 285 | 133.6.1 | CT1 part of Stage 2/3 for SMS in MME architecture option and related PS-only service subscription | 62d? | 2012-06-15 A | 2012-09-07 A | 100% |  | 2012-06-15 | 2012-09-07 | 62d? |  | finish no earlier than 2012-09-07 | C1 | 488h | 488h | SIMTC-PS_Only | PCG-29 | Ericsson | mikael.wass@ericsson.com | Rel-11 | CP-56 |  |  |  |  |
| 286 | 133.6.2 | CT4 part of Stage 2/3 for SMS in MME architecture option and related PS-only service subscription | 127d? | 2012-06-15 A | 2012-12-07 | 90% | 12.6d? | 2012-06-15 | 2012-12-07 | 127d? | 463d | finish no earlier than 2012-12-07 | C4 | 1008h | 907.2h | SIMTC-PS_Only | PCG-29 | Ericsson | mikael.wass@ericsson.com | Rel-11 | CP-56 | CP-120453 |  |  |  |
| 287 | 133.7 | BB5: Charging of SIMTC (Stage 2/3) | 268d? | 2011-12-07 A | 2012-12-12 | 80% | 53.6d? | 2011-12-07 | 2012-12-12 | 268d? | 460d | finish no earlier than 2012-12-12 | S5 | 2144h | 1715.2h | SIMTC-CH | PCG-28 | Ericsson | patrik.teppo@ericsson.com | Rel-11 | SP-54 | SP-120583 |  |  |  |
| 288 | 133.8 | **RAN overload control for Machine-Type Communications** | 259d? | 2011-09-16 A | 2012-09-07 A | 100% |  | 2011-09-16 | 2012-09-07 | 259d? |  |  | R2,R3,C1,C6 | 9818.29h | 9818.29h | SIMTC-RAN_OC | PCG-27 | Huawei | Jeff Gao (gaoyongqiang@huawei.com) | Rel-11 | RP-53 |  |  |  |  |
| 289 | 133.8.1 | Core part: RAN overload control for Machine-Type Communications | 257d? | 2011-09-19 A | 2012-09-07 A | 100% |  | 2011-09-19 | 2012-09-07 | 257d? |  | finish no earlier than 2012-09-07 | R2,R3 | 2056h | 2056h | SIMTC-RAN_OC-Core | PCG-27 | Huawei | Jeff Gao (gaoyongqiang@huawei.com) | Rel-11 | RP-53 | RP-120990 |  |  |  |
| 290 | 133.8.2 | **Stage 3 (CS+PS) Extended Access Barring for UTRAN and E-UTRAN** | 259d? | 2011-09-16 A | 2012-09-07 A | 100% |  | 2011-09-16 | 2012-09-07 | 259d? |  |  | C1,C6 | 5690.29h | 5690.29h | SIMTC-RAN_OC | PCG-27 | Ericsson | mikael.wass@ericsson.com | Rel-11 | CP-53 |  |  |  |  |
| 291 | 133.8.2.1 | CT1 part of Stage 3 Extended Access Barring for UTRAN and E-UTRAN | 198d? | 2011-09-16 A | 2012-06-15 A | 100% |  | 2011-09-16 | 2012-06-15 | 198d? |  | finish no earlier than 2012-09-14 | C1 | 1570.29h | 1570.29h | SIMTC-RAN_OC | PCG-27 | Ericsson | mikael.wass@ericsson.com | Rel-11 | CP-53 |  |  |  |  |
| 292 | 133.8.2.2 | CT6 part of Stage 3 Extended Access Barring for UTRAN and E-UTRAN | 257d? | 2011-09-20 A | 2012-09-07 A | 100% |  | 2011-09-20 | 2012-09-07 | 257d? |  | finish no earlier than 2012-09-07 | C6 | 2048h | 2048h | SIMTC-RAN_OC | PCG-27 | ST Ericsson | Andrzej Winiarski | Rel-11 | CP-53 |  |  |  |  |
| 293 | 133.9 | **Deleted - BB2: Stage 2 Signalling Optimizations of SIMTC** | 137d? | 2011-06-10 A | 2011-12-14 A | 100% |  | 2011-06-10 | 2011-12-14 | 137d? |  |  | S2,S3 | 3272h | 3272h | SIMTC-Sig | PCG-27 | Intel | puneet.jain@intel.com | Rel-11 | SP-52 |  | Maurice | PCG-28 | SP-55 |
| 294 | 133.9.1 | Deleted - Effectively maintain connectivity for a large number of MTC Devices (TS 22.368, 7.1.1) | 137d? | 2011-06-10 A | 2011-12-14 A | 100% |  | 2011-06-10 | 2011-12-14 | 137d? |  | finish no earlier than 2011-12-07 | S2 | 1088h | 1088h | SIMTC-Sig | PCG-27 | Intel | puneet.jain@intel.com | Rel-11 | SP-52 |  | Maurice | PCG-28 | SP-55 |
| 295 | 133.9.2 | Deleted - Small Data Transmissions (TS 22.368, 7.2.5) | 137d? | 2011-06-10 A | 2011-12-14 A | 100% |  | 2011-06-10 | 2011-12-14 | 137d? |  | finish no earlier than 2011-12-07 | S2 | 1088h | 1088h | SIMTC-Sig | PCG-27 | Intel | puneet.jain@intel.com | Rel-11 | SP-52 |  | Maurice | PCG-28 | SP-55 |
| 296 | 133.10 | **Deleted - BB2: Stage 3 (CS+PS) Signalling Optimizations of SIMTC** | 62d? | 2011-09-16 A | 2011-12-09 A | 100% |  | 2011-09-16 | 2011-12-09 | 62d? |  |  | C1,C6 | 1472h | 1472h | SIMTC-Sig | PCG-27 | Ericsson | mikael.wass@ericsson.com | Rel-11 | CP-53 |  |  | PCG-28 | CP-55 |
| 297 | 133.10.1 | Deleted - CT1 part of Stage 3 BB2: Signalling Optimizations of SIMTC | 62d? | 2011-09-16 A | 2011-12-09 A | 100% |  | 2011-09-16 | 2011-12-09 | 62d? |  | finish no earlier than 2011-12-02 | C1 | 488h | 488h | SIMTC-Sig | PCG-27 | Ericsson | mikael.wass@ericsson.com | Rel-11 | CP-53 |  |  | PCG-28 | CP-55 |
| 298 | 133.10.2 | Deleted - CT6 part of Stage 3 BB2: Signalling Optimizations of SIMTC | 62d? | 2011-09-16 A | 2011-12-09 A | 100% |  | 2011-09-16 | 2011-12-09 | 62d? |  | finish no earlier than 2011-12-02 | C6 | 488h | 488h | SIMTC-Sig | PCG-27 | ST Ericsson | Andrzej Winiarski | Rel-11 | CP-53 |  |  | PCG-28 | CP-55 |
| 299 | 133.11 | **Deleted - BB3: Stage 2 CN-based requirements and Power Considerations of SIMTC** | 139d? | 2011-06-08 A | 2011-12-14 A | 100% |  | 2011-06-08 | 2011-12-14 | 139d? |  |  | S2,S3 | 4392h | 4392h | SIMTC-CN_Pow | PCG-27 | Intel | puneet.jain@intel.com | Rel-11 | SP-52 |  | Maurice | PCG-28 | SP-55 |
| 300 | 133.11.1 | Deleted - Charging Requirements (TS 22.368, 7.1.5) | 137d? | 2011-06-10 A | 2011-12-14 A | 100% |  | 2011-06-10 | 2011-12-14 | 137d? |  | finish no earlier than 2012-03-21 | S2 | 1088h | 1088h | SIMTC-CN_Pow | PCG-27 | Intel | puneet.jain@intel.com | Rel-11 | SP-52 |  | Maurice | PCG-28 | SP-55 |
| 301 | 133.11.2 | Deleted - Lower Power Consumption (TS 22.368, 7.1.1) | 137d? | 2011-06-10 A | 2011-12-14 A | 100% |  | 2011-06-10 | 2011-12-14 | 137d? |  | finish no earlier than 2011-12-07 | S2 | 1088h | 1088h | SIMTC-CN_Pow | PCG-27 | Intel | puneet.jain@intel.com | Rel-11 | SP-52 |  | Maurice | PCG-28 | SP-55 |
| 302 | 133.11.3 | Deleted - MTC Monitoring (TS 22.368, 7.2.8) | 139d? | 2011-06-08 A | 2011-12-14 A | 100% |  | 2011-06-08 | 2011-12-14 | 139d? |  | finish no earlier than 2011-12-07 | S2 | 1104h | 1104h | SIMTC-CN_Pow | PCG-27 | Intel | puneet.jain@intel.com | Rel-11 | SP-52 |  | Maurice | PCG-28 | SP-55 |
| 303 | 133.12 | **Deleted - BB3: Stage 3 (CS+PS) CN-based requirements and Power Considerations of SIMTC** | 62d? | 2011-09-16 A | 2011-12-09 A | 100% |  | 2011-09-16 | 2011-12-09 | 62d? |  |  | C1,C6 | 1472h | 1472h | SIMTC-CN_Pow | PCG-27 | Ericsson | mikael.wass@ericsson.com | Rel-11 | CP-53 |  |  | PCG-28 | CP-55 |
| 304 | 133.12.1 | Deleted - CT1 part of Stage 3 BB3: CN-based requirements and Power Considerations of SIMTC | 62d? | 2011-09-16 A | 2011-12-09 A | 100% |  | 2011-09-16 | 2011-12-09 | 62d? |  | finish no earlier than 2011-12-02 | C1 | 488h | 488h | SIMTC-CN_Pow | PCG-27 | Ericsson | mikael.wass@ericsson.com | Rel-11 | CP-53 |  |  | PCG-28 | CP-55 |
| 305 | 133.12.2 | Deleted - CT6 part of Stage 3 BB3: CN-based requirements and Power Considerations of SIMTC | 62d? | 2011-09-16 A | 2011-12-09 A | 100% |  | 2011-09-16 | 2011-12-09 | 62d? |  | finish no earlier than 2011-12-02 | C6 | 488h | 488h | SIMTC-CN_Pow | PCG-27 | ST Ericsson | Andrzej Winiarski | Rel-11 | CP-53 |  |  | PCG-28 | CP-55 |
| 306 | 133.13 | Deleted - TR on Security aspects of Machine-Type Communications | 662d? | 2009-12-10 A | 2012-06-20 A | 100% |  | 2009-12-10 | 2012-06-20 | 662d? |  | finish no earlier than 2012-06-20 | S3 | 5288h | 5288h | NIMTC | PCG-25 | Samsung | Rajavelsamy R (rajvel@samsung.com) | Rel-11 | SP-49 | SP-120331 | Dionisio | PCG-29 | SP-56 |
| 307 | 133.14 | **Deleted - BB4: Secure Connection and Privacy of SIMTC** | 336d? | 2011-06-08 A | 2012-09-12 A | 100% |  | 2011-06-08 | 2012-09-12 | 336d? |  |  | S3 | 7424h | 7424h | SIMTC-Sec | PCG-27 | Samsung | Rajavelsamy R (rajvel@samsung.com) | Rel-11 | SP-52 |  | Dionisio | PCG-29 | CP-57 |
| 308 | 133.14.1 | Deleted - Secure Connection MTC Feature (TS 22.368, 7.2.10) | 333d? | 2011-06-08 A | 2012-09-12 A | 100% |  | 2011-06-08 | 2012-09-12 | 333d? |  | finish no earlier than 2012-09-12 | S3 | 2656h | 2656h | SIMTC-Sec | PCG-27 | Samsung | Rajavelsamy R (rajvel@samsung.com) | Rel-11 | SP-52 |  | Dionisio | PCG-29 | CP-57 |
| 309 | 133.14.2 | Deleted - MTC Location Privacy | 261d? | 2011-09-19 A | 2012-09-12 A | 100% |  | 2011-09-19 | 2012-09-12 | 261d? |  | finish no earlier than 2012-09-12 | S3 | 2080h | 2080h | SIMTC-Priv | PCG-27 | Samsung | Rajavelsamy R (rajvel@samsung.com) | Rel-11 | SP-53 |  |  | PCG-29 | CP-57 |
| 310 | 133.15 | Deleted - Stage 2 on SA2 part for System Improvements to Machine-Type Communications | 260d? | 2010-06-10 A | 2011-06-08 A | 100% |  | 2010-06-10 | 2011-06-08 | 260d? |  | finish no earlier than 2011-06-08 | S2 | 2080h | 2080h | SIMTC | PCG-25 | Intel | puneet.jain@intel.com | Rel-11 | SP-48 |  | Maurice | PCG-27 | SP-52 |
| 311 | 133.16 | Deleted - Stage 2 on Security part for System Improvements to Machine-Type Communications | 260d? | 2010-06-10 A | 2011-06-08 A | 100% |  | 2010-06-10 | 2011-06-08 | 260d? |  | finish no earlier than 2011-06-08 | S3 | 2080h | 2080h | SIMTC | PCG-25 | Samsung | Rajavelsamy R (rajvel@samsung.com) | Rel-11 | SP-48 |  | Dionisio | PCG-27 | SP-52 |

Notes:
- 284: CP#57 updated WID CP-120418=>CP-120617 / Text3: Stage 2/3
- 285: CP#57 completed / Text3: 23.040, 24.008, 24.011, 24.301, 29.018, 29.118
- 286: CP#57 completion 09/12=>12/12 (exception in CP-120453). TS 29.338 v100 (Diameter based protocols to support SMS capable MMEs) for Information + Approval / Text3: 23.003, 23.008, 23.012, 29.002, 29.272, 29.305, new TS 29.338
- 287: SP#57 completion 09/12=>12/12 (exception in SP-120583) / Text3: 32.240, 32.251, 32.298, 32.299
- 288: Stage 2,3. TSG#57 completed / Text3: UTRA, LTE
- 289: RP#57 completed / Text3: 25.304, 25.331, 25.413, 36.304, 36.331, 36.413
- 290: CP#57 completed. Updated WID CP-120418=>CP-120617 / Text3: Stage 3
- 291: CP#56 completed / Text3: 23.122, 24.008, 24.301
- 292: CP#57 completed / Text3: 31.102
- 293: SP#54 work stopped. SP#54 updated WID SP-110499=>SP-110877 (reduced Scope) / Text3: TBD
- 294: SP#54 work stopped / Text3: TBD
- 295: SP#54 work stopped / Text3: TBD
- 296: CP#54 stopped. CP#54 updated WID CP-110728=>CP-110756 (Align with reduced SA2 scope) / Text3: Stage 3
- 297: - / Text3: 23.122, 24.008, 24.301, 24.368
- 298: - / Text3: 31.102
- 299: SP#54 updated WID SP-110499=>SP-110877 (reduced Scope) / Text3: TBD
- 300: SP#54 work stopped / Text3: TBD
- 301: SP#54 work stopped / Text3: TBD
- 302: SP#54 work stopped / Text3: TBD
- 303: CP#54 stopped. CP#54 updated WID CP-110728=>CP-110756 (Align with reduced SA2 scope) / Text3: Stage 3
- 304: - / Text3: 23.122, 24.008, 24.301, 24.368
- 305: - / Text3: 31.101, 31.102
- 306: Was Rel-10 UID_460023 (Security for NIMTC). SP#56 stopped (activity transferred to Rel-12 Feature MTCe under UID_560722) / Text3: new TR 33.868
- 307: SP#57 stopped (activity transferred to Rel-12 Feature MTCe under UID_560522) / Text3: TBD
- 308: SP#57 stopped (activity transferred to Rel-12 Feature MTCe / Text3: TBD
- 309: SP#57 stopped (activity transferred to Rel-12 Feature MTCe / Text3: TBD
- 310: SP#52 stopped. Updated WID SP-100877=>SP-110422 (break-down in several BBs) / Text3: TBD
- 311: SP#52 stopped. Updated WID SP-100877=>SP-110422 (break-down in several BBs) / Text3: TBD

| ID | WBS | Task | Type | Duration | Start | Finish | Complete | Remaining | Baseline start | Baseline finish | Baseline duration | Total slack | Constraint | Resources | Work | Actual work | Text1 | Text2 | Text4 | Text6 | Text7 | Text8 | Text3 | Text11 | Text9 | Text12 |
| --- | --- | --- | --- | --- | --- | --- | --- | --- | --- | --- | --- | --- | --- | --- | --- | --- | --- | --- | --- | --- | --- | --- | --- | --- | --- | --- |
| 312 | 134 | **Unstructured Supplementary Service Data (USSD) simulation service in IMS** |  | 657d? | 2010-06-10 A | 2012-12-07 | 95% | 35.76d? | 2010-06-10 | 2012-12-07 | 657d? | 463d |  | S1,C1,C3 | 14312.1h | 8163.68h | USSI | PCG-25 | Deutsche Telekom | Rel-11 | SP-48 | Alain |  |  |  |  |
| 313 | 134.1 | Stage 1 for USSD simulation service in IMS | milestone | 0d? | 2010-06-10 A | 2010-06-10 A | 100% |  | 2010-06-10 | 2010-06-10 | 0d? |  | finish no earlier than 2010-06-10 | S1 |  |  | USSI | PCG-25 | Deutsche Telekom | Rel-11 | SP-48 | Alain | 22.173 |  |  |  |
| 314 | 134.2 | **Stage 3 for USSD simulation service in IMS** |  | 401d? | 2011-06-03 A | 2012-12-07 | 95% | 21.82d? | 2011-06-03 | 2012-12-07 | 401d? | 463d |  | C1,C3 | 9056.06h | 6665.38h | USSI | PCG-27 | Deutsche Telekom | Rel-11 | CP-52 | Frederic |  |  |  |  |
| 315 | 134.2.1 | CT1 part of Stage 3 for USSD simulation service in IMS |  | 401d? | 2011-06-03 A | 2012-12-07 | 90% | 40d? | 2011-06-03 | 2012-12-07 | 401d? | 463d | finish no earlier than 2012-12-07 | C1 | 3184.06h | 2864.06h | USSI | PCG-27 | Deutsche Telekom | Rel-11 | CP-52 | Frederic | 24.173, 24.229, new TS 24.390 | CP-120550 |  |  |
| 316 | 134.2.2 | CT3 part of Stage 3 for USSD simulation service in IMS |  | 334d? | 2011-06-07 A | 2012-09-07 A | 100% |  | 2011-06-07 | 2012-09-07 | 334d? |  | finish no earlier than 2012-09-07 | C3 | 2664h | 2664h | USSI | PCG-27 | Deutsche Telekom | Rel-11 | CP-52 | Jiwan | 29.165 |  |  |  |
| 317 | 135 | **QoS Control Based on Subscriber Spending Limits** |  | 459d? | 2010-09-23 A | 2012-06-20 A | 100% |  | 2010-09-23 | 2012-06-20 | 459d? |  |  | S1,S2,S5,C3 | 12136h | 12136h | QoS_SSL | PCG-25 | Vodafone | Rel-11 | SP-49 | Alain |  |  |  |  |
| 318 | 135.1 | Stage 1 for QoS Control Based on Subscriber Spending Limits |  | 262d? | 2010-09-23 A | 2011-09-21 A | 100% |  | 2010-09-23 | 2011-09-21 | 262d? |  | finish no earlier than 2011-09-21 | S1 | 2080h | 2080h | QoS_SSL | PCG-25 | Vodafone | Rel-11 | SP-49 | Alain | 22.115 |  |  |  |
| 319 | 135.2 | Stage 2 for QoS Control Based on Subscriber Spending Limits |  | 133d? | 2011-03-23 A | 2011-09-21 A | 100% |  | 2011-03-23 | 2011-09-21 | 133d? |  | finish no earlier than 2011-12-14 | S2 | 1048h | 1048h | QoS_SSL | PCG-26 | Huawei | Rel-11 | SP-51 | Maurice | 23.203 |  |  |  |
| 320 | 135.3 | Charging for QoS Control Based on Subscriber Spending Limits (Stage 2) |  | 397d? | 2010-12-16 A | 2012-06-20 A | 100% |  | 2010-12-16 | 2012-06-20 | 397d? |  | finish no earlier than 2012-06-20 | S5 | 3168h | 3168h | QoS_SSL | PCG-26 | Nokia Siemens Networks, Huawei | Rel-11 | SP-50 | Dionisio | 32.240, 32.296 |  |  |  |
| 321 | 135.4 | CT3 aspects of QoS Control Based on Subscriber Spending Limits (Stage 3) |  | 273d? | 2011-06-03 A | 2012-06-15 A | 100% |  | 2011-06-03 | 2012-06-15 | 273d? |  | finish no earlier than 2012-06-15 | C3 | 2168h | 2168h | QoS_SSL-CT3 | PCG-27 | Huawei | Rel-11 | CP-52 | Jiwan | 29.212, 29.213, 29.214, 29.215, new TS 29.219 |  |  |  |
| 322 | 136 | **Optimized Service Charging and Allocation of Resources in IMS whilst Roaming** |  | 383d? | 2010-09-23 A | 2012-03-07 A | 100% |  | 2010-09-23 | 2012-03-07 | 383d? |  |  | S1,S2 | 11224h | 11224h | OSCAR | PCG-25 | Vodafone | Rel-11 | SP-49 | Alain |  |  |  |  |
| 323 | 136.1 | TR on Stage 2 aspects of Optimized Service Charging and Allocation of Resources in IMS whilst Roaming |  | 383d? | 2010-09-23 A | 2012-03-07 A | 100% |  | 2010-09-23 | 2012-03-07 | 383d? |  | finish no earlier than 2011-12-07 | S2 | 3040h | 3040h | OSCAR | PCG-25 | Vodafone | Rel-11 | SP-49 | Maurice | new TR 23.849 |  |  |  |
| 324 | 136.2 | Stage 1 for Optimized Service Charging and Allocation of Resources in IMS whilst Roaming |  | 262d? | 2010-09-23 A | 2011-09-21 A | 100% |  | 2010-09-23 | 2011-09-21 | 262d? |  | finish no earlier than 2011-09-21 | S1 | 2080h | 2080h | OSCAR | PCG-25 | Vodafone | Rel-11 | SP-49 | Alain | 22.115, 22.173, 22.228 |  |  |  |
| 325 | 136.3 | Deleted - Stage 2 for Optimized Service Charging and Allocation of Resources in IMS whilst Roaming |  | 380d? | 2010-09-28 A | 2012-03-07 A | 100% |  | 2010-09-28 | 2012-03-07 | 380d? |  | finish no earlier than 2012-03-07 | S2 | 3040h | 3040h | OSCAR | PCG-25 | Vodafone | Rel-11 | SP-49 | Maurice | None |  | PCG-28 | SP-55 |
| 326 | 137 | **Inclusion of Media Resource Broker (Stage 2/3)** |  | 324d? | 2011-09-16 A | 2012-12-07 | 82% | 58.01d? | 2011-09-16 | 2012-12-07 | 324d? | 463d |  | C1,C3,IETF | 10524h | 5871.97h | MRB | PCG-27 | AT&T | Rel-11 | CP-53 |  | Stage 2/3 |  |  |  |
| 327 | 137.1 | Stage 2 for Inclusion of Media Resource Broker |  | 259d? | 2011-09-16 A | 2012-09-07 A | 100% |  | 2011-09-16 | 2012-09-07 | 259d? |  | finish no earlier than 2012-09-07 | C1 | 2049.98h | 2049.98h | MRB | PCG-27 | AT&T | Rel-11 | CP-53 |  | 23.218 |  |  |  |
| 328 | 137.2 | **Stage 3 for Inclusion of Media Resource Broker** |  | 324d? | 2011-09-16 A | 2012-12-07 | 75% | 81.38d? | 2011-09-16 | 2012-12-07 | 324d? | 463d |  | C1,C3,IETF | 6669.98h | 3821.98h | MRB | PCG-27 | AT&T | Rel-11 | CP-53 |  |  |  |  |  |
| 329 | 137.2.1 | CT1 part of Stage 3 for Inclusion of Media Resource Broker |  | 258d? | 2011-09-16 A | 2012-09-07 A | 100% |  | 2011-09-16 | 2012-09-07 | 258d? |  | finish no earlier than 2012-09-07 | C1 | 2049.98h | 2049.98h | MRB | PCG-27 | AT&T | Rel-11 | CP-53 |  | 24.229, 29.165 |  |  |  |
| 330 | 137.2.2 | (IETF) Inclusion of Media Resource Broker (Stage 3) |  | 323d? | 2011-09-16 A | 2012-12-07 | 50% | 161.5d? | 2011-09-16 | 2012-12-07 | 323d? | 463d | finish no earlier than 2012-12-07 | C1-IETF | 2576h | 1284h | MRB | PCG-27 | Keith Drage | Rel-11 | CP-53 |  | draft-ietf-mediactrl-mrb |  |  |  |
| 331 | 137.2.3 | CT3 part of Stage 3 for Inclusion of Media Resource Broker |  | 62d? | 2012-06-15 A | 2012-09-07 A | 100% |  | 2012-06-15 | 2012-09-07 | 62d? |  | finish no earlier than 2012-09-07 | C3 | 488h | 488h | MRB | PCG-29 | AT&T | Rel-11 | CP-56 |  | 29.165 |  |  |  |
| 332 | 138 | **Non Voice Emergency Services** |  | 323d? | 2010-12-16 A | 2012-03-07 A | 100% |  | 2010-12-16 | 2012-03-07 | 323d? |  |  | S1,S2 | 5152h | 5152h | NOVES | PCG-26 | Qualcomm | Rel-11 | SP-50 | Alain |  |  |  |  |
| 333 | 138.1 | Stage 1 for Non Voice Emergency Services |  | 202d? | 2010-12-16 A | 2011-09-21 A | 100% |  | 2010-12-16 | 2011-09-21 | 202d? |  | finish no earlier than 2011-09-21 | S1 | 1600h | 1600h | NOVES | PCG-26 | Qualcomm | Rel-11 | SP-50 | Alain | 22.101 |  |  |  |
| 334 | 138.2 | Stage 2 for Non Voice Emergency Services (Support of IMS Emergency Sessions with Other Media on UTRAN and E-UTRAN) |  | 121d? | 2011-09-22 A | 2012-03-07 A | 100% |  | 2011-09-22 | 2012-03-07 | 121d? |  | finish no earlier than 2012-03-07 | S2 | 968h | 968h | NOVES-IMSESOM | PCG-27 | Alcatel-Lucent | Rel-11 | SP-53 |  | 23.060, 23.167, 23.203, 23.401 |  |  |  |
| 335 | 139 | **Support for 3GPP Voice Interworking with Enterprise IP-PBX** |  | 453d? | 2011-03-23 A | 2012-12-07 | 77% | 102.12d? | 2011-03-23 | 2012-12-07 | 453d? | 463d |  | S1,C1 | 9288h | 7187.07h | VINE | PCG-26 | Tatara Systems | Rel-11 | SP-51 | Alain |  |  |  |  |
| 336 | 139.1 | Stage 1 for Support for 3GPP Voice Interworking with Enterprise IP-PBX |  | 133d? | 2011-03-23 A | 2011-09-21 A | 100% |  | 2011-03-23 | 2011-09-21 | 133d? |  | finish no earlier than 2011-09-21 | S1 | 1048h | 1048h | VINE | PCG-26 | Tatara Systems | Rel-11 | SP-51 | Alain | 22.228 |  |  |  |
| 337 | 139.2 | Stage 2 for Support for 3GPP Voice Interworking with Enterprise IP-PBX |  | 258d? | 2011-09-16 A | 2012-09-07 A | 100% |  | 2011-09-16 | 2012-09-07 | 258d? |  | finish no earlier than 2012-09-07 | C1 | 2048h | 2048h | VINE-CT1 | PCG-27 | Alcatel-Lucent | Rel-11 | CP-53 |  | 23.218 |  |  |  |
| 338 | 139.3 | Stage 3 for Support for 3GPP Voice Interworking with Enterprise IP-PBX |  | 321d? | 2011-09-20 A | 2012-12-07 | 50% | 160.5d? | 2011-09-20 | 2012-12-07 | 321d? | 463d | finish no earlier than 2012-12-07 | C1 | 2568h | 1284h | VINE-CT1 | PCG-27 | Alcatel-Lucent | Rel-11 | CP-53 |  | 24.229 | CP-120669 |  |  |

Notes:
- 312: - / Text5: kurt.bischinger@t-mobile.at
- 313: SP#48 completed. Specify a CS domain USSD like service over IMS (see GSM Mobile User Initiated USSD) / Text5: kurt.bischinger@t-mobile.at
- 314: No stage 2 impact, as reuse existing IMS architecture in TS 23.228 / Text5: reinhard.lauster@t-mobile.at
- 315: CP#57 completion 09/12=>12/12 (exception in CP-120550). TS 24.390 v200 for Approval / Text5: reinhard.lauster@t-mobile.at, TS 24.390 Rapp: lili.yang@huawei.com
- 316: CP#57 completed / Text5: reinhard.lauster@t-mobile.at
- 317: TSG#56 completed / Text5: mona.mustapha@vodafone.com
- 318: SP#53 completed. Use cases & service requirements to allow: 1) modification of QoS based on subscribers spending limits 2) enforcing of spending limits for roaming subscribers without having dedicated support in the visited network / Text5: mona.mustapha@vodafone.com
- 319: SP#53 completed / Text5: Xu Xia (xiatony@huawei.com)
- 320: SP#56 completed / Text5: Gerald.Goermer@nsn.com, shan.mingjun@huawei.com
- 321: CP#56 completed / Text5: QiaoWeihua@huawei.com
- 322: SP#55 completed (Stage 2/3 specified under CT1 Rel-11 Feature MRB (Inclusion of Media Resource Broker) UID_530021. Triggered by S1-102236/GSMA RILTE 10_007r1 (IREG LS_038 to 3GPP on Optimal Media Routing drawbacks) / Text5: mona.mustapha@vodafone.com
- 323: SP#55 completed / Text5: Susana.Sabater@vodafone.com
- 324: SP#53 completed / Text5: mona.mustapha@vodafone.com
- 325: SP#55 no normative work in SA2. Stage 2/3 to be done in under CT1 Rel-11 Feature MRB (Inclusion of Media Resource Broker) UID_530021 / Text5: Susana.Sabater@vodafone.com
- 326: Stage 1 and TR on Stage 2 in Rel-11 Feature OSCAR UID_490032 / Text5: Martin Dolly (md3135@att.com)
- 327: CP#57 completed / Text5: Martin Dolly (md3135@att.com)
- 328: CP#56 completion 06/12=>09/12 / Text5: Martin Dolly (md3135@att.com)
- 329: CP#57 completed / Text5: Martin Dolly (md3135@att.com)
- 330: Not completed internet-draft
- 331: CP#57 completed / Text5: Martin Dolly (md3135@att.com)
- 332: SP#55 Stage 2 completed. Triggered by SA1 Rel-11 TR 22.871 Study on Non Voice Emergency Services (FS_NOVES) / Text5: dwilliams@qualcomm.com
- 333: SP#53 completed / Text5: dwilliams@qualcomm.com
- 334: SP#55 completed / Text5: Deb.Barclay@alcatel-lucent.com
- 335: SP#53 Stage 1 completed. Triggered by Rel-11 TR 22.809 Study on Support for 3GPP Voice Interworking with Enterprise IP-PBX (FS_VINE) UID_480033 / Text5: Phillip Brown (pbrown@tatarasystems.com)
- 336: SP#53 completed / Text5: Phillip Brown (pbrown@tatarasystems.com)
- 337: CP#57 completed / Text5: keith.drage@alcatel-lucent.com
- 338: CP#57 completion 09/12=>12/12 (exception in CP-120669) / Text5: keith.drage@alcatel-lucent.com

| ID | WBS | Task | Duration | Start | Finish | Complete | Remaining | Baseline start | Baseline finish | Baseline duration | Total slack | Constraint | Resources | Work | Actual work | Text1 | Text2 | Text4 | Text5 | Text6 | Text7 | Text8 | Text9 | Text12 | Text11 |
| --- | --- | --- | --- | --- | --- | --- | --- | --- | --- | --- | --- | --- | --- | --- | --- | --- | --- | --- | --- | --- | --- | --- | --- | --- | --- |
| 339 | 140 | **Anonymous Call Rejection in the CS domain** | 132d? | 2011-06-07 A | 2011-12-02 A | 100% |  | 2011-06-07 | 2011-12-02 | 132d? |  |  | S1,C4,C3 | 2032h | 2032h | ACR_CS | PCG-27 | Alcatel-Lucent | Betsy.Covell@alcatel-lucent.com | Rel-11 | SP-52 | Alain |  |  |  |
| 340 | 140.1 | Stage 1 for Anonymous Call Rejection in the CS domain | 2d? | 2011-06-07 A | 2011-06-08 A | 100% |  | 2011-06-07 | 2011-06-08 | 2d? |  | finish no earlier than 2011-06-07 | S1 | 16h | 16h | ACR_CS | PCG-27 | Alcatel-Lucent | Betsy.Covell@alcatel-lucent.com | Rel-11 | SP-52 | Alain |  |  |  |
| 341 | 140.2 | **Core Network aspects of Anonymous Call Rejection in the CS domain** | 59d? | 2011-09-14 A | 2011-12-02 A | 100% |  | 2011-09-14 | 2011-12-02 | 59d? |  |  | C4,C3 | 960h | 960h | ACR_CS-CN | PCG-27 | Alcatel-Lucent | bruno.landais@alcatel-lucent.com | Rel-11 | CP-53 |  |  |  |  |
| 342 | 140.2.1 | CT4 part of Core Network aspects of Anonymous Call Rejection in the CS domain (Stage 2/3) | 59d? | 2011-09-14 A | 2011-12-02 A | 100% |  | 2011-09-14 | 2011-12-02 | 59d? |  | finish no earlier than 2011-12-02 | C4 | 464h | 464h | ACR_CS-CN | PCG-27 | Alcatel-Lucent | bruno.landais@alcatel-lucent.com | Rel-11 | CP-53 |  |  |  |  |
| 343 | 140.2.2 | CT3 part of Core Network aspects of Anonymous Call Rejection in the CS domain (Stage 3) | 3d? | 2011-09-14 A | 2011-09-16 A | 100% |  | 2011-09-14 | 2011-09-16 | 3d? |  | start no earlier than 2011-09-14 | C3 | 24h | 24h | ACR_CS-CN | PCG-27 | Alcatel-Lucent | bruno.landais@alcatel-lucent.com | Rel-11 | CP-53 |  |  |  |  |
| 344 | 141 | **Support for BroadBand Forum Accesses Interworking** | 787d? | 2009-12-10 A | 2012-12-07 | 97% | 23.83d? | 2009-12-10 | 2012-12-07 | 787d? | 463d |  | S2,S1,C1,C3,C4,IETF | 54912.2h | 47847.7h | BBAI | PCG-24 | Ericsson | peter.bleckert@ericsson.com | Rel-11 | SP-46 | Alain |  |  |  |
| 345 | 141.1 | Stage 1 BB I: BBF interworking with home routed traffic for WLAN and H(e)NB | 76d? | 2009-12-10 A | 2010-03-25 A | 100% |  | 2009-12-10 | 2010-03-25 | 76d? |  | start no earlier than 2009-12-10 | S1 | 608h | 608h | BBAI | PCG-24 | Ericsson | Olle.Eriksson@ericsson.com | Rel-11 | SP-46 | Alain |  |  |  |
| 346 | 141.2 | TR on Stage 2 for BBAI | 588d? | 2010-03-26 A | 2012-06-20 A | 100% |  | 2010-03-26 | 2012-06-20 | 588d? |  | finish no earlier than 2012-06-19 | S2 | 4704h | 4704h | BBAI | PCG-24 | Ericsson | marco.spini@huawei.com | Rel-11 | SP-47 |  |  |  |  |
| 347 | 141.3 | Stage 2 BB I: BBF interworking with home routed traffic for WLAN and H(e)NB | 588d? | 2010-03-26 A | 2012-06-20 A | 100% |  | 2010-03-26 | 2012-06-20 | 588d? |  | finish no earlier than 2012-06-20 | S2 | 4688.06h | 4688.06h | BBAI | PCG-24 | Ericsson | stefan.rommer@ericsson.com | Rel-11 | SP-47 | Maurice |  |  |  |
| 348 | 141.4 | (IETF) Stage 2 BB I: BBF interworking with home routed traffic for WLAN and H(e)NB | 262d? | 2011-12-12 A | 2012-12-07 | 50% | 131d? | 2011-12-12 | 2012-12-07 | 262d? | 463d | finish no earlier than 2012-12-07 | S2-IETF | 2096h | 1048h | BBAI | PCG-28 | Lionel Morand | Lionel Morand | Rel-11 | SP-54 |  |  |  |  |
| 349 | 141.5 | **Stage 3 BB I - Core Network impacts: BBF interworking with home routed traffic for WLAN and H(e)NB** | 324d? | 2011-09-16 A | 2012-12-07 | 97% | 8.77d? | 2011-09-16 | 2012-12-07 | 324d? | 463d |  | C1,C3,C4 | 12056.1h | 11727.6h | BBAI_BBI-CT | PCG-27 | Ericsson | Zu.Qiang@Ericsson.com | Rel-11 | CP-53 |  |  |  |  |
| 350 | 141.5.1 | TR on Stage 3 BB I for BBAI; UE to network protocols | 198d? | 2011-09-16 A | 2012-06-15 A | 100% |  | 2011-09-16 | 2012-06-15 | 198d? |  | finish no earlier than 2012-06-15 | C1 | 1568.15h | 1568.15h | BBAI_BBI-CT | PCG-27 | Ericsson | Zu.Qiang@Ericsson.com | Rel-11 | CP-53 |  |  |  |  |
| 351 | 141.5.2 | TR on Stage 3 BB I for BBAI; Home (e)Node B – Security Gateway Interface | 77d? | 2012-03-02 A | 2012-06-15 A | 100% |  | 2012-03-02 | 2012-06-15 | 77d? |  | finish no earlier than 2012-06-01 | C4 | 608h | 608h | BBAI_BBI-CT | PCG-28 | Ericsson | Zu.Qiang@Ericsson.com | Rel-11 | CP-55 |  |  |  |  |
| 352 | 141.5.3 | Deleted - (IETF) on Stage 3 BB I for BBAI; Home (e)Node B – Security Gateway Interface | 77d? | 2012-03-02 A | 2012-06-15 A | 100% |  | 2012-03-02 | 2012-06-15 | 77d? |  | finish no earlier than 2012-06-15 | C4-IETF | 616h | 616h | BBAI_BBI-CT | PCG-28 | Lionel Morand |  | Rel-11 | CP-55 |  | PCG-29 | CP-56 |  |
| 353 | 141.5.4 | CT1 part of Stage 3 BB I: BBF interworking with home routed traffic for WLAN and H(e)NB | 258d? | 2011-09-16 A | 2012-09-07 A | 100% |  | 2011-09-16 | 2012-09-07 | 258d? |  | finish no earlier than 2012-09-07 | C1 | 2048h | 2048h | BBAI_BBI-CT | PCG-27 | Ericsson | Zu.Qiang@Ericsson.com | Rel-11 | CP-53 |  |  |  |  |
| 354 | 141.5.5 | CT3 part of Stage 3 BB I: BBF interworking with home routed traffic for WLAN and H(e)NB | 259d? | 2011-09-16 A | 2012-09-07 A | 100% |  | 2011-09-16 | 2012-09-07 | 259d? |  | finish no earlier than 2012-09-07 | C3 | 2048h | 2048h | BBAI_BBI-CT | PCG-27 | Ericsson | Zu.Qiang@Ericsson.com | Rel-11 | CP-53 |  |  |  |  |
| 355 | 141.5.6 | CT4 part of Stage 3 BB I: BBF interworking with home routed traffic for WLAN and H(e)NB | 324d? | 2011-09-16 A | 2012-12-07 | 90% | 32.3d? | 2011-09-16 | 2012-12-07 | 324d? | 463d | finish no earlier than 2012-12-07 | C4 | 2576h | 2317.6h | BBAI_BBI-CT | PCG-27 | Ericsson | Zu.Qiang@Ericsson.com | Rel-11 | CP-53 |  |  |  | CP-120452 |
| 356 | 141.6 | Stage 1 BB II: BBF interworking with offload in access network for WLAN and for H(e)NB | 262d? | 2010-09-23 A | 2011-09-21 A | 100% |  | 2010-09-23 | 2011-09-21 | 262d? |  | finish no earlier than 2011-09-21 | S1 | 2080h | 2080h | BBAI | PCG-25 | Ericsson | Olle.Eriksson@ericsson.com | Rel-11 | SP-49 | Alain |  |  |  |
| 357 | 141.7 | Stage 2 BB II: BBF interworking with offload in access network for WLAN and for H(e)NB | 455d? | 2010-09-28 A | 2012-06-20 A | 100% |  | 2010-09-28 | 2012-06-20 | 455d? |  | finish no earlier than 2012-06-20 | S2 | 3640h | 3640h | BBAI | PCG-24 | Ericsson | stefan.rommer@ericsson.com | Rel-11 | SP-47 | Maurice |  |  |  |
| 358 | 141.8 | **Stage 3 BB II - Core Network impacts: BBF interworking with offload in access network for WLAN and for H(e)NB** | 259d? | 2011-09-16 A | 2012-09-07 A | 100% |  | 2011-09-16 | 2012-09-07 | 259d? |  |  | C3,C1,C4 | 8744h | 8744h | BBAI_BBII-CT | PCG-27 | Ericsson | Susana.Fernandez@ericsson.com | Rel-11 | CP-53 |  |  |  |  |
| 359 | 141.8.1 | TR on Stage 3 BB II for 3GPP System to Fixed Broadband Access Network Interworking; UE to network protocols | 198d? | 2011-09-16 A | 2012-06-15 A | 100% |  | 2011-09-16 | 2012-06-15 | 198d? |  | finish no earlier than 2012-06-15 | C1 | 1576h | 1576h | BBAI_BBII-CT | PCG-27 | Ericsson | Susana.Fernandez@ericsson.com | Rel-11 | CP-53 |  |  |  |  |
| 360 | 141.8.2 | CT1 part of Stage 3 BB II: BBF interworking with offload in access network for WLAN and for H(e)NB | 259d? | 2011-09-16 A | 2012-09-07 A | 100% |  | 2011-09-16 | 2012-09-07 | 259d? |  | finish no earlier than 2012-09-07 | C1 | 2064h | 2064h | BBAI_BBII-CT | PCG-27 | Ericsson | Susana.Fernandez@ericsson.com | Rel-11 | CP-53 |  |  |  |  |
| 361 | 141.8.3 | CT3 part of Stage 3 BB II: BBF interworking with offload in access network for WLAN and for H(e)NB | 259d? | 2011-09-16 A | 2012-09-07 A | 100% |  | 2011-09-16 | 2012-09-07 | 259d? |  | start no earlier than 2011-09-16 | C3 | 2056h | 2056h | BBAI_BBII-CT | PCG-27 | Ericsson | Susana.Fernandez@ericsson.com | Rel-11 | CP-53 |  |  |  |  |
| 362 | 141.8.4 | CT4 part of Stage 3 BB II: BBF interworking with offload in access network for WLAN and for H(e)NB | 122d? | 2011-09-16 A | 2012-03-02 A | 100% |  | 2011-09-16 | 2012-03-02 | 122d? |  | start no earlier than 2011-09-16 | C4 | 976h | 976h | BBAI_BBII-CT | PCG-27 | Ericsson | Susana.Fernandez@ericsson.com | Rel-11 | CP-53 |  |  |  |  |
| 363 | 141.9 | Deleted - Stage 1 BB III: BBF convergence and network based mobility | 262d? | 2010-09-23 A | 2011-09-21 A | 100% |  | 2010-09-23 | 2011-09-21 | 262d? |  | finish no earlier than 2011-09-21 | S1 | 2080h | 2080h | BBAI | PCG-25 | Huawei | Amar Deol (adeol@huawei.com) | Rel-11 | SP-49 | Alain | PCG-29 | SP-57 |  |
| 364 | 141.10 | Deleted - Stage 2 BB III: BBF convergence and network based mobility | 380d? | 2010-09-28 A | 2012-03-07 A | 100% |  | 2010-09-28 | 2012-03-07 | 380d? |  | finish no earlier than 2012-03-07 | S2 | 3040h | 3040h | BBAI | PCG-24 | Huawei | marco.spini@huawei.com | Rel-11 | SP-47 | Maurice | PCG-28 | SP-55 |  |

Notes:
- 339: CP#54 completed
- 340: SP#52 completed under TEI11. Approved WID and CRs in SP-110376 (22.082 CR#0005, 22.085 CR#0004, 22.081 CR#0007, 22.088 CR#0003, 22.004 CR#0013) / Text3: 22.004, 22.081, 22.082, 22.085, 22.088
- 341: CP#54 completed / Text3: Stage 2/3
- 342: CP#54 completed / Text3: 23.018, 23.081, 23.082, 23.085, 23.088, 23.205, 23.231, 24.088, 29.002, 29.011
- 343: CP#53 completed / Text3: 29.163, 29.292
- 344: SP#57 updated WID SP-120419=>SP-120539 (removed BB3 objectives not implemented in Stage 2). SP#56 completed. Triggered by BBF WT 203, WT-134 (interworking btw 3GPP EPS and BBF's fixed broadband accesses)
- 345: SP#57 updated WID SP-120419=>SP-120539 (removed BB3 objectives not implemented in Stage 2). SP#47 completed. Provide service requirements for supporting interworking between 3GPP EPS and the fixed broadband accesses defined by BBF / Text3: 22.278 CR#0058
- 346: SP#56 updated WID SP-110647=>SP-120382 (TR 23.839 not Approved in Rel-11; moved to Rel-12 Feature P4C). SP#54 TR 23.839 v140 for Information / Text3: new TR 23.839
- 347: SP#56 completed / Text3: 23.203, new 23.139
- 348: Public address for NAT-traversal for new TS 23.139 / Text3: no internet-draft available yet
- 349: CP#56 updated WID CP-120195=>CP-120419 / Text3: Stage 3
- 350: CP#56 completed. Identify additional FMC specific procedures in addition to those in 24.302 (on access authentication & authorization and tunnel management; IP mobility mode selection; security aspects) / Text3: new TR 24.820
- 351: CP#56 completed / Text3: new TR 29.839
- 352: Draft removed from 3GPP documentation / Text3: draft-so-ipsecme-ikev2-cpext
- 353: CP#57 completed / Text3: 24.229, new TS 24.139
- 354: CP#57 completed / Text3: 29.212, 29.213, 29.215
- 355: CP#57 completion 09/12=>12/12 (exception in CP-120452). TS 29.139 v100 for Information / Text3: 23.008, 29.273, 29.274, new TS 29.139
- 356: SP#53 completed / Text3: 22.278
- 357: SP#56 completed / Text3: 23.203, 23.401, 23.402, 23.139
- 358: CP#57 completed / Text3: Stage 3
- 359: CP#56 completed / Text3: 24.820
- 360: CP#57 completed / Text3: new TS 24.320
- 361: CP#57 completed / Text3: 29.212, 29.213, 29.215
- 362: CP#55 completed / Text3: 23.008, 29.273
- 363: SP#57 stopped. Updated WID SP-120419=>SP-120539 (removed BB3 objectives not implemented in Stage 2). SP#53 completed / Text3: 22.278
- 364: SP#57 updated WID SP-120419=>SP-120539 (removed BB3 objectives not implemented in Stage 2). SP#55 stopped / Text3: 23.203, 23.401, 23.402, 23.139

| ID | WBS | Task | Duration | Start | Finish | Complete | Remaining | Baseline start | Baseline finish | Baseline duration | Total slack | Constraint | Resources | Work | Actual work | Text1 | Text2 | Text4 | Text5 | Text6 | Text7 | Text9 | Text12 | Text8 | Text11 |
| --- | --- | --- | --- | --- | --- | --- | --- | --- | --- | --- | --- | --- | --- | --- | --- | --- | --- | --- | --- | --- | --- | --- | --- | --- | --- |
| 365 | 141.11 | **Deleted - Stage 3 BB III - Core Network impacts: BBF convergence and network based mobility** | 122d? | 2011-09-16 A | 2012-03-02 A | 100% |  | 2011-09-16 | 2012-03-02 | 122d? |  |  | C3,C1,C4 | 4880h | 4880h | BBAI_BBIII-CT | PCG-27 | Huawei | qiaoweihua@huawei.com | Rel-11 | CP-53 | PCG-28 | CP-55 |  |  |
| 366 | 141.11.1 | Deleted - TR on Stage 3 BB III for 3GPP System to Fixed Broadband Access Network Interworking; UE to network protocols | 122d? | 2011-09-16 A | 2012-03-02 A | 100% |  | 2011-09-16 | 2012-03-02 | 122d? |  | start no earlier than 2011-09-16 | C1 | 976h | 976h | BBAI_BBIII-CT | PCG-27 | Huawei | qiaoweihua@huawei.com | Rel-11 | CP-53 | PCG-28 | CP-55 |  |  |
| 367 | 141.11.2 | Deleted - CT1 part of Stage 3 BB III: BBF convergence and network based mobility | 122d? | 2011-09-16 A | 2012-03-02 A | 100% |  | 2011-09-16 | 2012-03-02 | 122d? |  | start no earlier than 2011-09-16 | C1 | 976h | 976h | BBAI_BBIII-CT | PCG-27 | Huawei | qiaoweihua@huawei.com | Rel-11 | CP-53 | PCG-28 | CP-55 |  |  |
| 368 | 141.11.3 | Deleted - CT3 part of Stage 3 BB III: BBF convergence and network based mobility | 122d? | 2011-09-16 A | 2012-03-02 A | 100% |  | 2011-09-16 | 2012-03-02 | 122d? |  | start no earlier than 2011-09-16 | C3 | 976h | 976h | BBAI_BBIII-CT | PCG-27 | Huawei | qiaoweihua@huawei.com | Rel-11 | CP-53 | PCG-28 | CP-55 |  |  |
| 369 | 141.11.4 | Deleted - CT4 part of Stage 3 BB III: BBF convergence and network based mobility | 122d? | 2011-09-16 A | 2012-03-02 A | 100% |  | 2011-09-16 | 2012-03-02 | 122d? |  | start no earlier than 2011-09-16 | C4 | 976h | 976h | BBAI_BBIII-CT | PCG-27 | Huawei | qiaoweihua@huawei.com | Rel-11 | CP-53 | PCG-28 | CP-55 |  |  |
| 370 | 142 | **Single Radio Voice Call Continuity (SRVCC) aspect of enhancements for Multimedia Priority Service** | 398d? | 2010-06-10 A | 2011-12-14 A | 100% |  | 2010-06-10 | 2011-12-14 | 398d? |  |  | S2 | 8432h | 8432h | eMPS_SRVCC | PCG-25 | NTT DoCoMo | Atsushi Minokuchi (minokuchi@nttdocomo.co.jp) | Rel-11 | SP-48 |  |  | Maurice |  |
| 371 | 142.1 | TR on SRVCC for eMPS | 260d? | 2010-06-10 A | 2011-06-08 A | 100% |  | 2010-06-10 | 2011-06-08 | 260d? |  | finish no earlier than 2011-06-08 | S2 | 2080h | 2080h | eMPS_SRVCC | PCG-25 | NTT DoCoMo | Atsushi Minokuchi (minokuchi@nttdocomo.co.jp) | Rel-11 | SP-48 |  |  | Maurice |  |
| 372 | 142.2 | Stage 2 on SRVCC for eMPS | 398d? | 2010-06-10 A | 2011-12-14 A | 100% |  | 2010-06-10 | 2011-12-14 | 398d? |  | finish no earlier than 2011-12-14 | S2 | 3168h | 3168h | eMPS_SRVCC | PCG-25 | NTT DoCoMo | Atsushi Minokuchi (minokuchi@nttdocomo.co.jp) | Rel-11 | SP-48 |  |  | Maurice |  |
| 373 | 143 | **Single Radio Video Call Continuity for 3G-CS** | 440d? | 2010-10-15 A | 2012-06-15 A | 100% |  | 2010-10-15 | 2012-06-15 | 440d? |  |  | S2,C1,C3,C4 | 11612.4h | 11612.4h | vSRVCC | PCG-26 | Samsung | xiaowan.ke@samsung.com | Rel-11 | SP-50 |  |  | Maurice |  |
| 374 | 143.1 | Stage 2 for Single Radio Video Call Continuity for 3G-CS | 199.85d? | 2010-10-15 A | 2011-09-21 A | 100% |  | 2010-10-15 | 2011-09-21 | 199.85d? |  | finish no earlier than 2011-12-07 | S2 | 1580.41h | 1580.41h | vSRVCC | PCG-26 | Samsung | xiaowan.ke@samsung.com | Rel-11 | SP-50 |  |  | Maurice |  |
| 375 | 143.2 | **CN aspects of Single Radio Video Call Continuity for 3G-CS** | 275d? | 2011-06-03 A | 2012-06-15 A | 100% |  | 2011-06-03 | 2012-06-15 | 275d? |  |  | C1,C3,C4 | 6512h | 6512h | vSRVCC-CT | PCG-27 | NEC | gottfried.punz@neclab.eu | Rel-11 | CP-52 |  |  | Frederic |  |
| 376 | 143.2.1 | CT1 aspects of Single Radio Video Call Continuity for 3G-CS | 275d? | 2011-06-03 A | 2012-06-15 A | 100% |  | 2011-06-03 | 2012-06-15 | 275d? |  | finish no earlier than 2012-06-15 | C1 | 2184h | 2184h | vSRVCC-CT | PCG-27 | NEC | gottfried.punz@neclab.eu | Rel-11 | CP-52 |  |  | Frederic |  |
| 377 | 143.2.2 | CT3 aspects of Single Radio Video Call Continuity for 3G-CS | 134d? | 2011-06-03 A | 2011-12-02 A | 100% |  | 2011-06-03 | 2011-12-02 | 134d? |  | finish no earlier than 2011-12-02 | C3 | 1064h | 1064h | vSRVCC-CT | PCG-27 | NEC | gottfried.punz@neclab.eu | Rel-11 | CP-52 |  |  | Jiwan |  |
| 378 | 143.2.3 | CT4 aspects of Single Radio Video Call Continuity for 3G-CS | 134d? | 2011-06-03 A | 2011-12-02 A | 100% |  | 2011-06-03 | 2011-12-02 | 134d? |  | finish no earlier than 2011-12-02 | C4 | 1064h | 1064h | vSRVCC-CT | PCG-27 | NEC | gottfried.punz@neclab.eu | Rel-11 | CP-52 |  |  | Kimmo |  |
| 379 | 144 | **Network Provided Location Information for IMS (NETLOC)** | 657d? | 2010-06-10 A | 2012-12-07 | 99% | 3.36d? | 2010-06-10 | 2012-12-07 | 657d? | 463d |  | S2,S1,S5,C3,C4,C1 | 22720h | 22572.9h | NWK-PL2IMS | PCG-25 | T-Mobile | michele.zarri@t-mobile.co.uk | Rel-11 | SP-48 |  |  | Maurice |  |
| 380 | 144.1 | Stage 1 for Network Provided Location Information for IMS | 203d? | 2010-12-15 A | 2011-09-21 A | 100% |  | 2010-12-15 | 2011-09-21 | 203d? |  | finish no earlier than 2011-09-21 | S1 | 1608h | 1608h | NWK-PL2IMS | PCG-26 | n/a | n/a | Rel-11 | SP-50 |  |  | Alain |  |
| 381 | 144.2 | TR on Stage 2 for network provided location information to the IMS | 395d? | 2010-06-10 A | 2011-12-14 A | 100% |  | 2010-06-10 | 2011-12-14 | 395d? |  | finish no earlier than 2011-12-06 | S2 | 3160h | 3160h | NWK-PL2IMS | PCG-25 | T-Mobile | michele.zarri@t-mobile.co.uk | Rel-11 | SP-48 |  |  | Maurice |  |
| 382 | 144.3 | Stage 2 for Network Provided Location Information for IMS | 455d? | 2010-06-15 A | 2012-03-07 A | 100% |  | 2010-06-15 | 2012-03-07 | 455d? |  | finish no earlier than 2012-03-07 | S2 | 3640h | 3640h | NWK-PL2IMS | PCG-25 | T-Mobile | michele.zarri@t-mobile.co.uk | Rel-11 | SP-48 |  |  | Maurice |  |
| 383 | 144.4 | Charging for Network Provided Location Information for IMS | 515d? | 2010-09-23 A | 2012-09-12 A | 100% |  | 2010-09-23 | 2012-09-12 | 515d? |  | finish no earlier than 2012-09-12 | S5 | 4120h | 4120h | NWK-PL2IMS_CH | PCG-25 | Nokia Siemens Networks | Gerald.Goermer@nsn.com | Rel-11 | SP-49 |  |  | Dionisio |  |
| 384 | 144.5 | **CT aspects of Network Provided Location Information for IMS (Stage 3)** | 203d? | 2012-03-02 A | 2012-12-07 | 98% | 4.93d? | 2012-03-02 | 2012-12-07 | 203d? | 463d |  | C3,C4,C1 | 4936h | 4815.78h | NWK-PL2IMS_CT | PCG-28 | Huawei | Qiao Weihua (qiaoweihua@huawei.com) | Rel-11 | CP-55 |  |  |  |  |
| 385 | 144.5.1 | CT3 part of CT aspects of Network Provided Location Information for IMS | 138d? | 2012-03-02 A | 2012-09-07 A | 100% |  | 2012-03-02 | 2012-09-07 | 138d? |  | finish no earlier than 2012-09-07 | C3 | 1088h | 1088h | NWK-PL2IMS_CT | PCG-28 | Huawei | Qiao Weihua (qiaoweihua@huawei.com) | Rel-11 | CP-55 |  |  |  |  |
| 386 | 144.5.2 | CT4 part of CT aspects of Network Provided Location Information for IMS | 77d? | 2012-03-02 A | 2012-06-15 A | 100% |  | 2012-03-02 | 2012-06-15 | 77d? |  | finish no earlier than 2012-06-01 | C4 | 608h | 608h | NWK-PL2IMS_CT | PCG-28 | Huawei | Qiao Weihua (qiaoweihua@huawei.com) | Rel-11 | CP-55 |  |  |  |  |
| 387 | 144.5.3 | CT1 part of CT aspects of Network Provided Location Information for IMS | 203d? | 2012-03-02 A | 2012-12-07 | 95% | 10.15d? | 2012-03-02 | 2012-12-07 | 203d? | 463d | finish no earlier than 2012-12-07 | C1 | 1616h | 1535.2h | NWK-PL2IMS_CT | PCG-28 | Huawei | Qiao Weihua (qiaoweihua@huawei.com) | Rel-11 | CP-55 |  |  |  | CP-120552 |
| 388 | 145 | **Service Awareness and Privacy Policies** | 301.15d? | 2010-10-12 A | 2011-12-02 A | 100% |  | 2010-10-12 | 2011-12-02 | 301.15d? |  |  | S2,S1,C3 | 5480h | 5480h | SAPP | PCG-26 | Allot Communications | Alla Goldner (agoldner@allot.com) | Rel-11 | SP-50 |  |  | Maurice |  |
| 389 | 145.1 | Stage 1 for Service Awareness and Privacy Policies | 46.15d? | 2010-10-12 A | 2010-12-15 A | 100% |  | 2010-10-12 | 2010-12-15 | 46.15d? |  | finish no earlier than 2010-12-15 | S1 | 369.2h | 369.2h | SAPP | PCG-26 | Allot Communications | Alla Goldner (agoldner@allot.com) | Rel-11 | SP-50 |  |  | Maurice |  |
| 390 | 145.2 | Stage 2 for Service Awareness and Privacy Policies | 199.85d? | 2010-10-15 A | 2011-09-21 A | 100% |  | 2010-10-15 | 2011-09-21 | 199.85d? |  | finish no earlier than 2011-09-21 | S2 | 1582.8h | 1582.8h | SAPP | PCG-26 | Allot Communications | Alla Goldner (agoldner@allot.com) | Rel-11 | SP-50 |  |  | Maurice |  |
| 391 | 145.3 | CT3 part of Service Awareness and Privacy Policies | 187d? | 2011-03-18 A | 2011-12-02 A | 100% |  | 2011-03-18 | 2011-12-02 | 187d? |  | finish no earlier than 2011-12-02 | C3 | 1488h | 1488h | SAPP-CT3 | PCG-26 | Allot Communications | Alla Goldner (agoldner@allot.com) | Rel-11 | CP-51 |  |  | Jiwan |  |

Notes:
- 365: CP#55 stopped / Text3: Stage 3
- 366: CP#55 stopped / Text3: new TR 24.820
- 367: CP#55 stopped / Text3: TBD
- 368: CP#55 stopped / Text3: 29.212, 29.213, 29.215
- 369: CP#55 stopped / Text3: 23.008, 29.273
- 370: SP#54 completed. Analyze and if needed specify mechanisms for the priority handling of SRVCC with regard to LTE/EPC / Text3: Stage 2
- 371: SP#52 completed / Text3: new TR 23.854
- 372: SP#54 completed / Text3: 23.216, 23.237
- 373: CP#56 completed. Provide Single Radio VIDEO Call Continuity from E-UTRAN to UTRAN-CS based on the agreed architecture alternative in TR 23.886
- 374: SP#53 completed. Triggered by Feasibility Study on video call handover capability in TR 23.886 UID_470048 Study on Single Radio Video Call Continuity for 3G-CS (FS_vSRVCC) / Text3: 23.203, 23.216, 23.237
- 375: Stage 3. CP#56 completed
- 376: CP#56 completed / Text3: 24.008, 24.237, 24.301
- 377: CP#54 completed / Text3: 29.211, 29.212, 29.213, 29.215
- 378: CP#54 completed / Text3: 29.280
- 379: SP#55 Stage 2 completed. Architecture solutions making Cell/PLMN ID (the UE is camped on) available to IMS nodes when the mobile operator needs to record this information either to fulfil legal obligations or for charging purposes.
- 380: SP#53 completed / Text3: 22.115
- 381: SP#54 completed / Text3: new TR 23.842
- 382: SP#55 completed / Text3: 23.060, 23.203, 23.228, 23.401
- 383: SP#57 completed / Text3: Stage 2 (32.240, 32.260), Stage 3 (32.298, 32.299)
- 384: Stage 3. CP#56 updated WID CP-120081=>CP-120359
- 385: CP#57 completed / Text3: 29.163, 29.165, 29.212, 29.213, 29.214, 29.215, 29.292
- 386: CP#56 completed / Text3: 29.002, 29.060, 29.230, 29.272, 29.274, 29.305, 29.328, 29.329
- 387: CP#57 completion 09/12=>12/12 (exception in CP-120552) / Text3: 24.229
- 388: CP#54 completed. Triggered by the SA1,SA2 Rel-10 TR 23.813 Study on Policy solutions and enhancements (FS_PP) UID_440047
- 389: For deep packet inspection (i.e. Traffic Detection Functionality) SA1 indicated that no new requirements are needed (see Objective of FS_PP SA1,SA2 Rel-10 Study on Policy solutions and enhancements UID_440047 TR 23.813)
- 390: SP#53 completed / Text3: 23.203
- 391: CP#54 completed. Stage 3 to support Application Detection and Control Functionality. Update Gx / introduce Sd reference points and procedures. Update S9 reference point in roaming scenarios / Text3: Stage 3: 29.212, 29.213, 29.214, 29.215

| ID | WBS | Task | Duration | Start | Finish | Complete | Remaining | Baseline start | Baseline finish | Baseline duration | Total slack | Constraint | Resources | Work | Actual work | Text1 | Text2 | Text4 | Text5 | Text6 | Text7 | Text8 | Text11 | Text9 | Text12 |
| --- | --- | --- | --- | --- | --- | --- | --- | --- | --- | --- | --- | --- | --- | --- | --- | --- | --- | --- | --- | --- | --- | --- | --- | --- | --- |
| 392 | 146 | **VPLMN Autonomous CSG Roaming** | 501d? | 2010-10-15 A | 2012-09-07 A | 100% |  | 2010-10-15 | 2012-09-07 | 501d? |  |  | S2,C4 | 6070.61h | 6070.61h | VCSG | PCG-26 | Qualcomm | AC Mahendran (ac@qualcomm.com) | Rel-11 | SP-50 | Maurice |  |  |  |
| 393 | 146.1 | Stage 2 for VPLMN Autonomous CSG Roaming | 260.85d? | 2010-10-15 A | 2011-12-14 A | 100% |  | 2010-10-15 | 2011-12-14 | 260.85d? |  | finish no earlier than 2011-12-07 | S2 | 2062.61h | 2062.61h | VCSG | PCG-26 | Qualcomm | AC Mahendran (ac@qualcomm.com) | Rel-11 | SP-50 | Maurice |  |  |  |
| 394 | 146.2 | CT aspects of VPLMN Autonomous CSG Roaming | 200d? | 2011-12-07 A | 2012-09-07 A | 100% |  | 2011-12-07 | 2012-09-07 | 200d? |  | finish no earlier than 2012-09-07 | C4 |  |  | VCSG-St3 | PCG-27 | ZTE | Fei Lu (lu.fei1@zte.com.cn) | Rel-11 | CP-53 |  |  |  |  |
| 395 | 147 | **Data Identification in Access Network Discovery and Selection Function (ANDSF)** | 453d? | 2011-03-23 A | 2012-12-07 | 96% | 16.32d? | 2011-03-23 | 2012-12-07 | 453d? | 463d |  | S2,C1 | 7200h | 3576h | DIDA | PCG-26 | Qualcomm | Gerardo Giaretta (gerardo@qualcomm.com) | Rel-11 | SP-51 | Maurice |  |  |  |
| 396 | 147.1 | TR on Stage 2 for Data Identification in ANDSF | 193d? | 2011-03-23 A | 2011-12-14 A | 100% |  | 2011-03-23 | 2011-12-14 | 193d? |  | finish no earlier than 2011-12-07 | S2 | 1544h | 1544h | DIDA | PCG-26 | Qualcomm | Gerardo Giaretta (gerardo@qualcomm.com) | Rel-11 | SP-51 | Maurice |  |  |  |
| 397 | 147.2 | Stage 2 for Data Identification in ANDSF | 253d? | 2011-03-24 A | 2012-03-07 A | 100% |  | 2011-03-24 | 2012-03-07 | 253d? |  | finish no earlier than 2012-03-07 | S2 | 2024h | 2024h | DIDA | PCG-26 | Qualcomm | Gerardo Giaretta (gerardo@qualcomm.com) | Rel-11 | SP-51 | Maurice |  |  |  |
| 398 | 147.3 | CT aspects of Data Identification in Access Network Discovery and Selection Function (ANDSF) Stage 3 | 141d? | 2012-03-02 A | 2012-12-07 | 85% | 21.15d? | 2012-03-02 | 2012-12-07 | 141d? | 463d | finish no earlier than 2012-12-07 | C1 | 8h | 8h | DIDA-CT | PCG-28 | Qualcomm | Patrick Stupar (pstupar@qualcomm.com) | Rel-11 | CP-55 |  | CP-120553 |  |  |
| 399 | 148 | **LOcation-Based Selection of gaTEways foR WLAN** | 327d? | 2011-03-23 A | 2012-06-15 A | 100% |  | 2011-03-23 | 2012-06-15 | 327d? |  |  | S2,C4 | 7554.52h | 7554.52h | LOBSTER | PCG-26 | ZTE | zhu.chunhui@zte.com.cn | Rel-11 | SP-51 | Maurice |  |  |  |
| 400 | 148.1 | Stage 2 for LOcation-Based Selection of gaTEways foR WLAN | 194d? | 2011-03-23 A | 2011-12-14 A | 100% |  | 2011-03-23 | 2011-12-14 | 194d? |  | finish no earlier than 2011-12-07 | S2 | 1546.52h | 1546.52h | LOBSTER | PCG-26 | ZTE | zhu.chunhui@zte.com.cn | Rel-11 | SP-51 | Maurice |  |  |  |
| 401 | 148.2 | **CT aspects of LOcation-Based Selection of gaTEways foR WLAN** | 142d? | 2011-12-02 A | 2012-06-15 A | 100% |  | 2011-12-02 | 2012-06-15 | 142d? |  |  | C4 | 3392h | 3392h | LOBSTER-CT | PCG-28 | ZTE | zhou.xingyue@zte.com.cn | Rel-11 | CP-54 |  |  |  |  |
| 402 | 148.2.1 | CT4 part of CT aspects of LOcation-Based Selection of gaTEways foR WLAN | 142d? | 2011-12-02 A | 2012-06-15 A | 100% |  | 2011-12-02 | 2012-06-15 | 142d? |  | finish no earlier than 2012-06-15 | C4 | 1128h | 1128h | LOBSTER-CT | PCG-28 | ZTE | zhou.xingyue@zte.com.cn | Rel-11 | CP-54 |  |  |  |  |
| 403 | 148.2.2 | Deleted - CT1 part of CT aspects of LOcation-Based Selection of gaTEways foR WLAN | 142d? | 2011-12-02 A | 2012-06-15 A | 100% |  | 2011-12-02 | 2012-06-15 | 142d? |  | finish no earlier than 2012-06-15 | C1 | 1128h | 1128h | LOBSTER-CT | PCG-28 | ZTE | zhou.xingyue@zte.com.cn | Rel-11 | CP-54 |  |  | PCG-29 | CP-56 |
| 404 | 149 | **Single Radio Voice Call Continuity from UTRAN/GERAN to E-UTRAN/HSPA** | 328d? | 2011-09-12 A | 2012-12-07 | 86% | 45.33d? | 2011-09-12 | 2012-12-07 | 328d? | 463d |  | S2,C1,C3,C4,G2,R2,R3 | 19584h | 17344.6h | rSRVCC | PCG-27 | Orange | antoine.mouquet@orange-ftgroup.com | Rel-11 | SP-53 |  |  |  |  |
| 405 | 149.1 | Stage 2 for Single Radio Voice Call Continuity from UTRAN/GERAN to E-UTRAN/HSPA | 197d? | 2011-09-22 A | 2012-06-20 A | 100% |  | 2011-09-22 | 2012-06-20 | 197d? |  | finish no earlier than 2012-06-20 | S2 | 1568h | 1568h | rSRVCC | PCG-27 | Orange | antoine.mouquet@orange-ftgroup.com | Rel-11 | SP-53 |  |  |  |  |
| 406 | 149.2 | **CT aspects for Single Radio Voice Call Continuity from UTRAN/GERAN to E-UTRAN/HSPA (Stage 3)** | 259d? | 2011-09-16 A | 2012-09-07 A | 100% |  | 2011-09-16 | 2012-09-07 | 259d? |  |  | C1,C3,C4 | 8216h | 8216h | rSRVCC-CT | PCG-27 | Ericsson | ivo.sedlacek@ericsson.com | Rel-11 | CP-53 |  |  |  |  |
| 407 | 149.2.1 | CT1 part for Single Radio Voice Call Continuity from UTRAN/GERAN to E-UTRAN/HSPA | 258d? | 2011-09-16 A | 2012-09-07 A | 100% |  | 2011-09-16 | 2012-09-07 | 258d? |  | finish no earlier than 2012-09-07 | C1 | 2048h | 2048h | rSRVCC-CT | PCG-27 | Ericsson | ivo.sedlacek@ericsson.com | Rel-11 | CP-53 |  |  |  |  |
| 408 | 149.2.2 | CT3 part for Single Radio Voice Call Continuity from UTRAN/GERAN to E-UTRAN/HSPA | 257d? | 2011-09-19 A | 2012-09-07 A | 100% |  | 2011-09-19 | 2012-09-07 | 257d? |  | finish no earlier than 2012-09-07 | C3 | 2048h | 2048h | rSRVCC-CT | PCG-27 | Ericsson | ivo.sedlacek@ericsson.com | Rel-11 | CP-53 |  |  |  |  |
| 409 | 149.2.3 | CT4 part for Single Radio Voice Call Continuity from UTRAN/GERAN to E-UTRAN/HSPA | 257d? | 2011-09-19 A | 2012-09-07 A | 100% |  | 2011-09-19 | 2012-09-07 | 257d? |  | finish no earlier than 2012-09-07 | C4 | 2048h | 2048h | rSRVCC-CT | PCG-27 | Ericsson | ivo.sedlacek@ericsson.com | Rel-11 | CP-53 |  |  |  |  |
| 410 | 149.3 | GERAN aspects of Single Radio Voice Call Continuity from UTRAN/GERAN to E-UTRAN/HSPA | 316d? | 2011-09-12 A | 2012-11-23 | 45% | 173.8d? | 2011-09-12 | 2012-11-23 | 316d? | 473d | finish no earlier than 2012-11-23 | G2 | 2048h | 940.8h | rSRVCC-GERAN | PCG-27 | ZTE | li.jing4@zte.com.cn | Rel-11 | GP-51 |  | GP-121116 |  |  |
| 411 | 149.4 | **UTRAN aspects of Single Radio Voice Call Continuity from UTRAN/GERAN to E-UTRAN/HSPA** | 323d? | 2011-09-19 A | 2012-12-07 | 85% | 48.44d? | 2011-09-19 | 2012-12-07 | 323d? | 463d |  | R3,R2 | 5160h | 4386.04h | rSRVCC-RAN_UTRA | PCG-27 | Huawei | liwei.qiu@huawei.com | Rel-11 | RP-53 |  |  |  |  |
| 412 | 149.4.1 | Core part: UTRAN aspects of Single Radio Voice Call Continuity from UTRAN/GERAN to E-UTRAN/HSPA | 322d? | 2011-09-19 A | 2012-12-07 | 85% | 48.3d? | 2011-09-19 | 2012-12-07 | 322d? | 463d | finish no earlier than 2012-12-07 | R3,R2 | 2576h | 2189.6h | rSRVCC-RAN_UTRA-Core | PCG-27 | Huawei | liwei.qiu@huawei.com | Rel-11 | RP-53 |  | RP-120984 |  |  |
| 413 | 150 | **S2a Mobility based On GTP and WLAN access to EPC** | 320d? | 2011-09-22 A | 2012-12-07 | 89% | 34.48d? | 2011-09-22 | 2012-12-07 | 320d? | 463d |  | S2,C4,C1,C3,IETF | 10872h | 5916h | SaMOG_WLAN | PCG-27 | ZTE | Chunhui Zhu (zhu.chunhui@zte.com.cn) | Rel-11 | SP-53 |  |  |  |  |
| 414 | 150.1 | Stage 2 for S2a Mobility based On GTP and WLAN access to EPC | 121d? | 2011-09-22 A | 2012-03-07 A | 100% |  | 2011-09-22 | 2012-03-07 | 121d? |  | finish no earlier than 2012-03-07 | S2 | 968h | 968h | SaMOG_WLAN | PCG-27 | ZTE | zhu.chunhui@zte.com.cn | Rel-11 | SP-53 |  |  |  |  |
| 415 | 150.2 | **CN aspects of Mobility based On GTP & PMIPv6 for WLAN access to EPC** | 268d? | 2011-12-02 A | 2012-12-07 | 87% | 34.22d? | 2011-12-02 | 2012-12-07 | 268d? | 463d |  | C4,C1,C3,IETF | 7344h | 4532h | SaMOG_WLAN-CN | PCG-28 | Alcatel-Lucent | bruno.landais@alcatel-lucent.com | Rel-11 | CP-54 |  |  |  |  |
| 416 | 150.2.1 | CT4 part of CN aspects of Mobility based On GTP & PMIPv6 for WLAN access to EPC | 203d? | 2011-12-02 A | 2012-09-07 A | 100% |  | 2011-12-02 | 2012-09-07 | 203d? |  | finish no earlier than 2012-09-07 | C4 | 1608h | 1608h | SaMOG_WLAN-CN | PCG-28 | Alcatel-Lucent | bruno.landais@alcatel-lucent.com | Rel-11 | CP-54 |  |  |  |  |
| 417 | 150.2.2 | (IETF) CT4 part of CN aspects of Mobility based On GTP & PMIPv6 for WLAN access to EPC | 167d? | 2012-04-23 A | 2012-12-07 | 50% | 83.5d? | 2012-04-23 | 2012-12-07 | 167d? | 463d | finish no earlier than 2012-12-07 | C4-IETF | 1336h | 668h | SaMOG_WLAN-CN | PCG-29 | Lionel Morand |  | Rel-11 | CP-56 |  |  |  |  |
| 418 | 150.2.3 | Deleted - CT1 part of CN aspects of Mobility based On GTP & PMIPv6 for WLAN access to EPC | 142d? | 2011-12-02 A | 2012-06-15 A | 100% |  | 2011-12-02 | 2012-06-15 | 142d? |  | finish no earlier than 2012-06-15 | C1 | 1128h | 1128h | SaMOG_WLAN-CN | PCG-28 | Alcatel-Lucent | bruno.landais@alcatel-lucent.com | Rel-11 | CP-54 |  |  | PCG-29 | CP-56 |
| 419 | 150.2.4 | CT3 part of CN aspects of Mobility based On GTP & PMIPv6 for WLAN access to EPC | 142d? | 2011-12-02 A | 2012-06-15 A | 100% |  | 2011-12-02 | 2012-06-15 | 142d? |  | finish no earlier than 2012-09-07 | C3 | 1128h | 1128h | SaMOG_WLAN-CN | PCG-28 | Alcatel-Lucent | bruno.landais@alcatel-lucent.com | Rel-11 | CP-54 |  |  |  |  |

Notes:
- 392: CP#56 completed. Linked to Rel-10 UID_450053 Enhanced Home NodeB / eNodeB (EHNB). Implements Rel-9 requirements for CSG support in SA1 TS 22.220
- 393: SP#54 completed / Text3: 23.002, 23.060, 23.401
- 394: CP#57 completed / Text3: 23.003, 23.007, 23.008, 23.012, 29.002, 29.230, 29.272
- 395: Linked to Rel-10 IFOM (IP Flow Mobility and seamless WLAN offload) UID_450041. Defines IP flow mobility, seamless and non seamless WLAN offload and respective ANDSF extensions / Text3: Stage 2/3
- 396: SP#54 completed / Text3: New TR 23.855
- 397: SP#55 completed / Text3: 23.402
- 398: Stage 3. CP#57 completion 09/12=>12/12 (exception in CP-120553) / Text3: 24.302, 24.312
- 399: CP#56 completed. Related to UID_350027 SAE for support for non-3GPP accesses (SAES-SA-FP_n3GPP). Enhancements to ePDG and PDN GW selection functions for S2b and S2c based on UE location
- 400: SP#54 completed / Text3: 23.402
- 401: Stage 3. CP#56 completed / Text3: Stage 3
- 402: CP#56 completed / Text3: 29.273
- 403: CP#56 stopped / Text3: 24.302
- 404: Stage 1 in Rel-8 TS 22.278 clause 7.1.4.2. Triggered by Rel-11 TR 23.885 Study on Single Radio Voice Call Continuity from UTRAN/GERAN to E-UTRAN/HSPA (FS_rSRVCC) UID_460030
- 405: SP#56 completed / Text3: 23.216, 23.237
- 406: CP#57 completed / Text3: Stage 3
- 407: CP#57 completed / Text3: 23.009, 24.008, 24.229, 24.237, 24.292, 24.301
- 408: CP#57 completed / Text3: 29.165, 29.292
- 409: CP#57 completed / Text3: 23.003, 23.008, 29.002, 29.230, 29.272, 29.280, 29.303, 29.305, 29.328
- 410: Stage 3. GP#55 completion 08/12=>11/12 (exception in GP-121116). GP#51 approved WID / Text3: 44.018, 48.008
- 411: - / Text3: UTRA
- 412: RP#57 completion 09/12=>12/12 (exception in RP-121252) / Text3: 25.331, 25.401, 25.413
- 413: Triggered by Rel-11 TR 23.852 FS_SaMOG UID_510061, Rel-8 UID_350027 SAE for support for non-3GPP accesses (defines PMIP-S2a) / Text3: Stage 2/3
- 414: SP#55 completed / Text3: 23.002, 23.203, 23.402
- 415: - / Text3: Stage 3
- 416: CP#57 completed / Text3: 23.003, 23.007, 23.008, 29.273, 29.274, 29.281, 29.303
- 417: Not completed internet-draft / Text3: draft-ietf-radext-ieee802ext
- 418: CP#56 stopped (no CT1 impact) / Text3: 24.302
- 419: CP#56 completed / Text3: 29.212, 29.213, 29.215

| ID | WBS | Task | Duration | Start | Finish | Complete | Remaining | Baseline start | Baseline finish | Baseline duration | Total slack | Constraint | Resources | Work | Actual work | Text1 | Text2 | Text3 | Text4 | Text6 | Text7 | Text11 | Text8 |
| --- | --- | --- | --- | --- | --- | --- | --- | --- | --- | --- | --- | --- | --- | --- | --- | --- | --- | --- | --- | --- | --- | --- | --- |
| 420 | 151 | **Roaming Architecture for Voice over IMS with Local Breakout** | 271d? | 2011-11-28 A | 2012-12-07 | 92% | 22.28d? | 2011-11-28 | 2012-12-07 | 271d? | 463d |  | S2,S5,C1,C3 | 8680h | 6990.58h | RAVEL | PCG-28 | Stage 2/3 | Deutsche Telekom | Rel-11 | SP-54 |  |  |
| 421 | 151.1 | Stage 2 for Roaming Architecture for Voice over IMS with Local Breakout | 12d? | 2011-11-28 A | 2011-12-14 A | 100% |  | 2011-11-28 | 2011-12-14 | 12d? |  | finish no earlier than 2012-03-07 | S2 | 96h | 96h | RAVEL | PCG-28 | 23.002, 23.228 | Deutsche Telekom | Rel-11 | SP-54 |  |  |
| 422 | 151.2 | Charging for Roaming Architecture for Voice over IMS with Local Breakout | 196d? | 2011-12-14 A | 2012-09-12 A | 100% |  | 2011-12-14 | 2012-09-12 | 196d? |  | finish no earlier than 2012-09-12 | S5 | 1568h | 1568h | RAVEL-CH | PCG-28 | 32.240, 32.260, 32.298, 32.299 | Nokia Siemens Networks | Rel-11 | SP-54 |  |  |
| 423 | 151.3 | **CT aspects of Roaming Architecture for Voice over IMS with Local Breakout (Stage 3)** | 203d? | 2012-03-02 A | 2012-12-07 | 88% | 25.24d? | 2012-03-02 | 2012-12-07 | 203d? | 463d |  | C1,C3 | 4848h | 3336.83h | RAVEL-CT | PCG-28 | Stage 3 | Deutsche Telekom | Rel-11 | CP-55 |  |  |
| 424 | 151.3.1 | CT1 part of CT aspects of Roaming Architecture for Voice over IMS with Local Breakout | 203d? | 2012-03-02 A | 2012-12-07 | 85% | 30.3d? | 2012-03-02 | 2012-12-07 | 203d? | 463d | finish no earlier than 2012-12-07 | C1 | 1608h | 1365.6h | RAVEL-CT | PCG-28 | 24.229, 24.292, 24.237 | Deutsche Telekom | Rel-11 | CP-55 | CP-120554 |  |
| 425 | 151.3.2 | CT3 part of CT aspects of Roaming Architecture for Voice over IMS with Local Breakout | 203d? | 2012-03-02 A | 2012-12-07 | 90% | 20.2d? | 2012-03-02 | 2012-12-07 | 203d? | 463d | finish no earlier than 2012-12-07 | C3 | 1616h | 1454.4h | RAVEL-CT | PCG-28 | 29.165, 29.162, 29.079 | Deutsche Telekom | Rel-11 | CP-55 | CP-120542 |  |
| 426 | 152 | **IMS Overload Control** | 126d? | 2012-06-18 A | 2012-12-07 | 82% | 22.27d? | 2012-06-18 | 2012-12-07 | 126d? | 463d |  | S2,C1,C3 | 4776.02h | 3912.42h | IOC | PCG-29 | Stage 2/3 | Orange, China Mobile | Rel-11 | SP-56 |  |  |
| 427 | 152.1 | Stage 2 for IMS Overload Control | 64d? | 2012-06-18 A | 2012-09-12 A | 100% |  | 2012-06-18 | 2012-09-12 | 64d? |  | finish no earlier than 2012-09-12 | S2 | 504h | 504h | IOC | PCG-29 | 23.228 | Orange, China Mobile | Rel-11 | SP-56 |  |  |
| 428 | 152.2 | **Stage 3 for IMS Overload Control** | 68d? | 2012-09-05 A | 2012-12-07 | 79% | 14.28d? | 2012-09-05 | 2012-12-07 | 68d? | 463d |  | C1,C3 | 3264.02h | 2578.57h | IOC | PCG-29 |  | Alcatel-Lucent | Rel-11 | CP-57 |  |  |
| 429 | 152.2.1 | CT1 part of Stage 3 for IMS Overload Control | 68d? | 2012-09-05 A | 2012-12-07 | 95% | 3.4d? | 2012-09-05 | 2012-12-07 | 68d? | 463d | finish no earlier than 2012-12-07 | C1 | 544h | 516.8h | IOC | PCG-29 | 24.229 | Alcatel-Lucent | Rel-11 | CP-57 | CP-120558 |  |
| 430 | 152.2.2 | CT3 part of Stage 3 for IMS Overload Control | 68d? | 2012-09-05 A | 2012-12-07 | 75% | 17d? | 2012-09-05 | 2012-12-07 | 68d? | 463d | start no earlier than 2012-09-05 | C3 | 544h | 408h | IOC | PCG-29 | 29.165 | Alcatel-Lucent | Rel-11 | CP-57 | CP-120541 |  |
| 431 | 152.2.3 | (IETF) CT3 part of Stage 3 for IMS Overload Control | 68d? | 2012-09-05 A | 2012-12-07 | 75% | 17d? | 2012-09-05 | 2012-12-07 | 68d? | 463d | finish no earlier than 2012-12-07 | C1-IETF,C3-IETF | 544h | 408h | IOC | PCG-29 | draft-ietf-soc-overload-control | Keith Drage | Rel-11 | CP-57 |  |  |
| 432 | 152.2.4 | (IETF) CT3 part of Stage 3 for IMS Overload Control | 68d? | 2012-09-05 A | 2012-12-07 | 75% | 17d? | 2012-09-05 | 2012-12-07 | 68d? | 463d | finish no earlier than 2012-12-07 | C1-IETF,C3-IETF | 544h | 408h | IOC | PCG-29 | draft-ietf-soc-overload-rate-control | Keith Drage | Rel-11 | CP-57 |  |  |
| 433 | 152.2.5 | (IETF) CT3 part of Stage 3 for IMS Overload Control | 68d? | 2012-09-05 A | 2012-12-07 | 75% | 17d? | 2012-09-05 | 2012-12-07 | 68d? | 463d | start no earlier than 2012-09-05 | C1-IETF,C3-IETF | 544h | 408h | IOC | PCG-29 | draft-ietf-soc-load-control-event-package | Keith Drage | Rel-11 | CP-57 |  |  |
| 434 | 153 | Rel-11 Security small Enhancements | 336d? | 2011-06-08 A | 2012-09-12 A | 100% |  | 2011-06-08 | 2012-09-12 | 336d? |  | finish no earlier than 2012-09-12 | S3 | 2680h | 2680h | SEC11 | PCG-27 |  |  | Rel-11 | SP-52 |  | Dionisio |
| 435 | 154 | Lawful Interception in the 3GPP Rel-11 | 272d? | 2011-06-10 A | 2012-06-20 A | 100% |  | 2011-06-10 | 2012-06-20 | 272d? |  | finish no earlier than 2012-06-20 | S3 | 2176h | 2176h | LI11 | PCG-27 | 33.106, 33.107, 33.108 | PIDS, Alcatel-Lucent | Rel-11 | SP-52 |  | Dionisio |
| 436 | 155 | **ZUC EEA3 and EIA3 (new Encryption & Integrity EPS security Algorithms)** | 857d? | 2009-06-04 A | 2012-09-07 A | 100% |  | 2009-06-04 | 2012-09-07 | 857d? |  |  | S3,R5 | 7328h | 7328h | EEA3_EIA3 | PCG-23 |  | CATR | Rel-11 | SP-44 |  | Dionisio |
| 437 | 155.1 | ZUC EEA3 and EIA3 (new Encryption & Integrity EPS security Algorithms) | 663d? | 2009-06-04 A | 2011-12-14 A | 100% |  | 2009-06-04 | 2011-12-14 | 663d? |  | finish no earlier than 2011-09-21 | S3 | 5288h | 5288h | EEA3_EIA3 | PCG-23 | 33.401, new (35.221, 35.222, 35.223, 35.924) | CATR | Rel-11 | SP-44 |  | Dionisio |
| 438 | 155.2 | Conformance Test Aspects – ZUC (EEA3 and EIA3 Encryption & Integrity EPS security Algorithms) | 61d? | 2012-06-18 A | 2012-09-07 A | 100% |  | 2012-06-18 | 2012-09-07 | 61d? |  | finish no earlier than 2013-03-01 | R5 | 488h | 488h | EEA3_EIA3_UEConTest | PCG-29 | 36.523-1, 36.523-2, 36.523-3 | CATR | Rel-11 | RP-56 | RP-120968 |  |
| 439 | 156 | Specification of Protection against Unsolicited Communication for IMS (produced TR-only) | 456d? | 2010-06-10 A | 2012-03-07 A | 100% |  | 2010-06-10 | 2012-03-07 | 456d? |  | finish no earlier than 2012-03-07 | S3 | 3640h | 3640h | SPUCI | PCG-25 | new TR 33.838, abandoned new TS 33.237 | NEC | Rel-11 | SP-48 |  | Dionisio |
| 440 | 157 | H(e)NB security features for UE mobility scenarios (Stage 2) | 252d? | 2011-03-23 A | 2012-03-07 A | 100% |  | 2011-03-23 | 2012-03-07 | 252d? |  | finish no earlier than 2012-03-07 | S3 | 2008h | 2008h | HNB_mob_Sec | PCG-26 | 33.320 Stage 2 | Huawei | Rel-11 | SP-51 |  | Dionisio |
| 441 | 158 | **Generic Bootstrapping Architecture (GBA) extensions for re-use of SIP Digest credentials** | 203d? | 2011-12-02 A | 2012-09-07 A | 100% |  | 2011-12-02 | 2012-09-07 | 203d? |  |  | S3,C4,C1 | 6952h | 6952h | GBA-ext | PCG-28 |  | Nokia | Rel-11 | SP-54 |  |  |
| 442 | 158.1 | Stage 2 for GBA extensions for re-use of SIP Digest credentials | 61d? | 2011-12-14 A | 2012-03-07 A | 100% |  | 2011-12-14 | 2012-03-07 | 61d? |  | finish no earlier than 2012-02-28 | S3 | 488h | 488h | GBA-ext | PCG-28 | 33.220 | Nokia | Rel-11 | SP-54 |  |  |
| 443 | 158.2 | **Stage 3 for GBA extensions for re-use of SIP Digest credentials** | 203d? | 2011-12-02 A | 2012-09-07 A | 100% |  | 2011-12-02 | 2012-09-07 | 203d? |  |  | C4,C1 | 4840h | 4840h | GBA-ext-St3 | PCG-28 | Stage 3 | Alcatel-Lucent | Rel-11 | CP-54 |  |  |
| 444 | 158.2.1 | CT4 part of Stage 3 for GBA extensions for re-use of SIP Digest credentials | 203d? | 2011-12-02 A | 2012-09-07 A | 100% |  | 2011-12-02 | 2012-09-07 | 203d? |  | finish no earlier than 2012-09-07 | C4 | 1608h | 1608h | GBA-ext-St3 | PCG-28 | 29.109 | Alcatel-Lucent | Rel-11 | CP-54 |  |  |
| 445 | 158.2.2 | CT1 part of Stage 3 for GBA extensions for re-use of SIP Digest credentials | 202d? | 2011-12-05 A | 2012-09-07 A | 100% |  | 2011-12-05 | 2012-09-07 | 202d? |  | finish no earlier than 2012-09-07 | C1 | 1608h | 1608h | GBA-ext-St3 | PCG-28 | 24.109 | Alcatel-Lucent | Rel-11 | CP-54 |  |  |
| 446 | 159 | Extensions of Acoustic Test Specifications in TS 26.131 and TS 26.132 | 332d? | 2011-06-08 A | 2012-09-12 A | 100% |  | 2011-06-08 | 2012-09-12 | 332d? |  | finish no earlier than 2012-09-12 | S4 | 2648h | 2648h | Ext_ATS | PCG-27 | 26.131, 26.132 | Orange, Qualcomm | Rel-11 | SP-52 |  | Paolo |

Notes:
- 420: SP#54 Stage 2 completed. Triggered by Rel-11 TR 23.850 Study on Roaming Architecture for Voice over IMS with Local Breakout (FS_RAVEL). GSMA CPWP LS_in S5-102806 asked 3GPP SA5 to check if CS voice charging principles also apply to voice over IMS / Text5: michele.zarri@telekom.com
- 421: SP#54 completed / Text5: michele.zarri@telekom.com
- 422: Stage 2/3. SP#57 completed / Text5: Gerald.Goermer@nsn.com
- 423: - / Text5: reinhard.lauster@)t-mobile.at
- 424: CP#57 completion 09/12=>12/12 (exception in CP-120554) / Text5: reinhard.lauster@)t-mobile.at
- 425: CP#57 completion 09/12=>12/12 (exception in CP-120542). Work can only begin when CT1 has decided the technical solution / Text5: reinhard.lauster@)t-mobile.at
- 426: SP#57 Stage 2 completed. Moved Rel-12=>Rel-11 as CT finished Stage 3. Linked to UID_410041 Study on IMS Evolution (TR 23.812). Solutions from IETF SOC WG and existing 3GPP procedures to be re-used if possible & backward compatibility ensured / Text5: Antoine MOUQUET, YU Qing
- 427: SP#57 completed. Moved Rel-12=>Rel-11 as CT finished Stage 3. / Text5: antoine.mouquet@orange-ftgroup.com, YU Qing
- 428: - / Text5: Keith Drage
- 429: CP#57 exception in CP-120558 / Text5: Keith Drage
- 430: CP#57 exception in CP-120541 / Text5: Keith Drage
- 431: Not completed internet-draft
- 432: Not completed internet-draft
- 433: Not completed internet-draft
- 434: SEC11 is an umbrella Feature for Security related TEI11 type of changes that are not part of any other dedicated feature
- 435: Stage 1/2/3. SP#56 completed / Text5: Koen Jaspers (k.b.jaspers@minjus.nl), terry.jacobson@alcatel-lucent.com
- 436: RP#57 completed testing / Text5: Yuan Qi (yuanqi@catr.cn)
- 437: SP#53 completed new EPS algorithms e.g. for China / Text5: Yuan Qi (yuanqi@catr.cn)
- 438: RP#57 completed. Testing for SA3 TSs 33.401, new (35.221, 35.222, 35.223) / Text5: Ms Jun Chen (chenjun@catr.cn)
- 439: SP#55 completed (No normative work). TR 33.838v200 for Approval & abandoned new TS 33.237. Continuation of Rel-9 UID_410027/410029. Builds on TR 33.937 Study of Mechanisms for PUCI / Text5: Anand R. Prasad (anand@bq.jp.nec.com)
- 440: SP#55 completed. Add HeNB Security extensions to Extended H(e)NB Features (EHNBF) UID_450053 / Text5: Marcus Wong (mwong@huawei.com)
- 441: Stage 2/3. CP#57 completed / Text5: Silke.Holtmanns@nokia.com
- 442: SP#55 completed / Text5: Silke.Holtmanns@nokia.com
- 443: CP#57 completed / Text5: jean-jacques.trottin@alcatel-lucent.com
- 444: CP#57 completed / Text5: jean-jacques.trottin@alcatel-lucent.com
- 445: CP#57 completed / Text5: jean-jacques.trottin@alcatel-lucent.com
- 446: SP#57 completed / Text5: stephane.ragot@orange-ftgroup.com, Andre Schevciw (aschevci@qualcomm.com)

| ID | WBS | Task | Duration | Start | Finish | Complete | Remaining | Baseline start | Baseline finish | Baseline duration | Total slack | Constraint | Resources | Work | Actual work | Text1 | Text2 | Text4 | Text6 | Text7 | Text11 | Text8 |
| --- | --- | --- | --- | --- | --- | --- | --- | --- | --- | --- | --- | --- | --- | --- | --- | --- | --- | --- | --- | --- | --- | --- |
| 447 | 160 | **Enhancements to Multimedia: PSS, MMS, and MBMS Enhancements and Performance Improvements** | 334d? | 2011-09-07 A | 2012-12-12 | 84% | 53.04d? | 2011-09-07 | 2012-12-12 | 334d? | 460d |  | S4 | 9944.59h | 8359.06h | EMM | PCG-27 | Qualcomm | Rel-11 | SP-53 |  |  |
| 448 | 160.1 | Enhancement to FEC for MBMS | 323d? | 2011-09-21 A | 2012-12-12 | 80% | 64.4d? | 2011-09-21 | 2012-12-12 | 323d? | 460d | finish no earlier than 2012-12-12 | S4 | 2568h | 2052.8h | EMM-EFEC | PCG-27 | Qualcomm | Rel-11 | SP-53 | SP-120507 |  |
| 449 | 160.2 | Download Delivery Enhancements for MBMS | 323d? | 2011-09-21 A | 2012-12-12 | 75% | 80.75d? | 2011-09-21 | 2012-12-12 | 323d? | 460d | finish no earlier than 2012-12-12 | S4 | 2576.59h | 1930.59h | EMM-DDE | PCG-27 | Qualcomm | Rel-11 | SP-53 | SP-120506 |  |
| 450 | 160.3 | IMS-based PSS and MBMS Streaming Synchronization Enhancements | 268d? | 2011-09-07 A | 2012-09-12 A | 100% |  | 2011-09-07 | 2012-09-12 | 268d? |  | finish no earlier than 2012-09-12 | S4 | 2128h | 2128h | EMM-IPME | PCG-27 | InterDigital Communications | Rel-11 | SP-53 |  |  |
| 451 | 161 | Mobile 3D Video Coding | 71d? | 2012-06-07 A | 2012-09-12 A | 100% |  | 2012-06-07 | 2012-09-12 | 71d? |  | finish no earlier than 2012-09-12 | S4 | 560h | 560h | M3DV | PCG-29 | Orange | Rel-11 | SP-56 |  |  |
| 452 | 162 | **Rel-11 Operations, Administration, Maintenance and Provisioning (OAM&P)** | 456d? | 2011-03-23 A | 2012-12-12 | 69% | 140.96d? | 2011-03-23 | 2012-12-12 | 456d? | 460d |  | S5 | 39482.5h | 25249.4h | OAM11 | PCG-26 |  | Rel-11 | SP-51 |  | Dionisio |
| 453 | 162.1 | **Rel-11 Network Infrastructure Management** | 456d? | 2011-03-23 A | 2012-12-12 | 42% | 262.92d? | 2011-03-23 | 2012-12-12 | 456d? | 460d |  | S5 | 12440h | 5258.26h | OAM11-NIM | PCG-26 |  | Rel-11 | SP-51 |  | Dionisio |
| 454 | 162.1.1 | IRP framework enhancements to support Management of Converged Networks | 453d? | 2011-03-23 A | 2012-12-12 | 60% | 181.2d? | 2011-03-23 | 2012-12-12 | 453d? | 460d | finish no earlier than 2012-12-12 | S5 | 3624h | 2174.4h | OAM-FMC-IRP | PCG-26 | Nokia Siemens Networks, Ericsson | Rel-11 | SP-51 | SP-120582 | Dionisio |
| 455 | 162.1.2 | Management of Carrier Aggregation for LTE | 324d? | 2011-09-21 A | 2012-12-12 | 40% | 194.4d? | 2011-09-21 | 2012-12-12 | 324d? | 460d | finish no earlier than 2012-12-12 | S5 | 2584h | 1028.8h | OAM-CA | PCG-27 | Nokia Siemens Networks, Ericsson | Rel-11 | SP-53 | SP-120581 |  |
| 456 | 162.1.3 | Network Management for 3GPP Interworking WLAN | 324d? | 2011-09-21 A | 2012-12-12 | 20% | 259.2d? | 2011-09-21 | 2012-12-12 | 324d? | 460d | finish no earlier than 2012-12-12 | S5 | 2584h | 510.4h | OAM-IWLAN | PCG-27 | China Mobile | Rel-11 | SP-53 | SP-120578 |  |
| 457 | 162.2 | **Rel-11 Performance Management** | 456d? | 2011-03-23 A | 2012-12-12 | 87% | 59.71d? | 2011-03-23 | 2012-12-12 | 456d? | 460d |  | S5 | 11930.5h | 9702.43h | OAM11-PM | PCG-26 |  | Rel-11 | SP-51 |  | Dionisio |
| 458 | 162.2.1 | IMS Performance Management enhancements | 252d? | 2011-03-23 A | 2012-03-07 A | 100% |  | 2011-03-23 | 2012-03-07 | 252d? |  | finish no earlier than 2012-09-12 | S5 | 2010.52h | 2010.52h | OAM-ePM-IMS | PCG-26 | ZTE | Rel-11 | SP-51 |  | Dionisio |
| 459 | 162.2.2 | Enhanced Management of UE based network performance measurements | 454d? | 2011-03-23 A | 2012-12-12 | 70% | 136.2d? | 2011-03-23 | 2012-12-12 | 454d? | 460d | finish no earlier than 2012-12-12 | S5 | 3624h | 2534.4h | OAM-ePM-UE | PCG-26 | Huawei, Ericsson, Nokia Siemens Networks | Rel-11 | SP-51 | SP-120577 | Dionisio |
| 460 | 162.2.3 | CN performance measurements enhancement | 334d? | 2011-06-08 A | 2012-09-12 A | 100% |  | 2011-06-08 | 2012-09-12 | 334d? |  | finish no earlier than 2012-09-12 | S5 | 2648h | 2648h | OAM-ePM-CN | PCG-27 | China Mobile | Rel-11 | SP-52 |  | Dionisio |
| 461 | 162.3 | **Rel-11 Self-Organizing Networks (SON) - OAM aspects** | 456d? | 2011-03-23 A | 2012-12-12 | 80% | 90.18d? | 2011-03-23 | 2012-12-12 | 456d? | 460d |  | S5 | 11464h | 8465.89h | OAM11-SON | PCG-26 |  | Rel-11 | SP-51 |  | Dionisio |
| 462 | 162.3.1 | UTRAN Self-Organizing Networks (SON) management | 388d? | 2011-03-23 A | 2012-09-12 A | 100% |  | 2011-03-23 | 2012-09-12 | 388d? |  | finish no earlier than 2012-09-12 | S5 | 3088h | 3088h | OAM-SON-UTRAN | PCG-26 | Huawei | Rel-11 | SP-51 |  | Dionisio |
| 463 | 162.3.2 | LTE Self-Organizing Networks (SON) coordination management | 324d? | 2011-09-21 A | 2012-12-12 | 65% | 113.4d? | 2011-09-21 | 2012-12-12 | 324d? | 460d | finish no earlier than 2012-12-12 | S5 | 2584h | 1676.8h | OAM-SON-LTE_COORD | PCG-27 | Huawei, Nokia Siemens Networks | Rel-11 | SP-53 | SP-120579 |  |
| 464 | 162.3.3 | Inter-RAT Energy Saving Management | 268d? | 2011-12-07 A | 2012-12-12 | 70% | 80.4d? | 2011-12-07 | 2012-12-12 | 268d? | 460d | finish no earlier than 2012-12-12 | S5 | 2144h | 1500.8h | OAM-IRAT-ESM | PCG-28 | Nokia Siemens Networks, Huawei | Rel-11 | SP-54 | SP-120580 |  |
| 465 | 163 | **Rel-11 Charging Management small Enhancements** | 715d? | 2010-03-25 A | 2012-12-12 | 92% | 59.42d? | 2010-03-25 | 2012-12-12 | 715d? | 460d |  | S5 | 11512h | 10551.8h | CH11 | PCG-26 |  | Rel-11 | SP-51 |  | Dionisio |
| 466 | 163.1 | Add solutions for Rc - reference point within the Online Charging System (OCS) | 392d? | 2010-03-25 A | 2011-09-21 A | 100% |  | 2010-03-25 | 2011-09-21 | 392d? |  | finish no earlier than 2011-08-26 | S5 | 3120h | 3120h | CH-Rc | PCG-24 | Huawei | Rel-11 | SP-47 |  | Dionisio |
| 467 | 163.2 | Charging for Policy Enhancements for Sponsored Connectivity and Coherent Access to Policy related Data Bases | 135d? | 2011-03-21 A | 2011-09-21 A | 100% |  | 2011-03-21 | 2011-09-21 | 135d? |  | finish no earlier than 2011-09-21 | S5 | 1064h | 1064h | PEST-CH | PCG-26 | Ericsson | Rel-11 | SP-51 |  | Dionisio |
| 468 | 163.3 | Unification of Charging session from SIP AS and SRVCC functions in IMS | 202d? | 2012-03-07 A | 2012-12-12 | 70% | 60.6d? | 2012-03-07 | 2012-12-12 | 202d? | 460d | finish no earlier than 2012-12-12 | S5 | 1608h | 1123.2h | UCHIMS_AS-SRVCC | PCG-28 | Alcatel-Lucent | Rel-11 | SP-55 | SP-120584 |  |
| 469 | 164 | **Transit Inter Operator Identifier for IMS Interconnection Charging in multi operator environment** | 432d? | 2010-10-27 A | 2012-06-15 A | 100% |  | 2010-10-27 | 2012-06-15 | 432d? |  |  | S5,S1,C1 | 9009.09h | 9009.09h | IOI_IMS_CH | PCG-26 | Deutsche Telekom | Rel-11 | SP-51 |  | Dionisio |
| 470 | 164.1 | Stage 1 for Transit Inter Operator Identifier for IMS Interconnection Charging in multi operator environment | 237d? | 2010-10-27 A | 2011-09-21 A | 100% |  | 2010-10-27 | 2011-09-21 | 237d? |  |  | S1 | 1896h | 1896h | IOI_IMS_CH | PCG-26 | Deutsche Telekom | Rel-11 | SP-51 |  | Dionisio |
| 471 | 164.2 | Stage 2/3 SA5 part of Transit Inter Operator Identifier for IMS Interconnection Charging in multi operator environment | 187d? | 2010-10-27 A | 2011-12-07 A | 100% |  | 2010-10-27 | 2011-12-07 | 187d? |  | finish no earlier than 2012-03-21 | S5 | 1488h | 1488h | IOI_IMS_CH | PCG-26 | Deutsche Telekom | Rel-11 | SP-51 |  | Dionisio |
| 472 | 164.3 | Stage 3 for Transit Inter Operator Identifier for IMS Interconnection Charging in multi operator environment | 273d? | 2011-06-07 A | 2012-06-15 A | 100% |  | 2011-06-07 | 2012-06-15 | 273d? |  | finish no earlier than 2012-06-01 | C1 | 2169.09h | 2169.09h | IOI_IMS_CH | PCG-27 | Deutsche Telekom | Rel-11 | CP-52 |  | Frederic |

Notes:
- 447: Stage 3. SP#57 TR 26.951 v100 for Information / Text3: 26.140, 26.234, 26.247, new TR 26.951 / Text5: Nikolai Leung (nleung@qualcomm.com)
- 448: SP#57 completion 09/12=>12/12. Exception sheet SP-120507. SP#56 TR 26.947 v100 for Information / Text3: 26.346, new TR 26.947 / Text5: Thomas Stockhammer (c_tstock@qualcomm.com)
- 449: SP#57 completion 09/12=>12/12. Exception sheet SP-120506. TR 26.951 v100 for Information / Text3: 26.346, new TR 26.951 / Text5: Nikolai Leung (nleung@qualcomm.com)
- 450: SP#57 completed. TR 26.951 v100 for Information (IPME part completed) / Text3: 26.237, new TR 26.951 / Text5: hang.liu@interdigital.com
- 451: SP#57 completed. Triggered by UID_520036 Rel-11 Study on Mobile 3D Video Coding (FS_M3DVC) TR 26.905. / Text3: 26.140, 26.234, 26.244, 26.245, 26.247, 26.346, 26.430, 26.905 / Text5: gilles.teniou@orange.com
- 452: OAM11 is an umbrella Feature also for OAM&P related TEI11 type of changes that are not part of any other dedicated feature/WI
- 453: -
- 454: SP#57 updated WID SP-110139=>SP-120553. Completion 09/12=>12/12 (exception in SP-120582). TR 32.853 v100 for Information & Approval. 32.107,32.156,28.620,28.621,28.622,28.623,32.854 v100 for Information. Triggered by SA5 Studies TR 32.833, 32.828, 32.831 / Text3: 32.101/103/150, new (28.620/621/622/623/624/625/626/627/628/629/631/632/633/651/652/653/654/655/656/657/658/659/661/662/663/664/665/666/671/672/673/674/675/676/701/702/703/704/705/706/707/708/709/731/732/733/734/735/736/751/752/753, 32.107/156/157/853/854 / Text5: thomas.tovinger@ericsson.com, olaf.pollakowski@nsn.com
- 455: SP#57 completion 09/12=>12/12 (exception in SP-120581). Stage 2 in Rel-10 RAN Feature UID_460007 Carrier Aggregation for LTE (LTE_CA). WT under 3 SA5 Rel-11 BBs (NIM, PM, SON) / Text3: 32.425, 32.450, 32.451, 32.501, 32.502, 32.506, 32.511, 32.521, 32.522, 32.526, 32.541, 32.551, 32.761, 32.762, 32.766 / Text5: yizhi.yao@nsn.com, per.elmdahl@ericsson.com
- 456: SP#57 SP-120578 exception. Stage 2 in Rel-6 WLAN-UMTS Interworking (WLAN) 23.234, Rel-7 WLAN Interworking Private Network access from WLAN 3GPP IP Access (WLANPNA) 23.234, Rel-8 Mobility between 3GPP-WLAN Interworking and 3GPP Systems (IWLAN_Mob) 23.327 / Text3: 32.632, 32.636, 32.752, 32.756, 8 new TS (3GPP interworking WLAN NRM IRP: Reqs, IS, SS, Performance measurements) / Text5: Chengang@chinamobile.com, lijian@chinamobile.com
- 457: -
- 458: SP#55 completed / Text3: 32.409 / Text5: guo.wenjie1@zte.com.cn
- 459: SP#57 completion 09/12=>12/12 (exception in SP-120577) / Text3: 32.421, 32.422, 32.423, 32.441, 32.442, 32.446 / Text5: Zou Lan (zlan@huawei.com), ulf.hubinette@ericsson.com, gyula.bodog@nsn.com
- 460: SP#57 completed / Text3: 32.406, 32.407, 32.426 / Text5: Liang Shuangchun (liangshuangchun@cmdi.chinamobile.com), Li Jian (lijian@chinamobile.com)
- 461: -
- 462: SP#57 completed. Updated WID SP-110518=>SP-120552 / Text3: UTRA 32.405, 32.500, 32.511, 32.521, 32.522, 32.526, 32.642, 32.646 / Text5: kai.zhangkai@huawei.com
- 463: SP#57 completion 09/12=>12/12 (exception in SP-120579) / Text3: LTE 32.425, 32.500, 32.521, 32.522, 32.526, 32.762, 32.766 / Text5: kai.zhangkai@huawei.com, clemens.suerbaum@nsn.com
- 464: SP#57 completion 09/12=>12/12 (exception in SP-120580). Triggered by Rel-11 TR 32.834 (Study on OAM aspects of inter-RAT Energy Saving) UID_510045. Needs coordination with RAN WGs / Text3: 32.405, 32.551, 32.522, 32.526, 32.642, 32.646, 32.762, 32.766 / Text5: clemens.suerbaum@nsn.com, xiahaitao@huawei.com
- 465: CH11 is an umbrella Feature also for OAM&P related TEI11 type of changes that are not part of any other dedicated feature/WI / Text3: TR 30.821
- 466: SP#53 completed. Stage 3 (Stage 1 in 22.115). Triggered by Rel-10 TR 32.825 SA5 Study on Rc Reference Point Functionalities and Message Flows (UID_410044) / Text3: 32.296, 32.299 / Text5: shan.mingjun@huawei.com
- 467: SP#53 completed. Stage 3 / Text3: 32.251, 32.298, 32.299 / Text5: patrik.teppo@@ericsson.com
- 468: SP#57 completion 09/12=>12/12 (exception in SP-120584). Stage 2/3 / Text3: 32.260, 32.275, 32.298, 32.299 / Text5: maryse.gardella@alcatel-lucent.com
- 469: Stage 2/3. CP#56 completed. Stage 1 in SA1 22.115 / Text5: matthias.seibel@telekom.de
- 470: SP#53 completed under IPXS / Text3: 22.115 / Text5: matthias.seibel@telekom.de
- 471: SP#54 completed / Text3: 32.240, 32.260, 32.298, 32.299 / Text5: matthias.seibel@telekom.de
- 472: CP#56 completed / Text3: 24.229 / Text5: martin.huelsemann@telekom.de]

| ID | WBS | Task | Type | Duration | Start | Finish | Complete | Remaining | Baseline start | Baseline finish | Baseline duration | Total slack | Constraint | Resources | Work | Actual work | Text1 | Text2 | Text4 | Text5 | Text6 | Text7 | Text8 | Text3 | Text11 | Text9 | Text12 |
| --- | --- | --- | --- | --- | --- | --- | --- | --- | --- | --- | --- | --- | --- | --- | --- | --- | --- | --- | --- | --- | --- | --- | --- | --- | --- | --- | --- |
| 473 | 165 | **User Data Convergence - Data Model** |  | 647d? | 2010-03-25 A | 2012-09-07 A | 100% |  | 2010-03-25 | 2012-09-07 | 647d? |  |  | C4,S1 | 17808h | 17808h | UDC_DM | PCG-25 | Telecom Italia | mauro.ficaccio@telecomitalia.it | Rel-11 | CP-48 | Kimmo |  |  |  |  |
| 474 | 165.1 | Stage 1 for UDC Data Model |  | 392d? | 2010-03-25 A | 2011-09-21 A | 100% |  | 2010-03-25 | 2011-09-21 | 392d? |  | finish no earlier than 2010-06-10 | S1 | 3136h | 3136h | UDC_DM | PCG-25 | Telecom Italia | mauro.ficaccio@telecomitalia.it | Rel-11 | CP-48 | Alain | 22.101 |  |  |  |
| 475 | 165.2 | TR on User Data Convergence (UDC) Data Model |  | 593d? | 2010-06-04 A | 2012-09-07 A | 100% |  | 2010-06-04 | 2012-09-07 | 593d? |  | finish no earlier than 2012-09-07 | C4 | 4736h | 4736h | UDC_DM | PCG-25 | Telecom Italia | mauro.ficaccio@telecomitalia.it | Rel-11 | CP-48 | Kimmo | new TR 29.935 |  |  |  |
| 476 | 165.3 | User Data Convergence (UDC) Data Model |  | 596d? | 2010-06-04 A | 2012-09-07 A | 100% |  | 2010-06-04 | 2012-09-07 | 596d? |  | finish no earlier than 2012-09-07 | C4 | 4760h | 4760h | UDC_DM | PCG-25 | Telecom Italia | mauro.ficaccio@telecomitalia.it | Rel-11 | CP-48 | Kimmo | 29.335 |  |  |  |
| 477 | 166 | Definition of the UICC Application for Hosting Party Module |  | 327d? | 2011-03-18 A | 2012-06-15 A | 100% |  | 2011-03-18 | 2012-06-15 | 327d? |  | finish no earlier than 2012-06-15 | C6 | 2608h | 2608h | HPM_UICC | PCG-26 | Gemalto | Denis.Lheriteau@gemalto.com | Rel-11 | CP-51 | Xavier | 31.102, new TS 31.104 |  |  |  |
| 478 | 167 | Usability improvement of Inter-IMS Network to Network Interface (II-NNI) specification for inter-connection by means of Option Item list |  | 273d? | 2011-06-07 A | 2012-06-15 A | 100% |  | 2011-06-07 | 2012-06-15 | 273d? |  | finish no earlier than 2012-06-01 | C3 | 2169.56h | 2169.56h | NNI_OI | PCG-27 | NTT | arai.kenjiro@lab.ntt.co.jp | Rel-11 | CP-52 | Jiwan | 29.165 |  |  |  |
| 479 | 168 | **enhanced Nodes Restoration for EPC** |  | 401d? | 2011-06-03 A | 2012-12-07 | 73% | 110.05d? | 2011-06-03 | 2012-12-07 | 401d? | 463d |  | C4,C1,C3 | 7456h | 3080h | eNR_EPC | PCG-27 | ZTE | lu.fei1@zte.com.cn | Rel-11 | CP-52 | Kimmo |  |  |  |  |
| 480 | 168.1 | CT4 part of enhanced Nodes Restoration for EPC |  | 400d? | 2011-06-03 A | 2012-12-07 | 80% | 80d? | 2011-06-03 | 2012-12-07 | 400d? | 463d | finish no earlier than 2012-12-07 | C4 | 3192h | 2552h | eNR_EPC | PCG-27 | ZTE | lu.fei1@zte.com.cn | Rel-11 | CP-52 | Kimmo | 23.007, 23.008, 23.018, 29.274, 29.275 | CP-120451 |  |  |
| 481 | 168.2 | CT1 part of enhanced Nodes Restoration for EPC |  | 66d? | 2011-12-02 A | 2012-03-02 A | 100% |  | 2011-12-02 | 2012-03-02 | 66d? |  | finish no earlier than 2012-06-15 | C1 | 528h | 528h | eNR_EPC | PCG-28 | ZTE | lu.fei1@zte.com.cn | Rel-11 | CP-54 |  | 29.118 |  |  |  |
| 482 | 168.3 | CT3 part of enhanced Nodes Restoration for EPC |  | 66d? | 2012-09-07 | 2012-12-07 |  |  | 2012-09-07 | 2012-12-07 | 66d? | 463d | finish no earlier than 2012-12-07 | C3 | 528h |  | eNR_EPC | PCG-29 | ZTE | lu.fei1@zte.com.cn | Rel-11 | CP-57 |  | 29.212 | CP-120544 |  |  |
| 483 | 169 | **Reference Location Information** |  | 78d? | 2011-06-03 A | 2011-09-16 A | 100% |  | 2011-06-03 | 2011-09-16 | 78d? |  |  | C4,C1 | 1236.74h | 1236.74h | RLI | PCG-27 | Huawei | susan.shishufeng@Huawei.com | Rel-11 | CP-52 | Kimmo |  |  |  |  |
| 484 | 169.1 | CT4 part of Reference Location Information | milestone | 0d? | 2011-06-03 A | 2011-06-03 A | 100% |  | 2011-06-03 | 2011-06-03 | 0d? |  | finish no earlier than 2011-06-03 | C4 |  |  | RLI | PCG-27 | Huawei | susan.shishufeng@Huawei.com | Rel-11 | CP-52 | Kimmo | 23.008, 29.228, 29.328, 29.329 |  |  |  |
| 485 | 169.2 | CT1 part of Reference Location Information |  | 78d? | 2011-06-03 A | 2011-09-16 A | 100% |  | 2011-06-03 | 2011-09-16 | 78d? |  | finish no earlier than 2011-08-30 | C1 | 612.74h | 612.74h | RLI | PCG-27 | Huawei | susan.shishufeng@Huawei.com | Rel-11 | CP-52 | Frederic | 24.229 |  |  |  |
| 486 | 170 | **IMS Stage 3 IETF Protocol Alignment - phase 5** |  | 334d? | 2011-06-07 A | 2012-09-07 A | 100% |  | 2011-06-07 | 2012-09-07 | 334d? |  |  | C1,C3 | 7968h | 7968h | IMSProtoc5 | PCG-27 | Alcatel-Lucent | keith.drage@alcatel-lucent.com | Rel-11 | CP-52 | Frederic |  |  |  |  |
| 487 | 170.1 | CT1 part of IMS Stage-3 IETF Protocol Alignment |  | 333d? | 2011-06-07 A | 2012-09-07 A | 100% |  | 2011-06-07 | 2012-09-07 | 333d? |  | finish no earlier than 2012-09-07 | C1 | 2648h | 2648h | IMSProtoc5 | PCG-27 | Alcatel-Lucent | keith.drage@alcatel-lucent.com | Rel-11 | CP-52 | Frederic | 23.218, 24.229, 24.930 |  |  |  |
| 488 | 170.2 | CT3 part of IMS Stage-3 IETF Protocol Alignment |  | 333d? | 2011-06-07 A | 2012-09-07 A | 100% |  | 2011-06-07 | 2012-09-07 | 333d? |  | finish no earlier than 2012-09-07 | C3 | 2648h | 2648h | IMSProtoc5 | PCG-27 | Alcatel-Lucent | keith.drage@alcatel-lucent.com | Rel-11 | CP-52 | Jiwan | 29.163, 29.165 |  |  |  |
| 489 | 171 | **Service Identification for RRC Improvements in GERAN (Stage 2/3)** |  | 258d? | 2011-09-19 A | 2012-09-07 A | 100% |  | 2011-09-19 | 2012-09-07 | 258d? |  |  | S2,C4,C3,G2 | 8400h | 8400h | SIRIG | PCG-27 | China Mobile | zhanghao@chinamobile.com | Rel-11 | GP-51 |  | GERAN |  |  |  |
| 490 | 171.1 | Stage 2 for Service Identification for RRC Improvements in GERAN |  | 61d? | 2012-06-18 A | 2012-09-07 A | 100% |  | 2012-06-18 | 2012-09-07 | 61d? |  | finish no earlier than 2012-09-07 | S2 | 480h | 480h | SIRIG | PCG-29 |  |  | Rel-11 | SP-56 |  | 23.060, 23.251 |  |  |  |
| 491 | 171.2 | **CN aspects of Service Identification for RRC Improvements in GERAN** |  | 203d? | 2011-12-02 A | 2012-09-07 A | 100% |  | 2011-12-02 | 2012-09-07 | 203d? |  |  | C4,C3 | 3840h | 3840h | SIRIG | PCG-28 | China Mobile | zhanghao@chinamobile.com | Rel-11 | CP-54 |  |  |  |  |  |
| 492 | 171.2.1 | CT4 part of CN aspects of Service Identification for RRC Improvements in GERAN |  | 203d? | 2011-12-02 A | 2012-09-07 A | 100% |  | 2011-12-02 | 2012-09-07 | 203d? |  | finish no earlier than 2012-09-07 | C4 | 1608h | 1608h | SIRIG | PCG-28 | China Mobile | zhanghao@chinamobile.com | Rel-11 | CP-54 |  | 29.281 |  |  |  |
| 493 | 171.2.2 | Deleted - CT3 part of CN aspects of Service Identification for RRC Improvements in GERAN |  | 77d? | 2012-03-02 A | 2012-06-15 A | 100% |  | 2012-03-02 | 2012-06-15 | 77d? |  | finish no earlier than 2012-06-01 | C3 | 608h | 608h | SIRIG | PCG-28 | China Mobile | zhanghao@chinamobile.com | Rel-11 | CP-55 |  | 29.212 |  | PCG-29 | CP-56 |
| 494 | 171.3 | GERAN2 part of Service Identification for RRC Improvements in GERAN |  | 252d? | 2011-09-19 A | 2012-08-31 A | 100% |  | 2011-09-19 | 2012-08-31 | 252d? |  | finish no earlier than 2012-08-31 | G2 | 2016h | 2016h | SIRIG | PCG-27 | China Mobile, Huawei | Juan Deng, Yang Zhao | Rel-11 | GP-51 |  | 48.018 |  |  |  |
| 495 | 172 | **IMS Emergency PSAP Callback (Stage 3)** |  | 322d? | 2011-09-20 | 2012-12-07 |  |  | 2011-09-20 | 2012-12-07 | 322d? | 463d |  | C1,C3,IETF | 10288h |  | EMC_PC | PCG-27 | Ericsson | christer.holmberg@ericsson.com | Rel-11 | CP-53 |  | Stage 3 |  |  |  |
| 496 | 172.1 | CT1 part of IMS Emergency PSAP Callback |  | 321d? | 2011-09-21 | 2012-12-07 |  |  | 2011-09-21 | 2012-12-07 | 321d? | 463d | finish no earlier than 2012-12-07 | C1 | 2568h |  | EMC_PC | PCG-27 | Ericsson | christer.holmberg@ericsson.com | Rel-11 | CP-53 |  | 24.229 | CP-120556 |  |  |
| 497 | 172.2 | (IETF) IMS Emergency PSAP Callback (Stage 3) |  | 322d? | 2011-09-20 | 2012-12-07 |  |  | 2011-09-20 | 2012-12-07 | 322d? | 463d | finish no earlier than 2012-12-07 | C1-IETF | 2576h |  | EMC_PC | PCG-27 | Christer Holmberg | christer.holmberg@ericsson.com | Rel-11 | CP-53 |  | no internet-draft available yet |  |  |  |
| 498 | 172.3 | CT3 part of IMS Emergency PSAP Callback |  | 321d? | 2011-09-21 | 2012-12-07 |  |  | 2011-09-21 | 2012-12-07 | 321d? | 463d | finish no earlier than 2012-12-07 | C3 | 2568h |  | EMC_PC | PCG-27 | Ericsson | christer.holmberg@ericsson.com | Rel-11 | CP-53 |  | 29.163, 29.165 | CP-120545 |  |  |

Notes:
- 473: CP#57 completed. SP#48 Stage 1 completed as Rel-10
- 474: SP#53 completed under Rel-10 UDC
- 475: CP#57 completed
- 476: CP#57 completed
- 477: CP#56 completed
- 478: CP#56 completed. Stage 3 (No architectural change, specify the list of selectable items related to control plane signalling directly for the same architecture)
- 479: CP#57 updated WID CP-110928=>C4-121619 (added CT3 part). Completion 09/12=>12/12. Stage 2/3 Triggered by DRAFT TR 23.857 Study on EPC Nodes Restoration UID_490014
- 480: CP#57 exception in CP-120451
- 481: CP#55 completed
- 482: CP#57 exception in CP-120544
- 483: CP#53 completed. Stage 3. Stage 2 clause C.1.1 of SA2 TS 23.167 CR#0182 (WI code: TEI11)
- 484: CP#52 completed
- 485: CP#53 completed
- 486: CP#57 completed
- 487: CP#57 completed
- 488: CP#57 completed
- 489: TSG#57, GP#55 completed. CT defined a generic solution (not only for GERAN)
- 490: SP#57 completed
- 491: CP#57 completed
- 492: CP#57 completed
- 493: CP#56 stopped (SA2 decided NO CT3 impact)
- 494: GP#55 completed. GP#51 approved WID
- 495: Stage 3 (Dependency IETF ECRIT on PSAP call back). Fulfil SA1/2 Rel-7 EMC1 reqs UID_32045 PS domain and IMS impacts for supporting IMS Emergency calls (related to BB UID_1653 Emergency Call Enhancements for IP& PS Based Calls
- 496: CP#57 completion 09/12=>12/12 (exception in CP-120556)
- 497: IETF ECRIT work on PSAP call back in draft-ietf-ecrit-psap-callback
- 498: CP#57 completion 09/12=>12/12 (exception in CP-120545). Work can only begin when CT1 has decided the technical solution

| ID | WBS | Task | Duration | Start | Finish | Complete | Remaining | Baseline start | Baseline finish | Baseline duration | Total slack | Constraint | Resources | Work | Actual work | Text1 | Text2 | Text4 | Text5 | Text6 | Text7 | Text9 | Text12 | Text11 | Text8 |
| --- | --- | --- | --- | --- | --- | --- | --- | --- | --- | --- | --- | --- | --- | --- | --- | --- | --- | --- | --- | --- | --- | --- | --- | --- | --- |
| 499 | 173 | **SAE Protocol Development** | 259d? | 2011-09-16 A | 2012-09-07 A | 100% |  | 2011-09-16 | 2012-09-07 | 259d? |  |  | C1 | 6168h | 6168h | SAES2 | PCG-27 | Nokia Siemens Networks | robert.zaus@nsn.com | Rel-11 | CP-53 |  |  |  |  |
| 500 | 173.1 | SAE Protocol Development (Stage 3) | 259d? | 2011-09-16 A | 2012-09-07 A | 100% |  | 2011-09-16 | 2012-09-07 | 259d? |  | finish no earlier than 2012-09-07 | C1 | 2048h | 2048h | SAES2 | PCG-27 | Nokia Siemens Networks | robert.zaus@nsn.com | Rel-11 | CP-53 |  |  |  |  |
| 501 | 173.2 | CS Fallback in EPS Phase 2 | 259d? | 2011-09-16 A | 2012-09-07 A | 100% |  | 2011-09-16 | 2012-09-07 | 259d? |  | finish no earlier than 2012-09-07 | C1 | 2048h | 2048h | SAES2-CSFB | PCG-27 | Nokia Siemens Networks | robert.zaus@nsn.com | Rel-11 | CP-53 |  |  |  |  |
| 502 | 174 | **GCSMSC and GCR Redundancy for VGCS/VBS (Stage 2/3)** | 258d? | 2011-09-19 A | 2012-09-07 A | 100% |  | 2011-09-19 | 2012-09-07 | 258d? |  |  | C1,C4 | 5680h | 5680h | RT_VGCS_Red | PCG-27 | Nokia Siemens Networks | robert.zaus@nsn.com | Rel-11 | CP-53 |  |  |  |  |
| 503 | 174.1 | CT1 part of GCSMSC and GCR Redundancy for VGCS/VBS | 258d? | 2011-09-19 A | 2012-09-07 A | 100% |  | 2011-09-19 | 2012-09-07 | 258d? |  | finish no earlier than 2012-09-07 | C1 | 2048h | 2048h | RT_VGCS_Red | PCG-27 | Nokia Siemens Networks | robert.zaus@nsn.com | Rel-11 | CP-53 |  |  |  |  |
| 504 | 174.2 | Deleted - CT4 part of GCSMSC and GCR Redundancy for VGCS/VBS | 197d? | 2011-09-19 A | 2012-06-15 A | 100% |  | 2011-09-19 | 2012-06-15 | 197d? |  | finish no earlier than 2012-06-15 | C4 | 1568h | 1568h | RT_VGCS_Red | PCG-27 | Nokia Siemens Networks | robert.zaus@nsn.com | Rel-11 | CP-53 | PCG-29 | CP-56 |  |  |
| 505 | 175 | Support of RFC 6140 in IMS | 203d? | 2011-12-02 A | 2012-09-07 A | 100% |  | 2011-12-02 | 2012-09-07 | 203d? |  | finish no earlier than 2012-09-07 | C1 | 1608h | 1608h | GINI | PCG-28 | Deutsche Telekom | martin.huelsemann@telekom.de | Rel-11 | CP-54 |  |  |  |  |
| 506 | 176 | **Enhancements for Multimedia Priority Service (MPS) – Gateway Control Priority** | 203d? | 2011-12-02 A | 2012-09-07 A | 100% |  | 2011-12-02 | 2012-09-07 | 203d? |  |  | C4,C3 | 4840h | 4840h | eMPS_Gateway | PCG-28 | Telcordia | Viqar Shaikh | Rel-11 | CP-54 |  |  |  |  |
| 507 | 176.1 | CT4 part of Enhancements for Multimedia Priority Service (MPS) – Gateway Control Priority | 202d? | 2011-12-02 A | 2012-09-07 A | 100% |  | 2011-12-02 | 2012-09-07 | 202d? |  | finish no earlier than 2012-09-07 | C4 | 1608h | 1608h | eMPS_Gateway | PCG-28 | Telcordia | Viqar Shaikh | Rel-11 | CP-54 |  |  |  |  |
| 508 | 176.2 | CT3 part of Enhancements for Multimedia Priority Service (MPS) – Gateway Control Priority | 202d? | 2011-12-02 A | 2012-09-07 A | 100% |  | 2011-12-02 | 2012-09-07 | 202d? |  | finish no earlier than 2012-09-07 | C3 | 1608h | 1608h | eMPS_Gateway | PCG-28 | Telcordia | Viqar Shaikh | Rel-11 | CP-54 |  |  |  |  |
| 509 | 177 | Inter-IMS Network to Network Interface (II-NNI) enhancements: SIP timers applicability (Stage 3) | 138d? | 2012-03-02 A | 2012-09-07 A | 100% |  | 2012-03-02 | 2012-09-07 | 138d? |  | start no earlier than 2012-03-02 | C3 | 1088h | 1088h | NNI_timers | PCG-28 | Telecom Italia | antonio.ascolese@telecomitalia.it | Rel-11 | CP-55 |  |  |  |  |
| 510 | 178 | AT commands for Universal Resource Identifier (URI) support | 126d? | 2012-06-15 A | 2012-12-07 | 30% | 88.2d? | 2012-06-15 | 2012-12-07 | 126d? | 463d | finish no earlier than 2012-12-07 | C1 | 1008h | 302.4h | ATURI | PCG-29 | Intel | frank.kowalewski@intel.com | Rel-11 | CP-56 |  |  | CP-120557 |  |
| 511 | 179 | PS Additional Number (Stage 3) | 62d? | 2012-06-15 A | 2012-09-07 A | 100% |  | 2012-06-15 | 2012-09-07 | 62d? |  | finish no earlier than 2012-09-07 | C4 | 488h | 488h | PSAN | PCG-29 | Deutsche Telekom | Yvette.koza@t-mobile.at | Rel-11 | CP-56 |  |  |  |  |
| 512 | 180 | Generic IMS User Group Over Sh | 62d? | 2012-06-15 A | 2012-09-07 A | 100% |  | 2012-06-15 | 2012-09-07 | 62d? |  | finish no earlier than 2012-09-07 | C4 | 488h | 488h | GenUG_Sh | PCG-29 | Alcatel-Lucent | jean-jacques.trottin@alcatel-lucent.com | Rel-11 | CP-56 |  |  |  |  |
| 513 | 181 | **IMS Operator Determined Call Barring (Stage 3)** | 66d? | 2012-09-07 | 2012-12-07 |  |  | 2012-09-07 | 2012-12-07 | 66d? | 463d |  | C1,C4 | 1257.6h |  | IODB | PCG-29 | Orange | Youssef.Chadli@Orange.com | Rel-11 | CP-57 |  |  |  |  |
| 514 | 181.1 | CT1 part of IMS Operator Determined Call Barring | 66d? | 2012-09-07 | 2012-12-07 |  |  | 2012-09-07 | 2012-12-07 | 66d? | 463d | finish no earlier than 2012-12-07 | C1 | 528h |  | IODB | PCG-29 | Orange | Youssef.Chadli@Orange.com | Rel-11 | CP-57 |  |  | CP-120670 |  |
| 515 | 181.2 | CT4 part of IMS Operator Determined Call Barring | 25.2d? | 2012-09-07 | 2012-12-07 |  |  | 2012-09-07 | 2012-12-07 | 25.2d? | 463d | finish no earlier than 2012-12-07 | C4 | 201.6h |  | IODB | PCG-29 | Orange | Youssef.Chadli@Orange.com | Rel-11 | CP-57 |  |  | CP-120672 |  |
| 516 | 182 | **Enhanced T.38 FAX support (Stage 3)** | 67d? | 2012-09-06 A | 2012-12-07 | 70% | 19.79d? | 2012-09-06 | 2012-12-07 | 67d? | 463d |  | C3,C1,C4 | 1600h | 1127.2h | MMTel_T.38_FAX | PCG-29 | NEC | Naoaki Suzuki (n-suzuki@en.jp.nec.com) | Rel-11 | CP-57 |  |  |  |  |
| 517 | 182.1 | CT3 part of Enhanced T.38 FAX support | 66d? | 2012-09-07 A | 2012-12-07 | 90% | 6.6d? | 2012-09-07 | 2012-12-07 | 66d? | 463d | finish no earlier than 2012-12-07 | C3 | 528h | 475.2h | MMTel_T.38_FAX | PCG-29 | NEC | Naoaki Suzuki (n-suzuki@en.jp.nec.com) | Rel-11 | CP-57 |  |  | CP-120674 |  |
| 518 | 182.2 | CT1 part of Enhanced T.38 FAX support | 66d? | 2012-09-07 A | 2012-12-07 | 50% | 33d? | 2012-09-07 | 2012-12-07 | 66d? | 463d | finish no earlier than 2012-12-07 | C1 | 528h | 264h | MMTel_T.38_FAX | PCG-29 | NEC | Naoaki Suzuki (n-suzuki@en.jp.nec.com) | Rel-11 | CP-57 |  |  | CP-120679 |  |
| 519 | 182.3 | CT4 part of Enhanced T.38 FAX support | 2d? | 2012-09-06 A | 2012-09-07 A | 100% |  | 2012-09-06 | 2012-09-07 | 2d? |  | finish no earlier than 2012-12-07 | C4 | 16h | 16h | MMTel_T.38_FAX | PCG-29 | NEC | Naoaki Suzuki (n-suzuki@en.jp.nec.com) | Rel-11 | CP-57 |  |  |  |  |
| 520 | 183 | **Full Support of Multi-Operator Core Network by GERAN** | 469d? | 2011-03-04 A | 2012-12-12 | 84% | 73.39d? | 2011-03-04 | 2012-12-12 | 469d? | 460d |  | G2,S2,C1 | 14652.9h | 10306.8h | Full_MOCN-GERAN | PCG-26 | Alcatel-Lucent | michel.robert@alcatel-lucent.com | Rel-11 | GP-49 |  |  |  | Paolo |
| 521 | 183.1 | GERAN part of Full Support of Multi-Operator Core Network by GERAN | 455d? | 2011-03-04 A | 2012-11-23 | 85% | 68.25d? | 2011-03-04 | 2012-11-23 | 455d? | 473d | finish no earlier than 2012-11-23 | G2 | 3632h | 3086h | Full_MOCN-GERAN | PCG-26 | Alcatel-Lucent | michel.robert@alcatel-lucent.com | Rel-11 | GP-49 |  |  | GP-121177 | Gert |
| 522 | 183.2 | Stage 2 for Full Support of Multi-Operator Core Network by GERAN | 160.8d? | 2011-06-08 A | 2012-03-07 A | 100% |  | 2011-06-08 | 2012-03-07 | 160.8d? |  | finish no earlier than 2012-03-07 | S2 | 1278.4h | 1278.4h | Full_MOCN-GERAN | PCG-26 | Alcatel-Lucent | nicolas.drevon@alcatel-lucent.com | Rel-11 | GP-49 |  |  |  | Maurice |

Notes:
- 499: CP#57 completed. Stage 3 continuation of Rel-8 Feature SAES (3GPP System Architecture Evolution Specification - Evolved Packet System) UID_320005
- 500: CP#57 completed / Text3: 23.122, 24.008, 24.167, 24.229, 24.301, 24.302, 24.303, 24.304, 24.305, 24.312, 29.018, 29.118
- 501: CP#57 completed / Text3: 23.122, 24.008, 24.167, 24.229, 24.301, 24.302, 24.303, 24.304, 24.305, 24.312, 29.018, 29.118
- 502: CP#57 completed. Stage 2/3 adding a CN internal functionality, not affecting Voice Group Call Service (VGCS)/VBS as perceived by service subscriber. Hence, no Stage 1 impact for VGCS/VBS (42.068, 42.069) / Text3: Stage 2/3
- 503: CP#57 completed / Text3: 43.068, 43.069
- 504: CP#56 stopped (no CT4 impact) / Text3: 29.002
- 505: CP#57 completed. Stage 3. Support procedures and protocol extensions in RFC6140 "Registration for Multiple Phone Numbers in SIP" to IMS for complex UEs. Ensure co-existence with NGCN IP-PBX registration procedures already defined in IMS. / Text3: 24.229
- 506: CP#57 completed. Stage 3. Stage 1 for MPS in 22.153. Details of any MGW actions for priority needs to be further studied within the scope of this WI. / Text3: Stage 3
- 507: CP#57 completed / Text3: 23.333, 23.334, 29.232, 29.238, 29.332, 29.333, 29.334
- 508: CP#57 completed / Text3: 29.162, 29.163, 29.292
- 509: CP#57 completed / Text3: 29.165
- 510: CP#57 exception=>12/12. Define new AT cmd for URI addresses for IMS services (eg VoLTE). 27.007 (AT cmd to control MT functions and GSM/UMTS/LTE network services from TE), 27.005 (AT commands for SMS). Currently address types for AT cmd based on dialling# / Text3: 27.005, 27.007
- 511: CP#57 completed. Stage 1 in Rel-11 SA1 TS 22.101 clause 17.7.3 (No Stage 2 needed since no architecture impact) / Text3: 23.003, 23.008, 29.002, 29.272, 29.230
- 512: CP#57 completed / Text3: 29.364
- 513: LS_in C4-121615 GSMA IREG RILTE concluded that TS 22.041 clause 5.4 Stage 1 requirements are not covered by stage 3 specifications
- 514: CP#57 exception in CP-120670 / Text3: New TS 24.315
- 515: CP#57 exception in CP-120672 / Text3: 23.008 , 23.015 , 29.328 , 29.329 , 29.364
- 516: Linked to Rel-8 Feature: IMS Multimedia Telephony Service (IMS-MMTel) UID_7038. SA1 added FAX stage 1 requirement only in Rel-10 under TEI10 to TS 22.173 (CR#0064)
- 517: CP#57 exception in CP-120674 / Text3: 29.163
- 518: CP#57 exception in CP-120679 / Text3: 24.229
- 519: CP#57 completed. Removed 152 Voice band data over IP (VBDoIP) from Rel-11 WID, resulting in exeption sheets needed for CT1, CT3 work only. / Text3: 29.332
- 520: GP#49 approved WID. Standardization of management of MOCN supporting MSs/UEs in GERAN. Continuation of Rel-10 MOCN-GERAN UID_490001 / Text3: GERAN
- 521: GP#55 updated WID GP-120737=>GP-121090 (removed CT spec). Exception in GP-121177 (await SA2 decision). GP#49 approved WID / Text3: 44.018, 44.060, 45.002, 45.008, 48.008, 48.018
- 522: SP#55 completed / Text3: 23.251, 23.272

| ID | WBS | Task | Duration | Start | Finish | Complete | Remaining | Baseline start | Baseline finish | Baseline duration | Total slack | Constraint | Resources | Work | Actual work | Text1 | Text2 | Text4 | Text5 | Text6 | Text7 | Text8 | Text11 |
| --- | --- | --- | --- | --- | --- | --- | --- | --- | --- | --- | --- | --- | --- | --- | --- | --- | --- | --- | --- | --- | --- | --- | --- |
| 523 | 183.3 | **CN Stage 3 for Full Support of Multi-Operator Core Network by GERAN** | 401d? | 2011-06-03 A | 2012-12-07 | 75% | 102.21d? | 2011-06-03 | 2012-12-07 | 401d? | 463d |  | C1,C4 | 4966.51h | 3689.59h | Full_MOCN-GERAN | PCG-26 | Alcatel-Lucent | jennifer.liu@alcatel-lucent.com | Rel-11 | GP-49 |  |  |
| 524 | 183.3.1 | CT1 part of CN Stage 3 for Full Support of Multi-Operator Core Network by GERAN | 361.8d? | 2011-06-03 A | 2012-12-07 | 70% | 108.54d? | 2011-06-03 | 2012-12-07 | 361.8d? | 463d | finish no earlier than 2012-12-07 | C1 | 2886.51h | 2018.19h | Full_MOCN-GERAN | PCG-26 | Alcatel-Lucent | jennifer.liu@alcatel-lucent.com | Rel-11 | GP-49 | Frederic | CP-120555 |
| 525 | 183.3.2 | CT4 part of CN Stage 3 for Full Support of Multi-Operator Core Network by GERAN | 64d? | 2012-06-13 A | 2012-09-07 A | 100% |  | 2012-06-13 | 2012-09-07 | 64d? |  | finish no earlier than 2012-09-07 | C4 | 504h | 504h | Full_MOCN-GERAN | PCG-29 | Alcatel-Lucent | michel.robert@alcatel-lucent.com | Rel-11 | GP-54 |  |  |
| 526 | 183.4 | Stage 2 for Gateway Core Network Sharing for GERAN | 129d? | 2012-06-18 A | 2012-12-12 | 95% | 6.4d? | 2012-06-18 | 2012-12-12 | 129d? | 460d | finish no earlier than 2012-12-12 | S2 | 1024h | 972.8h | Full_MOCN-GERAN-GWCN | PCG-29 | Vodafone | chris.pudney@vodafone.com | Rel-11 | SP-56 |  |  |
| 527 | 184 | **Medium range/local area requirements for multicarrier BTS** | 263d? | 2011-11-25 A | 2012-11-23 | 95% | 13.09d? | 2011-11-25 | 2012-11-23 | 263d? | 473d |  | G1 | 6288h | 5974.09h | MRLA | PCG-28 | Ericsson | Eric Nordström | Rel-11 | GP-52 |  | GP-121138 |
| 528 | 184.1 | Core part: Medium range/local area requirements for multicarrier BTS | 263d? | 2011-11-25 A | 2012-11-23 | 95% | 13.1d? | 2011-11-25 | 2012-11-23 | 263d? | 473d | finish no earlier than 2012-11-23 | G1 | 2096h | 1991.2h | MRLA-Core | PCG-28 | Ericsson | Eric Nordström | Rel-11 | GP-52 |  | GP-121138 |
| 529 | 184.2 | Perf. part: Medium range/local area requirements for multicarrier BTS | 262d? | 2011-11-28 A | 2012-11-23 | 95% | 13.05d? | 2011-11-28 | 2012-11-23 | 262d? | 473d | finish no earlier than 2012-11-23 | G1 | 2088h | 1983.6h | MRLA-Perf | PCG-28 | Ericsson | Eric Nordström | Rel-11 | GP-52 |  | GP-121138 |
| 530 | 185 | Domain Specific Access Control in GERAN | 131d? | 2012-03-05 A | 2012-08-31 A | 100% |  | 2012-03-05 | 2012-08-31 | 131d? |  | finish no earlier than 2012-08-31 | G2 | 1048h | 1048h | GDSAC | PCG-28 | Vodafone | chris.pudney@vodafone.com | Rel-11 | GP-53 |  |  |
| 531 | 186 | **Extending 850 MHz Upper Band (814 – 849 MHz)** | 526d? | 2010-12-10 A | 2012-12-07 | 98% | 10.89d? | 2010-12-10 | 2012-12-07 | 526d? | 463d |  | R4,R2,R3,R5 | 12984h | 9154h | e850_UB | PCG-26 | Sprint | John.J.Humbert@Sprint.com | Rel-11 | RP-50 | Issam |  |
| 532 | 186.1 | Core part: Extending 850 MHz Upper Band (814 – 849 MHz) | 322d? | 2010-12-10 A | 2012-03-02 A | 100% |  | 2010-12-10 | 2012-03-02 | 322d? |  | finish no earlier than 2012-03-02 | R4,R2,R3 | 2568h | 2568h | e850_UB-Core | PCG-26 | Sprint | John.J.Humbert@Sprint.com | Rel-11 | RP-50 | Issam | RP-120075 |
| 533 | 186.2 | Perf. part: Extending 850 MHz Upper Band (814 – 849 MHz) | 322d? | 2010-12-10 A | 2012-03-02 A | 100% |  | 2010-12-10 | 2012-03-02 | 322d? |  | finish no earlier than 2012-03-02 | R4,R2,R3 | 2568h | 2568h | e850_UB-Perf | PCG-26 | Sprint | John.J.Humbert@Sprint.com | Rel-11 | RP-50 | Issam | RP-120076 |
| 534 | 186.3 | Test part: Extending 850 MHz Upper Band (814 – 849 MHz) | 455d? | 2011-03-18 A | 2012-12-07 | 95% | 22.75d? | 2011-03-18 | 2012-12-07 | 455d? | 463d | finish no earlier than 2012-12-07 | R5 | 3640h | 3458h | e850_UB-UEConTest | PCG-26 | Sprint | John.J.Humbert@Sprint.com | Rel-11 | RP-51 | Ingbert | RP-120966 |
| 535 | 187 | **Further Self Optimizing Networks (SON) enhancements** | 323d? | 2011-09-19 A | 2012-12-07 | 70% | 96.89d? | 2011-09-19 | 2012-12-07 | 323d? | 463d |  | R3,R2 | 5160h | 3612.08h | SONenh2_LTE_UTRA | PCG-27 | Nokia Siemens Networks | krzysztof.kordybach@nsn.com | Rel-11 | RP-53 |  |  |
| 536 | 187.1 | Core part: Further Self Optimizing Networks (SON) enhancements | 322d? | 2011-09-19 A | 2012-12-07 | 70% | 96.6d? | 2011-09-19 | 2012-12-07 | 322d? | 463d | finish no earlier than 2012-12-07 | R3,R2 | 2576h | 1803.2h | SONenh2_LTE_UTRA-Core | PCG-27 | Nokia Siemens Networks | krzysztof.kordybach@nsn.com | Rel-11 | RP-53 |  | RP-120991 |
| 537 | 188 | **Enhancement of Minimization of Drive Tests for E-UTRAN and UTRAN** | 323d? | 2011-09-19 A | 2012-12-07 | 90% | 32.29d? | 2011-09-19 | 2012-12-07 | 323d? | 463d |  | R2,R1,R3,R4 | 5160h | 4644.08h | eMDT_UMTSLTE | PCG-27 | MediaTek | Johan Johansson | Rel-11 | RP-53 |  |  |
| 538 | 188.1 | Core part: Enhancement of Minimization of Drive Tests for E-UTRAN and UTRAN | 322d? | 2011-09-19 A | 2012-12-07 | 90% | 32.2d? | 2011-09-19 | 2012-12-07 | 322d? | 463d | finish no earlier than 2012-12-07 | R2,R1,R3,R4 | 2576h | 2318.4h | eMDT_UMTSLTE-Core | PCG-27 | MediaTek | Johan Johansson | Rel-11 | RP-53 |  | RP-120989 |
| 539 | 189 | **E-UTRA medium range and MSR medium range/local area BS class requirements** | 323d? | 2011-09-19 A | 2012-12-07 | 54% | 149.35d? | 2011-09-19 | 2012-12-07 | 323d? | 463d |  | R4,G1 | 9816h | 5273.63h | medBS_class_LTE_MSR | PCG-27 | Ericsson | johan.skold@ericsson.com | Rel-11 | RP-53 |  |  |
| 540 | 189.1 | Core part: E-UTRA medium range and MSR medium range/local area BS class requirements | 323d? | 2011-09-19 A | 2012-12-07 | 90% | 32.2d? | 2011-09-19 | 2012-12-07 | 323d? | 463d | finish no earlier than 2012-12-07 | R4 | 2576h | 2318.4h | medBS_class_LTE_MSR-Core | PCG-27 | Ericsson | johan.skold@ericsson.com | Rel-11 | RP-53 |  | RP-120992 |
| 541 | 189.2 | Perf. part: E-UTRA medium range and MSR medium range/local area BS class requirements | 321d? | 2011-09-21 | 2012-12-07 |  |  | 2011-09-21 | 2012-12-07 | 321d? | 463d | finish no earlier than 2012-12-07 | R4 | 2568h |  | medBS_class_LTE_MSR-Perf | PCG-27 | Ericsson | johan.skold@ericsson.com | Rel-11 | RP-53 |  | RP-120993 |
| 542 | 189.3 | GERAN part: E-UTRA medium range and MSR medium range/local area BS class requirements | 261d? | 2011-11-28 A | 2012-11-23 | 75% | 65.25d? | 2011-11-28 | 2012-11-23 | 261d? | 473d | finish no earlier than 2012-11-23 | G1 | 2088h | 1566h | medBS_class_LTE_MSR-GERAN | PCG-28 | Ericsson | Eric Nordström | Rel-11 | GP-52 |  |  |
| 543 | 190 | **RF Requirements for Multi-Band and Multi-Standard Radio (MB-MSR) Base Station** | 281.1d? | 2012-02-06 A | 2013-03-01 | 22% | 219.95d? | 2012-02-06 | 2013-03-01 | 281.1d? | 403d |  | R4,G1 | 5784h | 1258.2h | MB_MSR_RF | PCG-28 | Huawei | Liu Ye (leo.liuye@huawei.com) | Rel-11 | RP-55 |  |  |
| 544 | 190.1 | Core part: RF Requirements for Multi-Band and Multi-Standard Radio (MB-MSR) Base Station | 201d? | 2012-02-06 A | 2012-12-07 | 50% | 100.5d? | 2012-02-06 | 2012-12-07 | 201d? | 463d | finish no earlier than 2012-12-07 | R4,G1 | 1608h | 804h | MB_MSR_RF-Core | PCG-28 | Huawei | Liu Ye (leo.liuye@huawei.com) | Rel-11 | RP-55 |  | RP-120994 |
| 545 | 190.2 | Perf. part: RF Requirements for Multi-Band and Multi-Standard Radio (MB-MSR) Base Station | 261d? | 2012-03-06 | 2013-03-01 |  |  | 2012-03-06 | 2013-03-01 | 261d? | 403d | finish no earlier than 2013-03-01 | R4,G1 | 2088h |  | MB_MSR_RF-Perf | PCG-28 | Huawei | Liu Ye (leo.liuye@huawei.com) | Rel-11 | RP-55 |  | RP-120995 |
| 546 | 191 | **Verification of radiated multi-antenna reception performance of UEs in LTE/UMTS** | 202d? | 2012-03-05 A | 2012-12-07 | 30% | 141.4d? | 2012-03-05 | 2012-12-07 | 202d? | 463d |  | R4 | 3224h | 967.18h | HSPA_LTE_measRP_MIMO | PCG-28 | Vodafone | Luis Anaya | Rel-11 | RP-55 |  |  |
| 547 | 191.1 | Perf. part: Verification of radiated multi-antenna reception performance of UEs in LTE/UMTS | 201d? | 2012-03-05 A | 2012-12-07 | 30% | 140.7d? | 2012-03-05 | 2012-12-07 | 201d? | 463d | finish no earlier than 2012-12-07 | R4 | 1608h | 482.4h | HSPA_LTE_measRP_MIMO-Perf | PCG-28 | Vodafone | Luis Anaya | Rel-11 | RP-55 |  | RP-121426 |

Notes:
- 523: CP#57 updated WID CP-110758=>CP-120563 (added CT4 part in CT WID; was before in GERAN WID)
- 524: CP#57 completion 09/12=>12/12 (exception in CP-120555) / Text3: 24.008
- 525: CP#57 completed. Updated WID CP-110758=>CP-120563 (added CT4 part in CT WID; was before in GERAN WID) / Text3: 23.003
- 526: SP#57 completion 09/12=>12/12. (23.251CR0062R2 as TEI11. TS 23.251 specifies both MOCN and GWCN for E-UTRAN and UTRAN, but GWCN is not yet supported on GERAN. Extend Full_MOCN-GERAN to also cover GWCN GERAN / Text3: 23.251
- 527: GP#55 completion 08/12=>11/12 (exception in GP-121138) / Text3: GERAN
- 528: Stage 3. GP#55 completion 08/12=>11/12 (exception in GP-121138) / Text3: 45.005
- 529: Test spec. GP#55 completion 08/12=>11/12 (exception in GP-121138) / Text3: 51.021
- 530: GP#55 completed. GP#53 approved WID. Work is dependent upon Full_MOCN-GERAN (UID_510001) / Text3: GERAN 44.018
- 531: Stage 3 Triggered by R4 Rel-10 LTE TR 37.806 Study on Extending 850 MHz (UID_440016) / Text3: UTRA, LTE
- 532: RP#55 completed / Text3: 25.101, 25.104, 25.113, 25.133, 25.141, 25.461, 25.466, 36.101, 36.104, 36.113, 36.124, 36.133, 36.141, 36.307, 36.331, 37.104, 37.113, 37.141
- 533: RP#55 completed / Text3: 25.101, 25.104, 25.113, 25.133, 25.141, 25.461, 25.466, 36.101, 36.104, 36.124, 36.133, 36.141, 36.307, 36.331, 37.104, 37.113, 37.141
- 534: RP#57 completion 09/12=>12/12 / Text3: 34.108, 34.121-1, 34.121-2, 34.123-1, 34.123-2, 34.123-3, 36.508, 36.521-1, 36.521-2, 36.521-3, 36.523-1, 36.523-2, 36.523-3
- 535: Stage 1,2,3 / Text3: UTRA, LTE
- 536: RP#57 completion 09/12=>12/12 (exception in RP-121199) / Text3: 25.331, 25.401, 25.410, 25.413, 25.423, 25.433, 36.300, 36.331, 36.413, 36.423
- 537: Stage 2,3. RP#57 updated WID RP-120277=>RP-121204. Exception in RP-121203 / Text3: UTRA, LTE
- 538: RP#57 updated WID RP-120277=>RP-121204. Completion 09/12=>12/12 (exception in RP-121203) / Text3: 25.133, 25.123, 25.304, 25.331, 25.413, 25.423, 36.133, 36.304, 36.306, 36.331, 36.413, 36.423, 37.320, 36.300
- 539: Stage 3. GERAN BS RF requirements specs need aligned with RAN4 ongoing Rel-11 Feature UID_530037 E-UTRA medium range and MSR medium range/local area BS class requirements (medBS_class_LTE_MSR) / Text3: UTRA, LTE, GERAN
- 540: RP#57 completion 09/12=>12/12 (exception in RP-121180) / Text3: 25.104, 36.104, 37.104, new TR 37.809
- 541: RP#57 completion 09/12=>12/12 / Text3: 25.141, 36.141, 37.141
- 542: GP#55 completion 08/12=>11/12. GP#52 approved WID / Text3: 45.005, 51.021
- 543: - / Text3: UTRA, LTE, GERAN
- 544: RP#57 exception in RP-121253 / Text3: 25.104, 25.105, 36.104, 37.104, new TR 37.8xy
- 545: - / Text3: 25.141, 25.142, 36.141, 37.141, new TR 37.8xy
- 546: Triggered by FS_HSPA_LTE_measRP_MIMO_multi-antenna. Core functionality exists since Rel-6 & Rel-7 (MIMO). Adds a very generic test method to test UEs with 2 or more Rx antennas / Text3: UTRA, LTE
- 547: Rx diversity (defined as Rel-6 HSDPA RAN4 enhanced type 1 req.) & MIMO (defined as Rel-7 HSDPA MIMO for HSPA). Rx diversity & MIMO (defined as part of Rel-8 basic LTE WI) / Text3: new TR 37.9xy

| ID | WBS | Task | Duration | Start | Finish | Complete | Remaining | Baseline start | Baseline finish | Baseline duration | Total slack | Constraint | Resources | Work | Actual work | Text1 | Text2 | Text4 | Text5 | Text6 | Text7 | Text11 | Text8 |
| --- | --- | --- | --- | --- | --- | --- | --- | --- | --- | --- | --- | --- | --- | --- | --- | --- | --- | --- | --- | --- | --- | --- | --- |
| 548 | 192 | **Further enhancements to H(e)NB mobility - Part 1** | 127d? | 2012-06-15 A | 2012-12-07 | 40% | 76.2d? | 2012-06-15 | 2012-12-07 | 127d? | 463d |  | R3,R2 | 2032h | 812.8h | EHNB_enh1 | PCG-29 | Alcatel-Lucent | Martin.Warner@alcatel-lucent.com | Rel-11 | RP-56 |  |  |
| 549 | 192.1 | Core part: Further enhancements to H(e)NB mobility - Part 1 | 127d? | 2012-06-15 A | 2012-12-07 | 40% | 76.2d? | 2012-06-15 | 2012-12-07 | 127d? | 463d | finish no earlier than 2012-12-07 | R3,R2 | 1016h | 406.4h | EHNB_enh1-Core | PCG-29 | Alcatel-Lucent | Martin.Warner@alcatel-lucent.com | Rel-11 | RP-56 | RP-120997 |  |
| 550 | 193 | **Further enhancements to H(e)NB mobility - Part 2** | 127d? | 2012-06-15 | 2012-12-07 |  |  | 2012-06-15 | 2012-12-07 | 127d? | 463d |  | R3,R2 | 2032h |  | EHNB_enh2 | PCG-29 | Alcatel-Lucent | Martin.Warner@alcatel-lucent.com | Rel-11 | RP-56 |  |  |
| 551 | 193.1 | Core part: Further enhancements to H(e)NB mobility - Part 2 | 127d? | 2012-06-15 | 2012-12-07 |  |  | 2012-06-15 | 2012-12-07 | 127d? | 463d | finish no earlier than 2012-12-07 | R3,R2 | 1016h |  | EHNB_enh2-Core | PCG-29 | Alcatel-Lucent | Martin.Warner@alcatel-lucent.com | Rel-11 | RP-56 | RP-120998 |  |
| 552 | 194 | **Network-Based Positioning Support in LTE** | 986d? | 2009-03-09 A | 2012-12-07 | 36% | 631.39d? | 2009-03-09 | 2012-12-07 | 986d? | 463d |  | R2,R1,R3,R4 | 19368h | 6965.57h | LCS_LTE-NBPS | PCG-22 | TruePosition | terri.brooks@trueposition.com | Rel-11 | RP-43 |  | Joern |
| 553 | 194.1 | Core part: Network-Based Positioning Support in LTE | 719.5d? | 2009-03-09 A | 2012-12-07 | 85% | 107.92d? | 2009-03-09 | 2012-12-07 | 719.5d? | 463d | finish no earlier than 2012-12-07 | R2,R1,R3,R4 | 5756h | 4892.6h | LCS_LTE-NBPS-Core | PCG-22 | TruePosition | terri.brooks@trueposition.com | Rel-11 | RP-43 | RP-120999 | Joern |
| 554 | 194.2 | Perf. part: Network-Based Positioning Support in LTE | 981d? | 2009-03-16 | 2012-12-07 |  |  | 2009-03-16 | 2012-12-07 | 981d? | 463d | finish no earlier than 2012-12-07 | R4 | 7848h |  | LCS_LTE-NBPS-Perf | PCG-22 | TruePosition | terri.brooks@trueposition.com | Rel-11 | RP-43 | RP-121000 | Joern |
| 555 | 195 | **Service continuity improvements for MBMS for LTE** | 596d? | 2010-06-04 A | 2012-09-07 A | 100% |  | 2010-06-04 | 2012-09-07 | 596d? |  |  | R2,R3 | 9504h | 9504h | MBMS_LTE_SC | PCG-25 | Huawei | David.Lecompte@huawei.com | Rel-11 | RP-48 |  | Joern |
| 556 | 195.1 | Core part: Service continuity improvements for MBMS for LTE | 592d? | 2010-06-04 A | 2012-09-07 A | 100% |  | 2010-06-04 | 2012-09-07 | 592d? |  | finish no earlier than 2012-09-07 | R2,R3 | 4736h | 4736h | MBMS_LTE_SC-Core | PCG-25 | Huawei | David.Lecompte@huawei.com | Rel-11 | RP-48 | RP-121001 | Joern |
| 557 | 196 | **Further Enhanced Non CA-based ICIC for LTE** | 454d? | 2011-03-22 A | 2012-12-07 | 55% | 204.17d? | 2011-03-22 | 2012-12-07 | 454d? | 463d |  | R1,R2,R3,R4 | 10872h | 5982.61h | eICIC_enh_LTE | PCG-26 | China Mobile | ShenXiaodong@chinamobile.com | Rel-11 | RP-51 |  | Patrick |
| 558 | 196.1 | Core part: Further Enhanced Non CA-based ICIC for LTE | 453d? | 2011-03-22 A | 2012-12-07 | 80% | 90.6d? | 2011-03-22 | 2012-12-07 | 453d? | 463d | finish no earlier than 2012-12-07 | R1,R2,R3,R4 | 3624h | 2899.2h | eICIC_enh_LTE-Core | PCG-26 | China Mobile | ShenXiaodong@chinamobile.com | Rel-11 | RP-51 | RP-121002 | Patrick |
| 559 | 196.2 | Perf. part: Further Enhanced Non CA-based ICIC for LTE | 452d? | 2011-03-23 A | 2012-12-07 | 30% | 316.4d? | 2011-03-23 | 2012-12-07 | 452d? | 463d | finish no earlier than 2012-12-07 | R4 | 3616h | 1084.8h | eICIC_enh_LTE-Perf | PCG-26 | China Mobile | ShenXiaodong@chinamobile.com | Rel-11 | RP-51 | RP-121003 | Issam |
| 560 | 197 | **New Band LTE Downlink FDD 716-728 MHz** | 454d? | 2011-03-22 A | 2012-12-07 | 38% | 283.37d? | 2011-03-22 | 2012-12-07 | 454d? | 463d |  | R4 | 10864h | 4083.01h | LTE_DL_FDD700 | PCG-26 | AT&T | marc.grant@att.com | Rel-11 | RP-51 |  | Issam |
| 561 | 197.1 | Core part: New Band LTE Downlink FDD 716-728 MHz | 453d? | 2011-03-22 A | 2012-12-07 | 75% | 113.25d? | 2011-03-22 | 2012-12-07 | 453d? | 463d | finish no earlier than 2012-12-07 | R4 | 3624h | 2718h | LTE_DL_FDD700-Core | PCG-26 | AT&T | marc.grant@att.com | Rel-11 | RP-51 | RP-121070 | Issam |
| 562 | 197.2 | Perf. part: New Band LTE Downlink FDD 716-728 MHz | 451d? | 2011-03-25 | 2012-12-07 |  |  | 2011-03-25 | 2012-12-07 | 451d? | 463d | finish no earlier than 2012-12-07 | R4 | 3608h |  | LTE_DL_FDD700-Perf | PCG-26 | AT&T | marc.grant@att.com | Rel-11 | RP-51 | RP-121071 | Issam |
| 563 | 198 | **LTE RAN Enhancements for Diverse Data Applications** | 456d? | 2011-03-18 A | 2012-12-07 | 95% | 22.79d? | 2011-03-18 | 2012-12-07 | 456d? | 463d |  | R2 | 7280h | 6916.09h | LTE_eDDA | PCG-26 | Research In Motion | Gordon Young (gyoung@rim.com) | Rel-11 | RP-51 |  | Joern |
| 564 | 198.1 | Core part: LTE RAN Enhancements for Diverse Data Applications | 454d? | 2011-03-18 A | 2012-12-07 | 95% | 22.7d? | 2011-03-18 | 2012-12-07 | 454d? | 463d | finish no earlier than 2012-09-07 | R2 | 3632h | 3450.4h | LTE_eDDA-Core | PCG-26 | Research In Motion | Gordon Young (gyoung@rim.com) | Rel-11 | RP-51 | RP-121006 | Joern |
| 565 | 199 | **LTE E850 - Lower Band for Region 2 (non-US), Band 27** | 454d? | 2011-03-22 A | 2012-12-07 | 85% | 69.76d? | 2011-03-22 | 2012-12-07 | 454d? | 463d |  | R1,R2,R4,R5 | 9864h | 6004h | LTE_e850_LB | PCG-26 | NII Holdings | bill.shvodian@nii.com | Rel-11 | RP-51 |  | Patrick |
| 566 | 199.1 | Core part: LTE E850 - Lower Band for Region 2 (non-US), Band 27 | 327d? | 2011-03-22 A | 2012-06-15 A | 100% |  | 2011-03-22 | 2012-06-15 | 327d? |  | finish no earlier than 2012-09-07 | R1,R2,R4 | 2616h | 2616h | LTE_e850_LB-Core | PCG-26 | NII Holdings | bill.shvodian@nii.com | Rel-11 | RP-51 | RP-120570 | Patrick |
| 567 | 199.2 | Perf. part: LTE E850 - Lower Band for Region 2 (non-US), Band 27 | 326d? | 2011-03-23 A | 2012-06-15 A | 100% |  | 2011-03-23 | 2012-06-15 | 326d? |  | finish no earlier than 2012-12-07 | R4 | 2608h | 2608h | LTE_e850_LB-Perf | PCG-26 | NII Holdings | bill.shvodian@nii.com | Rel-11 | RP-51 | RP-120571 | Issam |
| 568 | 199.3 | Test part: LTE E850 - Lower Band for Region 2 (non-US), Band 27 | 126d? | 2012-06-18 A | 2012-12-07 | 5% | 119.7d? | 2012-06-18 | 2012-12-07 | 126d? | 463d | finish no earlier than 2012-12-07 | R5 | 1008h | 50.4h | LTE_e850_LB-UEConTest | PCG-29 | NII Holdings | bill.shvodian@nii.com | Rel-11 | RP-56 | RP-120969 |  |
| 569 | 200 | **LTE for 700 MHz Digital Dividend** | 459d? | 2011-06-07 A | 2013-03-01 | 76% | 111.4d? | 2011-06-07 | 2013-03-01 | 459d? | 403d |  | R4,R2,R3,R5 | 9496h | 7191.17h | LTE_APAC700 | PCG-27 | Ericsson | olav.queseth@ericsson.com | Rel-11 | RP-52 |  | Issam |
| 570 | 200.1 | Core part: LTE for 700 MHz Digital Dividend | 271d? | 2011-06-07 A | 2012-06-15 A | 100% |  | 2011-06-07 | 2012-06-15 | 271d? |  | finish no earlier than 2012-06-15 | R4,R2,R3 | 2168h | 2168h | LTE_APAC700-Core | PCG-27 | Ericsson | olav.queseth@ericsson.com | Rel-11 | RP-52 | RP-120572 | Issam |
| 571 | 200.2 | Perf. part: LTE for 700 MHz Digital Dividend | 271d? | 2011-06-09 A | 2012-06-15 A | 100% |  | 2011-06-09 | 2012-06-15 | 271d? |  | finish no earlier than 2012-06-15 | R4 | 2168h | 2168h | LTE_APAC700-Perf | PCG-27 | Ericsson | olav.queseth@ericsson.com | Rel-11 | RP-52 | RP-120573 | Issam |
| 572 | 200.3 | Test part: LTE for 700 MHz Digital Dividend | 186d? | 2012-06-18 A | 2013-03-01 | 5% | 176.7d? | 2012-06-18 | 2013-03-01 | 186d? | 403d | finish no earlier than 2013-03-01 | R5 | 1488h | 74.4h | LTE_APAC700-UEConTest | PCG-29 | Ericsson | fredrik.sundstrom@ericsson.com | Rel-11 | RP-56 | RP-120970 |  |

Notes:
- 548: Stage 2/3. RP#57 updated WID RP-120900=>RP-121427 (specs deleted in feature part). Triggered by FS_EHNB_enh (UTRA, LTE TR 37.803 under AI 12.3.2). Compare also Rel-10 WI HNB_HENB_mob_enh RP-110183 / Text3: UTRA, LTE
- 549: RP#57 updated WID RP-120900=>RP-121427. (exception in RP-121190) / Text3: 25.413, 25.467, 25.469, 36.300, 36.413, 36.423
- 550: Stage 2/3. RP#57 updated WID RP-120901=>RP-121147 (specs deleted in feature part). Triggered by FS_EHNB_enh (UTRA, LTE TR 37.803 under AI 12.3.2) / Text3: UTRA, LTE
- 551: RP#57 exception in RP-121191 / Text3: 25.413, 25.423, 25.467, 25.469, 25.471, 36.300, 36.413, 36.423
- 552: - / Text3: LTE
- 553: RP#57 exception in RP-121227. For Information v100 of TS 36.456, 36.457, 36.458, 36.459 / Text3: 36.133, 36.214, 36.300, 36.305, 36.455, new TS (36.111, 36.456, 36.457, 36.458, 36.459)
- 554: - / Text3: 36.104, 36.111, 36.133, 36.141
- 555: - / Text3: LTE
- 556: RP#57 completed / Text3: 25.446, 36.300, 36.304, 36.321, 36.322, 36.323, 36.331, 36.440, 36.441, 36.442, 36.443, 36.444, 36.445
- 557: Stage 2/3 / Text3: LTE
- 558: RP#57 completion 09/12=>12/12 (exception in RP-121430) / Text3: 36.101, 36.133, 36.201, 36.211, 36.212, 36.213, 36.214, 36.300, 36.304, 36.321, 36.331, 36.413, 36.423
- 559: - / Text3: 36.101, 36.104, 36.133, 36.141
- 560: Stage 3 / Text3: LTE
- 561: RP#57 completion 09/12=>12/12 (exception in RP-121347) / Text3: 36.101, 36.104, 36.141, 36.307
- 562: - / Text3: 36.101, 36.104, 36.133, 36.141, 36.307
- 563: Stage 2/3 / Text3: LTE
- 564: RP#57 completion 0912=1212 (exception in RP-121290). New TR 36.822 v200 for Approval / Text3: 36.300, 36.321, 36.331, new TR 36.822
- 565: Stage 3. RP#56 Core & Perf completed. Updated WID RP-110439=>RP-120602 (changed lower edge of band, impacted specs) / Text3: LTE
- 566: RP#56 completed / Text3: 25.101, 25.104, 25.461, 25.466, 36.101, 36.104, 36.113, 36.124, 36.307, 37.104, 37.113
- 567: RP#56 completed / Text3: 25.123, 25.133, 25.141, 36.133, 36.141, 37.141
- 568: - / Text3: 36.508, 36.521-1, 36.521-2, 36.521-3, 36.523-2, 36.523-3, 37.571-1
- 569: RP#56 Core & Perf completed. Stage 3 . Asian Pacific American Caucus (APAC) Asia-Pacific Telecommunity (APT) Wireless Forum / Text3: LTE
- 570: RP#56 completed. TR 36.820 v100 for Information and Approval / Text3: 25.461, 25.466, 36.101, 36.104, 36.113, 36.124, 36.133, 36.307, 37.104, 37.113, new TR 36.820
- 571: RP#56 completed / Text3: 36.133, 36.141, 37.141
- 572: - / Text3: 36.508, 36.521-1, 36.521-2, 36.521-3, 36.523-2, 36.523-3, 37.571-1

| ID | WBS | Task | Duration | Start | Finish | Complete | Remaining | Baseline start | Baseline finish | Baseline duration | Total slack | Constraint | Resources | Work | Actual work | Text1 | Text2 | Text4 | Text6 | Text7 | Text8 | Text11 |
| --- | --- | --- | --- | --- | --- | --- | --- | --- | --- | --- | --- | --- | --- | --- | --- | --- | --- | --- | --- | --- | --- | --- |
| 573 | 201 | **Relays for LTE (part 2)** | 791d? | 2009-12-04 A | 2012-12-07 | 86% | 111.16d? | 2009-12-04 | 2012-12-07 | 791d? | 463d |  | R4 | 15280.4h | 12424.9h | LTE_Relay2 | PCG-24 | Ericsson | Rel-11 | RP-46 | Patrick |  |
| 574 | 201.1 | Core part: Relays for LTE (part 2) | 333d? | 2011-06-07 A | 2012-09-07 A | 100% |  | 2011-06-07 | 2012-09-07 | 333d? |  | finish no earlier than 2012-09-07 | R4 | 2656.39h | 2656.39h | LTE_Relay2-Core | PCG-27 | Ericsson | Rel-11 | RP-52 | Issam | RP-121008 |
| 575 | 201.2 | Perf. part: Relays for LTE (part 2) | 787d? | 2009-12-04 A | 2012-12-07 | 80% | 157.4d? | 2009-12-04 | 2012-12-07 | 787d? | 463d | finish no earlier than 2012-12-07 | R4 | 6296h | 5036.8h | LTE_Relay2-Perf | PCG-24 | Ericsson | Rel-11 | RP-46 | Issam | RP-121009 |
| 576 | 202 | **Signalling and Procedure for Interference Avoidance for in-device coexistence** | 323d? | 2011-09-19 A | 2012-12-07 | 85% | 48.44d? | 2011-09-19 | 2012-12-07 | 323d? | 463d |  | R2,R4 | 7744h | 6582.46h | SPIA_IDC_LTE | PCG-27 | China Mobile | Rel-11 | RP-53 |  |  |
| 577 | 202.1 | Core part: Signalling and Procedure for Interference Avoidance for in-device coexistence | 323d? | 2011-09-19 A | 2012-12-07 | 85% | 48.45d? | 2011-09-19 | 2012-12-07 | 323d? | 463d | finish no earlier than 2012-12-07 | R2,R4 | 2584h | 2196.4h | SPIA_IDC_LTE-Core | PCG-27 | China Mobile | Rel-11 | RP-53 |  | RP-121010 |
| 578 | 202.2 | Perf. part: Signalling and Procedure for Interference Avoidance for in-device coexistence | 322d? | 2011-09-20 A | 2012-12-07 | 85% | 48.3d? | 2011-09-20 | 2012-12-07 | 322d? | 463d | finish no earlier than 2012-12-07 | R4 | 2576h | 2189.6h | SPIA_IDC_LTE-Perf | PCG-27 | China Mobile | Rel-11 | RP-53 |  | RP-121011 |
| 579 | 203 | **Coordinated Multi-Point Operation for LTE** | 458d? | 2011-09-19 A | 2013-06-14 | 40% | 276.38d? | 2011-09-19 | 2013-06-14 | 458d? | 328d |  | R1,R2,R3,R4 | 15032h | 5960.95h | COMP_LTE | PCG-27 | Samsung, Huawei | Rel-11 | RP-53 |  |  |
| 580 | 203.1 | Core part: Coordinated Multi-Point Operation for LTE – Uplink | 322d? | 2011-09-19 A | 2012-12-07 | 90% | 32.2d? | 2011-09-19 | 2012-12-07 | 322d? | 463d | finish no earlier than 2012-12-07 | R1,R2,R3,R4 | 2576h | 2318.4h | COMP_LTE_UL-Core | PCG-27 | Huawei | Rel-11 | RP-53 |  | RP-121012 |
| 581 | 203.2 | Perf. part: Coordinated Multi-Point Operation for LTE – Uplink | 321d? | 2011-09-21 | 2012-12-07 |  |  | 2011-09-21 | 2012-12-07 | 321d? | 463d | finish no earlier than 2012-12-07 | R4 | 2568h |  | COMP_LTE_UL-Perf | PCG-27 | Huawei | Rel-11 | RP-53 |  | RP-121013 |
| 582 | 203.3 | Core part: Coordinated Multi-Point Operation for LTE – Downlink | 322d? | 2011-09-19 A | 2012-12-07 | 85% | 48.3d? | 2011-09-19 | 2012-12-07 | 322d? | 463d | finish no earlier than 2012-12-07 | R1,R2,R3,R4 | 2576h | 2189.6h | COMP_LTE_DL-Core | PCG-27 | Samsung | Rel-11 | RP-53 |  | RP-121354 |
| 583 | 203.4 | Perf. part: Coordinated Multi-Point Operation for LTE – Downlink | 456d? | 2011-09-21 | 2013-06-14 |  |  | 2011-09-21 | 2013-06-14 | 456d? | 328d | finish no earlier than 2013-06-14 | R4 | 3648h |  | COMP_LTE_DL-Perf | PCG-27 | Samsung | Rel-11 | RP-53 |  | RP-121015 |
| 584 | 204 | **Network Energy Saving for E-UTRAN** | 258d? | 2011-09-19 A | 2012-09-07 A | 100% |  | 2011-09-19 | 2012-09-07 | 258d? |  |  | R3,GP | 4160h | 4160h | Netw_Energy_LTE | PCG-27 | China Mobile | Rel-11 | RP-53 |  |  |
| 585 | 204.1 | Core part: Network Energy Saving for E-UTRAN | 257d? | 2011-09-19 A | 2012-09-07 A | 100% |  | 2011-09-19 | 2012-09-07 | 257d? |  | finish no earlier than 2012-09-07 | R3 | 2056h | 2056h | Netw_Energy_LTE-Core | PCG-27 | China Mobile | Rel-11 | RP-53 |  | RP-121016 |
| 586 | 204.2 | GERAN part: Network Energy Saving for E-UTRAN | 5d? | 2012-08-27 A | 2012-08-31 A | 100% |  | 2012-08-27 | 2012-08-31 | 5d? |  | finish no earlier than 2012-08-31 | GP | 40h | 40h | Netw_Energy_LTE | PCG-29 | Alcatel-Lucent | Rel-11 | GP-55 |  |  |
| 587 | 205 | **Enhanced downlink control channel(s) for LTE Advanced** | 323d? | 2011-12-09 A | 2013-03-01 | 31% | 224.3d? | 2011-12-09 | 2013-03-01 | 323d? | 403d |  | R1,R2,R4 | 7248h | 2214.89h | LTE_enh_dl_ctrl | PCG-28 | Alcatel-Lucent | Rel-11 | RP-54 |  |  |
| 588 | 205.1 | Core part: Enhanced downlink control channel(s) for LTE Advanced | 262d? | 2011-12-09 A | 2012-12-07 | 68% | 83.84d? | 2011-12-09 | 2012-12-07 | 262d? | 463d | finish no earlier than 2012-12-07 | R1,R2,R4 | 2096h | 1425.28h | LTE_enh_dl_ctrl-Core | PCG-28 | Alcatel-Lucent | Rel-11 | RP-54 |  | RP-121017 |
| 589 | 205.2 | Perf. part: Enhanced downlink control channel(s) for LTE Advanced | 321d? | 2011-12-13 | 2013-03-01 |  |  | 2011-12-13 | 2013-03-01 | 321d? | 403d | finish no earlier than 2013-03-01 | R4 | 2568h |  | LTE_enh_dl_ctrl-Perf | PCG-28 | Alcatel-Lucent | Rel-11 | RP-54 |  | RP-121018 |
| 590 | 206 | **Public Safety Broadband High Power UE for Band 14 for Region 2** | 202d? | 2012-03-05 A | 2012-12-07 | 70% | 60.6d? | 2012-03-05 | 2012-12-07 | 202d? | 463d |  | R4 | 3224h | 2256.82h | LTE_B14_PSBB_HPUE | PCG-28 | Motorola Solutions | Rel-11 | RP-55 |  |  |
| 591 | 206.1 | Core part: Public Safety Broadband High Power UE for Band 14 for Region 2 | 201d? | 2012-03-05 A | 2012-12-07 | 70% | 60.3d? | 2012-03-05 | 2012-12-07 | 201d? | 463d | finish no earlier than 2012-12-07 | R4 | 1608h | 1125.6h | LTE_B14_PSBB_HPUE-Core | PCG-28 | Motorola Solutions | Rel-11 | RP-55 |  | RP-121020 |
| 592 | 207 | **Improved Minimum Performance Requirements for E-UTRA: Interference Rejection** | 202d? | 2012-03-05 A | 2012-12-07 | 70% | 60.6d? | 2012-03-05 | 2012-12-07 | 202d? | 463d |  | R4 | 3224h | 2256.82h | LTE_Interf_Rej | PCG-28 | Renesas Mobile | Rel-11 | RP-55 |  |  |
| 593 | 207.1 | Perf. part: Improved Minimum Performance Requirements for E-UTRA: Interference Rejection | 201d? | 2012-03-05 A | 2012-12-07 | 70% | 60.3d? | 2012-03-05 | 2012-12-07 | 201d? | 463d | finish no earlier than 2012-12-07 | R4 | 1608h | 1125.6h | LTE_Interf_Rej-Perf | PCG-28 | Renesas Mobile | Rel-11 | RP-55 |  | RP-121021 |
| 594 | 208 | **Additional special subframe configuration for LTE TDD** | 137d? | 2012-03-05 A | 2012-09-07 A | 100% |  | 2012-03-05 | 2012-09-07 | 137d? |  |  | R4,R2,R3 | 2184h | 2184h | LTE_TDD_add_subframe | PCG-28 | China Mobile | Rel-11 | RP-55 |  |  |
| 595 | 208.1 | Core part: Additional special subframe configuration for LTE TDD | 136d? | 2012-03-05 A | 2012-09-07 A | 100% |  | 2012-03-05 | 2012-09-07 | 136d? |  | finish no earlier than 2012-09-07 | R4,R2,R3 | 1088h | 1088h | LTE_TDD_add_subframe-Core | PCG-28 | China Mobile | Rel-11 | RP-55 |  | RP-121019 |
| 596 | 209 | **LTE Advanced Carrier Aggregation of Band 3 and Band 7** | 526d? | 2010-12-10 A | 2012-12-07 A | 100% |  | 2010-12-10 | 2012-12-07 | 526d? |  |  | R4 | 12024h | 12024h | LTE_CA_B3_B7 | PCG-25 | TeliaSonera | Rel-11 | RP-48 | Issam |  |
| 597 | 209.1 | Core part: LTE Advanced Carrier Aggregation of Band 3 and Band 7 | 456d? | 2010-12-10 A | 2012-09-07 A | 100% |  | 2010-12-10 | 2012-09-07 | 456d? |  | finish no earlier than 2012-09-07 | R4 | 3648h | 3648h | LTE_CA_B3_B7-Core | PCG-25 | TeliaSonera | Rel-11 | RP-48 | Issam | RP-121022 |
| 598 | 209.2 | Perf. part: LTE Advanced Carrier Aggregation of Band 3 and Band 7 | 521d? | 2010-12-17 A | 2012-12-07 A | 100% |  | 2010-12-17 | 2012-12-07 | 521d? |  | finish no earlier than 2012-12-07 | R4 | 4168h | 4168h | LTE_CA_B3_B7-Perf | PCG-25 | TeliaSonera | Rel-11 | RP-48 | Issam | RP-121023 |

Notes:
- 573: Continuation of Rel-10 (open RAN4 Core & Perf parts) / Text3: LTE / Text5: christian.hoymann@ericsson.com
- 574: RP#57 completed. TS 36.116, TR 36.826 v100 for Information & Approval. RP#52 Core part not completed in Rel-10 / Text3: 36.133, new RAN4 (36.116, 36.826) / Text5: christian.hoymann@ericsson.com
- 575: RP#57 completion 09/12=>12/12. RP#52 transferred completely from Rel-10 UID_460213 / Text3: 36.133, new TS 36.117 (E-UTRA Relay conformance testing) / Text5: christian.hoymann@ericsson.com
- 576: Stage 2,3 / Text3: LTE / Text5: Zhenping HU
- 577: RP#57 completion 09/12=>12/12 (exception in RP-121431) / Text3: 36.133, 36.300, 36.306, 36.321, 36.331 / Text5: Zhenping HU
- 578: RP#57 completion 09/12=>12/12 / Text3: 36.133 / Text5: Zhenping HU
- 579: Stage 3. Triggered by Rel-11 TR 36.819 Study on Coordinated Multi-Point Operation for LTE (FS_CoMP_LTE) / Text3: LTE / Text5: Juho Lee (juho95.lee@samsung.com), david.mazzarese@huawei.com
- 580: RP#57 completion 09/12=>12/12 (exception in RP-121432) / Text3: 36.101, 36.104, 36.133, 36.201, 36.211, 36.212, 36.213, 36.214, 36.300, 36.306, 36.321, 36.331, 36.423 / Text5: david.mazzarese@huawei.com
- 581: - / Text3: 36.101, 36.104, 36.133, 36.141 / Text5: Xinwei Zhi (zhixinwei@huawei.com)
- 582: RP#57 completion 09/12=>12/12 (exception in RP-121449) / Text3: 36.101, 36.104, 36.133, 36.201, 36.211, 36.212, 36.213, 36.214, 36.300, 36.306, 36.321, 36.331, 36.423 / Text5: Juho Lee (juho95.lee@samsung.com)
- 583: RP#57 completion 12/12=>06/13 / Text3: 36.101, 36.104, 36.133, 36.141, 36.307 / Text5: xutao.zhou@samsung.com
- 584: Stage 2,3. RP#56 updated WID RP-111376=>RP-120620 / Text3: LTE, GERAN / Text5: yangning@chinamobile.com
- 585: RP#57 completed. Inter-RAT aspect can affect UTRA and GERAN as well / Text3: 25.413, 36.300, 36.413, 36.423 / Text5: yangning@chinamobile.com
- 586: GP#55 approved WID and completed. Stage 3. Changes in RIM protocol and in SON Transfer RIM application to provide support for Energy Savings Indication feature / Text3: 48.018 [Serving GPRS Support Node (SGSN); BSS GPRS protocol (BSSGP)] / Text5: marguerite.woch@alcatel-lucent.com
- 587: Stage 3. Triggered by UID_510037 Rel-11 TR 36.871 Study on further Downlink MIMO enhancements for LTE-Advanced (FS_LTE_eDL_MIMO_enh) / Text3: LTE / Text5: sigen.ye@alcatel-lucent.com
- 588: RP#57 completion 09/12=>12/12 (exception in RP-121192) / Text3: 36.101, 36.211, 36.212, 36.213, 36.331 / Text5: sigen.ye@alcatel-lucent.com
- 589: - / Text3: 36.101, 36.104, 36.133, 36.141 / Text5: teck.hu@alcatel-lucent.com
- 590: Stage 3 / Text3: LTE / Text5: xiaowei.jin@motorolasolutions.com
- 591: RP#57 exception in RP-121164 / Text3: 36.101, new TR 36.837 / Text5: xiaowei.jin@motorolasolutions.com
- 592: Triggered by FS_enh_perf_UE_LTE. Adds Perf. requirements for demodulation of the already specified PDSCH with the transmission modes defined in Rel-8 to Rel-10 / Text3: LTE / Text5: Timo Roman
- 593: - / Text3: 36.101 / Text5: Timo Roman
- 594: Stage 3. Exists already for 1UL a WI LTE_CA_B3_B5 / Text3: LTE / Text5: Xiaodong Shen
- 595: RP#57 completed / Text3: 36.211, 36.213, 36.331, 36.423 / Text5: Xiaodong Shen
- 596: RP#57 completed. In Europe Band 3,7,20 are interesting for LTE and LTE-Advanced deployment. Different CA combinations for these bands are of high priority for Region 1 / Text3: LTE / Text5: Ralf.Schuh@TeliaSonera.com
- 597: RP#57 completed / Text3: 36.101, 36.104, 36.307, new generic TR 36.850 / Text5: Ralf.Schuh@TeliaSonera.com
- 598: RP#57 completed / Text3: 36.133, 36.141 / Text5: Ralf.Schuh@TeliaSonera.com

| ID | WBS | Task | Duration | Start | Finish | Complete | Remaining | Baseline start | Baseline finish | Baseline duration | Total slack | Constraint | Resources | Work | Actual work | Text1 | Text2 | Text4 | Text5 | Text6 | Text7 | Text8 | Text11 |
| --- | --- | --- | --- | --- | --- | --- | --- | --- | --- | --- | --- | --- | --- | --- | --- | --- | --- | --- | --- | --- | --- | --- | --- |
| 599 | 210 | **LTE Advanced Carrier Aggregation of Band 4 and Band 17** | 526d? | 2010-12-10 A | 2012-12-07 | 57% | 223.71d? | 2010-12-10 | 2012-12-07 | 526d? | 463d |  | R4 | 12048h | 6923.91h | LTE_CA_B4_B17 | PCG-26 | AT&T | marc.grant@att.com | Rel-11 | RP-50 | Issam |  |
| 600 | 210.1 | Core part: LTE Advanced Carrier Aggregation of Band 4 and Band 17 | 459d? | 2010-12-10 A | 2012-09-07 A | 100% |  | 2010-12-10 | 2012-09-07 | 459d? |  | finish no earlier than 2012-09-07 | R4 | 3672h | 3672h | LTE_CA_B4_B17-Core | PCG-26 | AT&T | marc.grant@att.com | Rel-11 | RP-50 | Issam | RP-121024 |
| 601 | 210.2 | Perf. part: LTE Advanced Carrier Aggregation of Band 4 and Band 17 | 521d? | 2010-12-17 A | 2012-12-07 | 20% | 416.8d? | 2010-12-17 | 2012-12-07 | 521d? | 463d | finish no earlier than 2012-12-07 | R4 | 4168h | 833.6h | LTE_CA_B4_B17-Perf | PCG-26 | AT&T | marc.grant@att.com | Rel-11 | RP-50 | Issam | RP-121025 |
| 602 | 211 | **LTE Advanced Carrier Aggregation of Band 4 and Band 13** | 526d? | 2010-12-10 A | 2012-12-07 | 47% | 280.5d? | 2010-12-10 | 2012-12-07 | 526d? | 463d |  | R4 | 12024h | 5612.02h | LTE_CA_B4_B13 | PCG-26 | Ericsson | christian.bergljung@stericsson.com | Rel-11 | RP-50 | Issam |  |
| 603 | 211.1 | Core part: LTE Advanced Carrier Aggregation of Band 4 and Band 13 | 456d? | 2010-12-10 A | 2012-09-07 A | 100% |  | 2010-12-10 | 2012-09-07 | 456d? |  | finish no earlier than 2012-09-07 | R4 | 3648h | 3648h | LTE_CA_B4_B13-Core | PCG-26 | Ericsson | christian.bergljung@stericsson.com | Rel-11 | RP-50 | Issam | RP-121026 |
| 604 | 211.2 | Perf. part: LTE Advanced Carrier Aggregation of Band 4 and Band 13 | 521d? | 2010-12-17 | 2012-12-07 |  |  | 2010-12-17 | 2012-12-07 | 521d? | 463d | finish no earlier than 2012-12-07 | R4 | 4168h |  | LTE_CA_B4_B13-Perf | PCG-26 | Ericsson | christian.bergljung@stericsson.com | Rel-11 | RP-50 | Issam | RP-121027 |
| 605 | 212 | **LTE Advanced Carrier Aggregation of Band 4 and Band 12** | 454d? | 2011-03-22 A | 2012-12-07 | 45% | 249.25d? | 2011-03-22 | 2012-12-07 | 454d? | 463d |  | R4,R2 | 10864h | 4899.6h | LTE_CA_B4_B12 | PCG-26 | Leap Wireless | Bill Chandler (bchandler@cricketcommunications.com) | Rel-11 | RP-51 | Issam |  |
| 606 | 212.1 | Core part: LTE Advanced Carrier Aggregation of Band 4 and Band 12 | 453d? | 2011-03-22 A | 2012-12-07 | 90% | 45.3d? | 2011-03-22 | 2012-12-07 | 453d? | 463d | finish no earlier than 2012-12-07 | R4,R2 | 3624h | 3261.6h | LTE_CA_B4_B12-Core | PCG-26 | Leap Wireless | Bill Chandler (bchandler@cricketcommunications.com) | Rel-11 | RP-51 | Issam | RP-121028 |
| 607 | 212.2 | Perf. part: LTE Advanced Carrier Aggregation of Band 4 and Band 12 | 451d? | 2011-03-25 | 2012-12-07 |  |  | 2011-03-25 | 2012-12-07 | 451d? | 463d | finish no earlier than 2012-12-07 | R4 | 3608h |  | LTE_CA_B4_B12-Perf | PCG-26 | Leap Wireless | Bill Chandler (bchandler@cricketcommunications.com) | Rel-11 | RP-51 | Issam | RP-121029 |
| 608 | 213 | **LTE Advanced Carrier Aggregation of Band 5 and Band 12** | 454d? | 2011-03-22 A | 2012-12-07 | 93% | 34.04d? | 2011-03-22 | 2012-12-07 | 454d? | 463d |  | R4,R2 | 10848h | 10034.5h | LTE_CA_B5_B12 | PCG-26 | US Cellular | Sebastian THALANANY | Rel-11 | RP-51 | Issam |  |
| 609 | 213.1 | Core part: LTE Advanced Carrier Aggregation of Band 5 and Band 12 | 451d? | 2011-03-22 A | 2012-12-07 | 95% | 22.55d? | 2011-03-22 | 2012-12-07 | 451d? | 463d | finish no earlier than 2012-09-07 | R4,R2 | 3608h | 3427.6h | LTE_CA_B5_B12-Core | PCG-26 | US Cellular | Sebastian THALANANY | Rel-11 | RP-51 | Issam | RP-121237 |
| 610 | 213.2 | Perf. part: LTE Advanced Carrier Aggregation of Band 5 and Band 12 | 451d? | 2011-03-25 A | 2012-12-07 | 90% | 45.1d? | 2011-03-25 | 2012-12-07 | 451d? | 463d | finish no earlier than 2012-12-07 | R4 | 3608h | 3247.2h | LTE_CA_B5_B12-Perf | PCG-26 | US Cellular | Sebastian THALANANY | Rel-11 | RP-51 | Issam | RP-121031 |
| 611 | 214 | **LTE Advanced Carrier Aggregation of Band 7 and Band 20** | 389d? | 2011-03-22 A | 2012-09-07 A | 100% |  | 2011-03-22 | 2012-09-07 | 389d? |  |  | R4 | 9288h | 9288h | LTE_CA_B7_B20 | PCG-26 | Huawei | Steven Chen | Rel-11 | RP-51 | Issam |  |
| 612 | 214.1 | Core part: LTE Advanced Carrier Aggregation of Band 7 and Band 20 | 386d? | 2011-03-22 A | 2012-09-07 A | 100% |  | 2011-03-22 | 2012-09-07 | 386d? |  | finish no earlier than 2012-09-07 | R4 | 3088h | 3088h | LTE_CA_B7_B20-Core | PCG-26 | Huawei | Steven Chen | Rel-11 | RP-51 | Issam | RP-121032 |
| 613 | 214.2 | Perf. part: LTE Advanced Carrier Aggregation of Band 7 and Band 20 | 386d? | 2011-03-25 A | 2012-09-07 A | 100% |  | 2011-03-25 | 2012-09-07 | 386d? |  | finish no earlier than 2012-09-07 | R4 | 3088h | 3088h | LTE_CA_B7_B20-Perf | PCG-26 | Huawei | Steven Chen | Rel-11 | RP-51 | Issam | RP-121033 |
| 614 | 215 | **LTE Advanced Carrier Aggregation of Band 2 and Band 17** | 453d? | 2011-03-23 A | 2012-12-07 | 57% | 195.27d? | 2011-03-23 | 2012-12-07 | 453d? | 463d |  | R4 | 10320h | 5871.42h | LTE_CA_B2_B17 | PCG-26 | AT&T | marc.grant@att.com | Rel-11 | RP-51 | Issam |  |
| 615 | 215.1 | Core part: LTE Advanced Carrier Aggregation of Band 2 and Band 17 | 386d? | 2011-03-23 A | 2012-09-07 A | 100% |  | 2011-03-23 | 2012-09-07 | 386d? |  | finish no earlier than 2012-09-07 | R4 | 3088h | 3088h | LTE_CA_B2_B17-Core | PCG-26 | AT&T | marc.grant@att.com | Rel-11 | RP-51 | Issam | RP-121034 |
| 616 | 215.2 | Perf. part: LTE Advanced Carrier Aggregation of Band 2 and Band 17 | 451d? | 2011-03-25 A | 2012-12-07 | 20% | 360.8d? | 2011-03-25 | 2012-12-07 | 451d? | 463d | finish no earlier than 2012-12-07 | R4 | 3608h | 721.6h | LTE_CA_B2_B17-Perf | PCG-26 | AT&T | marc.grant@att.com | Rel-11 | RP-51 | Issam | RP-121035 |
| 617 | 216 | **LTE Advanced Carrier Aggregation of Band 4 and Band 5** | 453d? | 2011-03-23 A | 2012-12-07 | 22% | 351.09d? | 2011-03-23 | 2012-12-07 | 453d? | 463d |  | R4 | 10840h | 2438.9h | LTE_CA_B4_B5 | PCG-26 | AT&T | marc.grant@att.com | Rel-11 | RP-51 | Issam |  |
| 618 | 216.1 | Core part: LTE Advanced Carrier Aggregation of Band 4 and Band 5 | 451d? | 2011-03-23 A | 2012-12-07 | 35% | 293.15d? | 2011-03-23 | 2012-12-07 | 451d? | 463d | finish no earlier than 2012-12-07 | R4 | 3608h | 1262.8h | LTE_CA_B4_B5-Core | PCG-26 | AT&T | marc.grant@att.com | Rel-11 | RP-51 | Issam | RP-121036 |
| 619 | 216.2 | Perf. part: LTE Advanced Carrier Aggregation of Band 4 and Band 5 | 451d? | 2011-03-25 A | 2012-12-07 | 10% | 405.9d? | 2011-03-25 | 2012-12-07 | 451d? | 463d | finish no earlier than 2012-12-07 | R4 | 3608h | 360.8h | LTE_CA_B4_B5-Perf | PCG-26 | AT&T | marc.grant@att.com | Rel-11 | RP-51 | Issam | RP-121037 |
| 620 | 217 | **LTE Advanced Carrier Aggregation of Band 5 and Band 17** | 453d? | 2011-03-23 A | 2012-12-07 | 22% | 351.09d? | 2011-03-23 | 2012-12-07 | 453d? | 463d |  | R4 | 10840h | 2438.9h | LTE_CA_B5_B17 | PCG-26 | AT&T | marc.grant@att.com | Rel-11 | RP-51 | Issam |  |
| 621 | 217.1 | Core part: LTE Advanced Carrier Aggregation of Band 5 and Band 17 | 451d? | 2011-03-23 A | 2012-12-07 | 35% | 293.15d? | 2011-03-23 | 2012-12-07 | 451d? | 463d | finish no earlier than 2012-12-07 | R4 | 3608h | 1262.8h | LTE_CA_B5_B17-Core | PCG-26 | AT&T | marc.grant@att.com | Rel-11 | RP-51 | Issam | RP-121038 |
| 622 | 217.2 | Perf. part: LTE Advanced Carrier Aggregation of Band 5 and Band 17 | 451d? | 2011-03-25 A | 2012-12-07 | 10% | 405.9d? | 2011-03-25 | 2012-12-07 | 451d? | 463d | finish no earlier than 2012-12-07 | R4 | 3608h | 360.8h | LTE_CA_B5_B17-Perf | PCG-26 | AT&T | marc.grant@att.com | Rel-11 | RP-51 | Issam | RP-121039 |

Notes:
- 599: Stage 3. RP#57 Core completed / Text3: LTE
- 600: RP#57 completed. Updated WID RP-111750=>RP-121458 / Text3: 36.101, 36.104, 36.133, 36.141, 36.307, new generic TR 36.850
- 601: Updated WID RP-111750=>RP-121458 / Text3: 36.101, 36.104, 36.133, 36.307
- 602: Stage 3. RP#57 Core completed / Text3: LTE
- 603: RP#57 completed / Text3: 36.101, 36.104, 36.133, 36.307, new generic TR 36.850
- 604: - / Text3: 36.101, 36.133, 36.141
- 605: Stage 3 / Text3: LTE
- 606: RP#57 completion 09/12=>12/12 (exception in RP-121167) / Text3: 36.101, 36.104, 36.307, new generic TR 36.850
- 607: - / Text3: 36.133, 36.141
- 608: Stage 3. RP#57 Core completed / Text3: LTE
- 609: RP#57 completion 09/12=>12/12 (exception in RP-121168) / Text3: 36.101, 36.104, 36.133, 36.141, 36.307, new generic TR 36.850
- 610: - / Text3: 36.101, 36.104, 36.133, 36.307
- 611: Stage 3. RP#57 completed / Text3: LTE
- 612: RP#57 completed / Text3: 36.101, 36.104, 36.307, new generic TR 36.850
- 613: RP#57 completed / Text3: 36.133, 36.141
- 614: Stage 3. RP#57 Core completed / Text3: LTE
- 615: RP#57 completed / Text3: 36.101, 36.104, 36.133, 36.141, 36.307, new generic TR 36.850
- 616: - / Text3: 36.101, 36.104, 36.133, 36.307
- 617: Stage 3 / Text3: LTE
- 618: RP#57 completion 09/12=>12/12 (exception in RP-121207) / Text3: 36.101, 36.104, 36.133, 36.141, 36.307, new generic TR 36.850
- 619: - / Text3: 36.101, 36.104, 36.133, 36.307
- 620: Stage 3 / Text3: LTE
- 621: RP#57 completion 09/12=>12/12 (exception in RP-121208) / Text3: 36.101, 36.104, 36.133, 36.141, 36.307, new generic TR 36.850
- 622: - / Text3: 36.101, 36.104, 36.133, 36.141, 36.307

| ID | WBS | Task | Duration | Start | Finish | Complete | Remaining | Baseline start | Baseline finish | Baseline duration | Total slack | Constraint | Resources | Work | Actual work | Text1 | Text2 | Text4 | Text5 | Text6 | Text7 | Text11 |
| --- | --- | --- | --- | --- | --- | --- | --- | --- | --- | --- | --- | --- | --- | --- | --- | --- | --- | --- | --- | --- | --- | --- |
| 623 | 218 | **LTE Advanced Carrier Aggregation of Band 3 and Band 20** | 258d? | 2011-09-19 A | 2012-09-07 A | 100% |  | 2011-09-19 | 2012-09-07 | 258d? |  |  | R4 | 6168h | 6168h | LTE_CA_B3_B20 | PCG-27 | Vodafone | tim.frost@vodafone.com | Rel-11 | RP-53 |  |
| 624 | 218.1 | Core part: LTE Advanced Carrier Aggregation of Band 3 and Band 20 | 256d? | 2011-09-19 A | 2012-09-07 A | 100% |  | 2011-09-19 | 2012-09-07 | 256d? |  | finish no earlier than 2012-09-07 | R4 | 2048h | 2048h | LTE_CA_B3_B20-Core | PCG-27 | Vodafone | tim.frost@vodafone.com | Rel-11 | RP-53 | RP-121046 |
| 625 | 218.2 | Perf. part: LTE Advanced Carrier Aggregation of Band 3 and Band 20 | 257d? | 2011-09-20 A | 2012-09-07 A | 100% |  | 2011-09-20 | 2012-09-07 | 257d? |  | finish no earlier than 2012-09-07 | R4 | 2056h | 2056h | LTE_CA_B3_B20-Perf | PCG-27 | Vodafone | tim.frost@vodafone.com | Rel-11 | RP-53 | RP-121047 |
| 626 | 219 | **LTE Advanced Carrier Aggregation of Band 8 and Band 20** | 323d? | 2011-09-19 A | 2012-12-07 | 25% | 242d? | 2011-09-19 | 2012-12-07 | 323d? | 463d |  | R4 | 7736h | 1940.01h | LTE_CA_B8_B20 | PCG-27 | Vodafone | Luis.Anaya@vodafone.com | Rel-11 | RP-53 |  |
| 627 | 219.1 | Core part: LTE Advanced Carrier Aggregation of Band 8 and Band 20 | 323d? | 2011-09-19 A | 2012-12-07 | 50% | 161.5d? | 2011-09-19 | 2012-12-07 | 323d? | 463d | finish no earlier than 2012-12-07 | R4 | 2584h | 1292h | LTE_CA_B8_B20-Core | PCG-27 | Vodafone | Luis.Anaya@vodafone.com | Rel-11 | RP-53 | RP-121048 |
| 628 | 219.2 | Perf. part: LTE Advanced Carrier Aggregation of Band 8 and Band 20 | 321d? | 2011-09-21 | 2012-12-07 |  |  | 2011-09-21 | 2012-12-07 | 321d? | 463d | finish no earlier than 2012-12-07 | R4 | 2568h |  | LTE_CA_B8_B20-Perf | PCG-27 | Vodafone | Luis.Anaya@vodafone.com | Rel-11 | RP-53 | RP-121049 |
| 629 | 220 | **LTE Advanced Carrier Aggregation of Band 1 and Band 7** | 323d? | 2011-09-19 A | 2012-12-07 | 40% | 193.6d? | 2011-09-19 | 2012-12-07 | 323d? | 463d |  | R4 | 7728h | 2459.52h | LTE_CA_B1_B7 | PCG-27 | China Telecom | Dong Zhao (zhaodong@ctbri.com.cn) | Rel-11 | RP-53 |  |
| 630 | 220.1 | Core part: LTE Advanced Carrier Aggregation of Band 1 and Band 7 | 322d? | 2011-09-19 A | 2012-12-07 | 80% | 64.4d? | 2011-09-19 | 2012-12-07 | 322d? | 463d | finish no earlier than 2012-12-07 | R4 | 2576h | 2060.8h | LTE_CA_B1_B7-Core | PCG-27 | China Telecom | Dong Zhao (zhaodong@ctbri.com.cn) | Rel-11 | RP-53 | RP-121040 |
| 631 | 220.2 | Perf. part: LTE Advanced Carrier Aggregation of Band 1 and Band 7 | 321d? | 2011-09-21 | 2012-12-07 |  |  | 2011-09-21 | 2012-12-07 | 321d? | 463d | finish no earlier than 2012-12-07 | R4 | 2568h |  | LTE_CA_B1_B7-Perf | PCG-27 | China Telecom | Dong Zhao (zhaodong@ctbri.com.cn) | Rel-11 | RP-53 | RP-121041 |
| 632 | 221 | **LTE Advanced Carrier Aggregation of Band 3 and Band 5** | 258d? | 2011-09-19 A | 2012-09-07 A | 100% |  | 2011-09-19 | 2012-09-07 | 258d? |  |  | R4 | 6160h | 6160h | LTE_CA_B3_B5 | PCG-27 | SK Telecom | Haesung Park | Rel-11 | RP-53 |  |
| 633 | 221.1 | Core part: LTE Advanced Carrier Aggregation of Band 3 and Band 5 | 256d? | 2011-09-19 A | 2012-09-07 A | 100% |  | 2011-09-19 | 2012-09-07 | 256d? |  | finish no earlier than 2012-09-07 | R4 | 2048h | 2048h | LTE_CA_B3_B5-Core | PCG-27 | SK Telecom | Haesung Park | Rel-11 | RP-53 | RP-121042 |
| 634 | 221.2 | Perf. part: LTE Advanced Carrier Aggregation of Band 3 and Band 5 | 256d? | 2011-09-21 A | 2012-09-07 A | 100% |  | 2011-09-21 | 2012-09-07 | 256d? |  | finish no earlier than 2012-09-07 | R4 | 2048h | 2048h | LTE_CA_B3_B5-Perf | PCG-27 | SK Telecom | Haesung Park | Rel-11 | RP-53 | RP-121043 |
| 635 | 222 | **LTE Advanced Carrier Aggregation of Band 4 and Band 7** | 323d? | 2011-09-19 A | 2012-12-07 | 33% | 217.86d? | 2011-09-19 | 2012-12-07 | 323d? | 463d |  | R4 | 7728h | 2515.5h | LTE_CA_B4_B7 | PCG-27 | Rogers Wireless | takwing.wan@rci.rogers.com | Rel-11 | RP-53 |  |
| 636 | 222.1 | Core part: LTE Advanced Carrier Aggregation of Band 4 and Band 7 | 322d? | 2011-09-19 A | 2012-12-07 | 65% | 112.7d? | 2011-09-19 | 2012-12-07 | 322d? | 463d | finish no earlier than 2012-12-07 | R4 | 2576h | 1674.4h | LTE_CA_B4_B7-Core | PCG-27 | Rogers Wireless | takwing.wan@rci.rogers.com | Rel-11 | RP-53 | RP-121044 |
| 637 | 222.2 | Perf. part: LTE Advanced Carrier Aggregation of Band 4 and Band 7 | 321d? | 2011-09-21 | 2012-12-07 |  |  | 2011-09-21 | 2012-12-07 | 321d? | 463d | finish no earlier than 2012-12-07 | R4 | 2568h |  | LTE_CA_B4_B7-Perf | PCG-27 | Rogers Wireless | takwing.wan@rci.rogers.com | Rel-11 | RP-53 | RP-121045 |
| 638 | 223 | **LTE Advanced Carrier Aggregation of Band 11 and Band 18** | 263d? | 2011-12-09 A | 2012-12-07 | 45% | 144.42d? | 2011-12-09 | 2012-12-07 | 263d? | 463d |  | R4,R2 | 6288h | 2835.01h | LTE_CA_B11_B18 | PCG-28 | KDDI | Masaaki Obara | Rel-11 | RP-54 |  |
| 639 | 223.1 | Core part: LTE Advanced Carrier Aggregation of Band 11 and Band 18 | 262d? | 2011-12-09 A | 2012-12-07 | 90% | 26.2d? | 2011-12-09 | 2012-12-07 | 262d? | 463d | finish no earlier than 2012-12-07 | R4,R2 | 2096h | 1886.4h | LTE_CA_B11_B18-Core | PCG-28 | KDDI | Masaaki Obara | Rel-11 | RP-54 | RP-121050 |
| 640 | 223.2 | Perf. part: LTE Advanced Carrier Aggregation of Band 11 and Band 18 | 261d? | 2011-12-13 | 2012-12-07 |  |  | 2011-12-13 | 2012-12-07 | 261d? | 463d | finish no earlier than 2012-12-07 | R4 | 2088h |  | LTE_CA_B11_B18-Perf | PCG-28 | KDDI | Masaaki Obara | Rel-11 | RP-54 | RP-121051 |
| 641 | 224 | **LTE Advanced Carrier Aggregation of Band 1 and Band 18** | 198d? | 2011-12-09 A | 2012-09-07 A | 100% |  | 2011-12-09 | 2012-09-07 | 198d? |  |  | R4,R2 | 4720h | 4720h | LTE_CA_B1_B18 | PCG-28 | KDDI | Masaaki Obara | Rel-11 | RP-54 |  |
| 642 | 224.1 | Core part: LTE Advanced Carrier Aggregation of Band 1 and Band 18 | 196d? | 2011-12-09 A | 2012-09-07 A | 100% |  | 2011-12-09 | 2012-09-07 | 196d? |  | finish no earlier than 2012-09-07 | R4,R2 | 1568h | 1568h | LTE_CA_B1_B18-Core | PCG-28 | KDDI | Masaaki Obara | Rel-11 | RP-54 | RP-121052 |
| 643 | 224.2 | Perf. part: LTE Advanced Carrier Aggregation of Band 1 and Band 18 | 196d? | 2011-12-13 A | 2012-09-07 A | 100% |  | 2011-12-13 | 2012-09-07 | 196d? |  | finish no earlier than 2012-12-07 | R4 | 1568h | 1568h | LTE_CA_B1_B18-Perf | PCG-28 | KDDI | Masaaki Obara | Rel-11 | RP-54 | RP-121053 |
| 644 | 225 | **LTE Advanced Carrier Aggregation of Band 1 and Band 19** | 137d? | 2011-12-09 A | 2012-06-15 A | 100% |  | 2011-12-09 | 2012-06-15 | 137d? |  |  | R4,R2 | 3274.63h | 3274.63h | LTE_CA_B1_B19 | PCG-28 | NTT DoCoMo | Hiromasa Umeda (umedah@nttdocomo.co.jp) | Rel-11 | RP-54 |  |
| 645 | 225.1 | Core part: LTE Advanced Carrier Aggregation of Band 1 and Band 19 | 137d? | 2011-12-09 A | 2012-06-15 A | 100% |  | 2011-12-09 | 2012-06-15 | 137d? |  | finish no earlier than 2012-09-07 | R4,R2 | 1090.63h | 1090.63h | LTE_CA_B1_B19-Core | PCG-28 | NTT DoCoMo | Hiromasa Umeda (umedah@nttdocomo.co.jp) | Rel-11 | RP-54 | RP-120552 |
| 646 | 225.2 | Perf. part: LTE Advanced Carrier Aggregation of Band 1 and Band 19 | 136d? | 2011-12-12 A | 2012-06-15 A | 100% |  | 2011-12-12 | 2012-06-15 | 136d? |  | finish no earlier than 2012-12-07 | R4 | 1088h | 1088h | LTE_CA_B1_B19-Perf | PCG-28 | NTT DoCoMo | Hiromasa Umeda (umedah@nttdocomo.co.jp) | Rel-11 | RP-54 | RP-120553 |

Notes:
- 623: Stage 3. RP#57 completed / Text3: LTE
- 624: RP#57 completed / Text3: 36.101, 36.104, 36.133, 36.307, new generic TR 36.850
- 625: RP#57 completed / Text3: 36.101, 36.104, 36.133, 36.141, 36.307
- 626: Stage 3 / Text3: LTE
- 627: RP#57 completion 09/12=>12/12 (exception in RP-121281) / Text3: 36.101, 36.104, 36.307, new generic TR 36.850
- 628: - / Text3: 36.101, 36.104, 36.133, 36.141
- 629: Stage 3 / Text3: LTE
- 630: RP#57 completion 09/12=>12/12 (exception in RP-121151) / Text3: 36.101, 36.104, 36.307, new generic TR 36.850
- 631: - / Text3: 36.101, 36.104, 36.113, 36.124, 36.133, 36.141, 36.307, 37.104, 37.141
- 632: Stage 3. RP#57 completed / Text3: LTE
- 633: RP#57 completed / Text3: 36.101, 36.104, 36.133, 36.307, new generic TR 36.850
- 634: RP#57 completed / Text3: 36.133, 36.141
- 635: Stage 3. RP#57 updated WID RP-120896=>RP-121152 (change of rapporteur) / Text3: LTE
- 636: RP#57 completion 09/12=>12/12 (exception in RP-121153) / Text3: 36.101, 36.104, 36.133, 36.141, 36.307, 37.104, new generic TR 36.850
- 637: - / Text3: 36.101, 36.104, 36.133, 36.141, 36.307
- 638: Stage 3 / Text3: LTE
- 639: RP#57 completion 09/12=>12/12 (exception in RP-121158) / Text3: 36.101, 36.104, 36.307, new generic TR 36.850
- 640: - / Text3: 36.133
- 641: Stage 3. RP#57 completed / Text3: LTE
- 642: RP#57 completed / Text3: 36.101, 36.104, 36.307, new generic TR 36.850
- 643: RP#57 completed / Text3: 36.133, 36.141
- 644: Stage 3. RP#56 completed. Updated WID RP-111765=>RP-120866 / Text3: LTE
- 645: RP#56 completed / Text3: 36.101, 36.104, 36.133, 36.307, new generic TR 36.850
- 646: RP#56 completed / Text3: 36.133, 36.141

| ID | WBS | Task | Duration | Start | Finish | Complete | Remaining | Baseline start | Baseline finish | Baseline duration | Total slack | Constraint | Resources | Work | Actual work | Text1 | Text2 | Text4 | Text6 | Text7 | Text11 | Text8 |
| --- | --- | --- | --- | --- | --- | --- | --- | --- | --- | --- | --- | --- | --- | --- | --- | --- | --- | --- | --- | --- | --- | --- |
| 647 | 226 | **LTE Advanced Carrier Aggregation of Band 1 and Band 21** | 263d? | 2011-12-09 A | 2012-12-07 A | 100% |  | 2011-12-09 | 2012-12-07 | 263d? |  |  | R4,R2 | 5760h | 5760h | LTE_CA_B1_B21 | PCG-28 | NTT DoCoMo | Rel-11 | RP-54 |  |  |
| 648 | 226.1 | Core part: LTE Advanced Carrier Aggregation of Band 1 and Band 21 | 196d? | 2011-12-09 A | 2012-09-07 A | 100% |  | 2011-12-09 | 2012-09-07 | 196d? |  | finish no earlier than 2012-09-07 | R4,R2 | 1568h | 1568h | LTE_CA_B1_B21-Core | PCG-28 | NTT DoCoMo | Rel-11 | RP-54 | RP-121054 |  |
| 649 | 226.2 | Perf. part: LTE Advanced Carrier Aggregation of Band 1 and Band 21 | 261d? | 2011-12-13 A | 2012-12-07 A | 100% |  | 2011-12-13 | 2012-12-07 | 261d? |  | finish no earlier than 2012-12-07 | R4 | 2088h | 2088h | LTE_CA_B1_B21-Perf | PCG-28 | NTT DoCoMo | Rel-11 | RP-54 | RP-121055 |  |
| 650 | 227 | **LTE Advanced Carrier Aggregation of Band 3 and Band 8** | 337d? | 2012-03-05 A | 2013-06-14 | 42% | 193.92d? | 2012-03-05 | 2013-06-14 | 337d? | 328d |  | R4 | 6992h | 2968.65h | LTE_CA_B3_B8 | PCG-28 | KT | Rel-11 | RP-55 |  |  |
| 651 | 227.1 | Core part: LTE Advanced Carrier Aggregation of Band 3 and Band 8 | 201d? | 2012-03-05 A | 2012-12-07 | 80% | 40.2d? | 2012-03-05 | 2012-12-07 | 201d? | 463d | finish no earlier than 2012-12-07 | R4 | 1608h | 1286.4h | LTE_CA_B3_B8-Core | PCG-28 | KT | Rel-11 | RP-55 | RP-121058 |  |
| 652 | 227.2 | Perf. part: LTE Advanced Carrier Aggregation of Band 3 and Band 8 | 336d? | 2012-03-06 A | 2013-06-14 | 20% | 268.8d? | 2012-03-06 | 2013-06-14 | 336d? | 328d | finish no earlier than 2013-06-14 | R4 | 2688h | 537.6h | LTE_CA_B3_B8-Perf | PCG-28 | KT | Rel-11 | RP-55 | RP-121059 |  |
| 653 | 228 | **LTE Carrier Aggregation Enhancements** | 514d? | 2011-03-22 A | 2013-03-01 | 33% | 345.12d? | 2011-03-22 | 2013-03-01 | 514d? | 403d |  | R1,R2,R3,R4 | 11816h | 3882.24h | LTE_CA_enh | PCG-26 | Nokia | Rel-11 | RP-51 |  | Patrick |
| 654 | 228.1 | Core part: LTE Carrier Aggregation Enhancements | 452d? | 2011-03-22 A | 2012-12-07 | 70% | 135.6d? | 2011-03-22 | 2012-12-07 | 452d? | 463d | finish no earlier than 2012-12-07 | R1,R2,R4,R3 | 3616h | 2531.2h | LTE_CA_enh-Core | PCG-26 | Nokia | Rel-11 | RP-51 | RP-121004 | Patrick |
| 655 | 228.2 | Perf. part: LTE Carrier Aggregation Enhancements | 511d? | 2011-03-25 | 2013-03-01 |  |  | 2011-03-25 | 2013-03-01 | 511d? | 403d | finish no earlier than 2013-03-01 | R4 | 4088h |  | LTE_CA_enh-Perf | PCG-26 | Nokia | Rel-11 | RP-51 | RP-121005 | Issam |
| 656 | 229 | **LTE Advanced Carrier Aggregation in Band 38** | 334d? | 2011-06-07 A | 2012-09-07 A | 100% |  | 2011-06-07 | 2012-09-07 | 334d? |  |  | R4 | 7976h | 7976h | LTE_CA_B38 | PCG-27 | Huawei | Rel-11 | RP-52 |  | Issam |
| 657 | 229.1 | Core part: LTE Advanced Carrier Aggregation in Band 38 | 331d? | 2011-06-07 A | 2012-09-07 A | 100% |  | 2011-06-07 | 2012-09-07 | 331d? |  | finish no earlier than 2012-09-07 | R4 | 2648h | 2648h | LTE_CA_B38-Core | PCG-27 | Huawei | Rel-11 | RP-52 | RP-121060 | Issam |
| 658 | 229.2 | Perf. part: LTE Advanced Carrier Aggregation in Band 38 | 333d? | 2011-06-08 A | 2012-09-07 A | 100% |  | 2011-06-08 | 2012-09-07 | 333d? |  | finish no earlier than 2012-09-07 | R4 | 2656h | 2656h | LTE_CA_B38-Perf | PCG-27 | Huawei | Rel-11 | RP-52 | RP-121061 | Issam |
| 659 | 230 | **LTE Advanced Carrier Aggregation in Band 41** | 197d? | 2011-06-07 A | 2012-03-02 A | 100% |  | 2011-06-07 | 2012-03-02 | 197d? |  |  | R4 | 4720h | 4720h | LTE_CA_B41 | PCG-27 | Clearwire | Rel-11 | RP-52 |  | Issam |
| 660 | 230.1 | Core part: LTE Advanced Carrier Aggregation in Band 41 | 196d? | 2011-06-07 A | 2012-03-02 A | 100% |  | 2011-06-07 | 2012-03-02 | 196d? |  | finish no earlier than 2012-02-23 | R4 | 1568h | 1568h | LTE_CA_B41-Core | PCG-27 | Clearwire | Rel-11 | RP-52 | RP-120126 | Issam |
| 661 | 230.2 | Perf. part: LTE Advanced Carrier Aggregation in Band 41 | 197d? | 2011-06-07 A | 2012-03-02 A | 100% |  | 2011-06-07 | 2012-03-02 | 197d? |  | finish no earlier than 2012-03-02 | R4 | 1576h | 1576h | LTE_CA_B41-Perf | PCG-27 | Clearwire | Rel-11 | RP-52 | RP-120127 | Issam |
| 662 | 231 | **LTE Advanced Carrier Aggregation in Band 7** | 258d? | 2011-09-19 A | 2012-09-07 A | 100% |  | 2011-09-19 | 2012-09-07 | 258d? |  |  | R4 | 6168h | 6168h | LTE_CA_B7 | PCG-27 | China Unicom | Rel-11 | RP-53 |  |  |
| 663 | 231.1 | Core part: LTE Advanced Carrier Aggregation in Band 7 | 256d? | 2011-09-19 A | 2012-09-07 A | 100% |  | 2011-09-19 | 2012-09-07 | 256d? |  | finish no earlier than 2012-09-07 | R4 | 2048h | 2048h | LTE_CA_B7-Core | PCG-27 | China Unicom | Rel-11 | RP-53 | RP-121062 |  |
| 664 | 231.2 | Perf. part: LTE Advanced Carrier Aggregation in Band 7 | 257d? | 2011-09-20 A | 2012-09-07 A | 100% |  | 2011-09-20 | 2012-09-07 | 257d? |  | finish no earlier than 2012-09-07 | R4 | 2056h | 2056h | LTE_CA_B7-Perf | PCG-27 | China Unicom | Rel-11 | RP-53 | RP-121063 |  |
| 665 | 232 | UE Conformance Test Aspects for LTE Advanced Carrier Aggregation of Intra-band contiguous and Inter-band configurations | 266d? | 2012-09-07 | 2013-09-13 |  |  | 2012-09-07 | 2013-09-13 | 266d? | 263d | finish no earlier than 2013-09-13 | R5 | 2128h |  | LTE_CA_intraC_inter_UEConTest | PCG-29 | Nokia | Rel-11 | RP-57 |  |  |
| 666 | 233 | **UE Over The Air (Antenna) conformance testing methodology - Laptop mounted equipment Free Space test** | 846d? | 2009-09-18 A | 2012-12-07 | 97% | 27.45d? | 2009-09-18 | 2012-12-07 | 846d? | 463d |  | R4,R5 | 14608h | 14133.6h | UEAnt_FSTest | PCG-23 | CATR | Rel-11 | RP-45 |  | Issam |
| 667 | 233.1 | Core part: UE Over The Air (Antenna) conformance testing methodology - Laptop mounted equipment Free Space test | 583d? | 2009-09-18 A | 2011-12-09 A | 100% |  | 2009-09-18 | 2011-12-09 | 583d? |  | finish no earlier than 2011-12-09 | R4 | 4664h | 4664h | UEAnt_FSTest | PCG-23 | CATR | Rel-11 | RP-45 | RP-111456 | Issam |
| 668 | 233.2 | Test part: UE Over The Air (Antenna) conformance testing methodology - Laptop mounted equipment Free Space test | 398d? | 2011-06-07 A | 2012-12-07 | 92% | 31.84d? | 2011-06-07 | 2012-12-07 | 398d? | 463d | finish no earlier than 2012-12-07 | R5 | 3176h | 2921.28h | UEAnt_FSTest-UEConTest | PCG-27 | ZTE | Rel-11 | RP-52 | RP-120967 | Ingbert |
| 669 | 234 | **Eight carrier HSDPA** | 526d? | 2010-12-10 A | 2012-12-07 A | 100% |  | 2010-12-10 | 2012-12-07 | 526d? |  |  | R1,R2,R3,R4 | 12024h | 12024h | 8C_HSDPA | PCG-26 | Ericsson | Rel-11 | RP-50 |  | Patrick |
| 670 | 234.1 | Core part: Eight carrier HSDPA | 458d? | 2010-12-10 A | 2012-09-10 A | 100% |  | 2010-12-10 | 2012-09-10 | 458d? |  | finish no earlier than 2012-06-15 | R1,R2,R3,R4 | 3648h | 3648h | 8C_HSDPA-Core | PCG-26 | Ericsson | Rel-11 | RP-50 | RP-120971 | Patrick |
| 671 | 234.2 | Perf. part: Eight carrier HSDPA | 521d? | 2010-12-15 A | 2012-12-07 A | 100% |  | 2010-12-15 | 2012-12-07 | 521d? |  | finish no earlier than 2012-12-07 | R4 | 4168h | 4168h | 8C_HSDPA-Perf | PCG-26 | Ericsson | Rel-11 | RP-50 | RP-120972 | Issam |

Notes:
- 647: Stage 3. RP#57 completed. Updated WID RP-111764=>RP-121173 / Text3: LTE / Text5: Hiromasa Umeda (umedah@nttdocomo.co.jp)
- 648: RP#57 completed / Text3: 36.101, 36.104, 36.133, 36.307, new generic TR 36.850 / Text5: Hiromasa Umeda (umedah@nttdocomo.co.jp)
- 649: RP#57 completed / Text3: 36.133, 36.141 / Text5: Hiromasa Umeda (umedah@nttdocomo.co.jp)
- 650: Stage 3. RP#57 updated WID RP-120907=>RP-121162 / Text3: LTE / Text5: Chungwoo HWANG (cwhwang@kt.com)
- 651: RP#57 updated WID RP-120907=>RP-121162. Exception in RP-121160 / Text3: 36.101, 36.104, 36.133, 36.307, new generic TR 36.850 / Text5: Chungwoo HWANG (cwhwang@kt.com)
- 652: - / Text3: 36.133, 36.141 / Text5: Chungwoo HWANG (cwhwang@kt.com)
- 653: Stage 3. Triggered by Rel-11 UID_500015 Study on HSDPA Multipoint Transmission (FS_HSDPA_MP_TX) / Text3: LTE / Text5: lars.e.lindh@nokia.com
- 654: RP#57 completion 09/12=>12/12 (exception in RP-121244) / Text3: 36.101, 36.104, 36.133, 36.201, 36.211, 36.212, 36.213, 36.300, 36.302, 36.306, 36.321, 36.331, 36.413, 36.423, new TR 36.823 / Text5: lars.e.lindh@nokia.com
- 655: - / Text3: 36.101, 36.104, 36.133, 36.141 / Text5: lars.e.lindh@nokia.com
- 656: Stage 3. RP#57 completed. WI only covers intra-band contiguous and not non-contiguous aspects / Text3: LTE / Text5: ronnie.zhang@huawei.com
- 657: RP#57 completed. TR 36.830 v100 for Information & Approval / Text3: 36.101, 36.104, 36.133, 36.141, 36.307, 37.104, 37.141, new TR 36.830 / Text5: ronnie.zhang@huawei.com
- 658: RP#57 completed / Text3: 36.101, 36.104, 36.133, 36.141, 36.307, 37.104, 37.141 / Text5: ronnie.zhang@huawei.com
- 659: RP#55 completed. WI only covers intra-band contiguous and not non-contiguous aspects. Stage 3 linked to Rel-10 Carrier Aggregation for LTE UID_460007 / Text3: LTE / Text5: michael.hart@clearwire.com
- 660: RP#55 completed. Updated WID RP-110673=>RP-120249. TR 36.827 v100 for Information + Approval / Text3: 36.101, 36.104, 36.133, 36.141, 36.307, 37.104, new TR 36.827 / Text5: michael.hart@clearwire.com
- 661: RP#55 completed / Text3: 36.101, 36.104, 36.133, 36.141, 36.307 / Text5: michael.hart@clearwire.com
- 662: Stage 3. RP#57 completed. Updated WID RP-111356=>RP-121193. WI only covers intra-band contiguous and not non-contiguous aspects / Text3: LTE / Text5: Zhangchao Ma (mazc@chinaunicom.cn), Zhonghao Zhang (zhangzh306@chinaunicom.cn)
- 663: RP#57 completed. TR 36.831 v100 for Information & Approval / Text3: 36.101, 36.104, 36.133, 36.141, 36.307, 37.104, 37.141, new TR 36.831 / Text5: Zhangchao Ma (mazc@chinaunicom.cn), Zhonghao Zhang (zhangzh306@chinaunicom.cn)
- 664: RP#57 completed / Text3: 36.101, 36.104, 36.133, 36.141, 36.307, 37.104, 37.141 / Text5: Zhangchao Ma (mazc@chinaunicom.cn), Zhonghao Zhang (zhangzh306@chinaunicom.cn)
- 665: Testing for LTE_CA_B7/CA_B38/CA_B41/CA_B1_B7/CA_B1_B18/CA_B1_B19/CA_B1_B21/CA_B2_B4/CA_B2_B17/CA_B3_B5/CA_B3_B7/CA_B3_B8/CA_B3_B20/CA_B4_B5/CA_B4_B7/CA_B4_B12/CA_B4_B13/CA_B4_B17/CA_B5_B12/CA_B5_B17/CA_B7_B20/CA_B8_B20/CA_B11_B18 / Text3: 36.508, 36.521-1, 36.521-2, 36.521-3, 36.523-1, 36.523-2, 36.523-3, 37.571-1 / Text5: jussi.kuusisto@nokia.com
- 666: RP#54 Core completed / Text3: UTRA / Text5: Guo Lin (guolin@emcite.com)
- 667: RP#54 completed / Text3: 25.144, 25.914, 34.114 / Text5: Guo Lin (guolin@emcite.com)
- 668: RP#56 completion 06/12=>12/12 / Text3: 34.114 / Text5: carolyn.tayl@zte.com.cn
- 669: Stage 3. RP#57 completed / Text3: UTRA / Text5: johan.hultell@ericsson.com
- 670: RP#57 completed / Text3: 25.101, 25.104, 25.133, 25.211, 25.212, 25.213, 25.214, 25.215, 25.308, 25.331, 25.423, 25.433, 26.306 / Text5: johan.hultell@ericsson.com
- 671: RP#57 completed / Text3: 25.101, 25.104, 25.133, 25.141 / Text5: johan.hultell@ericsson.com

| ID | WBS | Task | Duration | Start | Finish | Complete | Remaining | Baseline start | Baseline finish | Baseline duration | Total slack | Constraint | Resources | Work | Actual work | Text1 | Text2 | Text4 | Text5 | Text6 | Text7 | Text8 | Text11 |
| --- | --- | --- | --- | --- | --- | --- | --- | --- | --- | --- | --- | --- | --- | --- | --- | --- | --- | --- | --- | --- | --- | --- | --- |
| 672 | 235 | **UE demodulation performance requirements under multiple-cell scenario for 1.28Mcps TDD** | 324d? | 2010-12-10 A | 2012-03-02 A | 100% |  | 2010-12-10 | 2012-03-02 | 324d? |  |  | R4,R5 | 3552h | 3552h | LCR_TDD_UE_demod_mc | PCG-26 | China Mobile | Li Nan (linan@chinamobile.com) | Rel-11 | RP-50 | Issam |  |
| 673 | 235.1 | Perf. part: UE demodulation performance requirements under multiple-cell scenario for 1.28Mcps TDD | 201d? | 2010-12-10 A | 2011-09-16 A | 100% |  | 2010-12-10 | 2011-09-16 | 201d? |  | finish no earlier than 2011-09-16 | R4 | 1608h | 1608h | LCR_TDD_UE_demod_mc-Perf | PCG-26 | China Mobile | Li Nan (linan@chinamobile.com) | Rel-11 | RP-50 | Issam | RP-110996 |
| 674 | 235.2 | Test part: UE demodulation performance requirements under multiple-cell scenario for 1.28Mcps TDD | 121d? | 2011-09-19 A | 2012-03-02 A | 100% |  | 2011-09-19 | 2012-03-02 | 121d? |  | finish no earlier than 2012-02-23 | R5 | 968h | 968h | LCR_TDD_UE_demod_mc-UEConTest | PCG-27 | China Mobile | Ma Shuai (mashuai@chinamobile.com) | Rel-11 | RP-53 |  | RP-120052 |
| 675 | 236 | **Uplink Transmit Diversity for HSPA** | 526d? | 2010-12-10 A | 2012-12-07 | 86% | 74.88d? | 2010-12-10 | 2012-12-07 | 526d? | 463d |  | R1,R4,R2,R3 | 20896.3h | 17919.2h | HSPA_UL_TxDiv | PCG-26 | Huawei | zongjie.wang@huawei.com | Rel-11 | RP-50 | Patrick |  |
| 676 | 236.1 | Core part: Uplink Transmit Diversity for HSPA - Closed Loop | 523d? | 2010-12-10 A | 2012-12-07 | 98% | 10.46d? | 2010-12-10 | 2012-12-07 | 523d? | 463d | finish no earlier than 2012-12-07 | R1,R4,R2,R3 | 4176h | 4092.32h | HSPA_UL_TxDiv-CL-Core | PCG-26 | Huawei | zongjie.wang@huawei.com | Rel-11 | RP-50 | Patrick | RP-120973 |
| 677 | 236.2 | Perf. part: Uplink Transmit Diversity for HSPA - Closed Loop | 522d? | 2010-12-14 A | 2012-12-07 | 80% | 104.4d? | 2010-12-14 | 2012-12-07 | 522d? | 463d | finish no earlier than 2012-12-07 | R4 | 4168.31h | 3333.11h | HSPA_UL_TxDiv-CL-Perf | PCG-26 | Huawei | zongjie.wang@huawei.com | Rel-11 | RP-50 | Issam | RP-120974 |
| 678 | 236.3 | Core part: Uplink Transmit Diversity for HSPA - Open Loop | 522d? | 2010-12-10 A | 2012-12-07 | 95% | 26.1d? | 2010-12-10 | 2012-12-07 | 522d? | 463d | finish no earlier than 2012-12-07 | R4,R1,R2,R3 | 4176h | 3967.2h | HSPA_UL_TxDiv-OL-Core | PCG-26 | Huawei | zongjie.wang@huawei.com | Rel-11 | RP-50 | Patrick | RP-120975 |
| 679 | 236.4 | Perf. part: Uplink Transmit Diversity for HSPA - Open Loop | 521d? | 2010-12-14 A | 2012-12-07 | 70% | 156.3d? | 2010-12-14 | 2012-12-07 | 521d? | 463d | finish no earlier than 2012-12-07 | R4 | 4168h | 2917.6h | HSPA_UL_TxDiv-OL-Perf | PCG-26 | Huawei | zongjie.wang@huawei.com | Rel-11 | RP-50 | Issam | RP-120976 |
| 680 | 237 | **Introduction of New Configuration for 4C-HSDPA** | 328d? | 2011-03-22 A | 2012-06-15 A | 100% |  | 2011-03-22 | 2012-06-15 | 328d? |  |  | R4,R2 | 6760h | 6760h | 4C_HSDPA_Config | PCG-26 | Telus Communications | jorge.delrio@telus.com | Rel-11 | RP-51 | Issam |  |
| 681 | 237.1 | Core part: Introduction of New Configuration for 4C-HSDPA | 191d? | 2011-03-22 A | 2011-12-09 A | 100% |  | 2011-03-22 | 2011-12-09 | 191d? |  | finish no earlier than 2011-12-09 | R4,R2 | 1528h | 1528h | 4C_HSDPA_Config-Core | PCG-26 | Telus Communications | jorge.delrio@telus.com | Rel-11 | RP-51 | Issam | RP-111463 |
| 682 | 237.2 | Perf. part: Introduction of New Configuration for 4C-HSDPA | 326d? | 2011-03-24 A | 2012-06-15 A | 100% |  | 2011-03-24 | 2012-06-15 | 326d? |  | finish no earlier than 2012-06-15 | R4 | 2608h | 2608h | 4C_HSDPA_Config-Perf | PCG-26 | Telus Communications | jorge.delrio@telus.com | Rel-11 | RP-51 | Issam | RP-120475 |
| 683 | 238 | **Non-contiguous 4C-HSDPA operation** | 454d? | 2011-03-22 A | 2012-12-07 | 77% | 105.27d? | 2011-03-22 | 2012-12-07 | 454d? | 463d |  | R4,R2,R3 | 9856h | 7570.62h | NC_4C_HSDPA | PCG-26 | Ericsson | muhammad.kazmi@ericsson.com | Rel-11 | RP-51 | Issam |  |
| 684 | 238.1 | Core part: Non-contiguous 4C-HSDPA operation | 327d? | 2011-03-22 A | 2012-06-15 A | 100% |  | 2011-03-22 | 2012-06-15 | 327d? |  | finish no earlier than 2012-09-07 | R4,R2,R3 | 2616h | 2616h | NC_4C_HSDPA-Core | PCG-26 | Ericsson | muhammad.kazmi@ericsson.com | Rel-11 | RP-51 | Issam | RP-120842 |
| 685 | 238.2 | Perf. part: Non-contiguous 4C-HSDPA operation | 451d? | 2011-03-23 A | 2012-12-07 | 60% | 180.4d? | 2011-03-23 | 2012-12-07 | 451d? | 463d | finish no earlier than 2012-12-07 | R4 | 3608h | 2164.8h | NC_4C_HSDPA-Perf | PCG-26 | Ericsson | muhammad.kazmi@ericsson.com | Rel-11 | RP-51 | Issam | RP-120977 |
| 686 | 239 | **Further Enhancements to CELL_FACH** | 456d? | 2011-03-18 A | 2012-12-07 | 64% | 166.19d? | 2011-03-18 | 2012-12-07 | 456d? | 463d |  | R1,R2,R3,R4 | 10880h | 6914.52h | Cell_FACH_enh | PCG-26 | Qualcomm | Ravi Agarwal | Rel-11 | RP-51 | Patrick |  |
| 687 | 239.1 | Core part: Further Enhancements to CELL_FACH | 453d? | 2011-03-18 A | 2012-12-07 | 87% | 58.89d? | 2011-03-18 | 2012-12-07 | 453d? | 463d | finish no earlier than 2012-12-07 | R2,R1,R3,R4 | 3624h | 3152.88h | Cell_FACH_enh-Core | PCG-26 | Qualcomm | Ravi Agarwal | Rel-11 | RP-51 | Joern | RP-120978 |
| 688 | 239.2 | Perf. part: Further Enhancements to CELL_FACH | 451d? | 2011-03-24 A | 2012-12-07 | 40% | 270.6d? | 2011-03-24 | 2012-12-07 | 451d? | 463d | finish no earlier than 2012-12-07 | R4 | 3608h | 1443.2h | Cell_FACH_enh-Perf | PCG-26 | Qualcomm | Heechoon Lee | Rel-11 | RP-51 | Issam | RP-120979 |
| 689 | 240 | **HSDPA Multiflow Data Transmission** | 383d? | 2011-09-19 A | 2013-03-01 | 57% | 162.84d? | 2011-09-19 | 2013-03-01 | 383d? | 403d |  | R2,R1,R3,R4 | 8688h | 4994.09h | HSDPA_MFTX | PCG-27 | Nokia Siemens Networks | Alexander Sayenko | Rel-11 | RP-53 |  |  |
| 690 | 240.1 | Core part: HSDPA Multiflow Data Transmission | 322d? | 2011-09-19 A | 2012-12-07 | 90% | 32.2d? | 2011-09-19 | 2012-12-07 | 322d? | 463d | finish no earlier than 2012-12-07 | R2,R1,R3,R4 | 2576h | 2318.4h | HSDPA_MFTX-Core | PCG-27 | Nokia Siemens Networks | Alexander Sayenko | Rel-11 | RP-53 |  | RP-120982 |
| 691 | 240.2 | Perf. part: HSDPA Multiflow Data Transmission | 381d? | 2011-09-20 A | 2013-03-01 | 30% | 266.7d? | 2011-09-20 | 2013-03-01 | 381d? | 403d | finish no earlier than 2013-03-01 | R4 | 3048h | 914.4h | HSDPA_MFTX-Perf | PCG-27 | Nokia Siemens Networks | Kamil Bechta | Rel-11 | RP-53 |  | RP-120983 |
| 692 | 241 | **Four Branch MIMO transmission for HSDPA** | 383d? | 2011-09-19 A | 2013-03-01 | 42% | 221.91d? | 2011-09-19 | 2013-03-01 | 383d? | 403d |  | R1,R2,R3,R4 | 8688h | 3654.33h | 4Tx_HSDPA | PCG-27 | Ericsson | johan.hultell@ericsson.com | Rel-11 | RP-53 |  |  |
| 693 | 241.1 | Core part: Four Branch MIMO transmission for HSDPA | 322d? | 2011-09-19 A | 2012-12-07 | 80% | 64.4d? | 2011-09-19 | 2012-12-07 | 322d? | 463d | finish no earlier than 2012-12-07 | R1,R2,R3,R4 | 2576h | 2060.8h | 4Tx_HSDPA-Core | PCG-27 | Ericsson | johan.hultell@ericsson.com | Rel-11 | RP-53 |  | RP-120980 |
| 694 | 241.2 | Perf. part: Four Branch MIMO transmission for HSDPA | 381d? | 2011-09-21 A | 2013-03-01 | 10% | 342.9d? | 2011-09-21 | 2013-03-01 | 381d? | 403d | finish no earlier than 2013-03-01 | R4 | 3048h | 304.8h | 4Tx_HSDPA-Perf | PCG-27 | Ericsson | johan.hultell@ericsson.com | Rel-11 | RP-53 |  | RP-120981 |
| 695 | 242 | **MIMO with 64QAM for HSUPA** | 398d? | 2011-12-09 A | 2013-06-14 | 39% | 243.43d? | 2011-12-09 | 2013-06-14 | 398d? | 328d |  | R1,R2,R3,R4 | 8440h | 3277.74h | MIMO_64QAM_HSUPA | PCG-28 | Nokia Siemens Networks | Karri Ranta-aho | Rel-11 | RP-54 |  |  |
| 696 | 242.1 | Core part: MIMO with 64QAM for HSUPA | 261d? | 2011-12-09 A | 2012-12-07 | 75% | 65.25d? | 2011-12-09 | 2012-12-07 | 261d? | 463d | finish no earlier than 2012-12-07 | R1,R2,R3,R4 | 2088h | 1566h | MIMO_64QAM_HSUPA-Core | PCG-28 | Nokia Siemens Networks | Karri Ranta-aho | Rel-11 | RP-54 |  | RP-120985 |
| 697 | 242.2 | Perf. part: MIMO with 64QAM for HSUPA | 396d? | 2011-12-13 A | 2013-06-14 | 15% | 336.6d? | 2011-12-13 | 2013-06-14 | 396d? | 328d | finish no earlier than 2013-06-14 | R4 | 3168h | 475.2h | MIMO_64QAM_HSUPA-Perf | PCG-28 | Nokia Siemens Networks | Kamil Bechta | Rel-11 | RP-54 |  | RP-120986 |

Notes:
- 672: RP#53 Perf completed. Stage 3 / Text3: UTRA
- 673: RP#53 completed. TR 25.873v100 for Approval / Text3: 25.102, new TR 25.873
- 674: RP#55 completed / Text3: 34.108, 34.122
- 675: Stage 2/3 / Text3: UTRA
- 676: RP#57 completion 09/12=>12/12 (exception in RP-121250) / Text3: 25.101, 25.104, 25.133, 25.211, 25.212, 25.213, 25.214, 25.215, 25.306, 25.319, 25.321, 25.331, 25.423, 25.433
- 677: RP#57 completion 09/12=>12/12 / Text3: 25.101, 25.104, 25.133, 25.141
- 678: RP#57 completion 09/12=>12/12 (exception in RP-121251) / Text3: 25.101, 25.133, 25.306, 25.319, 25.321, 25.331, 25.423, 25.433
- 679: RP#57 completion 09/12=>12/12 / Text3: 25.101, 25.133
- 680: RP#56 Perf completed / Text3: UTRA
- 681: RP#54 completed / Text3: 25.101, 25.104, 25.141, 25.317
- 682: RP#56 completed / Text3: 25.101, 25.104, 25.141, 25.317
- 683: UTRA. RP#56 Core completed / Text3: UTRA
- 684: RP#56 completed / Text3: 25.101, 25.104, 25.133, 25.331, 25.423, 25.433
- 685: - / Text3: 25.101, 25.104, 25.133, 25.141
- 686: Stage 2/3 / Text3: UTRA
- 687: RP#57 completion 0912=>1212 (exception in RP-121171) / Text3: 25.101, 25.104, 25.133, 25.211, 25.212, 25.213, 25.214, 25.306, 25.308, 25.319, 25.321, 25.331, 25.423, 25.433
- 688: - / Text3: 25.101, 25.104, 25.133, 25.141
- 689: Stage 2,3 / Text3: UTRA
- 690: RP#57 completion 09/12=>12/12 (exception in RP-121159) / Text3: 25.101, 25.104, 25.133, 25.211, 25.212, 25.214, 25.306, 25.308, 25.321, 25.331, 25.423, 25.433
- 691: - / Text3: 25.101, 25.104, 25.133, 25.141
- 692: Stage 3 / Text3: UTRA
- 693: RP#57 completion 09/12=>12/12 (exception in RP-121425) / Text3: 25.101, 25.104, 25.133, 25.211, 25.212, 25.213, 25.214, 25.215, 25.308, 25.331, 25.423, 25.433, 26.306
- 694: - / Text3: 25.101, 25.104, 25.133, 25.141
- 695: Stage 3 / Text3: UTRA
- 696: RP#57 exception in RP-121262 / Text3: 25.101, 25.104, 25.133, 25.211, 25.212, 25.213, 25.214, 25.215, 25.308, 25.321, 25.331, 25.423, 25.433, 26.306
- 697: - / Text3: 25.101, 25.104, 25.133, 25.141

| ID | WBS | Task | Duration | Start | Finish | Complete | Remaining | Baseline start | Baseline finish | Baseline duration | Total slack | Constraint | Resources | Work | Actual work | Text1 | Text2 | Text3 | Text4 | Text6 | Text7 | Text11 | Text8 | Text9 | Text12 |
| --- | --- | --- | --- | --- | --- | --- | --- | --- | --- | --- | --- | --- | --- | --- | --- | --- | --- | --- | --- | --- | --- | --- | --- | --- | --- |
| 698 | 243 | **HSDPA Dual-Band Multi-Carrier combinations** | 198d? | 2011-12-09 A | 2012-09-07 A | 100% |  | 2011-12-09 | 2012-09-07 | 198d? |  |  | R4,R2 | 4736h | 4736h | HSDPA_DB_MC | PCG-28 | UTRA | Ericsson | Rel-11 | RP-54 |  |  |  |  |
| 699 | 243.1 | Core part: HSDPA Dual-Band Multi-Carrier combinations | 196d? | 2011-12-09 A | 2012-09-07 A | 100% |  | 2011-12-09 | 2012-09-07 | 196d? |  | finish no earlier than 2012-09-07 | R4,R2 | 1568h | 1568h | HSDPA_DB_MC-Core | PCG-28 | 25.101, 25.104, 25.141, 25.317 | Ericsson | Rel-11 | RP-54 | RP-120987 |  |  |  |
| 700 | 243.2 | Perf. part: HSDPA Dual-Band Multi-Carrier combinations | 198d? | 2011-12-09 A | 2012-09-07 A | 100% |  | 2011-12-09 | 2012-09-07 | 198d? |  | finish no earlier than 2012-09-07 | R4 | 1584h | 1584h | HSDPA_DB_MC-Perf | PCG-28 | 25.101, 25.104, 25.141 | Ericsson | Rel-11 | RP-54 | RP-120988 |  |  |  |
| 701 | 244 | (Small) Technical Enhancements and Improvements for Rel-11 | 594d? | 2010-06-10 A | 2012-09-12 A | 100% |  | 2010-06-10 | 2012-09-12 | 594d? |  | finish no earlier than 2012-09-20 | All | 4744.08h | 4744.08h | TEI11 | PCG-25 |  |  | Rel-11 | SP-48 |  | All |  |  |
| 702 | 245 | Test - (Small) Technical Enhancements and Improvements for Rel-11 | 390d? | 2012-06-15 A | 2013-12-11 A | 100% |  | 2012-06-15 | 2013-12-11 | 390d? |  | finish no earlier than 2013-12-11 | R5,G3new | 3112h | 3112h | TEI11_Test | PCG-29 |  |  | Rel-11 | RP-56 |  |  |  |  |
| 703 | 246 | (IETF) (Small) Technical Enhancements and Improvements for Rel-11 (draft-krishnan-netext-update-notifications) | 66d? | 2012-09-07 A | 2012-12-07 | 25% | 49.5d? | 2012-09-07 | 2012-12-07 | 66d? | 463d | finish no earlier than 2012-12-07 | C4-IETF | 528h | 132h | TEI11 | PCG-29 | draft-krishnan-netext-update-notifications | Lionel Morand | Rel-11 | CP-57 |  |  |  |  |
| 704 | 247 | **Deleted - Enhancement of the Protocols for SMS over SGs (Stage 3)** | 142d? | 2011-12-02 A | 2012-06-15 A | 100% |  | 2011-12-02 | 2012-06-15 | 142d? |  |  | C4,C1 | 4528h | 4528h | PROTOC_SMS_SGs | PCG-28 | Stage 3 | Alcatel-Lucent | Rel-11 | CP-54 |  |  | PCG-29 | CP-56 |
| 705 | 247.1 | Deleted - TR Study on enhancement of protocols for SMS service over SGs | 142d? | 2011-12-02 A | 2012-06-15 A | 100% |  | 2011-12-02 | 2012-06-15 | 142d? |  | finish no earlier than 2012-06-15 | C4 | 1128h | 1128h | PROTOC_SMS_SGs | PCG-28 | new TR 29.818 | Alcatel-Lucent | Rel-11 | CP-54 |  |  | PCG-29 | CP-56 |
| 706 | 247.2 | Deleted - CT4 part of Enhancement of the Protocols for SMS over SGs | 142d? | 2011-12-02 A | 2012-06-15 A | 100% |  | 2011-12-02 | 2012-06-15 | 142d? |  | finish no earlier than 2012-06-15 | C4 | 1128h | 1128h | PROTOC_SMS_SGs | PCG-28 | 29.305, new TS 29.218 | Alcatel-Lucent | Rel-11 | CP-54 |  |  | PCG-29 | CP-56 |
| 707 | 247.3 | Deleted - CT1 part of Enhancement of the Protocols for SMS over SGs | 142d? | 2011-12-02 A | 2012-06-15 A | 100% |  | 2011-12-02 | 2012-06-15 | 142d? |  | finish no earlier than 2012-06-15 | C1 | 1136h | 1136h | PROTOC_SMS_SGs | PCG-28 | 23.040, 24.011, 43.068 | Alcatel-Lucent | Rel-11 | CP-54 |  |  | PCG-29 | CP-56 |
| 708 | 248 | Release 11 Studies | 787d? | 2009-12-10 A | 2012-12-07 A | 100% |  | 2009-12-10 | 2012-12-07 | 787d? |  | finish no earlier than 2012-12-07 | SP,CP,GP,RP | 2606.4h | 2606.4h |  |  |  |  | Rel-11 |  |  | All |  |  |
| 709 | 249 | Study on IMS based Peer-to-Peer Content Distribution Services | 284d? | 2009-05-12 A | 2010-06-10 A | 100% |  | 2009-05-12 | 2010-06-10 | 284d? |  | finish no earlier than 2010-06-10 | S1,S2 | 2272h | 2272h | FS_IMS_P2P | PCG-23 | 22.906 | China Mobile | Rel-11 | SP-45 |  | Alain |  |  |
| 710 | 250 | Study on Non Voice Emergency Services | 467d? | 2009-12-10 A | 2011-09-21 A | 100% |  | 2009-12-10 | 2011-09-21 | 467d? |  | finish no earlier than 2011-09-21 | S1 | 3720h | 3720h | FS_NOVES | PCG-24 | 22.871 | Qualcomm | Rel-11 | SP-46 |  | Alain |  |  |
| 711 | 251 | Study on Support for 3GPP Voice Interworking with Enterprise IP-PBX | 130d? | 2010-09-23 A | 2011-03-23 A | 100% |  | 2010-09-23 | 2011-03-23 | 130d? |  | finish no earlier than 2011-02-21 | S1,S2 | 1040h | 1040h | FS_VINE | PCG-25 | 22.809 | Tatara Systems | Rel-11 | SP-48 |  | Alain |  |  |
| 712 | 252 | Study on IMS Network-Independent Public User Identities | 185d? | 2010-09-23 A | 2011-06-08 A | 100% |  | 2010-09-23 | 2011-06-08 | 185d? |  | finish no earlier than 2011-06-08 | S1 | 1480h | 1480h | FS_INIPUI | PCG-25 | 22.894 | Vodafone | Rel-11 | SP-49 |  | Alain |  |  |
| 713 | 253 | Study on IMS Evolution | 849d? | 2008-09-18 A | 2011-12-14 A | 100% |  | 2008-09-18 | 2011-12-14 | 849d? |  | finish no earlier than 2011-12-07 | S2 | 6784h | 6784h | FS_eIMS | PCG-21 | 23.812 | China Mobile | Rel-11 | SP-41 |  | Maurice |  |  |
| 714 | 254 | Study on Policy solutions and enhancements | 525d? | 2009-06-04 A | 2011-06-08 A | 100% |  | 2009-06-04 | 2011-06-08 | 525d? |  |  | S2,S1 | 4200h | 4200h | FS_PP | PCG-23 | 23.813 | AT&T | Rel-11 | SP-44 |  | Maurice |  |  |
| 715 | 255 | Study on IPv6 Migration | 525d? | 2009-06-04 A | 2011-06-08 A | 100% |  | 2009-06-04 | 2011-06-08 | 525d? |  | finish no earlier than 2011-06-08 | S2 | 4200h | 4200h | FS_IP6M | PCG-23 | 23.975 | China Mobile | Rel-11 | SP-44 |  | Maurice |  |  |
| 716 | 256 | Study on Single Radio Voice Call Continuity from UTRAN/GERAN to E-UTRAN/HSPA | 528d? | 2009-12-10 A | 2011-12-14 A | 100% |  | 2009-12-10 | 2011-12-14 | 528d? |  | finish no earlier than 2011-09-21 | S2 | 4208h | 4208h | FS_rSRVCC | PCG-24 | 23.885 | Orange | Rel-11 | SP-46 |  | Maurice |  |  |
| 717 | 257 | Study on Roaming Architecture for Voice over IMS with Local Breakout | 194d? | 2011-03-23 A | 2011-12-14 A | 100% |  | 2011-03-23 | 2011-12-14 | 194d? |  | finish no earlier than 2011-12-07 | S2 | 1535.79h | 1535.79h | FS_RAVEL | PCG-26 | 23.850 | Deutsche Telekom | Rel-11 | SP-51 |  | Maurice |  |  |
| 718 | 258 | Study on UTRAN key management enhancements | 1102d? | 2007-12-20 A | 2012-03-07 A | 100% |  | 2007-12-20 | 2012-03-07 | 1102d? |  | finish no earlier than 2012-02-20 | S3 | 8808.12h | 8808.12h | FS_UKM | PCG-21 | 33.859 | Ericsson | Rel-11 | SP-38 |  | Dionisio |  |  |
| 719 | 259 | Study on Single Sign On (SSO) Application Security for IMS - based on SIP Digest | 532d? | 2010-06-10 A | 2012-06-20 A | 100% |  | 2010-06-10 | 2012-06-20 | 532d? |  | finish no earlier than 2012-06-20 | S3 | 4247.09h | 4247.09h | FS_SSO_APS | PCG-25 | 33.914 converted to 33.804 | Nokia | Rel-11 | SP-48 |  | Dionisio |  |  |
| 720 | 260 | Study on Mobile 3D Video Coding | 273d? | 2011-06-08 A | 2012-06-20 A | 100% |  | 2011-06-08 | 2012-06-20 | 273d? |  | finish no earlier than 2012-06-20 | S4 | 2168h | 2168h | FS_M3DVC | PCG-27 | 26.905 | Orange | Rel-11 | SP-52 |  | Paolo |  |  |
| 721 | 261 | Study on Management of Converged Networks | 591d? | 2010-06-10 A | 2012-09-12 A | 100% |  | 2010-06-10 | 2012-09-12 | 591d? |  | finish no earlier than 2012-09-12 | S5 | 4720h | 4720h | FS_ManCon | PCG-25 | 32.833 | Nokia Siemens Networks | Rel-11 | SP-48 |  | Dionisio |  |  |
| 722 | 262 | Study on User Data Convergence (UDC) information model handling and provisioning: Example Use Cases | 321d? | 2010-09-23 A | 2011-12-14 A | 100% |  | 2010-09-23 | 2011-12-14 | 321d? |  | finish no earlier than 2011-12-14 | S5 | 2560h | 2560h | FS_UDC_AppUseCase | PCG-25 | 32.901 | Alcatel-Lucent | Rel-11 | SP-49 |  | Dionisio |  |  |
| 723 | 263 | Study on OAM aspects of inter-RAT Energy Saving | 194d? | 2011-03-23 A | 2011-12-14 A | 100% |  | 2011-03-23 | 2011-12-14 | 194d? |  | start no earlier than 2011-03-23 | S5 | 1528h | 1528h | FS_OAM_ES_iRAT | PCG-26 | 32.834 | Nokia Siemens Networks | Rel-11 | SP-51 |  | Dionisio |  |  |
| 724 | 264 | Study on impacts on UE-Core Network signalling from Energy Saving | 261d? | 2010-06-04 A | 2011-06-03 A | 100% |  | 2010-06-04 | 2011-06-03 | 261d? |  | finish no earlier than 2011-06-03 | C1 | 2088h | 2088h | FS_UE-CN_ES | PCG-25 | 24.826 | NEC | Rel-11 | CP-48 |  | Frederic |  |  |
| 725 | 265 | Study on EPC Nodes Restoration | 586d? | 2010-09-17 A | 2012-12-07 | 95% | 29.25d? | 2010-09-17 | 2012-12-07 | 586d? | 463d | finish no earlier than 2012-12-07 | C4 | 4664h | 4430h | FS_EPC_NR | PCG-25 | 23.857 | ZTE | Rel-11 | CP-49 | CP-120450 | Kimmo |  |  |
| 726 | 266 | Study on Signal Precoding enhancements for EGPRS2 DL | 392d? | 2010-09-03 A | 2012-03-02 A | 100% |  | 2010-09-03 | 2012-03-02 | 392d? |  | finish no earlier than 2012-03-02 | G1,G2 | 3128h | 3128h | FS_SPEED | PCG-25 | GERAN 45.860 | Ericsson | Rel-11 | GP-46 |  | Paolo |  |  |
| 727 | 267 | Study on Coordinated Multi-Point operation for LTE | 203d? | 2010-12-10 A | 2011-09-16 A | 100% |  | 2010-12-10 | 2011-09-16 | 203d? |  | finish no earlier than 2011-09-16 | R1,R2,R3 | 1624h | 1624h | FS_CoMP_LTE | PCG-24 | LTE 36.819 | Samsung | Rel-11 | RP-47 | RP-111343 | Patrick |  |  |
| 728 | 268 | Study on Signalling and procedure for interference avoidance for in-device coexistence | 336d? | 2010-06-04 A | 2011-09-16 A | 100% |  | 2010-06-04 | 2011-09-16 | 336d? |  | finish no earlier than 2011-09-16 | R2,R4 | 2688h | 2688h | FS_SPIA_IDC | PCG-25 | LTE 36.816 | China Mobile | Rel-11 | RP-48 | RP-111057 | Joern |  |  |
| 729 | 269 | Study on HetNet mobility enhancements for LTE | 386d? | 2011-03-18 A | 2012-09-07 A | 100% |  | 2011-03-18 | 2012-09-07 | 386d? |  | finish no earlier than 2012-09-07 | R2,R1,R3,R4 | 3088h | 3088h | FS_HetNet_eMOB_LTE | PCG-26 | LTE 36.839 | Alcatel-Lucent | Rel-11 | RP-51 | RP-121085 | Joern |  |  |
| 730 | 270 | Study on further Downlink MIMO enhancements for LTE-Advanced | 193d? | 2011-03-18 A | 2011-12-09 A | 100% |  | 2011-03-18 | 2011-12-09 | 193d? |  | finish no earlier than 2011-12-09 | R1 | 1544h | 1544h | FS_LTE_eDL_MIMO_enh | PCG-26 | LTE 36.871 | Alcatel-Lucent | Rel-11 | RP-51 | RP-111550 | Patrick |  |  |
| 731 | 271 | Study on Further Enhancements to LTE TDD for DL-UL Interference Management and Traffic Adaptation | 326d? | 2011-03-22 A | 2012-06-15 A | 100% |  | 2011-03-22 | 2012-06-15 | 326d? |  | finish no earlier than 2012-06-15 | R1,R4 | 2608h | 2608h | FS_LTE_TDD_eIMTA | PCG-26 | LTE 36.828 | CATT | Rel-11 | RP-51 | RP-120587 | Patrick |  |  |
| 732 | 272 | Study on LTE Coverage Enhancements | 196d? | 2011-09-19 A | 2012-06-15 A | 100% |  | 2011-09-19 | 2012-06-15 | 196d? |  | finish no earlier than 2012-06-15 | R1,R2 | 1568h | 1568h | FS_Cov_Enh_LTE | PCG-27 | LTE 36.824 | China Telecom | Rel-11 | RP-53 | RP-120589 |  |  |  |
| 733 | 273 | Study on Enhanced performance requirement for LTE UE | 121d? | 2011-09-19 A | 2012-03-02 A | 100% |  | 2011-09-19 | 2012-03-02 | 121d? |  | finish no earlier than 2012-03-02 | R4,R1 | 968h | 968h | FS_enh_perf_UE_LTE | PCG-27 | LTE 36.829 | NTT DoCoMo | Rel-11 | RP-53 | RP-120167 |  |  |  |
| 734 | 274 | Study on Measurements of radio performances for LTE terminals - Total Radiated Power (TRP) and Total Radiated Sensitivity (TRS) test methodology | 136d? | 2012-03-05 A | 2012-09-07 A | 100% |  | 2012-03-05 | 2012-09-07 | 136d? |  | finish no earlier than 2012-09-07 | R4 | 1088h | 1088h | FS_LTE_OTA | PCG-28 | LTE 25.914, new TR 37.902 | CATR | Rel-11 | RP-55 | RP-121083 |  |  |  |
| 735 | 275 | Study on Measurement of Radiated Performance for MIMO and multi-antenna reception for HSPA and LTE terminals | 712.8d? | 2009-03-06 A | 2012-03-02 A | 100% |  | 2009-03-06 | 2012-03-02 | 712.8d? |  | finish no earlier than 2012-03-02 | R4 | 5702.4h | 5702.4h | FS_HSPA_LTE_measRP_MIMO_multi-antenna | PCG-22 | UTRA, LTE 37.976 | Vodafone | Rel-11 | RP-43 | RP-120154 | Issam |  |  |
| 736 | 276 | Study on Extending 850 MHz | 860d? | 2009-05-30 A | 2012-09-07 A | 100% |  | 2009-05-30 | 2012-09-07 | 860d? |  | finish no earlier than 2012-09-07 | R4 | 6880h | 6880h | FS_e850 | PCG-23 | UTRA, LTE 37.806 | Ericsson | Rel-11 | RP-44 | RP-121080 | Issam |  |  |
| 737 | 277 | Study on RAN improvements for Machine-Type Communications | 521d? | 2009-09-18 A | 2011-09-16 A | 100% |  | 2009-09-18 | 2011-09-16 | 521d? |  | finish no earlier than 2011-09-16 | R2,R1,R3,R4 | 4168h | 4168h | FS_NIMTC_RAN | PCG-23 | UTRA, LTE 37.868 | Huawei | Rel-11 | RP-45 | RP-111052 | Joern |  |  |
| 738 | 278 | Study on UE Application Layer Data Throughput Performance | 264d? | 2010-12-10 A | 2011-12-09 A | 100% |  | 2010-12-10 | 2011-12-09 | 264d? |  | finish no earlier than 2011-09-16 | R5,R4 | 2104h | 2104h | FS_UE_App_Data_Perf | PCG-26 | UTRA, LTE 37.901 | Spirent | Rel-11 | RP-50 | RP-111543 | Ingbert |  |  |
| 739 | 279 | Study on further enhancements for HNB and HeNB | 329d? | 2011-03-18 A | 2012-06-15 A | 100% |  | 2011-03-18 | 2012-06-15 | 329d? |  | finish no earlier than 2012-06-15 | R3,R2 | 2632h | 2632h | FS_EHNB_enh | PCG-26 | UTRA, LTE 37.803 | Alcatel-Lucent | Rel-11 | RP-51 | RP-120579 | Juha |  |  |
| 740 | 280 | Study on Interference analysis between 800~900 MHz bands | 326d? | 2011-03-23 A | 2012-06-15 A | 100% |  | 2011-03-23 | 2012-06-15 | 326d? |  | finish no earlier than 2012-06-15 | R4 | 2608h | 2608h | FS_B800_B900_Interf_LTE | PCG-26 | UTRA, LTE impacts TR 37.804 | LG Uplus | Rel-11 | RP-51 | RP-120586 | Issam |  |  |
| 741 | 281 | Study on UMTS/LTE in 900 MHz band (Japan, Korea) | 272d? | 2011-06-07 A | 2012-06-15 A | 100% |  | 2011-06-07 | 2012-06-15 | 272d? |  | finish no earlier than 2012-06-15 | R4 | 2176h | 2176h | FS_UTRA_LTE_900MHz | PCG-27 | UTRA, LTE 37.804 | NTT DoCoMo | Rel-11 | SP-52 | RP-120580 | Issam |  |  |
| 742 | 282 | Study on Uplink MIMO | 203d? | 2010-12-10 A | 2011-09-16 A | 100% |  | 2010-12-10 | 2011-09-16 | 203d? |  | finish no earlier than 2011-09-16 | R1 | 1624h | 1624h | FS_UTRA_UL_MIMO | PCG-26 | UTRA 25.871 | Qualcomm | Rel-11 | RP-50 | RP-111048 | Patrick |  |  |
| 743 | 283 | Study on HSDPA Multipoint Transmission | 201d? | 2010-12-10 A | 2011-09-16 A | 100% |  | 2010-12-10 | 2011-09-16 | 201d? |  | finish no earlier than 2011-09-16 | R1,R2,R3 | 1608h | 1608h | FS_HSDPA_MP_TX | PCG-26 | UTRA 25.872 | Nokia Siemens Networks | Rel-11 | RP-50 | RP-111049 | Patrick |  |  |
| 744 | 284 | Study on UE Over The Air (OTA) test method with Head and Hand Phantoms | 257d? | 2011-09-19 A | 2012-09-07 A | 100% |  | 2011-09-19 | 2012-09-07 | 257d? |  | finish no earlier than 2012-09-07 | R4,R5 | 2056h | 2056h | FS_OTA_phantoms_UTRA | PCG-27 | UTRA 25.914 | Nokia | Rel-11 | RP-53 | RP-121078 |  |  |  |
| 745 | 285 | Study on HSPA feedback and signalling efficiency enhancements for LCR TDD | 199d? | 2011-12-07 A | 2012-09-07 A | 100% |  | 2011-12-07 | 2012-09-07 | 199d? |  | finish no earlier than 2012-09-07 | R1 | 1584h | 1584h | FS_LCRTDD_HSPAenh | PCG-28 | UTRA 25.874 | TD Tech | Rel-11 | RP-54 | RP-121079 |  |  |  |
| 746 | 286 | Deleted - Study on Enhanced Uplink Transmission for LTE | 328d? | 2011-03-22 A | 2012-06-15 A | 100% |  | 2011-03-22 | 2012-06-15 | 328d? |  | finish no earlier than 2012-06-15 | R1 | 2624h | 2624h | FS_eUL_TX_LTE | PCG-26 | LTE 36.8xy | Huawei | Rel-11 | RP-51 | RP-120585 | Patrick | PCG-29 | RP-56 |
| 747 | 287 | Release 10 Features | 370.2d? | 2008-12-11 A | 2011-09-21 A | 100% |  | 2008-12-11 | 2011-09-21 | 370.2d? |  | finish no earlier than 2011-09-21 | CP,GP,RP,SP | 2961.6h | 2961.6h |  |  |  |  | Rel-10 |  |  |  |  |  |

Notes:
- 698: Stage 3. RP#57 completed / Text5: muhammad.kazmi@ericsson.com
- 699: RP#57 completed / Text5: muhammad.kazmi@ericsson.com
- 700: RP#57 completed / Text5: muhammad.kazmi@ericsson.com
- 701: SP#50 EU-Alert is introduced under Public Warning System in parallel with the already existing ETWS and CMAS. SA1 22.268 CR#9r1 adds EU-ALERT specific requirements & CT1 23.041 CRs#
- 702: -
- 703: Not completed internet-draft
- 704: CP#56 stopped. Reason: Protocols for SMS over SGs is replaced by the SIMTC SMS in MME solution (as solution not only for MTC user but for general subscribers) / Text5: jean-jacques.trottin@alcatel-lucent.com
- 705: CP#56 stopped (abandonned new TR 29.818) / Text5: jean-jacques.trottin@alcatel-lucent.com
- 706: CP#56 stopped (abandonned new TS 29.218 Diameter based protocols for SMS service over SGs) / Text5: jean-jacques.trottin@alcatel-lucent.com
- 707: CP#56 stopped / Text5: jean-jacques.trottin@alcatel-lucent.com
- 708: -
- 709: SP#48 completed / Text5: Li Gang (ligangyf@chinamobile.com)
- 710: SP#53 completed. Spin-off Feature UID_500030 Non Voice Emergency Services (NOVES) / Text5: dwilliams@qualcomm.com
- 711: SP#51 TR 22.809 approved. Support Interworking between 3GPP networks and Enterprise environments to provide enterprise voice services via 3GPP mobile devices / Text5: Phillip Brown (pbrown@tatarasystems.com)
- 712: SP#52 completed / Text5: mona.mustapha@vodafone.com
- 713: SP#54 completed / Text5: Li Gang (ligangyf@chinamobile.com), Yu Qing (yuqing@chinamobile.com)
- 714: SP#52 completed / Text5: farooq.bari@att.com
- 715: SP#52 completed / Text5: Li Lianyuan (lilianyuan@chinamobile.com), Liu Hong (liuhongyfw@chinamobile.com)
- 716: SP#54 completed. Study on "reverse direction" from UTRAN/GERAN to E-UTRAN/HSPA (Rel-8 SRVCC was in the other direction E-UTRAN/HSPA to GERAN/UTRAN) / Text5: delphin.barankanira@orange-ftgroup.com
- 717: SP#54 completed. Linked to Rel-11 OSCAR (Optimized Service Charging and Allocation of Resources in IMS whilst Roaming) UID_490032. Related to LBO/home routing decision / Text5: michele.zarri@telekom.com
- 718: SP#55 completed. SP#54 TR 33.859v200 for Approval / Text5: karl.norrman@ericsson.com
- 719: SP#56 completed. SP#55 TR 33.914v200 approved (converted 33.804). Study reuse of non-UICC credentials (in particular SIP Digest) to provide security for access to applications. Provide reference material for IMS based non-UICC based SSO to applications / Text5: Silke.Holtmanns@nokia.com
- 720: SP#56 completed. Extends Rel-10 work on 3D video formats UID_480044 Improved Video Coding Support for PSS and MBMS / Text5: gilles.teniou@orange-ftgroup.com
- 721: SP#57 completed. TR 32.833v200 for Approval / Text5: Jörg Schmidt (J.Schmidt@nsn.com)
- 722: SP#54 completed / Text5: Nick Mazzarella (njmazzarella@alcatel-lucent.com)
- 723: SP#54 completed. Triggered by Rel-10 UID_430044 TR 32.826 Study on Energy Savings Management (FS_OAM_ESM) and UID_470037 OAM aspects of Energy Saving in Radio Networks (OAM-ES) / Text5: clemens.suerbaum@nsn.com
- 724: CP#52 completed. Linked to SA5 UID_430044 (FS_OAM-ESM) & UID_470037 (OAM-ES), RAN3 UID_470015 (FS_Energy_LTE), RAN1 UID_460016 (FS_Energy_UMTS) / Text5: gottfried.punz@nw.neclab.eu
- 725: CP#57 completion 09/12=>12/12 (exception in CP-120450). Continue work in Rel-11 especially to cover handling of Idle mode Signalling Reduction (ISR). Linked to SA2 UID_490036 Study on Core Network Overload solutions / Text5: lu.fei1@zte.com.cn
- 726: GP#53 completed (03/12). GP#46 approved WID. / Text5: marten.sundberg@ericsson.com
- 727: RP#53 completed / Text5: bruno.clerckx@samsung.com
- 728: RP#53 completed. Studied coexistence scenario of LTE and Industrial, Scientific and Medical (ISM) Radio within the same device working in adjacent frequencies / Text5: Zhenping Hu (huzhenping@chinamobile.com)
- 729: RP#57 completed. TR 36.839 v100 for Information & Approval / Text5: sudeep.palat@alcatel-lucent.com
- 730: RP#54 completed / Text5: federico.boccardi@alcatel-lucent.com
- 731: RP#56 completed. TR 36.828 for Information and Approval / Text5: Zukang Shen (shenzukang@datangmobile.cn)
- 732: RP#56 completed. TR 36.824 v200 for Approval / Text5: Peng Chen (chenpeng@ctbri.com.cn)
- 733: RP#55 completed. TR 36.829 v100 for Information + Approval / Text5: Yuta Sagae
- 734: RP#57 completed. TR 37.902 v200 for Approval / Text5: Xudong An (anxudong@emcite.com)
- 735: RP#55 completed. TR 37.976 v200 for Approval / Text5: Tim.frost@vodafone.com
- 736: RP#57 completed. TR 37.806 v200 for Approval / Text5: christian.bergljung@stericsson.com
- 737: RP#53 completed. TR 37.868v100 for Approval (No WID change: RAN overload only). Triggered by TR 22.868 Study on Facilitating Machine to Machine Communication in GSM and UMTS (M2M) UID_7027 and Rel-10 NIMTC UID_410030 / Text5: Jeff Gao (gaoyq@huawei.com)
- 738: RP#54 completed / Text5: ron.borsato@spirent.com
- 739: RP#56 completed. TR 37.803 v200 for Approval / Text5: Martin.Warner@alcatel-lucent.com
- 740: RP#56 completed. Impacts TR 37.804 Study on UMTS/LTE in 900 MHz band (Japan, Korea) UID_520018 / Text5: Koo Yeon Sang (yskoo@lguplus.co.kr)
- 741: RP#56 completed. Updated WID RP-111751=>RP-120617. TR 37.804 v100 for Information and Approval. Linked to Study on Interference analysis between 800~900 MHz bands UID_510038 / Text5: Masahiro Fujii (fujiima@nttdocomo.co.jp)
- 742: RP#53 completed (1-step Approval) / Text5: Sharad Sambhwani
- 743: RP#53 completed / Text5: karri.ranta-aho@nsn.com
- 744: RP#57 completed / Text5: petri.j.vasenkari@nokia.com
- 745: RP#57 TR 25.874 v100 for Information & Approval / Text5: limei.wei@td-tech.com
- 746: RP#56 stopped. RP-120856 discussion: most content moved to Rel-11 Coordinated Multi-Point Operation for LTE Uplink (COMP_LTE_UL) and RAN1 has no time to look at it / Text5: Yongxing Zhou
- 747: -

| ID | WBS | Task | Duration | Start | Finish | Complete | Remaining | Baseline start | Baseline finish | Baseline duration | Total slack | Constraint | Resources | Work | Actual work | Text1 | Text2 | Text4 | Text5 | Text6 | Text7 | Text8 | Text9 | Text12 | Text11 |
| --- | --- | --- | --- | --- | --- | --- | --- | --- | --- | --- | --- | --- | --- | --- | --- | --- | --- | --- | --- | --- | --- | --- | --- | --- | --- |
| 748 | 288 | **Enhancements for Multimedia Priority Service** | 1311d? | 2006-03-13 A | 2011-03-18 A | 100% |  | 2006-03-13 | 2011-03-18 | 1311d? |  |  | S1,S2,C4,C3,C1 | 28072h | 28072h | eMPS | PCG-21 | Telcordia | jgarraha@telcordia.com | Rel-10 | SP-39 | Alain |  |  |  |
| 749 | 288.1 | Stage 1 on enhancements for Multimedia Priority Service | 584d? | 2006-03-13 A | 2008-06-05 A | 100% |  | 2006-03-13 | 2008-06-05 | 584d? |  | start no earlier than 2006-03-12 | S1 | 4672h | 4672h | ePRIOR | PCG-21 | Telcordia | jgarraha@telcordia.com | Rel-10 | SP-39 | Alain |  |  |  |
| 750 | 288.2 | **Stage 2 on enhancements for Multimedia Priority Service** | 206d? | 2009-12-10 A | 2010-09-23 A | 100% |  | 2009-12-10 | 2010-09-23 | 206d? |  |  | S2 | 6592h | 6592h | eMPS | PCG-24 | Telcordia, NTT DoCoMo | Vijay Varma, Katsutoshi Nishida | Rel-10 | SP-46 | Maurice |  |  |  |
| 751 | 288.2.1 | Stage 2 on eMPS for CSFB | 206d? | 2009-12-10 A | 2010-09-23 A | 100% |  | 2009-12-10 | 2010-09-23 | 206d? |  | finish no earlier than 2010-09-24 | S2 | 1648h | 1648h | eMPS | PCG-24 | Telcordia, NTT DoCoMo | Vijay Varma, Katsutoshi Nishida | Rel-10 | SP-46 | Maurice |  |  |  |
| 752 | 288.2.2 | Stage 2 on eMPS for EPS Bearer Service | 206d? | 2009-12-10 A | 2010-09-23 A | 100% |  | 2009-12-10 | 2010-09-23 | 206d? |  | finish no earlier than 2010-12-09 | S2 | 1648h | 1648h | eMPS | PCG-24 | Telcordia, NTT DoCoMo | Vijay Varma, Katsutoshi Nishida | Rel-10 | SP-46 | Maurice |  |  |  |
| 753 | 288.2.3 | Stage 2 on eMPS for IMS Aspects | 206d? | 2009-12-10 A | 2010-09-23 A | 100% |  | 2009-12-10 | 2010-09-23 | 206d? |  | finish no earlier than 2010-12-09 | S2 | 1648h | 1648h | eMPS | PCG-24 | Telcordia, NTT DoCoMo | Vijay Varma, Katsutoshi Nishida | Rel-10 | SP-46 | Maurice |  |  |  |
| 754 | 288.3 | Deleted - TR 23.854 on Stage 2 on enhancements for Multimedia Priority Service | 266d? | 2009-12-10 A | 2010-12-16 A | 100% |  | 2009-12-10 | 2010-12-16 | 266d? |  | finish no earlier than 2011-03-17 | S2 | 2128h | 2128h | eMPS | PCG-24 | Telcordia, NTT DoCoMo | Vijay Varma, Katsutoshi Nishida | Rel-10 | SP-46 | Maurice | PCG-27 | SP-50 |  |
| 755 | 288.4 | **Stage 3 on enhancements for Multimedia Priority Service** | 131d? | 2010-09-17 A | 2011-03-18 A | 100% |  | 2010-09-17 | 2011-03-18 | 131d? |  |  | C4,C3,C1 | 4192h | 4192h | eMPS-CN | PCG-25 | Ericsson | Philip.hodges@ericsson.com | Rel-10 | CP-49 | Kimmo |  |  |  |
| 756 | 288.4.1 | CT4 part on Stage 3 on enhancements for Multimedia Priority Service | 131d? | 2010-09-17 A | 2011-03-18 A | 100% |  | 2010-09-17 | 2011-03-18 | 131d? |  | start no earlier than 2010-09-17 | C4 | 1048h | 1048h | eMPS-CN | PCG-25 | Ericsson | Philip.hodges@ericsson.com | Rel-10 | CP-49 | Kimmo |  |  |  |
| 757 | 288.4.2 | CT3 part on Stage 3 on enhancements for Multimedia Priority Service | 131d? | 2010-09-17 A | 2011-03-18 A | 100% |  | 2010-09-17 | 2011-03-18 | 131d? |  | start no earlier than 2010-09-17 | C3 | 1048h | 1048h | eMPS-CN | PCG-25 | Ericsson | Philip.hodges@ericsson.com | Rel-10 | CP-49 | Jiwan |  |  |  |
| 758 | 288.4.3 | CT1 part on Stage 3 on enhancements for Multimedia Priority Service | 131d? | 2010-09-17 A | 2011-03-18 A | 100% |  | 2010-09-17 | 2011-03-18 | 131d? |  | start no earlier than 2010-09-17 | C1 | 1048h | 1048h | eMPS-CN | PCG-25 | Ericsson | Philip.hodges@ericsson.com | Rel-10 | CP-49 | Frederic |  |  |  |
| 759 | 289 | **Network Improvements for Machine-Type Communications** | 1168d? | 2008-09-18 A | 2013-03-01 | 89% | 126.56d? | 2008-09-18 | 2013-03-01 | 1168d? | 403d |  | S1,S2,S5,C1,C4,C6,G2,R2,R3,R5,G3new | 30849.2h | 22577.2h | NIMTC | PCG-21 | KPN | toon.norp@tno.nl | Rel-10 | SP-41 | Alain |  |  |  |
| 760 | 289.1 | Stage 1 for Network Improvements for Machine-Type Communications | 397d? | 2008-09-18 A | 2010-03-25 A | 100% |  | 2008-09-18 | 2010-03-25 | 397d? |  | finish no earlier than 2009-12-10 | S1 | 3176h | 3176h | NIMTC | PCG-21 | KPN | toon.norp@tno.nl | Rel-10 | SP-41 | Alain |  |  |  |
| 761 | 289.2 | Deleted - TR on Stage 2 for Network Improvements for Machine-Type Communications | 321d? | 2009-09-24 A | 2010-12-16 A | 100% |  | 2009-09-24 | 2010-12-16 | 321d? |  | finish no earlier than 2010-11-30 | S2 | 2568h | 2568h | NIMTC | PCG-23 | Samsung | erik.guttman@partner.samsung.com | Rel-10 | SP-45 | Maurice | PCG-26 | SP-50 |  |
| 762 | 289.3 | Stage 2 for Network Improvements for Machine-Type Communications | 19d? | 2010-08-30 A | 2010-09-23 A | 100% |  | 2010-08-30 | 2010-09-23 | 19d? |  | finish no earlier than 2010-09-17 | S2 | 152h | 152h | NIMTC | PCG-23 | Samsung | erik.guttman@partner.samsung.com | Rel-10 | SP-45 | Maurice |  |  |  |
| 763 | 289.4 | Deleted - Security for Network Improvements for Machine-Type Communications | 193.15d? | 2009-12-10 A | 2010-09-23 A | 100% |  | 2009-12-10 | 2010-09-23 | 193.15d? |  | finish no earlier than 2010-09-23 | S3 | 1545.2h | 1545.2h | NIMTC | PCG-24 | Samsung | Rajavelsamy R (rajvel@samsung.com) | Rel-10 | SP-46 | Dionisio | PCG-25 | SP-49 |  |
| 764 | 289.5 | Charging for Network Improvements for Machine-Type Communication | 3d? | 2011-03-21 A | 2011-03-23 A | 100% |  | 2011-03-21 | 2011-03-23 | 3d? |  | start no earlier than 2011-03-21 | S5 | 24h | 24h | NIMTC-CH | PCG-26 | Ericsson | patrik.teppo@@ericsson.com | Rel-10 | SP-51 | Dionisio |  |  |  |
| 765 | 289.6 | **CN part of Stage 3 for Network Improvements for Machine-Type Communications** | 261d? | 2010-06-04 A | 2011-06-03 A | 100% |  | 2010-06-04 | 2011-06-03 | 261d? |  |  | C1,C4,C6 | 8800h | 8800h | NIMTC | PCG-25 | Ericsson | mikael.wass@ericsson.com | Rel-10 | CP-48 | Frederic |  |  |  |
| 766 | 289.6.1 | CT1 part of Stage 3 for Network Improvements for Machine-Type Communications | 261d? | 2010-06-04 A | 2011-06-03 A | 100% |  | 2010-06-04 | 2011-06-03 | 261d? |  | finish no earlier than 2011-06-03 | C1 | 2088h | 2088h | NIMTC | PCG-25 | Ericsson | mikael.wass@ericsson.com | Rel-10 | CP-48 | Frederic |  |  |  |
| 767 | 289.6.2 | Deleted - CT3 part of Stage 3 for Network Improvements for Machine-Type Communications | 261d? | 2010-06-04 A | 2011-06-03 A | 100% |  | 2010-06-04 | 2011-06-03 | 261d? |  | finish no earlier than 2010-12-10 | C3 | 2088h | 2088h | NIMTC | PCG-25 | Ericsson | mikael.wass@ericsson.com | Rel-10 | CP-48 | Jiwan | PCG-27 | CP-52 |  |
| 768 | 289.6.3 | CT4 part of Stage 3 for Network Improvements for Machine-Type Communications | 261d? | 2010-06-04 A | 2011-06-03 A | 100% |  | 2010-06-04 | 2011-06-03 | 261d? |  | finish no earlier than 2011-03-18 | C4 | 2088h | 2088h | NIMTC | PCG-25 | Ericsson | mikael.wass@ericsson.com | Rel-10 | CP-48 | Kimmo |  |  |  |
| 769 | 289.6.4 | CT6 part of Stage 3 for Network Improvements for Machine-Type Communications | 56d? | 2011-03-18 A | 2011-06-03 A | 100% |  | 2011-03-18 | 2011-06-03 | 56d? |  | finish no earlier than 2011-06-03 | C6 | 448h | 448h | NIMTC | PCG-26 | Sagem-Orga | heiko.kruse@sagem-orga.com | Rel-10 | CP-51 | Xavier |  |  |  |
| 770 | 289.7 | GERAN part of Network Improvements for Machine-Type Communications (Stage 3) | 261d? | 2010-09-03 A | 2011-09-02 A | 100% |  | 2010-09-03 | 2011-09-02 | 261d? |  | finish no earlier than 2011-09-02 | G2 | 2088h | 2088h | NIMTC | PCG-25 | Vodafone, Ericsson | leo.patanapongpibul@vodafone.com, john.diachina@ericsson.com | Rel-10 | GP-47 | Gert |  |  |  |
| 771 | 289.8 | MS Conformance Test Aspects for GERAN - Network Improvements for Machine-Type Communications | 137d? | 2012-08-24 | 2013-03-01 |  |  | 2012-08-24 | 2013-03-01 | 137d? | 403d | finish no earlier than 2013-03-01 | G3new | 1096h |  | NIMTC_GERAN-MSTest | PCG-29 | ST-Ericsson | hakan.e.grunditz@stericsson.com | Rel-10 | GP-55 |  |  |  |  |
| 772 | 289.9 | RAN mechanisms to avoid CN overload due to Machine-Type Communications | 131d? | 2010-09-17 A | 2011-03-18 A | 100% |  | 2010-09-17 | 2011-03-18 | 131d? |  | finish no earlier than 2011-03-18 | R2,R3 | 1048h | 1048h | NIMTC-RAN_overload | PCG-25 | Huawei | Jeff Gao (gaoyq@huawei.com) | Rel-10 | RP-49 | Joern |  |  | RP-110063 |
| 773 | 289.10 | UE Conformance Test Aspects - Network Improvements for Machine-Type Communications | 126d? | 2012-09-07 | 2013-03-01 |  |  | 2012-09-07 | 2013-03-01 | 126d? | 403d | finish no earlier than 2013-03-01 | R5 | 1008h |  | NIMTC-UEConTest | PCG-29 | Ericsson | calle.hagenfeldt@ericsson.com | Rel-10 | RP-57 |  |  |  |  |

Notes:
- 748: CP#51 completed. SP#49 moved Stage 1 from Rel-9 & Completed Stage 2. SP#40 Stage 1 completed. Continuation of Rel-8 Feature PRIOR (UID_340044)
- 749: ePRIOR started Mar 2006 as a Rel-8 Feature. It was delayed to Rel-9 (completed at SP#40), then moved to Rel-10 at SP#49 and demoted to Building Block level. / Text3: 22.153, 22.278
- 750: SP#49 completed. Updated WID SP-100166=>SP-100647
- 751: SP#49 completed / Text3: 23.002, 23.203, 23.221, 23.228, 23.272, 23.401
- 752: SP#49 completed / Text3: 23.002, 23.203, 23.221, 23.228, 23.272, 23.401
- 753: SP#49 completed / Text3: 23.002, 23.203, 23.221, 23.228, 23.272, 23.401
- 754: SP#49 TR 23.854 v100 for Information. SP#50 moved to Rel-11 SRVCC aspect of enhancements for Multimedia Priority Service UID_480135 (place holder for solution alternatives and agreed functions to be reflected in affected existing TS) / Text3: new TR 23.854
- 755: CP#51 completed / Text3: Stage 3
- 756: CP#51 completed / Text3: 23.008, 29.002, 29.228, 29.229, 29.272, 29.274, 29.277, 29.328, 29.329
- 757: CP#51 completed / Text3: 29.212, 29.213, 29.214
- 758: CP#51 completed / Text3: 24.008, 24.229, 24.301
- 759: GP#51 (09/11) completed. Triggered by Rel-8 UID_7027 Study on Facilitating Machine to Machine Communication in GSM and UMTS (FS_M2M) TR 22.868
- 760: SA#47 completed / Text3: 22.011, new 22.368
- 761: SP#50 updated WID SP-090832=>SP-100863 (TR 23.888 not submitted for approval to conclude Rel-10 NIMTC as it will continue to serve as basis for Rel-11 SIMTC work item) / Text3: new TR 23.888
- 762: SP#49 completed / Text3: 23.060, 23.236, 23.401
- 763: SP#49 stopped (activity transferred to Rel-11 Feature SIMTC under UID_490028 "TR on Security aspects of Machine-Type Communications". / Text3: new 33.868
- 764: SP#51 completed / Text3: 32.251, 32.298, 32.299
- 765: CP#52 completed / Text3: Stage 3
- 766: CP#52 completed / Text3: 23.122, 24.008, 24.301, new 24.368
- 767: CP#52 stopped (SA2 decided to move impact from CT3 to CT4). Updated WID CP-110147=>CP-110442 (no CT3 impact) / Text3: 29.212, 29.213, 29.215
- 768: CP#52 completed / Text3: 23.003, 23.008, 29.002, 29.060, 29.230, 29.272, 29.274, 29.275, 29.282
- 769: CP#52 completed / Text3: 31.102
- 770: GP#51 completed. GP#47 approved WID / Text3: 44.018, 44.060
- 771: GP#55 approved WID. Testing for CT1 part of Stage 3 for NIMTC UID_480105, GERAN part of NIMTC (Stage 3) UID_490003 / Text3: 51.010-1, 51.010-2
- 772: RP#51 completed / Text3: UTRA, LTE 25.331, 25.413, 36.331, 36.413
- 773: Testing for CT1 part of Stage 3 UID_480105, RAN mechanisms to avoid CN overload due to MTC UID_490024 / Text3: 34.123-1, 34.123-2, 34.123-3, 36.523-1, 36.523-2, 36.523-3

| ID | WBS | Task | Duration | Start | Finish | Complete | Remaining | Baseline start | Baseline finish | Baseline duration | Total slack | Constraint | Resources | Work | Actual work | Text1 | Text2 | Text4 | Text6 | Text7 | Text8 |
| --- | --- | --- | --- | --- | --- | --- | --- | --- | --- | --- | --- | --- | --- | --- | --- | --- | --- | --- | --- | --- | --- |
| 774 | 290 | **Multi Access PDN Connectivity** | 527d? | 2009-03-13 A | 2011-03-18 A | 100% |  | 2009-03-13 | 2011-03-18 | 527d? |  |  | S2,C4,C1,C3 | 9592h | 9592h | MAPCON | PCG-22 | Telecom Italia | Rel-10 | SP-43 | Maurice |
| 775 | 290.1 | Stage 2 for Multi Access PDN Connectivity | 401d? | 2009-03-13 A | 2010-09-23 A | 100% |  | 2009-03-13 | 2010-09-23 | 401d? |  |  | S2 | 3208h | 3208h | MAPCON |  | Telecom Italia | Rel-10 |  | Maurice |
| 776 | 290.2 | **CT aspects of Multi Access PDN Connectivity** | 90d? | 2010-11-15 A | 2011-03-18 A | 100% |  | 2010-11-15 | 2011-03-18 | 90d? |  |  | C4,C1,C3 | 2168h | 2168h | MAPCON-St3 | PCG-26 | ZTE | Rel-10 | CP-50 | Kimmo |
| 777 | 290.2.1 | CT4 aspects of Multi Access PDN Connectivity | 20d? | 2010-11-15 A | 2010-12-10 A | 100% |  | 2010-11-15 | 2010-12-10 | 20d? |  | start no earlier than 2010-12-10 | C4 | 160h | 160h | MAPCON-St3 | PCG-26 | ZTE | Rel-10 | CP-50 | Kimmo |
| 778 | 290.2.2 | CT1 aspects of Multi Access PDN Connectivity | 71d? | 2010-12-10 A | 2011-03-18 A | 100% |  | 2010-12-10 | 2011-03-18 | 71d? |  | start no earlier than 2010-12-10 | C1 | 568h | 568h | MAPCON-St3 | PCG-26 | ZTE | Rel-10 | CP-50 | Frederic |
| 779 | 290.2.3 | CT3 aspects of Multi Access PDN Connectivity | 90d? | 2010-11-15 A | 2011-03-18 A | 100% |  | 2010-11-15 | 2011-03-18 | 90d? |  | finish no earlier than 2011-03-18 | C3 | 720h | 720h | MAPCON-St3 | PCG-26 | ZTE | Rel-10 | CP-50 | Jiwan |
| 780 | 291 | **IMS Service Continuity – Inter Device Transfer enhancements** | 922d? | 2009-06-04 A | 2012-12-07 | 88% | 113.82d? | 2009-06-04 | 2012-12-07 | 922d? | 463d |  | S1,S2,C1,IETF | 17272h | 10154h | IMS_SC_eIDT | PCG-23 | Huawei | Rel-10 | SP-44 | Alain |
| 781 | 291.1 | Stage 1 - IMS Service Continuity – Inter Device Transfer enhancements | 211d? | 2009-06-04 A | 2010-03-25 A | 100% |  | 2009-06-04 | 2010-03-25 | 211d? |  | finish no earlier than 2010-03-25 | S1 | 1688h | 1688h | IMS_SC_eIDT | PCG-23 | Huawei | Rel-10 | SP-44 | Alain |
| 782 | 291.2 | Stage 2 - IMS Inter-UE Transfer enhancements | 261d? | 2009-09-24 A | 2010-09-23 A | 100% |  | 2009-09-24 | 2010-09-23 | 261d? |  | finish no earlier than 2010-09-23 | S2 | 2088h | 2088h | IMS_SC_eIDT | PCG-23 | Huawei | Rel-10 | SP-45 | Maurice |
| 783 | 291.3 | Stage 3 - IMS Inter-UE Transfer enhancements | 261d? | 2010-03-19 A | 2011-03-18 A | 100% |  | 2010-03-19 | 2011-03-18 | 261d? |  | start no earlier than 2010-03-19 | C1 | 2088h | 2088h | IMS_SC_eIDT | PCG-24 | Huawei | Rel-10 | CP-47 | Frederic |
| 784 | 291.4 | (IETF) Stage 3 - IMS Inter-UE Transfer enhancements | 715d? | 2010-03-19 A | 2012-12-07 | 75% | 178.75d? | 2010-03-19 | 2012-12-07 | 715d? | 463d | finish no earlier than 2012-12-07 | C1-IETF | 5720h | 4290h | IMS_SC_eIDT | PCG-27 | Christer Holmberg | Rel-10 | CP-52 | Frederic |
| 785 | 292 | **IP-Short-Message-Gateway enhancements for CPM-SMS Interworking** | 257d? | 2009-09-24 A | 2010-09-17 A | 100% |  | 2009-09-24 | 2010-09-17 | 257d? |  |  | S1,S2,C3 | 5792.8h | 5792.8h | CPM-SMS | PCG-23 | China Mobile | Rel-10 | SP-45 | Alain |
| 786 | 292.1 | Stage 1 for CPM-SMS | 131d? | 2009-09-24 A | 2010-03-25 A | 100% |  | 2009-09-24 | 2010-03-25 | 131d? |  | finish no earlier than 2010-03-25 | S1 | 1048h | 1048h | CPM-SMS | PCG-23 | China Mobile | Rel-10 | SP-45 | Alain |
| 787 | 292.2 | Stage 2 for CPM-SMS | 130.1d? | 2009-09-24 A | 2010-03-25 A | 100% |  | 2009-09-24 | 2010-03-25 | 130.1d? |  | finish no earlier than 2010-03-25 | S2 | 1040.8h | 1040.8h | CPM-SMS | PCG-23 | Orange | Rel-10 | SP-45 | Maurice |
| 788 | 292.3 | Stage 3 for IP-Short-Message-Gateway enhancements for CPM-SMS Interworking | 206d? | 2009-12-04 A | 2010-09-17 A | 100% |  | 2009-12-04 | 2010-09-17 | 206d? |  | finish no earlier than 2010-09-17 | C3 | 1648h | 1648h | CPM-SMS | PCG-24 | Ericsson | Rel-10 | CP-46 | Jiwan |
| 789 | 293 | **Completion of Communications on Not Logged-in** | 387d? | 2009-09-24 A | 2011-03-18 A | 100% |  | 2009-09-24 | 2011-03-18 | 387d? |  |  | S1,C1,C3 | 5800h | 5800h | CCNL | PCG-23 | Deutsche Telekom | Rel-10 | SP-45 | Alain |
| 790 | 293.1 | Stage 1 for Completion of Communications on Not Logged-in | 1d? | 2009-09-24 A | 2009-09-24 A | 100% |  | 2009-09-24 | 2009-09-24 | 1d? |  | start no earlier than 2009-09-24 | S1 | 8h | 8h | CCNL | PCG-23 | Deutsche Telekom | Rel-10 | SP-45 | Alain |
| 791 | 293.2 | CT1 part of Stage 3 for Completion of Communications on Not Logged-in | 261d? | 2010-03-19 A | 2011-03-18 A | 100% |  | 2010-03-19 | 2011-03-18 | 261d? |  | finish no earlier than 2011-03-18 | C1 | 2088h | 2088h | CCNL | PCG-24 | Deutsche Telekom | Rel-10 | CP-47 | Frederic |
| 792 | 293.3 | CT3 part of Stage 3 for Completion of Communications on Not Logged-in | 76d? | 2010-06-04 A | 2010-09-17 A | 100% |  | 2010-06-04 | 2010-09-17 | 76d? |  | finish no earlier than 2010-09-17 | C3 | 608h | 608h | CCNL | PCG-25 | Deutsche Telekom | Rel-10 | CP-48 | Jiwan |
| 793 | 294 | **Local IP Access and Selected Internet IP Traffic Offload** | 390d? | 2009-09-24 A | 2011-03-23 A | 100% |  | 2009-09-24 | 2011-03-23 | 390d? |  |  | S2,S1,S3,S5,C4,C1 | 28656h | 28656h | LIPA_SIPTO | PCG-23 | Huawei, China Mobile | Rel-10 | SP-45 | Maurice |
| 794 | 294.1 | Stage 1 for Local IP Access and Selected Internet IP Traffic Offload | 131d? | 2009-09-24 A | 2010-03-25 A | 100% |  | 2009-09-24 | 2010-03-25 | 131d? |  | finish no earlier than 2010-03-25 | S1 | 1048h | 1048h | LIPA_SIPTO | PCG-23 | Huawei, China Mobile | Rel-10 | SP-45 | Alain |
| 795 | 294.2 | TR on Local IP Access and Selected Internet IP Traffic Offload | 387d? | 2009-09-24 A | 2011-03-18 A | 100% |  | 2009-09-24 | 2011-03-18 | 387d? |  | finish no earlier than 2011-03-18 | S2 | 3096h | 3096h | LIPA_SIPTO | PCG-23 | Huawei, China Mobile | Rel-10 | SP-45 | Maurice |
| 796 | 294.3 | Security for Local IP Access and Selected Internet IP Traffic Offload | 261d? | 2009-09-24 A | 2010-09-23 A | 100% |  | 2009-09-24 | 2010-09-23 | 261d? |  | finish no earlier than 2010-09-23 | S3 | 2088h | 2088h | LIPA_SIPTO | PCG-23 | Huawei, Qualcomm | Rel-10 | SP-45 | Dionisio |
| 797 | 294.4 | OAM&P for Local IP Access and Selected Internet IP Traffic Offload | 390d? | 2009-09-24 A | 2011-03-23 A | 100% |  | 2009-09-24 | 2011-03-23 | 390d? |  | finish no earlier than 2011-03-23 | S5 | 3120h | 3120h | LIPA_SIPTO | PCG-23 | Huawei, China Mobile | Rel-10 | SP-45 | Dionisio |
| 798 | 294.5 | Charging for Local IP Access and Selected Internet IP Traffic Offload | 335d? | 2009-12-10 A | 2011-03-23 A | 100% |  | 2009-12-10 | 2011-03-23 | 335d? |  | finish no earlier than 2011-03-23 | S5 | 2680h | 2680h | LIPA_SIPTO | PCG-24 | Huawei, China Mobile | Rel-10 | SP-46 | Dionisio |
| 799 | 294.6 | Stage 2 for Local IP Access | 261d? | 2009-09-24 A | 2010-09-23 A | 100% |  | 2009-09-24 | 2010-09-23 | 261d? |  | finish no earlier than 2010-08-10 | S2 | 2088h | 2088h | LIPA | PCG-23 | Huawei, China Mobile | Rel-10 | SP-45 | Maurice |

Notes:
- 774: CP#51 completed. SP#49 Stage 2 completed. Triggered by TR 23.861 UID_410043 FS_MAPIM. Stage 1 in Rel-9 22.278 (6.2 - IP session control) / Text5: ivano.guardini@telecomitalia.it
- 775: SP#49 completed. Triggered by TR 23.861 UID_410043 FS_MAPIM. Stage 1 in Rel-9 22.278 (6.2 - IP session control) / Text3: 23.237, 23.401, 23.402 / Text5: ivano.guardini@telecomitalia.it
- 776: CP#51 completed / Text5: Xingyue (Joy) Zhou (zhou.xingyue@zte.com.cn)
- 777: CP#50 completed / Text3: 29.273, 29.272, 29.002, 23.008 / Text5: Xingyue (Joy) Zhou (zhou.xingyue@zte.com.cn)
- 778: CP#51 completed / Text3: 24.302, 24.312 / Text5: Xingyue (Joy) Zhou (zhou.xingyue@zte.com.cn)
- 779: CP#51 completed / Text3: 29.215 / Text5: Xingyue (Joy) Zhou (zhou.xingyue@zte.com.cn)
- 780: CP#51 completed. SP#47 Stage 1 completed. Rel-9 set Inter-Device Transfer requirements UID_410033 (IMS_SCC-IDT). Adds IDT scenarios and requirements / Text5: Amar Deol (adeol@huawei.com)
- 781: SA#47 completed / Text3: 22.228 / Text5: Amar Deol (adeol@huawei.com)
- 782: SP#49 completed / Text3: 23.237, 23.292, new 23.831 / Text5: Lee Valerius (lvalerius@huawei.com)
- 783: CP#51 completed. WID updated CP-100334=>CP-110285 / Text3: 24.216, 24.229, 24.237, new (24.837, 24.337) / Text5: georg.mayer@huawei.com
- 784: Passed WGLC / Text3: draft-ietf-sipcore-proxy-feature / Text5: christer.holmberg@ericsson.com
- 785: CP#49 completed. SP#47 Stage 1 completed. IP-SM-GW enhancements for interworking with OMA CPM / Text5: Qing Huang (huangqing@chinamobile.com)
- 786: SA#47 completed. External requirements (Stage 1 in OMA-RD-CPM-V1_0-20090310-C) / Text3: 22.340 / Text5: Qing Huang
- 787: SP#47 completed / Text3: 23.204, new TR 23.824 / Text5: antoine.mouquet@orange-ftgroup.com
- 788: CP#49 completed. Linked to Rel-8 UID_340031 Service-Level Interworking for Messaging Services (MESSIW) 23.204 / Text3: 29.311 / Text5: Jan Holm
- 789: CP#51 completed. SP#45 Stage 1 completed / Text5: Kurt Bischinger
- 790: SP#45 completed / Text3: 22.173 CR#0056r1 / Text5: Kurt Bischinger
- 791: CP#51 completed / Text3: 24.173, 24.642 / Text5: martin.huelsemann@telekom.de
- 792: CP#49 completed / Text3: 29.165 / Text5: martin.huelsemann@telekom.de
- 793: TSG#51 completed. Updated WID SP-100696=>SP-110131. SP#49 Stage 2 & Security completed. UID_400035 Enhanced Home NodeB/eNodeB (EHNB) formerly covered Local IP Access to Internet and Local access to Home Network from the Home NodeB/eNodeB / Text5: patrice.hede@huawei.com, Tao Sun (suntao@chinamobile.com)
- 794: SP#47 completed / Text3: 22.101, 22.220 / Text5: Amar Deol (adeolf@huawei.com), Gang Li (ligangyf@chinamobile.com)
- 795: SP#51 completed. TR 23.829 for Approval / Text3: new TR 23.829 / Text5: patrice.hede@huawei.com, Tao Sun (suntao@chinamobile.com)
- 796: SP#49 completed / Text3: 33.102, 33.107, 33.108, 33.320, 33.401 / Text5: Marcus Wong (mwong@huawei.com), Brian Rosenberg (bmr@qualcomm.com)
- 797: SP#51 completed. Updated WID SP-100696=>SP-110131 / Text3: 32.581, 32.582, 32.584, 32.591, 32.592, 32.642, 32.646, 32.772, 32.782 / Text5: Zou Lan (zlan@huawei.com), Chen Gang (chengang@chinamobile.com)
- 798: SP#51 completed. Updated WID SP-100696=>SP-110131 / Text3: 32.251 / Text5: shan.mingjun@huawei.com, Ai Chen (chenai@chinamobile.com)
- 799: SP#49 completed (has impacts to RAN) / Text3: 23.060, 23.401 / Text5: patrice.hede@huawei.com, Tao Sun (suntao@chinamobile.com)

| ID | WBS | Task | Duration | Start | Finish | Complete | Baseline start | Baseline finish | Baseline duration | Constraint | Resources | Work | Actual work | Text1 | Text2 | Text4 | Text5 | Text6 | Text7 | Text8 |
| --- | --- | --- | --- | --- | --- | --- | --- | --- | --- | --- | --- | --- | --- | --- | --- | --- | --- | --- | --- | --- |
| 800 | 294.7 | **Stage 3 for Local IP Access** | 206d? | 2010-06-04 A | 2011-03-18 A | 100% | 2010-06-04 | 2011-03-18 | 206d? |  | C4,C1 | 4944h | 4944h | LIPA | PCG-25 | China Mobile | Zhang Hao (zhanghao@chinamobile.com) | Rel-10 | CP-48 | Kimmo |
| 801 | 294.7.1 | CT4 part of Stage 3 for Local IP Access | 206d? | 2010-06-04 A | 2011-03-18 A | 100% | 2010-06-04 | 2011-03-18 | 206d? | finish no earlier than 2011-03-18 | C4 | 1648h | 1648h | LIPA | PCG-25 | China Mobile | Zhang Hao (zhanghao@chinamobile.com) | Rel-10 | CP-48 | Kimmo |
| 802 | 294.7.2 | CT1 part of Stage 3 for Local IP Access | 206d? | 2010-06-04 A | 2011-03-18 A | 100% | 2010-06-04 | 2011-03-18 | 206d? | finish no earlier than 2011-03-18 | C1 | 1648h | 1648h | LIPA | PCG-25 | China Mobile | Zhang Hao (zhanghao@chinamobile.com) | Rel-10 | CP-48 | Frederic |
| 803 | 294.8 | Stage 2 for SIPTO for macro networks | 261d? | 2009-09-24 A | 2010-09-23 A | 100% | 2009-09-24 | 2010-09-23 | 261d? | finish no earlier than 2010-09-23 | S2 | 2088h | 2088h | SIPTO | PCG-23 | Huawei, China Mobile | patrice.hede@huawei.com, Tao Sun (suntao@chinamobile.com) | Rel-10 | SP-45 | Maurice |
| 804 | 294.9 | **Stage 3 for SIPTO for macro networks** | 206d? | 2010-06-04 A | 2011-03-18 A | 100% | 2010-06-04 | 2011-03-18 | 206d? |  | C4,C1 | 4384h | 4384h | SIPTO | PCG-25 | Huawei | Caixia Qi (qcxmay@huawei.com) | Rel-10 | CP-48 | Kimmo |
| 805 | 294.9.1 | CT4 part of Stage 3 for SIPTO for macro networks | 206d? | 2010-06-04 A | 2011-03-18 A | 100% | 2010-06-04 | 2011-03-18 | 206d? | finish no earlier than 2011-03-18 | C4 | 1648h | 1648h | SIPTO | PCG-25 | Huawei | Caixia Qi (qcxmay@huawei.com) | Rel-10 | CP-48 | Kimmo |
| 806 | 294.9.2 | CT1 part of Stage 3 for SIPTO for macro networks | 136d? | 2010-06-04 A | 2010-12-10 A | 100% | 2010-06-04 | 2010-12-10 | 136d? | finish no earlier than 2011-03-18 | C1 | 1088h | 1088h | SIPTO | PCG-25 | Huawei | Caixia Qi (qcxmay@huawei.com) | Rel-10 | CP-48 | Frederic |
| 807 | 295 | **IP Flow Mobility and seamless WLAN offload** | 390d? | 2009-09-24 A | 2011-03-23 A | 100% | 2009-09-24 | 2011-03-23 | 390d? |  | S2,S1,S5,C1,C3 | 12680h | 12680h | IFOM | PCG-23 | Qualcomm | Gerardo Giaretta (gerardo@qualcomm.com) | Rel-10 | SP-45 | Maurice |
| 808 | 295.1 | Stage 1 for IP Flow Mobility and seamless WLAN offload | 56d? | 2009-09-24 A | 2009-12-10 A | 100% | 2009-09-24 | 2009-12-10 | 56d? | finish no earlier than 2009-12-10 | S1 | 448h | 448h | IFOM | PCG-23 | Qualcomm | David Williams (dwilliam@qualcomm.com) | Rel-10 | SP-45 | Alain |
| 809 | 295.2 | Stage 2 for IP Flow Mobility and seamless WLAN offload | 261d? | 2009-09-24 A | 2010-09-23 A | 100% | 2009-09-24 | 2010-09-23 | 261d? | finish no earlier than 2010-09-23 | S2 | 2088h | 2088h | IFOM | PCG-23 | Qualcomm | Gerardo Giaretta (gerardo@qualcomm.com) | Rel-10 | SP-45 | Maurice |
| 810 | 295.3 | Charging for IP Flow Mobility and seamless WLAN offload | 260d? | 2010-03-25 A | 2011-03-23 A | 100% | 2010-03-25 | 2011-03-23 | 260d? | finish no earlier than 2011-03-23 | S5 | 2080h | 2080h | IFOM | PCG-24 | Alcatel-Lucent | maryse.gardella@alcatel-lucent.com | Rel-10 | SP-47 | Dionisio |
| 811 | 295.4 | **Stage 3 for IP Flow Mobility and seamless WLAN offload** | 206d? | 2010-06-04 A | 2011-03-18 A | 100% | 2010-06-04 | 2011-03-18 | 206d? |  | C1,C3 | 4944h | 4944h | IFOM-CT | PCG-25 | Qualcomm | Patrick Stupar (pstupar@qualcomm.com) | Rel-10 | CP-48 | Frederic |
| 812 | 295.4.1 | CT1 part of Stage 3 for IP Flow Mobility and seamless WLAN offload | 206d? | 2010-06-04 A | 2011-03-18 A | 100% | 2010-06-04 | 2011-03-18 | 206d? | finish no earlier than 2011-03-18 | C1 | 1648h | 1648h | IFOM-CT | PCG-25 | Qualcomm | Patrick Stupar (pstupar@qualcomm.com) | Rel-10 | CP-48 | Frederic |
| 813 | 295.4.2 | CT3 part of Stage 3 for IP Flow Mobility and seamless WLAN offload | 206d? | 2010-06-04 A | 2011-03-18 A | 100% | 2010-06-04 | 2011-03-18 | 206d? | finish no earlier than 2011-03-18 | C3 | 1648h | 1648h | IFOM-CT | PCG-25 | Qualcomm | Patrick Stupar (pstupar@qualcomm.com) | Rel-10 | CP-48 | Jiwan |
| 814 | 296 | **Enabling Coder Selection and Rate Adaptation for UTRAN and E-UTRAN for Load Adaptive Applications** | 827.4d? | 2009-07-15 A | 2012-09-07 A | 100% | 2009-07-15 | 2012-09-07 | 827.4d? |  | S2,S4,C4,C3,C1,IETF | 26168h | 26168h | ECSRA_LAA | PCG-23 | Qualcomm | AC Mahendran (ac@qualcomm.com) | Rel-10 | SP-45 | Maurice |
| 815 | 296.1 | TR on Enabling Coder Selection and Rate Adaptation for UTRAN and E-UTRAN for Load Adaptive Applications | 186d? | 2009-09-24 A | 2010-06-10 A | 100% | 2009-09-24 | 2010-06-10 | 186d? | finish no earlier than 2010-09-23 | S2,S4 | 1488h | 1488h | ECSRA_LAA | PCG-23 | Qualcomm | AC Mahendran (ac@qualcomm.com) | Rel-10 | SP-45 | Maurice |
| 816 | 296.2 | SA4 review of TR on Enabling Coder Selection and Rate Adaptation for UTRAN and E-UTRAN for Load Adaptive Applications | 320d? | 2009-09-24 A | 2010-12-15 A | 100% | 2009-09-24 | 2010-12-15 | 320d? | finish no earlier than 2010-12-15 | S4 | 2560h | 2560h | ECSRA_LAA | PCG-23 | Qualcomm | AC Mahendran (ac@qualcomm.com) | Rel-10 | SP-45 | Paolo |
| 817 | 296.3 | Stage 2 for Enabling Coder Selection and Rate Adaptation for UTRAN and E-UTRAN for Load Adaptive Applications | 261d? | 2009-09-24 A | 2010-09-23 A | 100% | 2009-09-24 | 2010-09-23 | 261d? | finish no earlier than 2010-09-23 | S2 | 2088h | 2088h | ECSRA_LAA | PCG-23 | Qualcomm | AC Mahendran (ac@qualcomm.com) | Rel-10 | SP-45 | Maurice |
| 818 | 296.4 | SA4 aspects of Enabling Coder Selection and Rate Adaptation for UTRAN and E-UTRAN for Load Adaptive Applications | 130d? | 2010-09-23 A | 2011-03-23 A | 100% | 2010-09-23 | 2011-03-23 | 130d? | finish no earlier than 2011-03-23 | S4 | 1040h | 1040h | ECSRA_LAA | PCG-25 | Qualcomm | AC Mahendran (ac@qualcomm.com) | Rel-10 | SP-49 | Paolo |
| 819 | 296.5 | **CN aspects of Enabling Coder Selection and Rate Adaptation for UTRAN and E-UTRAN for Load Adaptive Applications** | 827.4d? | 2009-07-15 A | 2012-09-07 A | 100% | 2009-07-15 | 2012-09-07 | 827.4d? |  | C4,C3,C1 | 12776h | 12776h | ECSRA_LAA-CN | PCG-25 | Ericsson | Philip.hodges@ericsson.com | Rel-10 | CP-49 | Kimmo |
| 820 | 296.5.1 | CT4 part of CN aspects of Enabling Coder Selection and Rate Adaptation for UTRAN and E-UTRAN for Load Adaptive Applications | 186d? | 2010-09-17 A | 2011-06-03 A | 100% | 2010-09-17 | 2011-06-03 | 186d? | start no earlier than 2010-09-17 | C4 | 1488h | 1488h | ECSRA_LAA-CN | PCG-25 | Ericsson | Philip.hodges@ericsson.com | Rel-10 | CP-49 | Kimmo |
| 821 | 296.5.2 | (IETF) CT3, CT4 part of CN aspects of Enabling Coder Selection and Rate Adaptation for UTRAN and E-UTRAN for Load Adaptive Applications | 520d? | 2009-07-15 A | 2012-09-07 A | 100% | 2009-07-15 | 2012-09-07 | 520d? | finish no earlier than 2012-09-07 | C3-IETF, C4-IETF | 4144h | 4144h | ECSRA_LAA-CN | PCG-27 | Lionel Morand |  | Rel-10 | CP-53 |  |
| 822 | 296.5.3 | CT3 part of CN aspects of Enabling Coder Selection and Rate Adaptation for UTRAN and E-UTRAN for Load Adaptive Applications | 186d? | 2010-09-17 A | 2011-06-03 A | 100% | 2010-09-17 | 2011-06-03 | 186d? | finish no earlier than 2011-06-03 | C3 | 1488h | 1488h | ECSRA_LAA-CN | PCG-25 | Ericsson | Philip.hodges@ericsson.com | Rel-10 | CP-49 | Jiwan |
| 823 | 296.5.4 | CT1 part of CN aspects of Enabling Coder Selection and Rate Adaptation for UTRAN and E-UTRAN for Load Adaptive Applications | 186d? | 2010-09-17 A | 2011-06-03 A | 100% | 2010-09-17 | 2011-06-03 | 186d? | start no earlier than 2010-09-17 | C1 | 1488h | 1488h | ECSRA_LAA-CN | PCG-25 | Ericsson | Philip.hodges@ericsson.com | Rel-10 | CP-49 | Frederic |

Notes:
- 800: CP#51 completed
- 801: CP#51 completed / Text3: 23.008, 23.015, 29.002, 29.060, 29.272, 29.274, 29.281, 29.303
- 802: CP#51 completed / Text3: 24.008, 24.301
- 803: SP#49 completed (SIPTO GW selection for wild card APN and for GERAN. Serving-GW selection for SIPTO. Corrections and Clarifications of the SIPTO procedure) / Text3: 23.060, 23.401
- 804: CP#51 completed. Updated WID CP-100419=>CP-110091
- 805: CP#51 completed. Updated WID CP-100419=>CP-110091 / Text3: 23.003, 23.008, 29.002, 29.272, 29.303
- 806: CP#50 completed / Text3: 24.008, 24.301
- 807: SP#51 completed. Triggered by Rel-10 TR 23.861 (UID_410043 Study on Multi Access PDN connectivity and IP flow mobility - MAPIM)
- 808: SP#46 completed / Text3: 22.278
- 809: SP#49 completed / Text3: 23.203, 23.402, new 23.261
- 810: SP#51 completed / Text3: 32.240, 32.251, 32.252, 32.298, 32.299
- 811: CP#51 completed / Text3: Stage 3
- 812: CP#51 completed / Text3: 24.008, 24.301, 24.302, 24.303, 24.312, 24.327
- 813: CP#51 completed / Text3: 29.212, 29.213, 29.214, 29.215
- 814: CP#52 completed. Triggered by Rel-9 UID_440013 Vocoder rate adaptation for LTE / Text3: UTRA, LTE
- 815: SP#48 completed / Text3: new 23.860
- 816: SP#50 completed / Text3: new 23.860
- 817: SP#49 completed / Text3: 23.060, 23.203, 23.228, 23.401
- 818: SP#51 completed / Text3: 26.114
- 819: CP#52 completed / Text3: Stage 2/3
- 820: CP#52 completed / Text3: 23.334, 29.334, 29.238, 23.333, 29.333, 29.232, 29.332
- 821: CP#57 completed / Text3: RFC 6679 (was draft-ietf-avtcore-ecn-for-rtp)
- 822: CP#52 completed / Text3: 29.162, 29.163, 29.213, 29.235, 29.292
- 823: CP#52 completed / Text3: 24.229

| ID | WBS | Task | Type | Duration | Start | Finish | Complete | Baseline start | Baseline finish | Baseline duration | Constraint | Resources | Work | Actual work | Text1 | Text2 | Text3 | Text4 | Text5 | Text6 | Text7 | Text8 | Text9 | Text12 |
| --- | --- | --- | --- | --- | --- | --- | --- | --- | --- | --- | --- | --- | --- | --- | --- | --- | --- | --- | --- | --- | --- | --- | --- | --- |
| 824 | 297 | **Extended H(e)NB features** |  | 467d? | 2008-12-11 A | 2010-09-23 A | 100% | 2008-12-11 | 2010-09-23 | 467d? |  | S1,S2,S3 | 4344h | 4344h | EHNBF | PCG-23 | UTRA, LTE | NEC | joerg.swetina@nw.neclab.eu | Rel-10 | SP-45 | Alain |  |  |
| 825 | 297.1 | Stage 1 of Extended H(e)NB features |  | 131d? | 2009-09-24 A | 2010-03-25 A | 100% | 2009-09-24 | 2010-03-25 | 131d? | finish no earlier than 2010-03-25 | S1 | 1048h | 1048h | EHNBF | PCG-23 | 22.220 | NEC | joerg.swetina@nw.neclab.eu | Rel-10 | SP-45 | Alain |  |  |
| 826 | 297.2 | IMS aspects of Architecture for Home NodeB |  | 336d? | 2008-12-11 A | 2010-03-25 A | 100% | 2008-12-11 | 2010-03-25 | 336d? | finish no earlier than 2010-03-25 | S2 | 2688h | 2688h | EHNB-IMS | PCG-22 | new 23.832 | Alcatel-Lucent | Nicolas Drevon | Rel-10 | SP-42 | Maurice |  |  |
| 827 | 297.3 | Extended H(e)NB Security features (Stage 2) |  | 76d? | 2010-06-10 A | 2010-09-23 A | 100% | 2010-06-10 | 2010-09-23 | 76d? | finish no earlier than 2010-09-23 | S3 | 608h | 608h | EHNBF-Sec | PCG-25 | 33.320 | Huawei | Marcus Wong (mwong@huawei.com) | Rel-10 | SP-48 | Dionisio |  |  |
| 828 | 298 | **Optimal Media Routing** |  | 314d? | 2010-03-25 A | 2011-06-08 A | 100% | 2010-03-25 | 2011-06-08 | 314d? |  | S2,S5,C3,C1 | 10984h | 10984h | OMR | PCG-24 |  | Alcatel-Lucent | andy.bennett@alcatel-lucent.com | Rel-10 | SP-46 | Maurice |  |  |
| 829 | 298.1 | Stage 2 for Optimal Media Routing | milestone | 0d? | 2010-03-25 A | 2010-03-25 A | 100% | 2010-03-25 | 2010-03-25 | 0d? |  | S2 |  |  | OMR | PCG-24 | 23.228 | Alcatel-Lucent | andy.bennett@alcatel-lucent.com | Rel-10 | SP-46 | Maurice |  |  |
| 830 | 298.2 | **Stage 3 for Optimal Media Routing** |  | 261d? | 2010-06-04 A | 2011-06-03 A | 100% | 2010-06-04 | 2011-06-03 | 261d? |  | C3,C1,C4 | 7472h | 7472h | OMR | PCG-25 |  | Alcatel-Lucent | jim.calme@alcatel-lucent.com | Rel-10 | CP-48 | Jiwan |  |  |
| 831 | 298.2.1 | CT3 part of Stage 3 for Optimal Media Routeing |  | 261d? | 2010-06-04 A | 2011-06-03 A | 100% | 2010-06-04 | 2011-06-03 | 261d? | finish no earlier than 2011-06-03 | C3 | 2088h | 2088h | OMR | PCG-25 | 29.162, 29.163, 29.165, 29.235, new TS 29.079 | Alcatel-Lucent | jim.calme@alcatel-lucent.com | Rel-10 | CP-48 | Jiwan |  |  |
| 832 | 298.2.2 | CT1 part of Stage 3 for Optimal Media Routeing |  | 206d? | 2010-06-04 A | 2011-03-18 A | 100% | 2010-06-04 | 2011-03-18 | 206d? | finish no earlier than 2011-03-18 | C1 | 1648h | 1648h | OMR | PCG-25 | 24.229 | Alcatel-Lucent | jim.calme@alcatel-lucent.com | Rel-10 | CP-48 | Frederic |  |  |
| 833 | 298.2.3 | Deleted - CT4 part of Stage 3 for Optimal Media Routeing |  | 206d? | 2010-06-04 A | 2011-03-18 A | 100% | 2010-06-04 | 2011-03-18 | 206d? | finish no earlier than 2011-03-18 | C4 | 1648h | 1648h | OMR | PCG-25 |  | Alcatel-Lucent | jim.calme@alcatel-lucent.com | Rel-10 | CP-48 | Kimmo | PCG-26 | CP-51 |
| 834 | 298.3 | Charging for Optimal Media Routing |  | 125d? | 2010-12-16 A | 2011-06-08 A | 100% | 2010-12-16 | 2011-06-08 | 125d? | finish no earlier than 2011-06-08 | S5 | 1000h | 1000h | OMR | PCG-26 | 32.260, 32.298, 32.299 | Alcatel-Lucent | maryse.gardella@alcatel-lucent.com | Rel-10 | SP-50 | Dionisio |  |  |
| 835 | 299 | **IMS Emergency Session Enhancements** |  | 312d? | 2010-03-25 A | 2011-06-03 A | 100% | 2010-03-25 | 2011-06-03 | 312d? |  | S1,S2,C1 | 4560h | 4560h | IESE | PCG-24 |  | Deutsche Telekom, T-Mobile | michele.zarri@t-mobile.co.uk | Rel-10 | SP-47 | Maurice |  |  |
| 836 | 299.1 | Stage 1 for IMS Emergency Session Enhancements |  | 1d? | 2010-03-25 A | 2010-03-25 A | 100% | 2010-03-25 | 2010-03-25 | 1d? | start no earlier than 2010-03-25 | S1 | 8h | 8h | IESE | PCG-24 | 22.101 CR#0343 | Deutsche Telekom, T-Mobile | Kurt Bischinger | Rel-10 | SP-47 | Alain |  |  |
| 837 | 299.2 | Stage 2 for IMS Emergency Session Enhancements |  | 131d? | 2010-03-25 A | 2010-09-23 A | 100% | 2010-03-25 | 2010-09-23 | 131d? | finish no earlier than 2010-09-23 | S2 | 1048h | 1048h | IESE | PCG-24 | 23.167 | Deutsche Telekom, T-Mobile | michele.zarri@t-mobile.co.uk | Rel-10 | SP-47 | Maurice |  |  |
| 838 | 299.3 | Stage 3 for IMS Emergency Session Enhancements |  | 126d? | 2010-12-10 A | 2011-06-03 A | 100% | 2010-12-10 | 2011-06-03 | 126d? | finish no earlier than 2011-06-03 | C1 | 1008h | 1008h | IESE | PCG-26 | 24.229 | Deutsche Telekom | reinhard.lauster@t-mobile.at | Rel-10 | CP-50 | Frederic |  |  |
| 839 | 300 | **S2b Mobility based on GTP** |  | 202d? | 2010-06-10 A | 2011-03-18 A | 100% | 2010-06-10 | 2011-03-18 | 202d? |  | S2,C4,C3,C1 | 5856h | 5856h | SMOG | PCG-25 |  | Alcatel-Lucent | bruno.landais@alcatel-lucent.com | Rel-10 | SP-48 | Maurice |  |  |
| 840 | 300.1 | Stage 2 for S2b Mobility based on GTP |  | 76d? | 2010-06-10 A | 2010-09-23 A | 100% | 2010-06-10 | 2010-09-23 | 76d? | finish no earlier than 2010-09-23 | S2 | 608h | 608h | SMOG | PCG-25 | 23.002, 23.203, 23.402 | Alcatel-Lucent | bruno.landais@alcatel-lucent.com | Rel-10 | SP-48 | Maurice |  |  |
| 841 | 300.2 | **Stage 3 for S2b Mobility based on GTP** |  | 131d? | 2010-09-17 A | 2011-03-18 A | 100% | 2010-09-17 | 2011-03-18 | 131d? |  | C4,C3,C1 | 3632h | 3632h | SMOG-St3 | PCG-25 |  | Alcatel-Lucent | bruno.landais@alcatel-lucent.com | Rel-10 | CP-49 | Kimmo |  |  |
| 842 | 300.2.1 | CT4 part of Stage 3 for S2b Mobility based on GTP |  | 131d? | 2010-09-17 A | 2011-03-18 A | 100% | 2010-09-17 | 2011-03-18 | 131d? | finish no earlier than 2011-03-18 | C4 | 1048h | 1048h | SMOG-St3 | PCG-25 | 23.003, 23.007, 23.008, 29.273, 29.274, 29.281, 29.303 | Alcatel-Lucent | bruno.landais@alcatel-lucent.com | Rel-10 | CP-49 | Kimmo |  |  |
| 843 | 300.2.2 | CT3 part of Stage 3 for S2b Mobility based on GTP |  | 131d? | 2010-09-17 A | 2011-03-18 A | 100% | 2010-09-17 | 2011-03-18 | 131d? | finish no earlier than 2011-03-18 | C3 | 1048h | 1048h | SMOG-St3 | PCG-25 | 29.212, 29.213, 29.215 | Alcatel-Lucent | bruno.landais@alcatel-lucent.com | Rel-10 | CP-49 | Jiwan |  |  |
| 844 | 300.2.3 | CT1 part of Stage 3 for S2b Mobility based on GTP |  | 61d? | 2010-09-17 A | 2010-12-10 A | 100% | 2010-09-17 | 2010-12-10 | 61d? | finish no earlier than 2010-12-10 | C1 | 488h | 488h | SMOG-St3 | PCG-25 | 24.302 | Alcatel-Lucent | bruno.landais@alcatel-lucent.com | Rel-10 | CP-49 | Frederic |  |  |
| 845 | 301 | **Policy Enhancements for Sponsored Connectivity and Coherent Access to Policy related Databases** |  | 113.15d? | 2010-10-12 A | 2011-03-18 A | 100% | 2010-10-12 | 2011-03-18 | 113.15d? |  | S2,C3 | 1473.2h | 1473.2h | PEST | PCG-26 |  | Qualcomm | AC Mahendran (ac@qualcomm.com) | Rel-10 | SP-50 | Maurice |  |  |
| 846 | 301.1 | Stage 2 for Policy Enhancements for Sponsored Connectivity and Coherent Access to Policy related Databases | milestone | 0d? | 2010-10-12 A | 2010-12-15 A | 100% | 2010-10-12 | 2010-12-15 | 0d? | finish no earlier than 2010-12-15 | S2 |  |  | PEST | PCG-26 | 23.002, 23.203 | Qualcomm | AC Mahendran (ac@qualcomm.com) | Rel-10 | SP-50 | Maurice |  |  |
| 847 | 301.2 | CT3 aspects of Policy Enhancements for Sponsored Connectivity and Coherent Access to Policy related Databases |  | 71d? | 2010-12-10 A | 2011-03-18 A | 100% | 2010-12-10 | 2011-03-18 | 71d? | finish no earlier than 2011-03-18 | C3 | 568h | 568h | PEST-CT3 | PCG-26 | 29.212, 29.213, 29.214, 29.215 | ZTE | zhou.xiaoyun@zte.com.cn | Rel-10 | CP-50 | Jiwan |  |  |

Notes:
- 824: SP#49 completed. Adds extensions to Rel-9 functionality in UID_400035 Enhanced Home NodeB / eNodeB (EHNB)
- 825: SP#47 completed
- 826: SP#47 completed. Chosen solution has no normative impacts
- 827: SP#49 completed
- 828: CP#52 completed. SP#47 Stage 2 completed. Triggered by TR 23.894 (UID_370050 Study on System enhancements for the use of IMS services in local breakout)
- 829: SP#47 completed
- 830: CP#51 completion 03/11=>06/11. WID updated CP-100327=>CP-110134
- 831: CP#52 completed
- 832: CP#51 completed. WID updated CP-100327=>CP-110134
- 833: CP#51 stopped (CT4 specs not impacted). WID updated CP-100327=>CP-110134
- 834: SP#52 completed. Stage 3: Linked to CT3 TS 29.079 OMR within the IMS; Stage 3 (UID_480110)
- 835: CP#52 completed. SP#49 completed. Source of external requirements: ETSI TISPAN TS 181.019 (Business Communication Requirements)
- 836: SP#47 completed
- 837: SP#49 completed
- 838: CP#52 completed
- 839: CP#51 completed. SP#49 Stage 2 completed. Related to Rel-10 UID_470049 Study on S2b mobility based on GTP (TR23.834), UID_350027 SAE for support for non-3GPP accesses. Stage1 in Rel-8 UID_320022 Reqs for evolution of 3GPP system architecture (AIPN-SAE)
- 840: SP#49 completed
- 841: CP#51 Stage 3 completed
- 842: CP#51 completed
- 843: CP#51 completed
- 844: CP#50 completed
- 845: CP#51 completed. SP#50 Stage 2 completed. Triggered by the SA1,SA2 Rel-10 TR 23.813 Study on Policy solutions and enhancements (FS_PP) UID_440047. Provides Video Call seamless service continuity for 3G/LTE terminal user
- 846: SP#51 updated WID SP-100702=>SP-110196. SA#49 work completed as SA2 CRs approved under TEI10 (SP-10557)
- 847: CP#51 completed

| ID | WBS | Task | Duration | Start | Finish | Complete | Baseline start | Baseline finish | Baseline duration | Constraint | Resources | Work | Actual work | Text1 | Text2 | Text4 | Text5 | Text6 | Text7 | Text8 | Text9 | Text12 |
| --- | --- | --- | --- | --- | --- | --- | --- | --- | --- | --- | --- | --- | --- | --- | --- | --- | --- | --- | --- | --- | --- | --- |
| 848 | 302 | **Lawful Interception in the 3GPP Rel-10** | 315d? | 2010-03-25 A | 2011-06-08 A | 100% | 2010-03-25 | 2011-06-08 | 315d? |  | S3 | 20480h | 20480h | LI10 | PCG-24 | PIDS, BT | Koen Jaspers (k.b.jaspers@minjus.nl), alex.leadbeater@bt.com | Rel-10 | SP-47 | Dionisio |  |  |
| 849 | 302.1 | LI for CAT (Customer Alerting Tones) | 315d? | 2010-03-25 A | 2011-06-08 A | 100% | 2010-03-25 | 2011-06-08 | 315d? | finish no earlier than 2011-03-23 | S3 | 2520h | 2520h | LI10 | PCG-24 | PIDS, BT | Koen Jaspers (k.b.jaspers@minjus.nl), alex.leadbeater@bt.com | Rel-10 | SP-47 | Dionisio |  |  |
| 850 | 302.2 | LI for CRS (Customized Ringing Signal) | 315d? | 2010-03-25 A | 2011-06-08 A | 100% | 2010-03-25 | 2011-06-08 | 315d? | finish no earlier than 2011-03-23 | S3 | 2520h | 2520h | LI10 | PCG-24 | PIDS, BT | Koen Jaspers (k.b.jaspers@minjus.nl), alex.leadbeater@bt.com | Rel-10 | SP-47 | Dionisio |  |  |
| 851 | 302.3 | LI for EPS enhancements | 315d? | 2010-03-25 A | 2011-06-08 A | 100% | 2010-03-25 | 2011-06-08 | 315d? | finish no earlier than 2011-03-23 | S3 | 2520h | 2520h | LI10 | PCG-24 | PIDS, BT | Koen Jaspers (k.b.jaspers@minjus.nl), alex.leadbeater@bt.com | Rel-10 | SP-47 | Dionisio |  |  |
| 852 | 302.4 | LI for VCC (Voice Call Continuity) | 260d? | 2010-03-25 A | 2011-03-23 A | 100% | 2010-03-25 | 2011-03-23 | 260d? | finish no earlier than 2011-03-23 | S3 | 2080h | 2080h | LI10 | PCG-24 | PIDS, BT | Koen Jaspers (k.b.jaspers@minjus.nl), alex.leadbeater@bt.com | Rel-10 | SP-47 | Dionisio |  |  |
| 853 | 302.5 | LI for MEDIASEC (IMS Media security) | 260d? | 2010-03-25 A | 2011-03-23 A | 100% | 2010-03-25 | 2011-03-23 | 260d? | finish no earlier than 2011-03-23 | S3 | 2080h | 2080h | LI10 | PCG-24 | PIDS, BT | Koen Jaspers (k.b.jaspers@minjus.nl), alex.leadbeater@bt.com | Rel-10 | SP-47 | Dionisio |  |  |
| 854 | 302.6 | LI for H(e)NB also with Local IP Access and Selected IP Traffic Offload (LIPA, SIPTO) | 260d? | 2010-03-25 A | 2011-03-23 A | 100% | 2010-03-25 | 2011-03-23 | 260d? | finish no earlier than 2011-03-23 | S3 | 2080h | 2080h | LI10 | PCG-24 | PIDS, BT | Koen Jaspers (k.b.jaspers@minjus.nl), alex.leadbeater@bt.com | Rel-10 | SP-47 | Dionisio |  |  |
| 855 | 302.7 | LI for MBMS enhancements | 260d? | 2010-03-25 A | 2011-03-23 A | 100% | 2010-03-25 | 2011-03-23 | 260d? | finish no earlier than 2011-03-23 | S3 | 2080h | 2080h | LI10 | PCG-24 | PIDS, BT | Koen Jaspers (k.b.jaspers@minjus.nl), alex.leadbeater@bt.com | Rel-10 | SP-47 | Dionisio |  |  |
| 856 | 302.8 | LI for LCLS (Local Call Local Switch) | 260d? | 2010-03-25 A | 2011-03-23 A | 100% | 2010-03-25 | 2011-03-23 | 260d? | finish no earlier than 2011-03-23 | S3 | 2080h | 2080h | LI10 | PCG-24 | PIDS, BT | Koen Jaspers (k.b.jaspers@minjus.nl), alex.leadbeater@bt.com | Rel-10 | SP-47 | Dionisio |  |  |
| 857 | 303 | Optimization of IMS based PSS and MBMS User Service | 260d? | 2010-03-25 A | 2011-03-23 A | 100% | 2010-03-25 | 2011-03-23 | 260d? | finish no earlier than 2011-03-23 | S4 | 2080h | 2080h | OPT_IMS_PSS_MBMS_US | PCG-24 | Ericsson | markus.kampmann@ericsson.com | Rel-10 | SP-47 | Paolo |  |  |
| 858 | 304 | **HTTP-based Streaming and Download Services** | 392d? | 2010-03-25 A | 2011-09-21 A | 100% | 2010-03-25 | 2011-09-21 | 392d? |  | S4,IETF | 5356.4h | 5356.4h | HTTP_SDS | PCG-24 | Qualcomm | Thomas Stockhammer (c_tstock@qualcomm.com) | Rel-10 | SP-47 | Paolo |  |  |
| 859 | 304.1 | HTTP-based Streaming and Download Services in 3GPP | 315d? | 2010-03-25 A | 2011-06-08 A | 100% | 2010-03-25 | 2011-06-08 | 315d? | finish no earlier than 2011-05-26 | S4 | 2520h | 2520h | HTTP_SDS | PCG-24 | Qualcomm | Thomas Stockhammer (c_tstock@qualcomm.com) | Rel-10 | SP-47 | Paolo |  |  |
| 860 | 304.2 | (IETF) HTTP-based Streaming and Download Services in 3GPP | 211.6d? | 2010-03-25 A | 2011-09-21 A | 100% | 2010-03-25 | 2011-09-21 | 211.6d? | start no earlier than 2010-03-25 | S4-IETF | 1676.8h | 1676.8h | HTTP_SDS | PCG-27 |  |  | Rel-10 | CP-52 | Paolo |  |  |
| 861 | 305 | PSS and MBMS enhancements | 205d? | 2010-06-10 A | 2011-03-23 A | 100% | 2010-06-10 | 2011-03-23 | 205d? | finish no earlier than 2011-03-23 | S4 | 1640h | 1640h | MBS_Enh | PCG-25 | Ericsson | Markus.Kampmann@ericsson.com | Rel-10 | SP-48 | Paolo |  |  |
| 862 | 306 | Enhancements and Addition of Audio Tests to 26.131 and 26.132 | 260d? | 2010-06-10 A | 2011-06-08 A | 100% | 2010-06-10 | 2011-06-08 | 260d? | finish no earlier than 2011-06-08 | S4 | 2080h | 2080h | EAAT | PCG-25 | Vodafone | ramin.afchar@vodafone.com | Rel-10 | SP-48 | Paolo |  |  |
| 863 | 307 | Video Coding Enhancements in MTSI | 3d? | 2011-03-21 A | 2011-03-23 A | 100% | 2011-03-21 | 2011-03-23 | 3d? | start no earlier than 2011-03-21 | S4 | 24h | 24h | VCEM | PCG-26 | Ericsson | frederic.gabin@ericsson.com | Rel-10 | SP-51 | Paolo |  |  |
| 864 | 308 | **Rel-10 Operations, Administration, Maintenance and Provisioning (OAM&P)** | 467d? | 2009-12-10 A | 2011-09-21 A | 100% | 2009-12-10 | 2011-09-21 | 467d? |  | S5,C4 | 45368h | 45368h | OAM10 | PCG-24 |  |  | Rel-10 | SP-46 | Dionisio |  |  |
| 865 | 308.1 | **Rel-10 Network Infrastructure Management** | 467d? | 2009-12-10 A | 2011-09-21 A | 100% | 2009-12-10 | 2011-09-21 | 467d? |  | S5 | 14592h | 14592h | OAM10-NIM | PCG-24 |  |  | Rel-10 | SP-46 | Dionisio |  |  |
| 866 | 308.1.1 | Common RAT Network Resource Model (NRM) | 390d? | 2009-12-10 A | 2011-06-08 A | 100% | 2009-12-10 | 2011-06-08 | 390d? | finish no earlier than 2011-06-08 | S5 | 3120h | 3120h | RAT_NRM_common | PCG-24 | Ericsson | robert.petersen@ericsson.com | Rel-10 | SP-46 | Dionisio |  |  |
| 867 | 308.1.2 | IRP Solution Set specification organisation improvements | 260d? | 2010-03-25 A | 2011-03-23 A | 100% | 2010-03-25 | 2011-03-23 | 260d? | finish no earlier than 2011-03-23 | S5 | 2080h | 2080h | OAM-IRP-SS | PCG-24 | Nokia Siemens Networks, Huawei | Jörg Schmidt (J.Schmidt@nsn.com), Lan Zou (zlan@huawei.com) | Rel-10 | SP-47 | Dionisio |  |  |
| 868 | 308.1.3 | Deleted - Service Oriented Architecture (SOA) for IRP continuation from Rel-9 | 260d? | 2010-03-25 A | 2011-03-23 A | 100% | 2010-03-25 | 2011-03-23 | 260d? | finish no earlier than 2011-06-08 | S5 | 2080h | 2080h | OAM-SOA-IRP | PCG-24 | Nokia Siemens Networks, Ericsson | Jörg Schmidt (J.Schmidt@NSN.com), edwin.tse@ericsson.com | Rel-10 | SP-47 | Dionisio | PCG-26 | SP-51 |
| 869 | 308.1.4 | IRP Overview, Profiles & Usage Guide | 260d? | 2010-06-10 A | 2011-06-08 A | 100% | 2010-06-10 | 2011-06-08 | 260d? | finish no earlier than 2011-06-08 | S5 | 2080h | 2080h | OAM-NIM-IRP_OPU | PCG-25 | Nokia Siemens Networks | Jörg Schmidt (J.Schmidt@NSN.com) | Rel-10 | SP-48 | Dionisio |  |  |
| 870 | 308.1.5 | Alarm Correlation and Root Cause Analysis | 133d? | 2011-03-23 A | 2011-09-21 A | 100% | 2011-03-23 | 2011-09-21 | 133d? | finish no earlier than 2011-09-21 | S5 | 1048h | 1048h | OAM-AC-RCA | PCG-26 | Ericsson | brendan.hassett@ericsson.com | Rel-10 | SP-51 | Dionisio |  |  |
| 871 | 308.1.6 | Inventory Management Network Resource Model enhancements | 56d? | 2011-03-23 A | 2011-06-08 A | 100% | 2011-03-23 | 2011-06-08 | 56d? | start no earlier than 2011-03-23 | S5 | 448h | 448h | OAM-IM-NMR | PCG-26 | Nokia Siemens Networks | olaf.pollakowski@nsn.com | Rel-10 | SP-51 | Dionisio |  |  |

Notes:
- 848: SP#52 completed / Text3: 33.106 (LI requirements), 33.107 (LI architecture and functions), 33.108 (Handover interface for LI)
- 849: SP#52 completed / Text3: 33.106, 33.107, 33.108
- 850: SP#52 completed / Text3: 33.106, 33.107, 33.108
- 851: SP#52 completed / Text3: 33.106, 33.107, 33.108
- 852: SP#51 completed / Text3: 33.106, 33.107, 33.108
- 853: SP#51 completed / Text3: 33.106, 33.107, 33.108
- 854: SP#51 completed / Text3: 33.106, 33.107, 33.108
- 855: SP#51 completed / Text3: 33.106, 33.107, 33.108
- 856: SP#51 completed / Text3: 33.106, 33.107, 33.108
- 857: SP#51 completed. Work to enhance UID_430046 Rel-9 IMS_PSS_MBMS_US_EXT / Text3: 26.237
- 858: SP#52 completed. Work to enhance UID_430038 Rel-9 PSS and MBMS extensions
- 859: SP#52 completed / Text3: 26.234, 26.244, 26.346, new TS 26.247
- 860: SP#53/IETF#81: Draft not included in 3GPP documentation / Text3: draft-gellens-mime-bucket-bis
- 861: SP#51 completed. Linked to Rel-9 Feature UID_430038 PSS and MBMS extensions (PMA-MBS_Ext). / Text3: 26.234, 26.346
- 862: SP#52 completed. Reduce fragmentation in acoustic testing (3GPP SA4, ETSI STQ, GCF CAG, CTIA) & Review existing acoustic tests to determine need for new spec / Text3: 26.131, 26.132
- 863: SP#51 completed. Linked to Rel-7 UID_7040 Multimedia Telephony Service for IMS - Media handling and interaction in MTSI (MTSI-MHI) / Text3: 26.114
- 864: OAM10 is an umbrella Feature also for OAM&P related TEI10 type of changes that are not part of any other dedicated feature/WI / Text3: TR 30.820
- 865: umbrella BB
- 866: SP#52 completed. Share equipment btw several RATs (RET,TMA,repeaters) to reduce costs. With existing modelling is difficult to see that several cells are affected when an antenna tilt is changed etc / Text3: 32.616, 32.642, 32.646, 32.652, 32.656, 32.762, 32.766 new (32.791, 32.792, 32.796)
- 867: SP#51 completed / Text3: 32.153, new (32.111-6,32.126,32.176,32.306,32.316,32.326,32.336,32.346,32.356,32.366,32.376,32.386,32.396,32.416,32.446,32.506/26/36,32.606,32.616,32.626,32.636,32.646,32.656,32.666,32.676,32.696,32.716,32.726,32.736,32.746,32.756,32.766,32.776,32.786)
- 868: SP#51 work stopped (Reason: lack of progress). Continuation of Rel-9 UID_440065 SOA for IRP (covering SOA Architecture & SOA-supporting Solution Set) to address SOA conforming Registration & Discovery capabilities / Text3: 32.101, 32.150
- 869: SP#52 completed. Updated WID SP-100777=>SP-110277 / Text3: new TS 32.103
- 870: SP#53 completed. Triggered by Rel-10 TR 32.832 Study on Alarm Correlation and Alarm Root Cause Analysis UID_480045 & TR 32.829 Study on Harmonization of 3GPP Alarm IRP and TMF Interface Program Fault Management UID_460038 / Text3: 32.111-1, 32.111-2, 32.111-6
- 871: SP#52 completed. Inventory NRM specified in Rel-6 is mainly hardware related. Rel-10 TR 32.828 recommends extending the scope of inventory NRM. Additionally, NGMN Top OPE Recs, v1.0 sets inventory enhancements as one of top 10 priority items / Text3: 32.690, 32.691, 32.692, 32.696

| ID | WBS | Task | Duration | Start | Finish | Complete | Remaining | Baseline start | Baseline finish | Baseline duration | Total slack | Constraint | Resources | Work | Actual work | Text1 | Text2 | Text6 | Text7 | Text8 | Text4 |
| --- | --- | --- | --- | --- | --- | --- | --- | --- | --- | --- | --- | --- | --- | --- | --- | --- | --- | --- | --- | --- | --- |
| 872 | 308.2 | **Rel-10 Self-Organizing Networks (SON) - OAM aspects** | 390d? | 2009-12-10 A | 2011-06-08 A | 100% |  | 2009-12-10 | 2011-06-08 | 390d? |  |  | S5 | 11000h | 11000h | OAM10-SON | PCG-24 | Rel-10 | SP-46 | Dionisio |  |
| 873 | 308.2.1 | SON Self-optimization management continuation | 390d? | 2009-12-10 A | 2011-06-08 A | 100% |  | 2009-12-10 | 2011-06-08 | 390d? |  | finish no earlier than 2011-03-23 | S5 | 3120h | 3120h | LTE-SON-OAM_SO | PCG-24 | Rel-10 | SP-46 | Dionisio | Huawei |
| 874 | 308.2.2 | SON Self-healing management | 335d? | 2009-12-10 A | 2011-03-23 A | 100% |  | 2009-12-10 | 2011-03-23 | 335d? |  | finish no earlier than 2011-03-23 | S5 | 2680h | 2680h | LTE-SON-OAM_SH | PCG-24 | Rel-10 | SP-46 | Dionisio | ZTE |
| 875 | 308.2.3 | OAM aspects of Energy Saving in Radio Networks | 260d? | 2010-03-25 A | 2011-03-23 A | 100% |  | 2010-03-25 | 2011-03-23 | 260d? |  | finish no earlier than 2011-03-23 | S5 | 2080h | 2080h | OAM-ES | PCG-24 | Rel-10 | SP-47 | Dionisio | Nokia Siemens Networks |
| 876 | 308.3 | Rel-10 Subscription Management (SuM) evolution | 260d? | 2010-03-25 A | 2011-03-23 A | 100% |  | 2010-03-25 | 2011-03-23 | 260d? |  | finish no earlier than 2011-03-23 | S5 | 2080h | 2080h | OAM10-SuM | PCG-24 | Rel-10 | SP-47 | Dionisio | Ericsson |
| 877 | 308.4 | **Rel-10 Performance Management** | 315d? | 2010-03-25 A | 2011-06-08 A | 100% |  | 2010-03-25 | 2011-06-08 | 315d? |  |  | S5,C4 | 13960h | 13960h | OAM10-PM | PCG-24 | Rel-10 | SP-47 | Dionisio |  |
| 878 | 308.4.1 | Key Performance Indicators (KPIs) for IMS | 260d? | 2010-03-25 A | 2011-03-23 A | 100% |  | 2010-03-25 | 2011-03-23 | 260d? |  | finish no earlier than 2011-03-23 | S5 | 2080h | 2080h | OAM-PM-KPI_IMS | PCG-24 | Rel-10 | SP-47 | Dionisio | China Mobile |
| 879 | 308.4.2 | Key Performance Indicators (KPIs) for EPC | 260d? | 2010-03-25 A | 2011-03-23 A | 100% |  | 2010-03-25 | 2011-03-23 | 260d? |  | finish no earlier than 2011-03-23 | S5 | 2080h | 2080h | OAM-PM-KPI_EPC | PCG-24 | Rel-10 | SP-47 | Dionisio | China Mobile |
| 880 | 308.4.3 | **Management of UE based network performance measurements** | 315d? | 2010-03-25 A | 2011-06-08 A | 100% |  | 2010-03-25 | 2011-06-08 | 315d? |  |  | S5,C4 | 5200h | 5200h | OAM-PM-UE | PCG-24 | Rel-10 | SP-47 | Dionisio | Huawei, Nokia Siemens Networks, Ericsson |
| 881 | 308.4.3.1 | SA5 aspects of Management of UE based network performance measurements | 315d? | 2010-03-25 A | 2011-06-08 A | 100% |  | 2010-03-25 | 2011-06-08 | 315d? |  | finish no earlier than 2011-06-08 | S5 | 2520h | 2520h | OAM-PM-UE | PCG-24 | Rel-10 | SP-47 | Dionisio | Huawei, Nokia Siemens Networks, Ericsson |
| 882 | 308.4.3.2 | CN aspects of Management of UE based network performance measurements | 20d? | 2011-02-21 A | 2011-03-18 A | 100% |  | 2011-02-21 | 2011-03-18 | 20d? |  | start no earlier than 2011-02-21 | C4 | 160h | 160h | OAM-PM-UE | PCG-26 | Rel-10 | CP-51 | Kimmo | Nokia Siemens Networks |
| 883 | 308.4.4 | 3G HNB and LTE HeNB Subsystem performance measurements | 260d? | 2010-03-25 A | 2011-03-23 A | 100% |  | 2010-03-25 | 2011-03-23 | 260d? |  | finish no earlier than 2011-03-23 | S5 | 2080h | 2080h | OAM-PM-HeNS | PCG-24 | Rel-10 | SP-47 | Dionisio | China Mobile |
| 884 | 309 | **Rel-10 Charging Management small Enhancements** | 470d? | 2009-06-04 A | 2011-03-23 A | 100% |  | 2009-06-04 | 2011-03-23 | 470d? |  |  | S5 | 7520h | 7520h | CH10 | PCG-24 | Rel-10 | SP-47 | Dionisio |  |
| 885 | 309.1 | IWLAN mobility charging | 470d? | 2009-06-04 A | 2011-03-23 A | 100% |  | 2009-06-04 | 2011-03-23 | 470d? |  | finish no earlier than 2011-03-23 | S5 | 3760h | 3760h | eIWLAN_Mob | PCG-23 | Rel-10 | SP-44 | Dionisio | Orange |
| 886 | 310 | **Advice of Charge (AoC) service support enhancements** | 312d? | 2010-03-25 A | 2011-06-03 A | 100% |  | 2010-03-25 | 2011-06-03 | 312d? |  |  | S5,C1 | 6064h | 6064h | eAoC | PCG-24 | Rel-10 | SP-47 | Dionisio | Deutsche Telekom |
| 887 | 310.1 | SA5 part - AoC enhancements | 260d? | 2010-03-25 A | 2011-03-23 A | 100% |  | 2010-03-25 | 2011-03-23 | 260d? |  | finish no earlier than 2011-03-23 | S5 | 2080h | 2080h | eAoC | PCG-24 | Rel-10 | SP-47 | Dionisio | Deutsche Telekom |
| 888 | 310.2 | CT1 part - AoC enhancements (Stage 3) | 186d? | 2010-09-17 A | 2011-06-03 A | 100% |  | 2010-09-17 | 2011-06-03 | 186d? |  | finish no earlier than 2011-06-03 | C1 | 1488h | 1488h | eAoC | PCG-25 | Rel-10 | CP-49 | Frederic | Deutsche Telekom |
| 889 | 311 | IMS Stage 3 IETF Protocol Alignment - phase 4 | 261d? | 2010-03-19 A | 2011-03-18 A | 100% |  | 2010-03-19 | 2011-03-18 | 261d? |  | finish no earlier than 2011-03-18 | C1 | 2088h | 2088h | IMSProtoc4 | PCG-24 | Rel-10 | CP-47 | Frederic | Alcatel-Lucent |
| 890 | 312 | Enhanced User Data Convergence (UDC) Model | 206d? | 2010-06-04 A | 2011-03-18 A | 100% |  | 2010-06-04 | 2011-03-18 | 206d? |  | finish no earlier than 2011-03-18 | C4 | 1648h | 1648h | eUDC | PCG-25 | Rel-10 | CP-48 | Kimmo | China Mobile |
| 891 | 313 | **Further improvements of II-NNI Stage 3 based on operational feedback and evolution of other specifications** | 661d? | 2010-06-04 A | 2012-12-07 | 86% | 92.18d? | 2010-06-04 | 2012-12-07 | 661d? | 463d |  | C3 | 9608h | 5363.2h | II-NNI2 | PCG-25 | Rel-10 | CP-48 | Jiwan | Orange |
| 892 | 313.1 | Further improvements of II-NNI Stage 3 | 206d? | 2010-06-04 A | 2011-03-18 A | 100% |  | 2010-06-04 | 2011-03-18 | 206d? |  | start no earlier than 2010-06-04 | C3 | 1648h | 1648h | II-NNI2 | PCG-25 | Rel-10 | CP-48 |  | Orange |
| 893 | 313.2 | (IETF) Further improvements of II-NNI Stage 3 (draft-ietf-sip-session-policy-framework) | 168d? | 2012-04-20 A | 2012-12-07 | 80% | 33.6d? | 2012-04-20 | 2012-12-07 | 168d? | 463d | finish no earlier than 2012-12-07 | C3-IETF | 1336h | 1067.2h | II-NNI2 | PCG-29 | Rel-10 | CP-56 |  | Lionel Morand |
| 894 | 313.3 | (IETF) Further improvements of II-NNI Stage 3 (draft-ietf-sipcore-proxy-feature) | 168d? | 2012-04-20 A | 2012-12-07 | 75% | 42d? | 2012-04-20 | 2012-12-07 | 168d? | 463d | finish no earlier than 2012-12-07 | C3-IETF | 1336h | 1000h | II-NNI2 | PCG-29 | Rel-10 | CP-56 |  | Christer Holmberg |
| 895 | 314 | AT Commands for IMS-configuration | 206d? | 2010-06-04 A | 2011-03-18 A | 100% |  | 2010-06-04 | 2011-03-18 | 206d? |  |  | C1 | 1648h | 1648h | AT_IMS | PCG-25 | Rel-10 | CP-48 | Frederic | Ericsson |
| 896 | 315 | AT Commands for USIM Application Toolkit (USAT) | 131d? | 2010-09-17 A | 2011-03-18 A | 100% |  | 2010-09-17 | 2011-03-18 | 131d? |  |  | C1 | 52.4h | 52.4h | AT_UICC | PCG-25 | Rel-10 | CP-49 | Frederic | ST-Ericsson |
| 897 | 316 | Communication Control for IMS by USIM (Stage 3) | 131d? | 2010-09-17 A | 2011-03-18 A | 100% |  | 2010-09-17 | 2011-03-18 | 131d? |  | start no earlier than 2010-09-17 | C6 | 1048h | 1048h | CC_IMS_USIM | PCG-25 | Rel-10 | CP-49 | Xavier | Gemalto |
| 898 | 317 | Dynamic view of SIP message for Inter-IMS Network to Network Interface (II-NNI) (Stage 3) | 126d? | 2010-12-10 A | 2011-06-03 A | 100% |  | 2010-12-10 | 2011-06-03 | 126d? |  | finish no earlier than 2011-06-03 | C3 | 1008h | 1008h | NNI_DV | PCG-26 | Rel-10 | CP-50 | Jiwan | NTT |
| 899 | 318 | Introduction of Smart Card Web Server launch functionality | 71d? | 2010-12-10 A | 2011-03-18 A | 100% |  | 2010-12-10 | 2011-03-18 | 71d? |  | finish no earlier than 2011-03-18 | C6 | 568h | 568h | SCWS_L | PCG-26 | Rel-10 | CP-50 | Xavier | Telecom Italia |
| 900 | 319 | USAT using AT Commands | 71d? | 2010-12-10 A | 2011-03-18 A | 100% |  | 2010-12-10 | 2011-03-18 | 71d? |  | finish no earlier than 2011-03-18 | C6 | 568h | 568h | USAT_AT | PCG-26 | Rel-10 | CP-50 | Xavier | Giesecke & Devrient |

Notes:
- 872: umbrella BB
- 873: SP#52 completed. Cont'd Rel-9 SON self-optimization management UID_390007 / Text3: 32.425, 32.521, 32.522, 32.526, 32.762, 32.766 / Text5: Lan Zou (zlan@huawei.com)
- 874: SP#51 completed. WID updated SP-100776=>SP-110150. Work moved to Rel-10 after split of the Rel-9 UID_390007 SON self-optimization (removed Self-Healing handling) / Text3: 32.522, 32.526, 32.762, 32.766, new TS 32.541 / Text5: zhu.weihong@zte.com.cn
- 875: SP#51 completed. WID updated SP-100226=>SP-110128. Triggered by Rel-10 TR 32.826 Study on Telecommunication Management; Energy Savings Management (FS_OAM_ESM) UID_430044 / Text3: 32.425, 32.522, 32.526, 32.626, 32.762, 32.766, new TS 32.551 / Text5: clemens.suerbaum@nsn.com
- 876: SP#51 completed / Text3: 32.172, 32.175, 32.176 / Text5: leo.yang@ericsson.com
- 877: umbrella BB
- 878: SP#51 completed / Text3: new 32.454 / Text5: Li Jian (lijian@chinamobile.com), Liang Shuangchun (liangshuangchun@cmdi.chinamobile.com)
- 879: SP#51 completed / Text3: new 32.455 / Text5: Li Jian (lijian@chinamobile.com), Liang Shuangchun (liangshuangchun@cmdi.chinamobile.com)
- 880: SP#52 completed. Stage 2/3. Linked to UID_460003 Minimization of drive tests for E-UTRAN and UTRAN (MDT_UMTSLTE) / Text5: Zou Lan (zlan@huawei.com), gyula.bodog@nsn.com, ulf.hubinette@ericsson.com
- 881: SP#52 completed / Text3: 32.421, 32.422, 32.423, 32.441, 32.442, 32.446 / Text5: Zou Lan (zlan@huawei.com), gyula.bodog@nsn.com, ulf.hubinette@ericsson.com
- 882: CP#51 completed under the SA5 WI code / Text3: 23.008 (CR#0330), 29.002 (CR#1007), 29.230 (CR#0207), 29.272 (CR#0329) / Text5: ulrich.wiehe@nsn.com
- 883: SP#51 completed / Text3: 32.582, 32.592, new (32.452, 32.453) / Text5: Chen Gang (chengang@chinamobile.com)
- 884: CH10 is an umbrella Feature also for OAM&P related TEI10 type of changes that are not part of any other dedicated feature/WI / Text3: TR 30.820
- 885: SP#51 completed. RAT differentiation for charging. Completes Rel-8 Feature IWLAN_Mob UID_370049 Mobility between 3GPP-WLAN Interworking and 3GPP Systems. Cooperation with CT1,CT3 on affected protocols / Text3: 32.240, 32.252, 32.298, 32.299 / Text5: Jean-Luc Garcia (jl.garcia@orange-ftgroup.com)
- 886: CP#52 completed. SP#51 completed SA5. Continuation of Rel-8 BB UID_80042: Advice of Charge (AoC) support in IMS Charging (IMSTSS). Stage 2/3 work / Text5: matthias.seibel@telekom.de
- 887: SP#51 completed. SA1 Stage 1 in 22.115 / Text3: 32.275, 32.280, 32.298, 32.299 / Text5: matthias.seibel@telekom.de
- 888: CP#52 completed. SA1 Stage 1 in 22.115, 22.173, 22.024. Add mobile-specific CAI format and volume charging elements. Extensions to existing AoC XML / Text3: 24.647 / Text5: reinhard.lauster@t-mobile.at
- 889: CP#51 completed. Ensure protocol alignment between 3GPP Stage 3 IMS work and IETF. Review capabilities provided in SIP by IETF and document whether these capabilities are supported in the IM CN Subsystem or not / Text3: 23.218, 24.229, 24.930 / Text5: keith.drage@alcatel-lucent.com
- 890: CP#51 completed. Specify CRUD (Create/Read/Update/Delete) operations based on SOAP protocol, which may be used by the applications having no high real-time requirement to the data access operations / Text3: 29.335 / Text5: Lan Sizhong (lansizhong@chinamobile.com)
- 891: CP#56 added IETF dependencies. Improvements of Rel-9 Feature UID_440027 Operational description of the Inter-IMS Network to Network Interface (II-NNI) / Text5: beata.dobrowolska@orange-ftgroup.com
- 892: CP#51 completed / Text3: 29.165
- 893: RFC editors queue, miss reference / Text3: draft-ietf-sip-session-policy-framework
- 894: Passed WGLC (29.165) / Text3: draft-ietf-sipcore-proxy-feature
- 895: CP#51 completed. Specify 1) IMS-related AT-commands to configure MT and 2) IMS-related unsolicited response codes from MT to present to end-user / Text3: 27.007 / Text5: atle.monrad@ericsson.com
- 896: CP#51 completed / Text3: 27.007 / Text5: magnus.mk.karlsson@stericsson.com
- 897: CT#51 completed. Stage 1 in TS 22.038 USAT service description. Linked to CT6's UID_1273 Rel-5 BB Provisioning of IP-based multimedia services (24.229, 31.103) and UID_390021 Rel-8 BB CT6 aspects of SAE (31.102, 31.111) / Text3: 31.102, 31.103, 31.111 / Text5: Denis.Lheriteau@gemalto.com
- 898: CP#52 completed. Linked to CT3 Rel-10 Feature UID_480014 Further improvements of II-NNI Stage 3 based on operational feedback and evolution of other specifications (II-NNI2) / Text3: 29.165 / Text5: arai.kenjiro@lab.ntt.co.jp
- 899: CP#51 completed. Define a solution which allows enabling to launch Smart Card Web Server services in an easy and simple manner / Text3: 31.102 / Text5: davide.pratone@telecomitalia.it
- 900: CP#51 completed. Stage 3 based on SA1 22.038CR#37r1 (Make USAT proactive capability reqs applicable to ME as a whole without regard to any particular configuration; e.g. a modem connected to an external display) / Text3: Stage 3 31.102, 31.111 / Text5: enric.fort@gi-de.com

| ID | WBS | Task | Type | Duration | Start | Finish | Complete | Remaining | Baseline start | Baseline finish | Baseline duration | Total slack | Constraint | Resources | Work | Actual work | Text1 | Text2 | Text4 | Text5 | Text6 | Text7 | Text8 | Text9 | Text12 |
| --- | --- | --- | --- | --- | --- | --- | --- | --- | --- | --- | --- | --- | --- | --- | --- | --- | --- | --- | --- | --- | --- | --- | --- | --- | --- |
| 901 | 320 | **Single Radio Voice Call Continuity (SRVCC) enhancements (Stage 3)** |  | 526d? | 2010-12-10 A | 2012-12-07 | 81% | 99.12d? | 2010-12-10 | 2012-12-07 | 526d? | 463d |  | C1,C4,IETF | 8254.4h | 3744.8h | eSRVCC | PCG-26 | China Mobile | Jiang Y (jiangyi@chinamobile.com) | Rel-10 | CP-50 | Frederic |  |  |
| 902 | 320.1 | CT1 part of Stage 3 for SRVCC enhancements |  | 71d? | 2010-12-10 A | 2011-03-18 A | 100% |  | 2010-12-10 | 2011-03-18 | 71d? |  | finish no earlier than 2011-03-18 | C1 | 568h | 568h | eSRVCC | PCG-26 | China Mobile | Jiang Y (jiangyi@chinamobile.com) | Rel-10 | CP-50 | Frederic |  |  |
| 903 | 320.2 | CT4 part of Stage 3 for SRVCC enhancements |  | 71d? | 2010-12-10 A | 2011-03-18 A | 100% |  | 2010-12-10 | 2011-03-18 | 71d? |  | finish no earlier than 2011-03-18 | C4 | 568h | 568h | eSRVCC | PCG-26 | China Mobile | Jiang Y (jiangyi@chinamobile.com) | Rel-10 | CP-50 | Kimmo |  |  |
| 904 | 320.3 | (IETF) CT1 part of Stage 3 for SRVCC enhancements |  | 434.8d? | 2010-12-10 A | 2012-12-07 | 75% | 108.7d? | 2010-12-10 | 2012-12-07 | 434.8d? | 463d | finish no earlier than 2012-12-07 | C1-IETF | 3478.4h | 2608.8h | eSRVCC | PCG-27 | Christer Holmberg | christer.holmberg@ericsson.com | Rel-10 | CP-52 | Frederic |  |  |
| 905 | 321 | **Single Radio Voice Call Continuity (SRVCC) in alerting phase (Stage 3)** |  | 586d? | 2010-12-10 A | 2013-03-01 | 50% | 293d? | 2010-12-10 | 2013-03-01 | 586d? | 403d |  | C1,R5 | 6704h | 2016h | aSRVCC | PCG-26 | ZTE | li.shitao@zte.com.cn | Rel-10 | CP-50 | Frederic |  |  |
| 906 | 321.1 | CT aspects of Single Radio Voice Call Continuity (SRVCC) in alerting phase (Stage 3) |  | 126d? | 2010-12-10 A | 2011-06-03 A | 100% |  | 2010-12-10 | 2011-06-03 | 126d? |  | finish no earlier than 2011-06-03 | C1 | 1008h | 1008h | aSRVCC | PCG-26 | ZTE | li.shitao@zte.com.cn | Rel-10 | CP-50 | Frederic |  |  |
| 907 | 321.2 | Conformance test aspects SRVCC in alerting phase |  | 126d? | 2012-09-07 | 2013-03-01 |  |  | 2012-09-07 | 2013-03-01 | 126d? | 403d | finish no earlier than 2013-03-01 | R5 | 1008h |  | aSRVCC-UEConTest | PCG-29 | NTT DoCoMo | Takao.Shimizu.rp@nttdocomo.com | Rel-10 | RP-57 |  |  |  |
| 908 | 322 | **PCRF failure and restoration** |  | 71d? | 2010-12-10 A | 2011-03-18 A | 100% |  | 2010-12-10 | 2011-03-18 | 71d? |  |  | C4,C3 | 1562h | 1562h | PCRF_FR | PCG-26 | NEC | Toshiyuki Tamura (tamurato@aj.jp.nec.com) | Rel-10 | CP-50 | Kimmo |  |  |
| 909 | 322.1 | CT4 part of PCRF failure and restoration |  | 71d? | 2010-12-10 A | 2011-03-18 A | 100% |  | 2010-12-10 | 2011-03-18 | 71d? |  | finish no earlier than 2011-03-18 | C4 | 568h | 568h | PCRF_FR | PCG-26 | NEC | Toshiyuki Tamura (tamurato@aj.jp.nec.com) | Rel-10 | CP-50 | Kimmo |  |  |
| 910 | 322.2 | CT3 part of PCRF failure and restoration |  | 53.25d? | 2010-12-10 A | 2011-03-18 A | 100% |  | 2010-12-10 | 2011-03-18 | 53.25d? |  | start no earlier than 2010-12-10 | C3 | 426h | 426h | PCRF_FR | PCG-26 | NEC | Toshiyuki Tamura (tamurato@aj.jp.nec.com) | Rel-10 | CP-50 | Jiwan |  |  |
| 911 | 323 | Formalization of WLAN Files | milestone | 0d? | 2011-02-23 A | 2011-03-18 A | 100% |  | 2011-02-23 | 2011-03-18 | 0d? |  | start no earlier than 2011-03-16 | C1 |  |  | FoWF | PCG-26 | Deutsche Telekom | dieter.jacobsohn@telekom.de | Rel-10 | CP-51 | Frederic |  |  |
| 912 | 324 | CS and IMS Interworking for CAT service - Early Session model |  | 58d? | 2011-03-16 A | 2011-06-03 A | 100% |  | 2011-03-16 | 2011-06-03 | 58d? |  |  | C3 | 464h | 464h | CIIC_ES | PCG-26 | ZTE | li.shitao@zte.com.cn | Rel-10 | CP-51 | Jiwan |  |  |
| 913 | 325 | EPC Node Restoration without Idle mode Signalling Reduction (ISR) activated |  | 3d? | 2011-03-16 A | 2011-03-18 A | 100% |  | 2011-03-16 | 2011-03-18 | 3d? |  | finish no earlier than 2011-03-18 | C4 | 24h | 24h | EPC_NR | PCG-26 | Alcatel-Lucent | bruno.landais@alcatel-lucent.com | Rel-10 | CP-51 | Kimmo |  |  |
| 914 | 326 | EPC Node Restoration with Idle mode Signalling Reduction (ISR) activated |  | 58d? | 2011-03-16 A | 2011-06-03 A | 100% |  | 2011-03-16 | 2011-06-03 | 58d? |  | finish no earlier than 2011-03-18 | C4 | 464h | 464h | EPC_NR_ISR | PCG-26 | NEC | Toshiyuki Tamura (tamurato@aj.jp.nec.com) | Rel-10 | CP-51 | Kimmo |  |  |
| 915 | 327 | Mobile Terminating Roaming Forwarding with pre-paging |  | 58d? | 2011-03-16 A | 2011-06-03 A | 100% |  | 2011-03-16 | 2011-06-03 | 58d? |  | finish no earlier than 2011-03-18 | C4 | 464h | 464h | MTRF | PCG-26 | Ericsson | philip.hodges@ericsson.com | Rel-10 | CP-51 | Kimmo |  |  |
| 916 | 328 | **UICC access to IMS Specification** |  | 58d? | 2011-03-16 A | 2011-06-03 A | 100% |  | 2011-03-16 | 2011-06-03 | 58d? |  |  | C6,C1 | 952h | 952h | IMS-UICC-S | PCG-26 | Gemalto | Denis.Lheriteau@gemalto.com | Rel-10 | CP-51 | Xavier |  |  |
| 917 | 328.1 | CT6 part of UICC access to IMS Specification |  | 3d? | 2011-03-16 A | 2011-03-18 A | 100% |  | 2011-03-16 | 2011-03-18 | 3d? |  | start no earlier than 2011-03-16 | C6 | 24h | 24h | IMS-UICC-S | PCG-26 | Gemalto | Denis.Lheriteau@gemalto.com | Rel-10 | CP-51 | Xavier |  |  |
| 918 | 328.2 | CT1 part of UICC access to IMS Specification |  | 58d? | 2011-03-16 A | 2011-06-03 A | 100% |  | 2011-03-16 | 2011-06-03 | 58d? |  | start no earlier than 2011-03-16 | C1 | 464h | 464h | IMS-UICC-S | PCG-26 | Gemalto | Denis.Lheriteau@gemalto.com | Rel-10 | CP-51 | Frederic |  |  |
| 919 | 329 | Testing for Terminal support of Rel-10 USIM, ISIM and USAT features |  | 201d? | 2012-03-05 A | 2012-12-07 | 40% | 120.6d? | 2012-03-05 | 2012-12-07 | 201d? | 463d | finish no earlier than 2012-12-07 | C6 | 1608h | 643.2h | USIM_R10_Test | PCG-28 | Gemalto | Denis.Praca@gemalto.com | Rel-10 | CP-55 |  |  |  |
| 920 | 330 | **CN aspects of Local Call Local Switch** |  | 472d? | 2009-05-29 A | 2011-03-18 A | 100% |  | 2009-05-29 | 2011-03-18 | 472d? |  |  | C4 | 13008h | 13008h | LCLS-CN | PCG-23 | Vodafone | David.Hutton@vodafone.com | Rel-10 | CP-44 | Kimmo |  |  |
| 921 | 330.1 | TR on CN aspects of Local Call Local Switch |  | 341d? | 2009-05-29 A | 2010-09-16 A | 100% |  | 2009-05-29 | 2010-09-16 | 341d? |  | finish no earlier than 2010-09-17 | C4 | 2728h | 2728h | LCLS-CN | PCG-23 | Vodafone | David.Hutton@vodafone.com | Rel-10 | CP-44 | Kimmo |  |  |
| 922 | 330.2 | Stage 2/3 for CN aspects of Local Call Local Switch |  | 131d? | 2010-09-17 A | 2011-03-18 A | 100% |  | 2010-09-17 | 2011-03-18 | 131d? |  | finish no earlier than 2011-03-18 | C4 | 1048h | 1048h | LCLS-CN | PCG-25 | Vodafone | David.Hutton@vodafone.com | Rel-10 | CP-49 | Kimmo |  |  |
| 923 | 330.3 | Deleted - CT3 aspects of Local Call Local Switch |  | 341d? | 2009-05-29 A | 2010-09-16 A | 100% |  | 2009-05-29 | 2010-09-16 | 341d? |  | finish no earlier than 2010-09-17 | C3 | 2728h | 2728h | LCLS-CN | PCG-23 | Vodafone | David.Hutton@vodafone.com | Rel-10 | CP-44 | Jiwan | PCG-25 | CP-49 |
| 924 | 330.4 | Deleted - CT1 aspects of Local Call Local Switch |  | 341d? | 2009-05-29 A | 2010-09-16 A | 100% |  | 2009-05-29 | 2010-09-16 | 341d? |  | finish no earlier than 2010-09-17 | C1 | 2728h | 2728h | LCLS-CN | PCG-23 | Vodafone | David.Hutton@vodafone.com | Rel-10 | CP-44 | Frederic | PCG-25 | CP-49 |
| 925 | 331 | Local Call Local Switch |  | 1055.8d? | 2007-05-07 A | 2011-05-20 A | 100% |  | 2007-05-07 | 2011-05-20 | 1055.8d? |  |  | GP,G2 | 8446.4h | 8446.4h | LCLS | PCG-22 | Huawei | wang_zhixi@huawei.com | Rel-10 | GP-41 | Paolo |  |  |

Notes:
- 901: CP#51 completed, Triggered by SA2 TR 23.856 Study on Single Radio Voice Call Continuity enhancements (FS_eSRVCC) UID_440049
- 902: CP#51 completed / Text3: 24.229, 24.237
- 903: CP#51 completed / Text3: 23.003, 23.008, 29.002, 29.230, 29.272, 29.305, 29.328, 29.329
- 904: Passed WGLC / Text3: draft-ietf-sipcore-proxy-feature
- 905: Builds on Rel-8 UID_390057 (IMS-Cont) TS 23.216 Stage 2. Provide Stage 3 for SRVCC PS-CS transfer of a call in alerting phase. Stage 2 TEI10 in TS 23.237 (6.3.2.1.4c/d, 6.3.2.1.7a/b)
- 906: CP#52 completed / Text3: 24.008, 24.237
- 907: Testing for Rel-10 SRVCC in alerting phase (aSRVCC) that builds on Rel-8 service continuity feature by adding access transfer of media of an IM session in PS to CS direction during the alerting phase for access transfers as specified in TS 23.216 / Text3: 36.523-1, 36.523-2, 36.523-3
- 908: CP#51 completed. Triggered by CT3 TR 29.816 Study on Policy and Charging Rules Function (PCRF) failure and restoration (FS_PCRF-FR) UID_450013 / Text3: Stage 2/3 work
- 909: CP#51 completed / Text3: Stage 2 23.007, Stage 3 29.230
- 910: CP#51 completed / Text3: Stage 3 29.212, 29.213, 29.214, 29.215
- 911: CP#51 completed. TS 24.235 for Info+Approval. Define the ME files as specified in 24.234 in OMA Device Management structure / Text3: Stage 3: 24.234, new 24.235
- 912: CP#52 completed. Stage 1 in Rel-8 TS 22.182 Customized Alerting Tones (CAT) service. Stage 3 TS 24.182 defines 3 impl models: Gateway, Forking, Early Session. Specify missing CAT service interworking procedures btw CS & IMS networks / Text3: Stage 3 29.163, 29.235, 29.292
- 913: CP#51 completed. Triggered by DRAFT TR 23.857 Study on EPC Nodes Restoration (FS_EPC_NR) UID_490014 / Text3: Stage 2/3: 23.007, 29.274
- 914: CP#52 completed. Triggered by DRAFT TR 23.857 Study on EPC Nodes Restoration (FS_EPC_NR) UID_490014 / Text3: Stage 2/3: 23.007, 29.274
- 915: CP#52 completed. Provides Stage 2/3 alternative solution to Mobile Terminating Roaming Retry to solve roaming events during paging, in particular to support CSFB. Hence, no new Stage 1 requirements exist / Text3: Stage 2/3: 23.012, 23.018, 23.116, 29.002
- 916: CP#52 completed. Triggered by Rel-10 TR 31.828 Study on UICC access to IMS (FS_IMS-UICC) UID_480017. Specify mechanism in UICC and ME to make use of IMS functionality implemented in ME for case a) an ISIM is present b) no ISIM is present in UICC
- 917: CP#51 completed / Text3: 31.102, 31.103, 31.111
- 918: CP#52 completed / Text3: 24.229
- 919: CP#56 updated WID CP-120174=>CP-120396. Testing for New features in Rel-10 specifications for USIM, ISIM applications and USIM Application Toolkit (USAT) in TS 31.102, 31.103, 31.111 / Text3: 31.121, 31.124, new TS 31.ABC (Conformance Testing of specific features)
- 920: CP#51 completed / Text3: GERAN Stage 2/3
- 921: CT#49 completed / Text3: new TR 23.889
- 922: CP#51 completed / Text3: 23.003, 23.009, 23.205, 23.231, 29.002, 29.205, 29.232, new TS 23.284
- 923: CP#49 stopped. Result of study TR 23.889: no CT3 specification impact
- 924: CP#49 stopped. Result of study TR 23.889: no CT1 specification impact
- 925: GP#50 completed. GP#41 WID approved / Text3: GERAN Stage 3: 48.008, 48.103

| ID | WBS | Task | Duration | Start | Finish | Complete | Remaining | Baseline start | Baseline finish | Baseline duration | Total slack | Constraint | Resources | Work | Actual work | Text1 | Text2 | Text4 | Text6 | Text7 | Text8 | Text11 |
| --- | --- | --- | --- | --- | --- | --- | --- | --- | --- | --- | --- | --- | --- | --- | --- | --- | --- | --- | --- | --- | --- | --- |
| 926 | 332 | **Tightened Link Level Performance Requirements for Single Antenna MS** | 586d? | 2010-09-03 A | 2012-11-23 | 82% | 106.06d? | 2010-09-03 | 2012-11-23 | 586d? | 473d |  | G1,G2,C1,G3new | 12392h | 10149.1h | TIGHTER | PCG-25 | Renesas Mobile | Rel-10 | GP-46 | Paolo |  |
| 927 | 332.1 | CT1 part for TIGHTER | 196d? | 2010-09-03 A | 2011-06-03 A | 100% |  | 2010-09-03 | 2011-06-03 | 196d? |  | finish no earlier than 2011-06-03 | C1 | 1568h | 1568h | TIGHTER | PCG-25 | Renesas Mobile | Rel-10 | GP-46 | Frederic |  |
| 928 | 332.2 | TIGHTER Performance Requirements | 186d? | 2010-09-03 A | 2011-05-20 A | 100% |  | 2010-09-03 | 2011-05-20 | 186d? |  | finish no earlier than 2011-05-20 | G1,G2 | 1488h | 1488h | TIGHTER | PCG-25 | Renesas Mobile | Rel-10 | GP-46 | Paolo |  |
| 929 | 332.3 | TIGHTER Testing | 581d? | 2010-09-08 A | 2012-11-23 | 70% | 174.3d? | 2010-09-08 | 2012-11-23 | 581d? | 473d | finish no earlier than 2012-11-23 | G3new | 4648h | 3253.6h | TIGHTER | PCG-25 | Renesas Mobile | Rel-10 | GP-46 | Ingbert |  |
| 930 | 333 | **Support of Multi-Operator Core Network by GERAN** | 206d? | 2010-05-21 A | 2011-03-04 A | 100% |  | 2010-05-21 | 2011-03-04 | 206d? |  |  | G2,S2,C1 | 5096h | 5096h | MOCN-GERAN | PCG-25 | Alcatel-Lucent | Rel-10 | GP-47 | Gert |  |
| 931 | 333.1 | Stage 2 for Support of Multi-Operator Core Network by GERAN | 150d? | 2010-05-21 A | 2010-12-16 A | 100% |  | 2010-05-21 | 2010-12-16 | 150d? |  | finish no earlier than 2010-12-15 | S2 | 1200h | 1200h | MOCN-GERAN | PCG-25 | Alcatel-Lucent | Rel-10 | GP-47 | Maurice |  |
| 932 | 333.2 | CT1 part of Stage 3 for Support of Multi-Operator Core Network by GERAN | 146d? | 2010-05-21 A | 2010-12-10 A | 100% |  | 2010-05-21 | 2010-12-10 | 146d? |  | finish no earlier than 2010-12-10 | C1 | 1168h | 1168h | MOCN-GERAN | PCG-25 | Alcatel-Lucent | Rel-10 | GP-47 | Frederic |  |
| 933 | 333.3 | GERAN2 part of Stage 3 for Support of Multi-Operator Core Network by GERAN | 135d? | 2010-08-30 A | 2011-03-04 A | 100% |  | 2010-08-30 | 2011-03-04 | 135d? |  | finish no earlier than 2011-03-04 | G2 | 1080h | 1080h | MOCN-GERAN | PCG-25 | Alcatel-Lucent | Rel-10 | GP-47 | Gert |  |
| 934 | 334 | **Enhancements of Iur-g interface** | 196d? | 2010-09-03 A | 2011-06-03 A | 100% |  | 2010-09-03 | 2011-06-03 | 196d? |  |  | G2,R3 | 4184h | 4184h | eIurg | PCG-25 | China Mobile, ZTE | Rel-10 | GP-47 | Gert |  |
| 935 | 334.1 | GERAN part for Enhancements of Iur-g interface (Stage 2/3) | 131d? | 2010-09-03 A | 2011-03-04 A | 100% |  | 2010-09-03 | 2011-03-04 | 131d? |  | finish no earlier than 2011-03-04 | G2 | 1048h | 1048h | eIurg-GERAN | PCG-25 | China Mobile, ZTE | Rel-10 | GP-47 | Gert |  |
| 936 | 334.2 | Core part: Enhancements of Iur-g interface (Stage 2/3) | 196d? | 2010-09-03 A | 2011-06-03 A | 100% |  | 2010-09-03 | 2011-06-03 | 196d? |  | finish no earlier than 2011-06-03 | R3 | 1568h | 1568h | eIurg-RAN | PCG-25 | ZTE | Rel-10 | RP-49 | Juha | RP-110526 |
| 937 | 335 | 1.28 Mcps TDD Repeater | 599d? | 2007-12-04 A | 2010-03-19 A | 100% |  | 2007-12-04 | 2010-03-19 | 599d? |  | finish no earlier than 2010-03-19 | R4 | 4792h | 4792h | RANimp-Repeaters1.28TDD | PCG-21 | RITT | Rel-10 | RP-38 | Issam | RP-100039 |
| 938 | 336 | 1.28 Mcps TDD Multi-carrier HSUPA | 321d? | 2009-09-18 A | 2010-12-10 A | 100% |  | 2009-09-18 | 2010-12-10 | 321d? |  | finish no earlier than 2010-12-10 | R1,R2,R3,R4 | 2568h | 2568h | TDD_MC_HSUPA | PCG-23 | CATR | Rel-10 | RP-45 | Patrick | RP-101079 |
| 939 | 337 | **1.28 Mcps TDD Home NodeB RF requirements** | 266d? | 2009-12-04 A | 2010-12-10 A | 100% |  | 2009-12-04 | 2010-12-10 | 266d? |  |  | R4 | 5304h | 5304h | HNB_LCRTDD_RF | PCG-24 | TD Tech | Rel-10 | RP-46 | Issam |  |
| 940 | 337.1 | Core part: 1.28Mcps TDD Home NodeB RF requirements | 131d? | 2009-12-04 A | 2010-06-04 A | 100% |  | 2009-12-04 | 2010-06-04 | 131d? |  | finish no earlier than 2010-12-10 | R4 | 1048h | 1048h | HNB_LCRTDD_RF-Core | PCG-24 | TD Tech | Rel-10 | RP-46 | Issam | RP-100446 |
| 941 | 337.2 | Perf. part: 1.28Mcps TDD Home NodeB RF requirements | 266d? | 2009-12-04 A | 2010-12-10 A | 100% |  | 2009-12-04 | 2010-12-10 | 266d? |  | finish no earlier than 2010-12-10 | R4 | 2128h | 2128h | HNB_LCRTDD_RF-Perf | PCG-24 | TD Tech | Rel-10 | RP-46 | Issam | RP-101081 |
| 942 | 338 | **Multi-User Multiple-Input and Multiple-Output (MU-MIMO) for 1.28Mcps TDD** | 316d? | 2010-03-19 A | 2011-06-03 A | 100% |  | 2010-03-19 | 2011-06-03 | 316d? |  |  | R1,R2,R3,R4 | 6584h | 6584h | MUMIMO_LCR_TDD | PCG-24 | CATT | Rel-10 | RP-47 | Patrick |  |
| 943 | 338.1 | Core part: MU-MIMO for 1.28Mcps TDD | 191d? | 2010-03-19 A | 2010-12-10 A | 100% |  | 2010-03-19 | 2010-12-10 | 191d? |  | finish no earlier than 2010-12-10 | R1,R2,R3 | 1528h | 1528h | MUMIMO_LCR_TDD-Core | PCG-24 | CATT | Rel-10 | RP-47 | Patrick | RP-101085 |
| 944 | 338.2 | Perf. part: MU-MIMO for 1.28Mcps TDD | 316d? | 2010-03-19 A | 2011-06-03 A | 100% |  | 2010-03-19 | 2011-06-03 | 316d? |  | finish no earlier than 2011-06-03 | R4 | 2528h | 2528h | MUMIMO_LCR_TDD-Perf | PCG-24 | CATT | Rel-10 | RP-47 | Issam | RP-110520 |
| 945 | 339 | **AGNSS Minimum Performance for UTRAN** | 523d? | 2009-09-18 A | 2011-09-16 A | 100% |  | 2009-09-18 | 2011-09-16 | 523d? |  |  | R4,R5 | 9440h | 9440h | AGNSSPerf_UTRAN | PCG-23 | Thales | Rel-10 | RP-45 | Issam |  |
| 946 | 339.1 | AGNSS Minimum Performance Specification Development | 321d? | 2009-09-18 A | 2010-12-10 A | 100% |  | 2009-09-18 | 2010-12-10 | 321d? |  | finish no earlier than 2010-12-10 | R4 | 2568h | 2568h | AGNSSPerf_UTRAN | PCG-23 | Thales | Rel-10 | RP-45 | Issam | RP-101078 |
| 947 | 339.2 | AGNSS test case development for UMTS | 336d? | 2010-06-04 A | 2011-09-16 A | 100% |  | 2010-06-04 | 2011-09-16 | 336d? |  | finish no earlier than 2011-09-16 | R5 | 2688h | 2688h | AGNSSTest_UTRAN | PCG-25 | Thales | Rel-10 | RP-48 | Ingbert | RP-110979 |
| 948 | 340 | **Inclusion of RF Pattern Matching Technologies as positioning method in the UTRAN** | 336d? | 2009-12-04 A | 2011-03-18 A | 100% |  | 2009-12-04 | 2011-03-18 | 336d? |  |  | R2,R3 | 5376h | 5376h | LCS_UMTS_RFPMT | PCG-24 | Polaris Wireless | Rel-10 | RP-46 | Joern | RP-110048 |
| 949 | 340.1 | Core part: Inclusion of RF Pattern Matching Technologies as positioning method in the UTRAN | 336d? | 2009-12-04 A | 2011-03-18 A | 100% |  | 2009-12-04 | 2011-03-18 | 336d? |  | finish no earlier than 2011-03-18 | R2,R3 | 2688h | 2688h | LCS_UMTS_RFPMT-Core | PCG-24 | Polaris Wireless | Rel-10 | RP-46 | Joern | RP-110048 |

Notes:
- 926: CP#52 completed. GP#50 completed (except Testing). GP#46 approved WID / Text3: GERAN / Text5: carsten.juncker@renesasmobile.com
- 927: CP#52 completed / Text3: 24.008 / Text5: marko.niemi@renesasmobile.com
- 928: GP#50 completed / Text3: 45.005, 45.015 / Text5: carsten.juncker@renesasmobile.com
- 929: GP#53 completion 09/12=>11/12 / Text3: 51.010 / Text5: carsten.juncker@renesasmobile.com
- 930: GP#49 completed. SP/CP#50 completed. GP#47 approved WID. 900 MHz spectrum re-farming to other RATs lead operators to reduce GSM capacity and therefore share their GSM networks. Hence the need for the most suitable (GE)RAN sharing method / Text3: GERAN / Text5: michel.robert@alcatel-lucent.com
- 931: SP#50 completed / Text3: 23.251 / Text5: michel.robert@alcatel-lucent.com
- 932: CP#50 completed / Text3: 24.008 CR#1644 / Text5: michel.robert@alcatel-lucent.com
- 933: GP#49 completed / Text3: 48.008 CR#0325, 48.018 CR#0303 / Text5: michel.robert@alcatel-lucent.com
- 934: RP#52 completed. GP#49 completed. GP#47 approved WID / Text3: GERAN,UTRA / Text5: Ms Juan Deng (dengjuan@chinamobile.com), Xinhui Wang (wangxinhui@zte.com.cn)
- 935: GP#49 completed. GP#48 updated WID GP-101659=>GP-101758 (restricting the scope to GERAN BSC and TD-SCDMA RNC only). GP#47 approved WID / Text3: 43.130, 48.008 / Text5: Ms Juan Deng (dengjuan@chinamobile.com), Xinhui Wang (wangxinhui@zte.com.cn)
- 936: RP#52 completed / Text3: UTRA Stage 2 (25.401, 25.420), Stage 3 (25.423) / Text5: Liu Junqiang (liu.junqiang@zte.com.cn)
- 937: RP#47 completed / Text3: UTRA 25.113, new 25.116, 25.153 (testing) / Text5: qinyan@chinattl.com
- 938: RP#50 completed / Text3: UTRA 25.102, 25.105, 25.123, 25.221, 25.222, 25.223, 25.224, 25.225, 25.306, 25.319, 25.321, 25.331, 25.423, 25.427, 25.433 / Text5: Aihui Song (songaihui@mail.ritt.com.cn)
- 939: RP#50 completed. Triggered by FS_RAN-HNBLCRTDD UID_410016 Study on 1.28 Mcps TDD Home NodeB (TR 25.866) / Text3: UTRA / Text5: Li Rong (lirong@td-tech.com)
- 940: RP#48 completed / Text3: 25.105 / Text5: Li Rong (lirong@td-tech.com)
- 941: RP#50 completed. TR 25.968 v100 for Approval / Text3: 25.142, new TR 25.968 / Text5: Li Rong (lirong@td-tech.com)
- 942: RP#52 completed / Text3: UTRA / Text5: Yanping Xing (xingyanping@datangmobile.cn)
- 943: RP#50 completed / Text3: 25.221, 25.222, 25.224, 25.306, 25.308, 25.319, 25.331, 25.423, 25.425, 25.433, 25.435 / Text5: Yanping Xing (xingyanping@datangmobile.cn)
- 944: RP#52 completed / Text3: 25.102, 25.105, 25.142 / Text5: Sanjun Feng (fengsanjun@datangmobile.cn)
- 945: RP#53 completed. Triggered by Rel-7 UID_20050 (GNSS in UTRAN) and Rel-8 UID_400051 (Support for Additional NSS). Linked to GERAN Rel-9 UID_38002 (AGNSS Performances and Testing Procedures) / Text3: UTRA / Text5: Michel.monnerat@thalesaleniaspace.com
- 946: RP#50 completed / Text3: new 25.172 / Text5: Michel.monnerat@thalesaleniaspace.com
- 947: RP#53 completed / Text3: 34.108, 34.109, 34.123-1, 34.123-2, 34.123-3, 36.37.571-5, new 34.172 / Text5: Michel.monnerat@thalesaleniaspace.com
- 948: RP#51 completed. Triggered by Study UID_380079 Evaluation of the inclusion of Path Loss Based Technology in the UTRAN (25.907) / Text3: UTRA / Text5: Norman Shaw (nshaw@polariswireless.com)
- 949: RP#51 completed / Text3: 25.305, 25.453 / Text5: Norman Shaw (nshaw@polariswireless.com)

| ID | WBS | Task | Duration | Start | Finish | Complete | Remaining | Baseline start | Baseline finish | Baseline duration | Total slack | Constraint | Resources | Work | Actual work | Text1 | Text2 | Text4 | Text5 | Text6 | Text7 | Text8 | Text11 | Text9 | Text12 |
| --- | --- | --- | --- | --- | --- | --- | --- | --- | --- | --- | --- | --- | --- | --- | --- | --- | --- | --- | --- | --- | --- | --- | --- | --- | --- |
| 950 | 341 | **Four carrier HSDPA** | 791d? | 2009-12-04 A | 2012-12-07 | 86% | 108.35d? | 2009-12-04 | 2012-12-07 | 791d? | 463d |  | R1,R2,R3,R4,R5 | 14872h | 10061.6h | 4C_HSDPA | PCG-24 | Qualcomm | Arjun Bharadwaj (arjunb@qualcomm.com) | Rel-10 | RP-46 | Patrick |  |  |  |
| 951 | 341.1 | Core part: Four carrier HSDPA | 336d? | 2009-12-04 A | 2011-03-18 A | 100% |  | 2009-12-04 | 2011-03-18 | 336d? |  | finish no earlier than 2011-03-18 | R1,R2,R3,R4 | 2688h | 2688h | 4C_HSDPA-Core | PCG-24 | Qualcomm | Arjun Bharadwaj (arjunb@qualcomm.com) | Rel-10 | RP-46 | Patrick | RP-110046 |  |  |
| 952 | 341.2 | Perf. part: Four carrier HSDPA | 466d? | 2009-12-04 A | 2011-09-16 A | 100% |  | 2009-12-04 | 2011-09-16 | 466d? |  | finish no earlier than 2011-09-16 | R4 | 3728h | 3728h | 4C_HSDPA-Perf | PCG-24 | Qualcomm | Arjun Bharadwaj (arjunb@qualcomm.com) | Rel-10 | RP-46 | Issam | RP-110986 |  |  |
| 953 | 341.3 | Test part: Four carrier HSDPA | 266d? | 2011-12-02 A | 2012-12-07 | 45% | 146.3d? | 2011-12-02 | 2012-12-07 | 266d? | 463d | finish no earlier than 2012-12-07 | R5 | 2128h | 957.6h | 4C_HSDPA-UEConTest | PCG-28 | Qualcomm | Shubhang Vora (svora@qualcomm.com) | Rel-10 | RP-54 |  | RP-120961 |  |  |
| 954 | 342 | **Performance Requirements for two-antenna 1.28Mcps TDD Type 1 and Type 2 UE receiver** | 316d? | 2010-03-19 A | 2011-06-03 A | 100% |  | 2010-03-19 | 2011-06-03 | 316d? |  |  | R4 | 5504h | 5504h | 2ant_UE_LCR_TDD | PCG-24 | TD Tech | dafei.wang@td-tech.com | Rel-10 | RP-47 | Issam |  |  |  |
| 955 | 342.1 | Core part: Performance Requirements for two-antenna 1.28Mcps TDD Type 1 and Type 2 UE receiver | 56d? | 2010-03-19 A | 2010-06-04 A | 100% |  | 2010-03-19 | 2010-06-04 | 56d? |  | finish no earlier than 2010-06-04 | R4 | 448h | 448h | 2ant_UE_LCR_TDD-Core | PCG-24 | TD Tech | dafei.wang@td-tech.com | Rel-10 | RP-47 | Issam | RP-100454 |  |  |
| 956 | 342.2 | Perf. part: Performance Requirements for two-antenna 1.28Mcps TDD Type 1 and Type 2 UE receiver | 316d? | 2010-03-19 A | 2011-06-03 A | 100% |  | 2010-03-19 | 2011-06-03 | 316d? |  | finish no earlier than 2011-06-03 | R4 | 2528h | 2528h | 2ant_UE_LCR_TDD-Perf | PCG-24 | TD Tech | dafei.wang@td-tech.com | Rel-10 | RP-47 | Issam | RP-110521 |  |  |
| 957 | 343 | **Automatic Neighbour Relation (ANR) for UTRAN** | 661d? | 2010-06-04 A | 2012-12-07 | 94% | 36.55d? | 2010-06-04 | 2012-12-07 | 661d? | 463d |  | R3,R2,R5 | 7872h | 4413.6h | ANR_UTRAN | PCG-25 | ZTE | Zhai.hengxing@zte.com.cn | Rel-10 | RP-48 | Juha |  |  |  |
| 958 | 343.1 | Core part: Automatic Neighbour Relation (ANR) for UTRAN | 261d? | 2010-06-04 A | 2011-06-03 A | 100% |  | 2010-06-04 | 2011-06-03 | 261d? |  | finish no earlier than 2011-06-03 | R3,R2 | 2088h | 2088h | ANR_UTRAN-Core | PCG-25 | ZTE | Zhai.hengxing@zte.com.cn | Rel-10 | RP-48 | Juha | RP-110522 |  |  |
| 959 | 343.2 | Test part: Automatic Neighbour Relation (ANR) for UTRAN | 323d? | 2011-09-19 A | 2012-12-07 | 90% | 32.3d? | 2011-09-19 | 2012-12-07 | 323d? | 463d | finish no earlier than 2012-12-07 | R5 | 2584h | 2325.6h | ANR_UTRAN-UEConTest | PCG-27 | Ericsson | leif.mattisson@ericsson.com | Rel-10 | RP-53 |  | RP-120960 |  |  |
| 960 | 344 | **Support of New Band Combinations for Dual-Band Dual Cell HSDPA** | 261d? | 2010-06-04 A | 2011-06-03 A | 100% |  | 2010-06-04 | 2011-06-03 | 261d? |  |  | R4,R2 | 4784h | 4784h | DB_DC_HSDPA | PCG-25 | AT&T | Vince Spatafora (vs5785@att.com) | Rel-10 | RP-48 | Issam |  |  |  |
| 961 | 344.1 | Core part: Support of New Band Combinations for Dual-Band Dual Cell HSDPA | 261d? | 2010-06-04 A | 2011-06-03 A | 100% |  | 2010-06-04 | 2011-06-03 | 261d? |  | finish no earlier than 2011-06-03 | R4,R2 | 2088h | 2088h | DB_DC_HSDPA-Core | PCG-25 | AT&T | Vince Spatafora (vs5785@att.com) | Rel-10 | RP-48 | Issam | RP-110523 |  |  |
| 962 | 344.2 | Deleted - Perf. part: Support of New Band Combinations for Dual-Band Dual Cell HSDPA | 76d? | 2010-06-04 A | 2010-09-17 A | 100% |  | 2010-06-04 | 2010-09-17 | 76d? |  | finish no earlier than 2010-09-17 | R4,R2 | 608h | 608h | DB_DC_HSDPA-Perf | PCG-25 | AT&T | Vince Spatafora (vs5785@att.com) | Rel-10 | RP-48 | Issam | RP-100759 | PCG-25 | RP-49 |
| 963 | 345 | **MIMO operation with non-MIMO coexistence in HSDPA** | 459d? | 2010-06-04 A | 2012-03-02 A | 100% |  | 2010-06-04 | 2012-03-02 | 459d? |  |  | R4,R5 | 9264h | 9264h | MIMO_HSDPA | PCG-25 | Qualcomm | Heechoon Lee | Rel-10 | RP-48 | Issam |  |  |  |
| 964 | 345.1 | Core part: MIMO operation with non-MIMO coexistence in HSDPA | 186d? | 2010-09-17 A | 2011-06-03 A | 100% |  | 2010-09-17 | 2011-06-03 | 186d? |  | finish no earlier than 2011-06-03 | R4 | 1488h | 1488h | MIMO_HSDPA-Core | PCG-25 | Qualcomm | Heechoon Lee | Rel-10 | RP-49 | Issam | RP-110524 |  |  |
| 965 | 345.2 | Perf. part: MIMO operation with non-MIMO coexistence in HSDPA | 261d? | 2010-06-04 A | 2011-06-03 A | 100% |  | 2010-06-04 | 2011-06-03 | 261d? |  | finish no earlier than 2011-06-03 | R4 | 2088h | 2088h | MIMO_HSDPA-Perf | PCG-25 | Qualcomm | Heechoon Lee | Rel-10 | RP-48 | Issam | RP-110525 |  |  |
| 966 | 345.3 | Test part: MIMO operation with non-MIMO coexistence in HSDPA | 252d? | 2011-03-18 A | 2012-03-02 A | 100% |  | 2011-03-18 | 2012-03-02 | 252d? |  | finish no earlier than 2012-03-02 | R5 | 2016h | 2016h | MIMO_HSDPA-UEConTest | PCG-26 | Qualcomm | Shubhang Vora (svora@qualcomm.com) | Rel-10 | RP-51 | Ingbert | RP-120042 |  |  |
| 967 | 346 | Interfrequency detected set measurements for UMTS | 61d? | 2010-09-17 A | 2010-12-10 A | 100% |  | 2010-09-17 | 2010-12-10 | 61d? |  | finish no earlier than 2010-12-10 | R2,R4 | 488h | 488h | Interf_dset_meas_UMTS | PCG-25 | Nokia | Chris.callender@nokia.com | Rel-10 | RP-49 | Joern | RP-101093 |  |  |
| 968 | 347 | **Carrier Aggregation for LTE** | 791d? | 2009-12-04 A | 2012-12-07 | 87% | 102.38d? | 2009-12-04 | 2012-12-07 | 791d? | 463d |  | R1,R2,R3,R4,R5 | 16248h | 10872.8h | LTE_CA | PCG-24 | Nokia | Asbjorn.grovlen@nokia.com | Rel-10 | RP-46 | Patrick |  |  |  |
| 969 | 347.1 | Core part: Carrier Aggregation for LTE | 391d? | 2009-12-04 A | 2011-06-03 A | 100% |  | 2009-12-04 | 2011-06-03 | 391d? |  | finish no earlier than 2011-06-03 | R1,R2,R3,R4 | 3128h | 3128h | LTE_CA-Core | PCG-24 | Nokia | lars.e.lindh@nokia.com | Rel-10 | RP-46 | Patrick | RP-110535 |  |  |
| 970 | 347.2 | Perf. part: Carrier Aggregation for LTE | 528d? | 2009-12-04 A | 2011-12-09 A | 100% |  | 2009-12-04 | 2011-12-09 | 528d? |  | finish no earlier than 2011-12-09 | R4 | 4224h | 4224h | LTE_CA-Perf | PCG-24 | Nokia | lars.e.lindh@nokia.com | Rel-10 | RP-46 | Issam | RP-111452 |  |  |
| 971 | 347.3 | Test part: Carrier Aggregation for LTE | 321d? | 2011-09-19 A | 2012-12-07 | 50% | 160.5d? | 2011-09-19 | 2012-12-07 | 321d? | 463d | finish no earlier than 2012-12-07 | R5 | 2568h | 1284h | LTE_CA-UEConTest | PCG-27 | Nokia | jussi.kuusisto@nokia.com | Rel-10 | RP-53 |  | RP-120959 |  |  |
| 972 | 348 | **Enhanced Downlink Multiple Antenna Transmission for LTE** | 926d? | 2009-12-04 A | 2013-06-14 | 81% | 173.21d? | 2009-12-04 | 2013-06-14 | 926d? | 328d |  | R1,R2,R4,R5 | 16896h | 10401.2h | LTE_eDL_MIMO | PCG-24 | NTT DoCoMo | Hidekazu Taoka (taoka@nttdocomo.com) | Rel-10 | RP-46 | Patrick |  |  |  |
| 973 | 348.1 | Core part: Enhanced Downlink Multiple Antenna Transmission for LTE | 336d? | 2009-12-04 A | 2011-03-18 A | 100% |  | 2009-12-04 | 2011-03-18 | 336d? |  | finish no earlier than 2011-03-18 | R1,R2,R4 | 2688h | 2688h | LTE_eDL_MIMO-Core | PCG-24 | NTT DoCoMo | Hidekazu Taoka (taoka@nttdocomo.com) | Rel-10 | RP-46 | Patrick | RP-110067 |  |  |
| 974 | 348.2 | Perf. part: Enhanced Downlink Multiple Antenna Transmission for LTE | 589d? | 2009-12-04 A | 2012-03-02 A | 100% |  | 2009-12-04 | 2012-03-02 | 589d? |  | finish no earlier than 2012-03-02 | R4 | 4712h | 4712h | LTE_eDL_MIMO-Perf | PCG-24 | NTT DoCoMo | Hidekazu Taoka (taoka@nttdocomo.com) | Rel-10 | RP-46 | Issam | RP-120053 |  |  |
| 975 | 348.3 | Test part: Enhanced Downlink Multiple Antenna Transmission for LTE | 261d? | 2012-06-18 A | 2013-06-14 | 15% | 221.85d? | 2012-06-18 | 2013-06-14 | 261d? | 328d | finish no earlier than 2013-06-14 | R5 | 2088h | 313.2h | LTE_eDL_MIMO-UEConTest | PCG-29 | ZTE | Carolyn Taylor (carolyn.tayl@zte.com.cn) | Rel-10 | RP-56 |  | RP-120965 |  |  |

Notes:
- 950: RP#53 completed / Text3: UTRA
- 951: RP#51 completed. RP#52 TR 25.864 v200 for Approval / Text3: 25.101, 25.104, 25.133, 25.211, 25.212, 25.213, 25.214, 25.215, 25.308, 25.331, 25.423, 25.433, 26.306, new TR 25.864
- 952: RP#53 completed / Text3: 25.101, 25.104, 25.133, 25.141
- 953: - / Text3: 34.108, 34.121-1, 34.121-2, 34.123-1, 34.123-2, 34.123-3
- 954: Stage 3. RP#52 completed / Text3: UTRA
- 955: RP#48 completed / Text3: 25.102
- 956: RP#52 completed / Text3: 25.102
- 957: RP#52 Core completed. Automatic Neighbour Relation (ANR) function for UTRAN relieves operators from the burden of manually managing the Neighbour cell Relations (NRs) / Text3: UTRA
- 958: RP#52 completed / Text3: 25.331, 25.413, 25.423, new TS 25.484 (Stage 2)
- 959: RP#57 completion 09/12=>12/12 / Text3: 34.108, 34.123-1, 34.123-2, 34.123-3
- 960: RP#52 completed. Rel-9 Dual-Band Dual-Cell HSDPA (UID_430015 Support for different bands for Dual-Cell HSDPA) has one combination per region in principle. This work adds additional combinations: Band I and XI (Region 3) and Band II and V (Region 2) / Text3: UTRA
- 961: RP#52 completed / Text3: 25.101, 25.104, 25.141, 25.317
- 962: RP#49 stopped (Reason: no need for Performance work) / Text3: 25.101, 25.104, 25.141, 25.317
- 963: RP#52 completed. RP#49 updated WID RP-100687=>RP-100993 (changed Title: MIMO Testing in HSDPA => MIMO operation with non-MIMO coexistence in HSDPA) / Text3: UTRA
- 964: RP#52 completed / Text3: 25.104
- 965: RP#52 completed / Text3: 25.101, 25.141
- 966: RP#55 completed / Text3: 34.108, 34.121-1, 34.121-2, 34.123-1, 34.123-2, 34.123-3
- 967: RP#50 completed / Text3: UTRA 25.133, 25.331
- 968: - / Text3: LTE
- 969: RP#52 completed. RP#56 new RAN4 TR (36.807, 36.808) v200 for Approval / Text3: 36.101, 36.104, 36.133, 36.211, 36.212, 36.213, 36.300, 36.302, 36.306, 36.321, 36.331, 36.413, 36.423, 37.104, new RAN4 TR (36.807, 36.808)
- 970: RP#54 completed / Text3: 36.101, 36.104, 36.133, 36.141, 37.141
- 971: RP#57 updated WID RP-111221=>RP-121246 (additional impacted specs 37.571-1, 37.571-3, 37.571-5) / Text3: 36.508, 36.521-1, 36.521-2, 36.521-3, 36.523-1, 36.523-2, 36.523-3, 37.571-1, 37.571-3, 37.571-5
- 972: - / Text3: LTE
- 973: RP#51 completed. RP#56 new RAN4 TR 36.807 v200 for Approval / Text3: 36.101, 36.104, 36.133, 36.201, 36.211, 36.212, 36.213, 36.300, 36.306, 36.321, 36.331, new RAN4 TR 36.807
- 974: RP#55 completed / Text3: 36.101, 36.104, 36.133, 36.141
- 975: Testing for 36.101, 36.133 / Text3: 36.508, 36.521-1, 36.521-2

| ID | WBS | Task | Duration | Start | Finish | Complete | Remaining | Baseline start | Baseline finish | Baseline duration | Total slack | Constraint | Resources | Work | Actual work | Text1 | Text2 | Text4 | Text5 | Text6 | Text7 | Text8 | Text11 | Text9 | Text12 |
| --- | --- | --- | --- | --- | --- | --- | --- | --- | --- | --- | --- | --- | --- | --- | --- | --- | --- | --- | --- | --- | --- | --- | --- | --- | --- |
| 976 | 349 | **Uplink Multiple Antenna Transmission for LTE** | 791d? | 2009-12-04 A | 2012-12-07 | 95% | 37.46d? | 2009-12-04 | 2012-12-07 | 791d? | 463d |  | R1,R2,R4,R5 | 15312h | 11686.4h | LTE_UL_MIMO | PCG-24 | Huawei | Mattias.wennstrom@huawei.com | Rel-10 | RP-46 | Patrick |  |  |  |
| 977 | 349.1 | Core part: UL multiple antenna transmission for LTE | 391d? | 2009-12-04 A | 2011-06-03 A | 100% |  | 2009-12-04 | 2011-06-03 | 391d? |  |  | R1,R2,R4 | 3128h | 3128h | LTE_UL_MIMO-Core | PCG-24 | Huawei | Mattias.wennstrom@huawei.com | Rel-10 | RP-46 | Patrick | RP-110537 |  |  |
| 978 | 349.2 | Perf. part: UL multiple antenna transmission for LTE | 466d? | 2009-12-04 A | 2011-09-16 A | 100% |  | 2009-12-04 | 2011-09-16 | 466d? |  | finish no earlier than 2011-09-16 | R4 | 3728h | 3728h | LTE_UL_MIMO-Perf | PCG-24 | Huawei | Mattias.wennstrom@huawei.com | Rel-10 | RP-46 | Issam | RP-110992 |  |  |
| 979 | 349.3 | Test part: UL multiple antenna transmission for LTE | 266d? | 2011-12-02 A | 2012-12-07 | 80% | 53.2d? | 2011-12-02 | 2012-12-07 | 266d? | 463d | finish no earlier than 2012-12-07 | R5 | 2128h | 1702.4h | LTE_UL_MIMO-UEConTest | PCG-28 | Huawei | Zhang Xin (suzanna.zhang@huawei.com) | Rel-10 | RP-54 |  | RP-120962 |  |  |
| 980 | 350 | **Relays for LTE** | 394d? | 2009-12-04 A | 2011-06-08 A | 100% |  | 2009-12-04 | 2011-06-08 | 394d? |  |  | R1,R2,R4,S2,S3,C4,C6 | 10584h | 10584h | LTE_Relay | PCG-24 | Ericsson | christian.hoymann@ericsson.com | Rel-10 | RP-46 | Patrick |  |  |  |
| 981 | 350.1 | Core part: Relays for LTE | 391d? | 2009-12-04 A | 2011-06-03 A | 100% |  | 2009-12-04 | 2011-06-03 | 391d? |  | finish no earlier than 2011-06-03 | R1,R2,R4 | 3128h | 3128h | LTE_Relay-Core | PCG-24 | Ericsson | christian.hoymann@ericsson.com | Rel-10 | RP-46 | Patrick | RP-110540 |  |  |
| 982 | 350.2 | Deleted - Perf. part: Relays for LTE | 391d? | 2009-12-04 A | 2011-06-03 A | 100% |  | 2009-12-04 | 2011-06-03 | 391d? |  | finish no earlier than 2011-09-16 | R4 | 3128h | 3128h | LTE_Relay-Perf | PCG-24 | Ericsson | christian.hoymann@ericsson.com | Rel-10 | RP-46 | Issam | RP-110541 | PCG-27 | RP-52 |
| 983 | 350.3 | Stage 2 for Relays for LTE | 3d? | 2011-06-06 A | 2011-06-08 A | 100% |  | 2011-06-06 | 2011-06-08 | 3d? |  | start no earlier than 2011-06-06 | S2 | 24h | 24h | LTE_Relay | PCG-27 | Vodafone | Chris Pudney | Rel-10 | SP-52 | Maurice |  |  |  |
| 984 | 350.4 | TR on LTE Relay Nodes Security | 69d? | 2010-12-16 A | 2011-03-22 A | 100% |  | 2010-12-16 | 2011-03-22 | 69d? |  | finish no earlier than 2011-03-23 | S3 | 552h | 552h | LTE_Relay-Sec | PCG-26 | Qualcomm | Adrian Escott (aescott@qualcomm.com) | Rel-10 | SP-50 | Dionisio |  |  |  |
| 985 | 350.5 | Security for LTE Relay Nodes (Stage 2) | 69d? | 2010-12-16 A | 2011-03-22 A | 100% |  | 2010-12-16 | 2011-03-22 | 69d? |  | finish no earlier than 2011-03-23 | S3 | 552h | 552h | LTE_Relay-Sec | PCG-26 | Qualcomm | Adrian Escott (aescott@qualcomm.com) | Rel-10 | SP-50 | Dionisio |  |  |  |
| 986 | 350.6 | CT6 aspects of LTE Relay Node Security | 3d? | 2011-03-16 A | 2011-03-18 A | 100% |  | 2011-03-16 | 2011-03-18 | 3d? |  | start no earlier than 2011-03-16 | C6 | 24h | 24h | LTE_Relay-Sec | PCG-26 | n/a | n/a | Rel-10 | CP-51 | Xavier |  |  |  |
| 987 | 350.7 | Core Network Impacts for Relay Nodes | 3d? | 2011-03-16 A | 2011-03-18 A | 100% |  | 2011-03-16 | 2011-03-18 | 3d? |  | finish no earlier than 2011-03-18 | C4 | 24h | 24h | LTE_Relay-CN | PCG-26 | Vodafone | David.Hutton@vodafone.com | Rel-10 | CP-51 | Kimmo |  |  |  |
| 988 | 351 | **Enhanced Inter-Cell Interference Control (ICIC) for non-Carrier Aggregation (CA) based deployments of heterogeneous networks for LTE** | 716d? | 2010-03-19 A | 2012-12-07 | 85% | 110.6d? | 2010-03-19 | 2012-12-07 | 716d? | 463d |  | R1,R2,R3,R4,R5 | 12048h | 7481.2h | eICIC_LTE | PCG-24 | China Mobile | Xiaodong XU (xuxiaodong@chinamobile.com) | Rel-10 | RP-47 | Patrick |  |  |  |
| 989 | 351.1 | Core part: Enhanced Inter-Cell Interference Control (ICIC) for non-Carrier Aggregation (CA) based deployments of heterogeneous networks for LTE | 316d? | 2010-03-19 A | 2011-06-03 A | 100% |  | 2010-03-19 | 2011-06-03 | 316d? |  | finish no earlier than 2011-06-03 | R1,R2,R3,R4 | 2528h | 2528h | eICIC_LTE-Core | PCG-24 | China Mobile | Xiaodong XU (xuxiaodong@chinamobile.com) | Rel-10 | RP-47 | Patrick | RP-110543 |  |  |
| 990 | 351.2 | Perf. part: Enhanced Inter-Cell Interference Control (ICIC) for non-Carrier Aggregation (CA) based deployments of heterogeneous networks for LTE | 589d? | 2010-03-19 A | 2012-06-15 A | 100% |  | 2010-03-19 | 2012-06-15 | 589d? |  | finish no earlier than 2012-06-15 | R4 | 4712h | 4712h | eICIC_LTE-Perf | PCG-24 | China Mobile | Xiaodong XU (xuxiaodong@chinamobile.com) | Rel-10 | RP-47 | Issam | RP-120461 |  |  |
| 991 | 351.3 | Test part: Enhanced Inter-Cell Interference Control (ICIC) for non-Carrier Aggregation (CA) based deployments of heterogeneous networks for LTE | 201d? | 2012-03-05 A | 2012-12-07 | 15% | 170.85d? | 2012-03-05 | 2012-12-07 | 201d? | 463d | finish no earlier than 2012-12-07 | R5 | 1608h | 241.2h | eICIC_LTE-UEConTest | PCG-28 | Qualcomm | Anjali Mishra (ajha@qualcomm.com) | Rel-10 | RP-55 |  | RP-120963 |  |  |
| 992 | 352 | **LTE TDD in 2600MHz for US** | 191d? | 2010-03-19 A | 2010-12-10 A | 100% |  | 2010-03-19 | 2010-12-10 | 191d? |  |  | R4,R2,R3,R5 | 4712h | 4712h | LTE_TDD_2600_US | PCG-24 | Clearwire | michael.hart@clearwire.com | Rel-10 | RP-47 | Issam |  |  |  |
| 993 | 352.1 | Core part: LTE TDD in 2600MHz for US | 131d? | 2010-03-19 A | 2010-09-17 A | 100% |  | 2010-03-19 | 2010-09-17 | 131d? |  | finish no earlier than 2010-09-17 | R4,R2,R3 | 1048h | 1048h | LTE_TDD_2600_US-Core | PCG-24 | Clearwire | michael.hart@clearwire.com | Rel-10 | RP-47 | Issam | RP-100782 |  |  |
| 994 | 352.2 | Perf. part: LTE TDD in 2600MHz for US | 131d? | 2010-03-19 A | 2010-09-17 A | 100% |  | 2010-03-19 | 2010-09-17 | 131d? |  | finish no earlier than 2010-09-17 | R4 | 1048h | 1048h | LTE_TDD_2600_US-Perf | PCG-24 | Clearwire | michael.hart@clearwire.com | Rel-10 | RP-47 | Issam | RP-100783 |  |  |
| 995 | 352.3 | UE conformance test part: LTE TDD in 2600MHz for US | 136d? | 2010-06-04 A | 2010-12-10 A | 100% |  | 2010-06-04 | 2010-12-10 | 136d? |  | finish no earlier than 2010-12-10 | R5 | 1088h | 1088h | LTE_TDD_2600_US-UEConTest | PCG-25 | Clearwire | michael.hart@clearwire.com | Rel-10 | RP-48 | Ingbert | RP-101071 |  |  |
| 996 | 353 | **Adding 2 GHz band LTE FDD (Band 23) for Ancillary Terrestrial Component (ATC) of Mobile Satellite Service (MSS) in North America** | 454d? | 2010-03-19 A | 2011-12-09 A | 100% |  | 2010-03-19 | 2011-12-09 | 454d? |  |  | R2,R4,R5 | 9776h | 9776h | S_Band_LTE_ATC_MSS | PCG-24 | DBSD | Mariam.Sorond@ico.com | Rel-10 | RP-47 | Joern |  |  |  |
| 997 | 353.1 | Core part: Adding 2 GHz band LTE FDD (Band 23) for ATC of MSS in North America | 316d? | 2010-03-19 A | 2011-06-03 A | 100% |  | 2010-03-19 | 2011-06-03 | 316d? |  | finish no earlier than 2011-06-03 | R4,R2 | 2528h | 2528h | S_Band_LTE_ATC_MSS-Core | PCG-24 | DBSD | Mariam.Sorond@ico.com | Rel-10 | RP-47 | Issam | RP-110545 |  |  |
| 998 | 353.2 | Perf. part: Adding 2 GHz band LTE FDD (Band 23) for ATC of MSS in North America | 316d? | 2010-03-19 A | 2011-06-03 A | 100% |  | 2010-03-19 | 2011-06-03 | 316d? |  | finish no earlier than 2011-06-03 | R4 | 2528h | 2528h | S_Band_LTE_ATC_MSS-Perf | PCG-24 | DBSD | Mariam.Sorond@ico.com | Rel-10 | RP-47 | Issam | RP-110546 |  |  |
| 999 | 353.3 | Test part: Adding 2 GHz band LTE FDD (Band 23) for ATC of MSS in North America | 137d? | 2011-06-07 A | 2011-12-09 A | 100% |  | 2011-06-07 | 2011-12-09 | 137d? |  | finish no earlier than 2011-12-09 | R5 | 1088h | 1088h | S_Band_LTE_ATC_MSS-UEConTest | PCG-27 | DBSD | Mariam.Sorond@ico.com | Rel-10 | RP-52 | Ingbert | RP-111444 |  |  |

Notes:
- 976: RP#56 new TR 36.807 v200 for Approval / Text3: LTE
- 977: RP#52 completed. TR 36.817 v110 for Approval. RP#56 new TR 36.807 v200 for Approval / Text3: 36.101, 36.104, 36.133, 36.201, 36.211, 36.212, 36.213, 36.300, 36.306, 36.321, 36.331, new RAN4 (TR 36.807, 36.817)
- 978: RP#53 completed / Text3: 36.101, 36.104, 36.133, 36.141, 36.817
- 979: - / Text3: 36.508, 36.521-1, 36.521-2, 36.521-3, 36.523-1, 36.523-2, 36.523-3
- 980: RP#52 completed (open RAN4 Core & Perf parts moved to new Rel-11) / Text3: LTE
- 981: RP#52 completed. Updated WID RP-101417=>RP-101911 (contains only Core part completed in Rel-10). Open RAN4 Core & Perf parts moved to new Rel-11 / Text3: 36.201, 36.211, 36.212, 36.213, 36.300, 36.321, 36.323, 36.331, new RAN1 TS 36.216
- 982: RP#52 stopped at 30% (no CRs so far) . Transferred completely to Rel-11 together with remaining core part / Text3: 36.133, new TS 36.117 (E-UTRA Relay conformance testing)
- 983: SP#52 SP-110338 (S2-85/S2-112851) 23.401 Cat F CR#2128 Completion of Relay procedure overview / Text3: 23.401
- 984: SP#51 completed / Text3: 33.816
- 985: SP#51 completed (impacting Stage 3 in CT and RAN) / Text3: 33.401 (CR#0437,0438), CT1 24.301, CT4 (29.272, 29.274), CT6 31.102, RAN2 (36.331, 36.323), RAN3 36.413
- 986: CP#51 completed / Text3: 31.101, 31.102
- 987: CP#51 completed / Text3: 23.003, 23.008, 29.303, 29.230, 29.272
- 988: RP#56 completed / Text3: LTE
- 989: RP#52 completed / Text3: 36.101, 36.133, 36.201, 36.211, 36.212, 36.213, 36.214, 36.300, 36.321, 36.331, 36.413, 36.423
- 990: RP#56 completed / Text3: 36.101, 36.133
- 991: - / Text3: 36.508, 36.521-1, 36.521-2, 36.521-3, 36.523-1, 36.523-2, 36.523-3
- 992: RP#50 Testing completed. RP#49 Core+Perf completed / Text3: LTE
- 993: RP#49 completed / Text3: 25.461, 25.466, 36.101, 36.104, 36.113, 36.124, 36.133, 36.141, 36.307, 36.331, 37.104, 37.113, 37.141, new TR 36.812
- 994: RP#49 completed / Text3: 36.101, 36.104, 36.133, 36.141, 36.307, 37.104, 37.141, new TR 36.812
- 995: RP#50 completed / Text3: 36.508, 36.521-1, 36.521-2, 36.521-3, 36.523-1, 36.523-2, 36.523-3
- 996: RP#52 completed. Updated WID RP-101401=>RP-110775 (changed in Title "LTE" to "LTE FDD (Band 23)" / Text3: LTE
- 997: RP#52 completed / Text3: 25.101, 25.104, 25.141, 25.461, 25.466, 36.101, 36.104, 36.113, 36.124, 36.133, 36.307, 37.104, 37.141, new TR 36.811
- 998: RP#52 completed / Text3: 36.101, 36.104, 36.113, 36.124, 36.133, 36.141, 36.307, 36.811
- 999: RP#54 completed / Text3: 36.508, 36.521-1, 36.521-2, 36.521-3, 36.523-1, 36.523-2, 36.523-3

| ID | WBS | Task | Duration | Start | Finish | Complete | Remaining | Baseline start | Baseline finish | Baseline duration | Total slack | Constraint | Resources | Work | Actual work | Text1 | Text2 | Text4 | Text5 | Text6 | Text7 | Text8 | Text11 |
| --- | --- | --- | --- | --- | --- | --- | --- | --- | --- | --- | --- | --- | --- | --- | --- | --- | --- | --- | --- | --- | --- | --- | --- |
| 1000 | 354 | **Adding L-Band (Band 24) LTE for Ancillary Terrestrial Component (ATC) of Mobile Satellite Service (MSS) in North America** | 393d? | 2010-03-19 A | 2011-09-16 A | 100% |  | 2010-03-19 | 2011-09-16 | 393d? |  |  | R4,R2,R5 | 8808h | 8808h | L_Band_LTE_ATC_MSS | PCG-24 | LightSquared | Eric.Jacks@lightsquared.com, Maqbool.Aliani@lightsquared.com | Rel-10 | RP-47 | Issam |  |
| 1001 | 354.1 | Core part: Adding L-Band (Band 24) LTE for ATC of MSS in North America | 261d? | 2010-03-19 A | 2011-03-18 A | 100% |  | 2010-03-19 | 2011-03-18 | 261d? |  | finish no earlier than 2010-12-10 | R4,R2 | 2088h | 2088h | L_Band_LTE_ATC_MSS-Core | PCG-24 | LightSquared | Eric.Jacks@lightsquared.com, Maqbool.Aliani@lightsquared.com | Rel-10 | RP-47 | Issam | RP-101117 |
| 1002 | 354.2 | Perf. part: Adding L-Band (Band 24) LTE for ATC of MSS in North America | 316d? | 2010-03-19 A | 2011-06-03 A | 100% |  | 2010-03-19 | 2011-06-03 | 316d? |  | finish no earlier than 2011-06-03 | R4 | 2528h | 2528h | L_Band_LTE_ATC_MSS-Perf | PCG-24 | LightSquared | Eric.Jacks@lightsquared.com, Maqbool.Aliani@lightsquared.com | Rel-10 | RP-47 | Issam | RP-110548 |
| 1003 | 354.3 | Test part: Adding L-Band (Band 24) LTE for ATC of MSS in North America | 131d? | 2011-03-18 A | 2011-09-16 A | 100% |  | 2011-03-18 | 2011-09-16 | 131d? |  | finish no earlier than 2011-09-16 | R5 | 1048h | 1048h | L_Band_LTE_ATC_MSS-UEConTest | PCG-26 | LightSquared | Masoud.olfat@LightSquared.com | Rel-10 | RP-51 | Ingbert | RP-110980 |
| 1004 | 355 | **LTE Self Optimizing Networks (SON) enhancements** | 316d? | 2010-03-19 A | 2011-06-03 A | 100% |  | 2010-03-19 | 2011-06-03 | 316d? |  |  | R3,R2,R4 | 5056h | 5056h | SONenh_LTE | PCG-24 | Nokia Siemens Networks | krzysztof.kordybach@nsn.com | Rel-10 | RP-47 | Juha |  |
| 1005 | 355.1 | Core part: LTE Self Optimizing Networks (SON) enhancements | 316d? | 2010-03-19 A | 2011-06-03 A | 100% |  | 2010-03-19 | 2011-06-03 | 316d? |  | finish no earlier than 2011-06-03 | R3,R2,R4 | 2528h | 2528h | SONenh_LTE-Core | PCG-24 | Nokia Siemens Networks | krzysztof.kordybach@nsn.com | Rel-10 | RP-47 | Juha | RP-110547 |
| 1006 | 356 | **Further enhancements to MBMS for LTE** | 459d? | 2010-06-04 A | 2012-03-02 A | 100% |  | 2010-06-04 | 2012-03-02 | 459d? |  |  | R2,R3,R5 | 5848h | 5848h | MBMS_LTE_enh | PCG-25 | Huawei | Ms Zhao Junhui (zhaojh@huawei.com) | Rel-10 | RP-48 | Joern |  |
| 1007 | 356.1 | Core part: Further enhancements to MBMS for LTE | 206d? | 2010-06-04 A | 2011-03-18 A | 100% |  | 2010-06-04 | 2011-03-18 | 206d? |  | finish no earlier than 2011-03-18 | R2,R3 | 1648h | 1648h | MBMS_LTE_enh-Core | PCG-25 | Huawei | Ms Zhao Junhui (zhaojh@huawei.com) | Rel-10 | RP-48 | Joern | RP-110083 |
| 1008 | 356.2 | Test part: Further enhancements to MBMS for LTE | 66d? | 2011-12-02 A | 2012-03-02 A | 100% |  | 2011-12-02 | 2012-03-02 | 66d? |  | finish no earlier than 2012-03-02 | R5 | 528h | 528h | MBMS_LTE_enh-UEConTest | PCG-28 | Huawei | Zhang Xin (suzanna.zhang@huawei.com) | Rel-10 | RP-54 |  | RP-120049 |
| 1009 | 357 | **UMTS/LTE 3500 MHz** | 1317d? | 2007-11-30 A | 2012-12-07 | 97% | 42.14d? | 2007-11-30 | 2012-12-07 | 1317d? | 463d |  | R4,R2,R3,R5 | 31250h | 30250h | RInImp8-UMTSLTE3500 | PCG-21 | Ericsson | johan.skold@ericsson.com | Rel-10 | RP-38 | Issam |  |
| 1010 | 357.1 | Core part: UMTS/LTE 3500 MHz | 980d? | 2007-11-30 A | 2011-09-16 A | 100% |  | 2007-11-30 | 2011-09-16 | 980d? |  | finish no earlier than 2011-09-16 | R4,R2,R3 | 7840h | 7840h | RInImp8-UMTSLTE3500 | PCG-21 | Ericsson | johan.skold@ericsson.com | Rel-10 | RP-38 | Issam | RP-110987 |
| 1011 | 357.2 | Conformance Test Aspects – LTE 3500 | 1051d? | 2008-12-05 A | 2012-12-07 | 91% | 94.59d? | 2008-12-05 | 2012-12-07 | 1051d? | 463d | finish no earlier than 2012-12-07 | R5 | 8408h | 7651.28h | LTE-UEConTest_LTE3500 | PCG-22 | Ericsson | fredrik.sundstrom@ericsson.com | Rel-10 | RP-42 | Ingbert | RP-120956 |
| 1012 | 357.3 | Conformance Test Aspects – UMTS 3500 | 925d? | 2008-12-05 A | 2012-06-15 A | 100% |  | 2008-12-05 | 2012-06-15 | 925d? |  | finish no earlier than 2012-06-15 | R5 | 7400h | 7400h | RInImp-UEConTest_UMTS3500 | PCG-22 | Ericsson | fredrik.sundstrom@ericsson.com | Rel-10 | RP-42 | Ingbert | RP-120450 |
| 1013 | 358 | **Minimization of Drive Tests for E-UTRAN and UTRAN** | 791d? | 2009-12-04 A | 2012-12-07 | 77% | 178.61d? | 2009-12-04 | 2012-12-07 | 791d? | 463d |  | R2,R4,R3,R5 | 12032h | 7544h | MDT_UMTSLTE | PCG-24 | Nokia Siemens Networks | malgorzata.tomala@nsn.com | Rel-10 | RP-46 | Joern |  |
| 1014 | 358.1 | Core part: Minimization of Drive Tests for E-UTRAN and UTRAN | 391d? | 2009-12-04 A | 2011-06-03 A | 100% |  | 2009-12-04 | 2011-06-03 | 391d? |  | finish no earlier than 2011-06-03 | R2,R4,R3 | 3128h | 3128h | MDT_UMTSLTE-Core | PCG-24 | Nokia Siemens Networks | malgorzata.tomala@nsn.com | Rel-10 | RP-46 | Joern | RP-110528 |
| 1015 | 358.2 | Test part: Minimization of Drive Tests for E-UTRAN and UTRAN | 322d? | 2011-09-19 A | 2012-12-07 | 50% | 161d? | 2011-09-19 | 2012-12-07 | 322d? | 463d | finish no earlier than 2012-12-07 | R5 | 2576h | 1288h | MDT_UMTSLTE-UEConTest | PCG-27 | Ericsson | leif.mattisson@ericsson.com | Rel-10 | RP-53 |  | RP-120958 |
| 1016 | 359 | **HNB and HeNB Mobility Enhancements** | 716d? | 2010-03-19 A | 2012-12-07 | 60% | 289.7d? | 2010-03-19 | 2012-12-07 | 716d? | 463d |  | R3,R2,R5 | 9424h | 2200.56h | HNB_HENB_mob_enh | PCG-24 | Alcatel-Lucent | Martin,Warner@alcatel-lucent.com | Rel-10 | RP-47 | Juha |  |
| 1017 | 359.1 | Core part: HNB and HeNB Mobility Enhancements | 261d? | 2010-03-19 A | 2011-03-18 A | 100% |  | 2010-03-19 | 2011-03-18 | 261d? |  | start no earlier than 2010-03-19 | R3,R2 | 2088h | 2088h | HNB_HENB_mob_enh-Core | PCG-24 | Alcatel-Lucent | Martin.Warner@alcatel-lucent.com | Rel-10 | RP-47 | Juha | RP-110058 |
| 1018 | 359.2 | Test part: HeNB Mobility Enhancements | 201d? | 2012-03-05 A | 2012-12-07 | 7% | 186.93d? | 2012-03-05 | 2012-12-07 | 201d? | 463d | finish no earlier than 2012-12-07 | R5 | 1608h | 112.56h | HNB_HENB_mob_enh-UEConTest_LTE | PCG-28 | Qualcomm | Anjali Mishra (ajha@qualcom.com) | Rel-10 | RP-55 |  | RP-120964 |
| 1019 | 360 | **Expanded 1900 MHz Band for UTRA and LTE** | 596d? | 2010-06-04 A | 2012-09-07 A | 100% |  | 2010-06-04 | 2012-09-07 | 596d? |  |  | R4,R2,R5 | 11600h | 11600h | E1900 | PCG-25 | Sprint | nick.j.baustert@sprint.com | Rel-10 | RP-48 | Issam |  |
| 1020 | 360.1 | Core part: Expanded 1900 MHz Band for UTRA and LTE | 261d? | 2010-06-04 A | 2011-06-03 A | 100% |  | 2010-06-04 | 2011-06-03 | 261d? |  | finish no earlier than 2011-06-03 | R4,R2 | 2088h | 2088h | E1900-Core | PCG-25 | Sprint | nick.j.baustert@sprint.com | Rel-10 | RP-48 | Issam | RP-110529 |
| 1021 | 360.2 | Perf. part: Expanded 1900 MHz Band for UTRA and LTE | 261d? | 2010-06-04 A | 2011-06-03 A | 100% |  | 2010-06-04 | 2011-06-03 | 261d? |  | finish no earlier than 2011-06-03 | R4,R2 | 2088h | 2088h | E1900-Perf | PCG-25 | Sprint | nick.j.baustert@sprint.com | Rel-10 | RP-48 | Issam | RP-110530 |
| 1022 | 360.3 | Test part: Expanded 1900 MHz Band for UTRA and LTE | 333d? | 2011-06-07 A | 2012-09-07 A | 100% |  | 2011-06-07 | 2012-09-07 | 333d? |  | finish no earlier than 2012-09-07 | R5 | 2656h | 2656h | E1900-UEConTest | PCG-27 | Sprint | nick.j.baustert@sprint.com | Rel-10 | RP-52 | Ingbert | RP-120957 |
| 1023 | 361 | **Multi-standard radio Base Station RF requirements for non-contiguous spectrum deployments** | 389d? | 2010-06-04 A | 2011-11-25 A | 100% |  | 2010-06-04 | 2011-11-25 | 389d? |  |  | R4,G1 | 10472h | 10472h | MSR_NC | PCG-25 | Ericsson | johan.skold@ericsson.com | Rel-10 | RP-48 | Issam |  |
| 1024 | 361.1 | Core part: Multi-standard radio Base Station RF requirements for non-contiguous spectrum deployments | 261d? | 2010-06-04 A | 2011-06-03 A | 100% |  | 2010-06-04 | 2011-06-03 | 261d? |  | finish no earlier than 2011-06-03 | R4 | 2088h | 2088h | MSR_NC-Core | PCG-25 | Ericsson | johan.skold@ericsson.com | Rel-10 | RP-48 | Issam | RP-110531 |
| 1025 | 361.2 | Perf. part: Multi-standard radio Base Station RF requirements for non-contiguous spectrum deployments | 336d? | 2010-06-04 A | 2011-09-16 A | 100% |  | 2010-06-04 | 2011-09-16 | 336d? |  | finish no earlier than 2011-09-16 | R4 | 2688h | 2688h | MSR_NC-Perf | PCG-25 | Ericsson | johan.skold@ericsson.com | Rel-10 | RP-48 | Issam | RP-110988 |
| 1026 | 361.3 | GERAN Core part: Multi-standard radio Base Station RF requirements for non-contiguous spectrum deployments | 261d? | 2010-09-03 A | 2011-09-02 A | 100% |  | 2010-09-03 | 2011-09-02 | 261d? |  | finish no earlier than 2011-09-02 | G1 | 2088h | 2088h | MSR_NC-GERAN | PCG-25 | Ericsson | mats.y.samuelsson@ericsson.com | Rel-10 | GP-47 | Paolo |  |
| 1027 | 361.4 | GERAN BS Test part: Multi-standard radio Base Station RF requirements for non-contiguous spectrum deployments | 62d? | 2011-09-02 A | 2011-11-25 A | 100% |  | 2011-09-02 | 2011-11-25 | 62d? |  | finish no earlier than 2011-11-25 | G1 | 496h | 496h | MSR_NC-GERAN | PCG-28 | Ericsson | mats.y.samuelsson@ericsson.com | Rel-10 | GP-52 |  |  |
| 1028 | 362 | (Small) Technical Enhancements and Improvements for Rel-10 | 470d? | 2009-06-04 A | 2011-03-23 A | 100% |  | 2009-06-04 | 2011-03-23 | 470d? |  | finish no earlier than 2011-03-23 | All | 3760h | 3760h | TEI10 | PCG-23 |  |  | Rel-10 | SP-44 |  |  |
| 1029 | 363 | (IETF) (Small) Technical Enhancements and Improvements for Rel-10 (draft-atarius) | 715d? | 2009-06-04 A | 2012-12-07 | 75% | 178.75d? | 2009-06-04 | 2012-12-07 | 715d? | 463d | finish no earlier than 2012-12-07 | C1-IETF | 5720h | 4290h | TEI10 | PCG-27 | Andrew Allen |  | Rel-10 | CP-52 | Frederic |  |
| 1030 | 364 | (IETF) (Small) Technical Enhancements and Improvements for Rel-10 (RFC6275) | 562d? | 2009-06-04 A | 2011-07-29 A | 100% |  | 2009-06-04 | 2011-07-29 | 562d? |  | finish no earlier than 2011-07-29 | C1-IETF | 4496h | 4496h | TEI10 | PCG-27 |  |  | Rel-10 | CP-53 |  |  |
| 1031 | 365 | Test - (Small) Technical Enhancements and Improvements for Rel-10 | 268d? | 2011-12-01 A | 2012-12-07 A | 100% |  | 2011-12-01 | 2012-12-07 | 268d? |  | finish no earlier than 2012-12-07 | R5,G3new | 2136h | 2136h | TEI10_Test | PCG-28 | n/a |  | Rel-10 | RP-54 |  |  |

Notes:
- 1000: RP#53 completed / Text3: LTE
- 1001: RP#51 completed / Text3: 25.101, 25.104, 25.141, 25.461, 25.466, 34.124, 36.101, 36.104, 36.113, 36.124, 36.133, 36.307, 37.104, 37.141, new RAN4 TR 36.813
- 1002: RP#52 completed / Text3: 34.121-1, 36.101, 36.104, 36.113, 36.124, 36.133, 36.141, 36.307, 36.521-1, 36.813
- 1003: RP#53 completed / Text3: 36.508, 36.521-1, 36.521-2, 36.521-3, 36.523-2
- 1004: RP#52 completed / Text3: LTE
- 1005: RP#52 completed (Stage 1,2,3) / Text3: 36.300, 36.331, 36.413, 36.423
- 1006: RP#51 completed. SA2 decided not to support MBR>GBR in Rel-10 MBMS. For SA2, MBR=GBR in Rel-10 MBMS. Hence RAN removed enabling statistical multiplexing gains for variable bit rate services in Objectives / Text3: LTE
- 1007: RP#51 completed / Text3: 25.446, 36.300, 36.321, 36.322, 36.323, 36.331, 36.440, 36.441, 36.442, 36.443, 36.444, 36.445
- 1008: RP#55 completed / Text3: 36.508, 36.523-1, 36.523-2, 36.523-3
- 1009: RP#53 completed (test ongoing) / Text3: UTRA, LTE
- 1010: RP#53 completed. TR 37.801v200 for Approval / Text3: 25.101, 25.104, 25.113, 25.133, 25.141, 25.307, 25.307, 25.331, 25.461, 25.463, 34.124, 36.101, 36.104, 36.113, 36.141, 36.331, new 37.801
- 1011: RP#56 completion 06/12=>12/12 / Text3: 36.508, 36.521-1, 36.521-2, 36.521-3
- 1012: RP#56 completed / Text3: 34.108, 34.121-1, 34.121-2
- 1013: RP#52 Core completed. Triggered by UID_430021 TR 36.805 (Study on Minimization of drive-tests in NGN) / Text3: UTRA, LTE
- 1014: RP#52 completed / Text3: 25.133, 25.215, 25.304, 25.331, 25.423, 36.133, 36.214, 36.300, 36.304, 36.331, 36.413, 36.423, new 37.320 (Stage 2)
- 1015: RP#57 completion 09/12=>12/12. Testing for LTE only / Text3: LTE 34.108, 34.109, 34.123-1, 34.123-2, 34.123-3, 36.508, 36.509, 36.523-1, 36.523-2, 36.523-3
- 1016: RP#51 Core completed / Text3: UTRA, LTE
- 1017: RP#51 completed / Text3: 25.413, 25.467, 25.469, 36.300, 36.413, 36.423, new 25.471
- 1018: - / Text3: 34.108, 34.123-1, 34.123-2, 34.123-3, 36.508, 36.523-1, 36.523-2, 36.523-3
- 1019: Expand UTRA and E-UTRA band 2 to include frequencies between 1910 1915 MHz and 1990-1995 MHz (US FCC allocation) / Text3: UTRA, LTE
- 1020: RP#52 completed / Text3: 25.101, 25.104, 25.113, 25.133, 25.141, 25.461, 25.466, 36.101, 36.104, 36.113, 36.124, 36.133, 36.141, 36.307, 36.331, new TR 36.818
- 1021: RP#52 completed / Text3: 25.101, 25.104, 25.113, 25.133, 25.141, 25.461, 25.466, 36.101, 36.104, 36.113, 36.124, 36.133, 36.141, 36.307, 36.331, new TR 36.818
- 1022: RP#57 completed / Text3: 34.108, 34.121-1, 34.121-2, 34.123-1, 34.123-2, 34.123-3, 36.508, 36.521-1, 36.521-2, 36.521-3, 36.523-1, 36.523-2, 36.523-3
- 1023: RP#53 completed / Text3: UTRA, LTE, GERAN
- 1024: RP#52 completed. TR 37.802 v100 for Approval / Text3: 25.104, 36.104, 37.104, new TR 37.802
- 1025: RP#53 completed / Text3: 25.141, 36.141, 37.141, 37.802
- 1026: GP#51 completed. GP#47 approved WID / Text3: 45.005
- 1027: GP#52 completed / Text3: 51.021
- 1028: -
- 1029: Not completed internet-draft / Text3: draft-atarius-dispatch-meid-urn
- 1030: SP#53/IETF#81: RFC 6275 completed / Text3: RFC 6275 (was draft-ietf-mext-rfc3775bis)
- 1031: -

| ID | WBS | Task | Type | Duration | Start | Finish | Complete | Baseline start | Baseline finish | Baseline duration | Constraint | Resources | Work | Actual work | Text1 | Text4 | Text6 | Text7 | Text8 | Text9 | Text12 | Text3 | Text2 | Text11 |
| --- | --- | --- | --- | --- | --- | --- | --- | --- | --- | --- | --- | --- | --- | --- | --- | --- | --- | --- | --- | --- | --- | --- | --- | --- |
| 1032 | 366 | **Deleted - Registration in Densely-populated area (RED)** |  | 665d? | 2007-03-12 A | 2009-09-24 A | 100% | 2007-03-12 | 2009-09-24 | 665d? |  | S1 | 9544h | 9544h | RED | NTT DoCoMo | Rel-10 | SP-35 | Alain | PCG-24 | SP-46 |  |  |  |
| 1033 | 366.1 | Deleted - Stage 1 for RED |  | 4d? | 2007-03-12 A | 2007-03-15 A | 100% | 2007-03-12 | 2007-03-15 | 4d? | start no earlier than 2007-03-12 | S1 | 32h | 32h | RED | NTT DoCoMo | Rel-10 | SP-35 | Alain | PCG-24 | SP-46 | 22.101 CR#0207 |  |  |
| 1034 | 366.2 | Deleted - Stage 2 for RED |  | 524d? | 2007-09-25 A | 2009-09-24 A | 100% | 2007-09-25 | 2009-09-24 | 524d? | finish no earlier than 2009-09-24 | S2 | 4192h | 4192h | RED | NTT DoCoMo | Rel-10 | SP-37 | Maurice | PCG-23 | SP-45 | draft TR 23.880 withdrawn, 23.002, 23.060, 23.221, 23.236 |  |  |
| 1035 | 367 | **Deleted - Network Selection for non-3GPP Access** |  | 471d? | 2007-12-07 A | 2009-09-24 A | 100% | 2007-12-07 | 2009-09-24 | 471d? |  | S1,C6 | 10452.8h | 10452.8h | N3GtoNSP | Telefónica O2 | Rel-10 | SP-38 | Alain | PCG-23 | SP-45 |  | PCG-21 |  |
| 1036 | 367.1 | Deleted - Stage 1 for N3GtoNSP |  | 471d? | 2007-12-07 A | 2009-09-24 A | 100% | 2007-12-07 | 2009-09-24 | 471d? | finish no earlier than 2009-12-10 | S1 | 3768h | 3768h | N3GtoNSP | Telefónica O2 | Rel-10 | SP-38 | Alain | PCG-23 | SP-45 | 22.011 | PCG-21 |  |
| 1037 | 367.2 | Deleted - CT6 issues for N3GtoNSP |  | 471d? | 2007-12-07 A | 2009-09-24 A | 100% | 2007-12-07 | 2009-09-24 | 471d? | finish no earlier than 2009-12-04 | C6 | 3768h | 3768h | N3GtoNSP | Telefónica O2 | Rel-10 | CP-38 | Xavier | PCG-23 | CP-45 | 36.300 | PCG-21 |  |
| 1038 | 368 | **Deleted - GTP-based S8 chaining** |  | 337d? | 2008-12-11 A | 2010-03-25 A | 100% | 2008-12-11 | 2010-03-25 | 337d? |  | S2 | 5392h | 5392h | GTPchaining | Huawei | Rel-10 | SP-42 | Maurice | PCG-24 | SP-47 |  | PCG-22 |  |
| 1039 | 368.1 | Deleted - Stage 2 for GTPchaining |  | 337d? | 2008-12-11 A | 2010-03-25 A | 100% | 2008-12-11 | 2010-03-25 | 337d? | finish no earlier than 2010-03-25 | S2 | 2696h | 2696h | GTPchaining | Huawei | Rel-10 | SP-42 | Maurice | PCG-24 | SP-47 | 23.402 | PCG-22 |  |
| 1040 | 369 | Deleted - UTRAN 2 ms TTI uplink range improvement |  | 272d? | 2009-03-06 A | 2010-03-19 A | 100% | 2009-03-06 | 2010-03-19 | 272d? | finish no earlier than 2010-03-19 | R1,R2,R3,R4 | 2176h | 2176h | RANimp-2mTTI_ULimp | Nokia Siemens Networks | Rel-10 | RP-43 | Patrick | PCG-24 | RP-47 | 25.133, 25.212, 25.214, 25.321, 25.331 | PCG-22 | RP-100040 |
| 1041 | 370 | Deleted - Enhanced Home NodeB / eNodeB continuation of Rel-9 |  | 337d? | 2008-12-11 A | 2010-03-25 A | 100% | 2008-12-11 | 2010-03-25 | 337d? |  | S2 | 2696h | 2696h | eEHNB | Alcatel-Lucent | Rel-10 | SP-44 | Maurice | PCG-24 | SP-47 |  | PCG-23 |  |
| 1042 | 371 | **Deleted - Fixed Wireless Customer-Premises Equipment (CPE) RF Requirements** |  | 391d? | 2009-12-04 A | 2011-06-03 A | 100% | 2009-12-04 | 2011-06-03 | 391d? |  | R4,R5 | 9384h | 9384h | FW_CPE_RF | Verizon Wireless | Rel-10 | RP-46 | Issam | PCG-27 | RP-52 | LTE | PCG-24 |  |
| 1043 | 371.1 | Deleted - Core part: Fixed Wireless Customer-Premises Equipment (CPE) RF Requirements |  | 391d? | 2009-12-04 A | 2011-06-03 A | 100% | 2009-12-04 | 2011-06-03 | 391d? | finish no earlier than 2011-06-03 | R4 | 3128h | 3128h | FW_CPE_RF-Core | Verizon Wireless | Rel-10 | RP-46 | Issam | PCG-27 | RP-52 | 36.101 | PCG-24 | RP-110539 |
| 1044 | 371.2 | Deleted - Test part: Fixed Wireless Customer-Premises Equipment (CPE) RF Requirements |  | 391d? | 2009-12-04 A | 2011-06-03 A | 100% | 2009-12-04 | 2011-06-03 | 391d? | finish no earlier than 2011-06-03 | R5 | 3128h | 3128h | FW_CPE_RF-UEConTest | Verizon Wireless | Rel-10 | RP-46 | Ingbert | PCG-27 | RP-52 | 36.521-1 | PCG-24 | RP-110504 |
| 1045 | 372 | **Deleted - Latency reductions for LTE** |  | 266d? | 2009-12-04 A | 2010-12-10 A | 100% | 2009-12-04 | 2010-12-10 | 266d? |  | R2,R1 | 4256h | 4256h | LTE_LATRED | Ericsson | Rel-10 | RP-46 | Joern | PCG-26 | RP-50 | LTE | PCG-24 |  |
| 1046 | 372.1 | Deleted - Core part: Latency reductions for LTE |  | 266d? | 2009-12-04 A | 2010-12-10 A | 100% | 2009-12-04 | 2010-12-10 | 266d? | finish no earlier than 2010-12-10 | R2,R1 | 2128h | 2128h | LTE_LATRED-Core | Ericsson | Rel-10 | RP-46 | Joern | PCG-26 | RP-50 | 36.213, 36.300, 36.306, 36.321, 36.331 | PCG-24 | RP-101112 |
| 1047 | 373 | **Deleted - Enhanced Interference Management for Home NodeBs** |  | 131d? | 2010-03-19 A | 2010-09-17 A | 100% | 2010-03-19 | 2010-09-17 | 131d? |  | R3 | 2096h | 2096h | HNB_IM | Qualcomm | Rel-10 | RP-47 | Juha | PCG-25 | RP-49 | UTRA | PCG-24 | RP-100754 |
| 1048 | 373.1 | Deleted - Core part: Enhanced Interference Management for Home NodeBs |  | 131d? | 2010-03-19 A | 2010-09-17 A | 100% | 2010-03-19 | 2010-09-17 | 131d? | finish no earlier than 2010-09-17 | R3 | 1048h | 1048h | HNB_IM-Core | Qualcomm | Rel-10 | RP-47 | Juha | PCG-25 | RP-49 | 25.413, 25.467, 25.469 | PCG-24 | RP-100754 |
| 1049 | 374 | Release 10 Studies |  | 531d? | 2009-03-12 A | 2011-03-23 A | 100% | 2009-03-12 | 2011-03-23 | 531d? | finish no earlier than 2011-03-23 | CP,GP,RP,SP | 4248h | 4248h |  |  | Rel-10 |  |  |  |  |  |  |  |
| 1050 | 375 | **Study on enhanced voice service requirements for the Evolved Packet System (EPS)** |  | 670d? | 2007-09-03 A | 2010-03-25 A | 100% | 2007-09-03 | 2010-03-25 | 670d? |  | S1,S4 | 13384h | 13384h | FS_EV_EPS | France Telecom | Rel-10 | SP-37 | Alain |  |  | 22.813 |  |  |
| 1051 | 375.1 | Use cases definition and service and system requirements |  | 334d? | 2007-09-03 A | 2008-12-11 A | 100% | 2007-09-03 | 2008-12-11 | 334d? | finish no earlier than 2008-12-11 | S1 | 2672h | 2672h | FS_EV_EPS-S1 | France Telecom | Rel-10 | SP-37 | Alain |  |  | 22.813 |  |  |
| 1052 | 375.2 | Codec specific part of FS_EV_EPS |  | 669d? | 2007-09-03 A | 2010-03-25 A | 100% | 2007-09-03 | 2010-03-25 | 669d? | finish no earlier than 2010-03-25 | S4 | 5352h | 5352h | FS_EV_EPS-S4 | Ericsson | Rel-10 | SP-37 | Paolo |  |  | 22.813 |  |  |
| 1053 | 376 | Study on advanced requirements for IP interconnect |  | 528d? | 2007-12-04 A | 2009-12-10 A | 100% | 2007-12-04 | 2009-12-10 | 528d? | finish no earlier than 2009-12-10 | S1 | 4224h | 4224h | FS_IPXS | Telefónica O2 | Rel-10 | SP-38 | Alain |  |  | 22.893 | PCG-21 |  |
| 1054 | 377 | Study on Personal Broadcast Service |  | 397d? | 2008-09-18 A | 2010-03-25 A | 100% | 2008-09-18 | 2010-03-25 | 397d? | finish no earlier than 2010-03-25 | S1 | 3168h | 3168h | FS_PBS | ETRI | Rel-10 | SP-41 | Alain |  |  | 22.947 | PCG-21 |  |
| 1055 | 378 | Study on LCS support in SAE for non-3GPP accesses |  | 397d? | 2008-09-18 A | 2010-03-25 A | 100% | 2008-09-18 | 2010-03-25 | 397d? | finish no earlier than 2010-03-25 | S1 | 3168h | 3168h | FS_LCS_n3GPP | SK Telecom | Rel-10 | SP-41 | Alain |  |  | 22.814 | PCG-21 |  |
| 1056 | 379 | Study on Haptic Services |  | 272d? | 2009-03-12 A | 2010-03-25 A | 100% | 2009-03-12 | 2010-03-25 | 272d? | finish no earlier than 2010-03-25 | S1 | 2168h | 2168h | FS_Haptics | SK Telecom | Rel-10 | SP-43 | Alain |  |  | 22.987 | PCG-22 |  |
| 1057 | 380 | Study on System enhancements for the use of IMS services in Local BreakOut and Optimal Routing of Media |  | 575d? | 2007-10-01 A | 2009-12-10 A | 100% | 2007-10-01 | 2009-12-10 | 575d? | finish no earlier than 2009-12-10 | S2 | 4600h | 4600h | FS_IMS_LBO_ORM | Telecom Italia, BT | Rel-10 | SP-37 | Maurice |  |  | 23.894 |  |  |
| 1058 | 381 | Study on Intra Domain Connection of RAN Nodes to Multiple CN Nodes |  | 533d? | 2008-03-12 A | 2010-03-25 A | 100% | 2008-03-12 | 2010-03-25 | 533d? | finish no earlier than 2010-03-25 | S2 | 4264h | 4264h | FS_IDC | China Mobile | Rel-10 | SP-39 | Maurice |  |  | 23.924 (was 23.823) | PCG-21 |  |
| 1059 | 382 | Study on Single Radio Voice Call Continuity enhancements |  | 341d? | 2009-06-04 A | 2010-09-23 A | 100% | 2009-06-04 | 2010-09-23 | 341d? | finish no earlier than 2010-09-23 | S2 | 2728h | 2728h | FS_eSRVCC | China Mobile | Rel-10 | SP-44 | Maurice |  |  | 23.856 | PCG-23 |  |
| 1060 | 383 | Study on Single Radio Video Call Continuity for 3G-CS |  | 131d? | 2010-03-25 A | 2010-09-23 A | 100% | 2010-03-25 | 2010-09-23 | 131d? | finish no earlier than 2010-09-23 | S2 | 1048h | 1048h | FS_vSRVCC | Samsung | Rel-10 | SP-47 | Maurice |  |  | 23.886 | PCG-24 |  |
| 1061 | 384 | Study on S2b Mobility based on GTP |  | 56d? | 2010-03-25 A | 2010-06-10 A | 100% | 2010-03-25 | 2010-06-10 | 56d? | finish no earlier than 2010-06-07 | S2 | 448h | 448h | FS_SMOG | Alcatel-Lucent | Rel-10 | SP-47 | Maurice |  |  | 23.834 | PCG-24 |  |
| 1062 | 385 | Study on Surround Sound codec extension for PSS and MBMS |  | 530d? | 2009-03-12 A | 2011-03-23 A | 100% | 2009-03-12 | 2011-03-23 | 530d? | finish no earlier than 2011-03-23 | S4 | 4240h | 4240h | FS_SS_PSS_MBMS | Fraunhofer Gesellschaft | Rel-10 | SP-43 | Paolo |  |  | 26.950 | PCG-22 |  |
| 1063 | 386 | Study on Improved Video Coding Support |  | 205d? | 2010-06-10 A | 2011-03-23 A | 100% | 2010-06-10 | 2011-03-23 | 205d? | finish no earlier than 2011-03-23 | S4 | 1640h | 1640h | FS_IVCS | Nokia, ETRI | Rel-10 | SP-48 | Paolo |  |  | 26.904 | PCG-25 |  |
| 1064 | 387 | Study on Rc Reference Point Functionalities and Message Flows |  | 397d? | 2008-09-18 A | 2010-03-25 A | 100% | 2008-09-18 | 2010-03-25 | 397d? | finish no earlier than 2010-03-23 | S5 | 3170.08h | 3170.08h | FS_OAM_Rc | Huawei | Rel-10 | SP-41 | Dionisio |  |  | 32.825 | PCG-21 |  |
| 1065 | 388 | Study on Telecommunication Management; Energy Savings Management |  | 271d? | 2009-03-12 A | 2010-03-25 A | 100% | 2009-03-12 | 2010-03-25 | 271d? | finish no earlier than 2010-03-25 | S5 | 2168h | 2168h | FS_OAM_ESM | Orange, Vodafone | Rel-10 | SP-43 | Dionisio |  |  | 32.826 | PCG-22 |  |
| 1066 | 389 | Study on Integration of Device Management Information with Itf-N |  | 211d? | 2009-06-04 A | 2010-03-25 A | 100% | 2009-06-04 | 2010-03-25 | 211d? | finish no earlier than 2010-03-25 | S5 | 1688h | 1688h | FS_IDMI_Itf-N | Motorola | Rel-10 | SP-44 | Dionisio |  |  | 32.827 | PCG-23 |  |
| 1067 | 390 | Study on Alignment of 3GPP Generic NRM IRP and TMF Shared Information Data (SID) model |  | 335d? | 2009-12-10 A | 2011-03-23 A | 100% | 2009-12-10 | 2011-03-23 | 335d? | finish no earlier than 2011-03-23 | S5 | 2680h | 2680h | FS_3GNRM_TMFSID | Nokia Siemens Networks | Rel-10 | SP-46 | Dionisio |  |  | 32.828 | PCG-24 |  |
| 1068 | 391 | Study on Harmonization of 3GPP Alarm IRP and TMF Interface Program (TIP) Fault Management |  | 335d? | 2009-12-10 A | 2011-03-23 A | 100% | 2009-12-10 | 2011-03-23 | 335d? | finish no earlier than 2011-03-23 | S5 | 2680h | 2680h | FS_3G_TMF_FM | Nokia Siemens Networks, Alcatel-Lucent | Rel-10 | SP-46 | Dionisio |  |  | 32.829 | PCG-24 |  |
| 1069 | 392 | Study on Alarm Correlation and Alarm Root Cause Analysis |  | 205d? | 2010-06-10 A | 2011-03-23 A | 100% | 2010-06-10 | 2011-03-23 | 205d? | finish no earlier than 2011-03-23 | S5 | 1640h | 1640h | FS_AC_ARCA | Ericsson | Rel-10 | SP-48 | Dionisio |  |  | 32.832 | PCG-25 |  |
| 1070 | 393 | Study on Alignment of 3GPP PM IRP and TMF Interface Program (TIP) PM |  | 205d? | 2010-06-10 A | 2011-03-23 A | 100% | 2010-06-10 | 2011-03-23 | 205d? | finish no earlier than 2011-03-23 | S5 | 1640h | 1640h | FS_3G_TMF_PM | Alcatel-Lucent | Rel-10 | SP-48 | Dionisio |  |  | 32.831 | PCG-25 |  |
| 1071 | 394 | Study on Policy and Charging Rules Function (PCRF) failure and restoration |  | 261d? | 2009-08-18 A | 2010-09-17 A | 100% | 2009-08-18 | 2010-09-17 | 261d? | finish no earlier than 2010-09-17 | C3 | 2088h | 2088h | FS_PCRF-FR | NEC | Rel-10 | CP-45 | Jiwan |  |  | 29.816 | PCG-23 |  |
| 1072 | 395 | Study on User Data Convergence (UDC) evolution |  | 206d? | 2010-06-04 A | 2011-03-18 A | 100% | 2010-06-04 | 2011-03-18 | 206d? | finish no earlier than 2011-03-18 | C4 | 1648h | 1648h | FS_UDCe | Alcatel-Lucent | Rel-10 | CP-48 | Kimmo |  |  | 23.845 | PCG-25 |  |
| 1073 | 396 | Study on UICC access to IMS |  | 206d? | 2010-06-04 A | 2011-03-18 A | 100% | 2010-06-04 | 2011-03-18 | 206d? | finish no earlier than 2011-03-18 | C6 | 1648h | 1648h | FS_IMS-UICC | Gemalto | Rel-10 | CP-48 | Xavier |  |  | 31.828 | PCG-25 |  |
| 1074 | 397 | Study on Uplink Tx Diversity for HSPA |  | 208.4d? | 2009-08-18 A | 2010-06-04 A | 100% | 2009-08-18 | 2010-06-04 | 208.4d? | finish no earlier than 2010-06-04 | R4 | 1667.2h | 1667.2h | FS_UL-TxDiv-HSPA | Qualcomm | Rel-10 | RP-45 | Issam |  |  | UTRA 25.863 | PCG-23 | RP-100499 |
| 1075 | 398 | Study on Solutions for Energy Saving within UTRA Node B |  | 206d? | 2009-12-04 A | 2010-09-17 A | 100% | 2009-12-04 | 2010-09-17 | 206d? | finish no earlier than 2010-09-17 | R1,R3 | 1648h | 1648h | FS_Energy_UMTS | Vodafone | Rel-10 | RP-46 | Patrick |  |  | UTRA 25.927 | PCG-24 | RP-100796 |
| 1076 | 399 | Study on Potential solutions for energy saving for E-UTRAN |  | 316d? | 2010-02-02 A | 2011-06-03 A | 100% | 2010-02-02 | 2011-06-03 | 316d? | finish no earlier than 2011-06-03 | R3,R2 | 2528h | 2528h | FS_Energy_LTE | China Mobile | Rel-10 | RP-47 | Juha |  |  | LTE 36.927 | PCG-24 | RP-110597 |
| 1077 | 400 | Study on Improvements of distributed antenna for 1.28Mcps TDD |  | 191d? | 2010-03-05 A | 2010-12-10 A | 100% | 2010-03-05 | 2010-12-10 | 191d? | finish no earlier than 2010-12-10 | R1,R2,R3 | 1528h | 1528h | FS_distr_ant_LCR_TDD | ZTE | Rel-10 | RP-47 | Patrick |  |  | UTRA 25.865 | PCG-24 | RP-101287 |
| 1078 | 401 | Deleted - Study on Unauthenticated PS Emergency Calls |  | 471d? | 2008-06-05 A | 2010-03-25 A | 100% | 2008-06-05 | 2010-03-25 | 471d? | finish no earlier than 2010-03-25 | S1 | 3768h | 3768h | FS_UAPSEC | Nokia Siemens Networks | Rel-10 | SP-40 | Alain | PCG-24 | SP-47 | 22.984 | PCG-21 |  |
| 1079 | 402 | Deleted - Study on enhancements to IMS border functions for IMS Interconnection of services |  | 586d? | 2008-09-18 A | 2010-12-15 A | 100% | 2008-09-18 | 2010-12-15 | 586d? | finish no earlier than 2010-12-15 | S2 | 4688h | 4688h | FS_eIMS_IBCF | Starent Networks | Rel-10 | SP-41 | Maurice | PCG-26 | SP-50 | 23.848 | PCG-21 |  |
| 1080 | 403 | Deleted - Study on EPC Charging enhancement |  | 211d? | 2009-06-04 A | 2010-03-25 A | 100% | 2009-06-04 | 2010-03-25 | 211d? | finish no earlier than 2010-03-25 | S5 | 1688h | 1688h | FS_EPCcharg | Nokia Siemens Networks | Rel-10 | SP-44 | Dionisio | PCG-24 | SP-47 |  | PCG-23 |  |
| 1081 | 404 | Deleted - Study on Interworking Proxy between GTP based and PMIP based interfaces |  | 186d? | 2009-09-18 A | 2010-06-04 A | 100% | 2009-09-18 | 2010-06-04 | 186d? | finish no earlier than 2010-06-04 | C4 | 1488h | 1488h | FS_GTP-MIP-IW | NTT DoCoMo | Rel-10 | CP-45 | Kimmo | PCG-25 | CP-48 | 29.875 | PCG-23 |  |
| 1082 | 405 | Release 9 Features | milestone | 0d? | 2008-06-05 A | 2008-06-05 A | 100% | 2008-06-05 | 2008-06-05 | 0d? |  | CP,GP,RP,SP |  |  |  |  | Rel-9 |  |  |  |  |  |  |  |

Notes:
- 1032: SP#35 Stage 1 completed. SP#45 Stage 2 work stopped. SP#46 work stopped/abandoned / Text5: tanakai@nttdocomo.co.jp
- 1033: SP#35 completed. SP#46 work stopped/abandoned / Text5: takakurat@s1.nttdocomo.co.jp
- 1034: SP#45 Stage 2 work stopped / Text5: tanakai@nttdocomo.co.jp
- 1035: SP#45 work stopped/abandoned / Text5: chris.friel@O2.com
- 1036: SP#45 work stopped/abandoned / Text5: chris.friel@O2.com
- 1037: SP#45 work stopped/abandoned / Text5: chris.friel@O2.com
- 1038: SP#47 work stopped (depending on ongoing related CT4 work). Stage 1 in UID_320022 Rel-8 Requirements for evolution of the 3GPP system architecture (AIPN-SAE): 22.278, 22.011, 22.246 / Text5: Haining Wang (wanghaining@huawei.com)
- 1039: SP#47 work stopped / Text5: Haining Wang (wanghaining@huawei.com)
- 1040: RP#47 work stopped/abandoned (no CR approved). Cell sets the TTI (Transmission Time Interval) to 2 ms / Text5: Karri Ranta-aho (karri.ranta-aho@nsn.com)
- 1041: SP#47 deleted (SA2 work moved under SA1 UID_450053). SP#44 Umbrella Feature created to host WIs moved out of Rel-9 (SA2 UID_420034 on IMS aspects of Architecture for Home NodeB) / Text5: Nicolas Drevon
- 1042: RP#52 work stopped (lack of contributions). Add new power classes in E-UTRAN UL to allow CPE type applications to be operated at higher max output power / Text5: zheng.zhao@verizonwireless.com
- 1043: RP#52 work stopped at 55% (lack of contributions) / Text5: zheng.zhao@verizonwireless.com
- 1044: RP#52 work stopped (lack of contributions) / Text5: zheng.zhao@verizonwireless.com
- 1045: RP#50 work stopped (RP-101266) / Text5: henrik.enbuske@ericsson.com
- 1046: RP#50 work stopped (RP-101266) / Text5: henrik.enbuske@ericsson.com
- 1047: RP#49 stopped (no further standardization needed). Ensure that Enhanced Interference Management methods identified in Rel-9 for HNBs do not fail in deployments with a large penetration of CSG-aware UEs / Text5: Andrei Radulescu (aradules@qualcomm.com)
- 1048: RP#49 stopped (no further standardization needed) / Text5: Andrei Radulescu (aradules@qualcomm.com)
- 1049: -
- 1050: SP#47 completed. TR 22.813-100 for Approval. Spin-off Feature UID_470030 Codec for Enhanced Voice Services / Text5: LOTTIN, Philippe
- 1051: SP#47 completed. TR 22.813-100 for Approval / Text5: LOTTIN, Philippe
- 1052: SP#47 completed. TR 22.813-100 for Approval / Text5: stefan.bruhn@ericson.com
- 1053: SP#46 completed. Linked to Rel-8 Feature UID_380060 IP Interconnection of Services (IPinterc). Spin-off Feature Rel-11 UID_470051 Advanced IP Interconnection of Services / Text5: chris.friel@O2.com
- 1054: SP#47 completed / Text5: Jaihyung Cho
- 1055: SP#47 completed / Text5: jinhan.song@sktelecom.com
- 1056: SP#47 completed. Covers Mobile/Fixed/Cordless/etc terminals. Haptic (human-machine tactile communication) extend service offering & richness of user experience beyond current visual & auditory senses / Text5: jinhan.song@sktelecom.com
- 1057: SP#46 completed. Spin-off Feature UID_460028 Optimal Media Routeing (OMR). Linked to Study on Multimedia Session Continuity UID_350051, Study on Centralized IMS Service Control UID_330012, IMS inter-operator service interconnection interface UID_360011 / Text5: mario.madella@telecomitalia.it, victor.kueh@bt.com
- 1058: SP#47 completed. Concluded no further normative work expected. Linked to 23.236 / Text5: LIU HONG (liuhongyfw@chinamobile.com)
- 1059: SP#49 completed (Conclusion: select the SIP anchoring based solution for normative work CR (TEI10) introducing and completing stage-2). Analyzed performance of Rel-8 SRVCC solution from E-UTRAN/HSPA to UTRAN/GERAN / Text5: Hou zhiqiang (houzhiqiang@chinamobile.com), Jiang Yi (jiangyi@chinamobile.com)
- 1060: SP#49 completed. TR 23.886v100 for Approval. Related to Rel-8 UID_350030 Single Radio Voice Call Continuity for 3GPP (SAES-SRVCC). Study how to provide Video Call seamless service continuity for 3G/LTE terminal user / Text5: Haris Zisimopoulos (haris.z@samsung.com)
- 1061: SP#48 completed. Triggered by Rel-8 UID_350027 SAE for support for non-3GPP accesses. Nature of relationship: S2b one of the interfaces defined for non-3GPP accesses support in EPS. Stage 1 in Rel-8 UID_320022 (AIPN-SAE) 22.278,22.101 / Text5: bruno.landais@alcatel-lucent.com
- 1062: SP#51 completed. Extend Rel-8 UID_34043 (Extending PSS and MBMS User Services for optimized Mobile TV) / Text5: jan.plogsties@iis.franhofer.de
- 1063: SP#51 completed. Extends Rel-9 Improved Video Support for PSS and MBMS (UID_430039) / Text5: imed.bouazizi@nokia.com, jaihyung@etri.re.kr
- 1064: SP#47 completed / Text5: shan.mingjun@huawei.com
- 1065: SP#47 completed. Study result might impact Feature UID_420011 Self Organising Networks (SON) / Text5: Jean-Michel Cornilly (Orange)
- 1066: SP#47 completed. TR 32.827 v100 for Information + Approval. WID updated SP-090462=>SP-100088. Study the missing Itf-N part in the Framework. Study changes to Itf-N to utilize UE based measurements / Text5: Yizhi Yao (yzyao@motorola.com)
- 1067: SP#51 completed / Text5: olaf.pollakowski@nsn.com
- 1068: SP#51 completed / Text5: olaf.pollakowski@nsn.com, Padma.Sudarsan@alcatel-lucent.com
- 1069: SP#51 completed / Text5: edwin.tse@ericsson.com
- 1070: SP#51 completed / Text5: Padma.Sudarsan@alcatel-lucent.com
- 1071: CP#49 completed / Text5: gottfried.punz@nw.neclab.eu
- 1072: CP#51 completed. Study UDC evolution from Features in Rel-9 UID_400034 and Rel-10 UID_480011 UDC Data Model / Text5: jean-jacques.trottin@alcatel-lucent.com
- 1073: CP#51 completed / Text5: Denis.Lheriteau@gemalto.com
- 1074: RP#48 completed / Text5: Heechoon Lee (heechoon@qualcomm.com)
- 1075: RP#49 completed. Based on ETSI EE TS 102 706. / Text5: Prakash.bhat@vodafone.com
- 1076: RP#52 completed / Text5: Yang Ning (yangning@chinamobile.com)
- 1077: RP#50 completed. TR 25.865 v101 for Approval / Text5: huang.he4@zte.com.cn
- 1078: SP#47 work stopped/abandoned / Text5: Juergen Merkel
- 1079: SP#50 work stopped. Additional work may be addressed as part of the Rel-11 Feature UID_470051 Advanced IP Interconnection of Services (IPXS) / Text5: Rajat Ghai (rghai@starentnetworks.com)
- 1080: SP#47 work stopped. Issue covered by Rel-10 UID_460039 Charging for LIPA_SIPTO and UID_4700xy Charging for IFOM / Text5: Gerald.Goermer@nsn.com
- 1081: CP#48 work stopped/abandoned / Text5: takaaki.matsuura.sp@s1.nttdocomo.com
- 1082: -

| ID | WBS | Task | Duration | Start | Finish | Complete | Baseline start | Baseline finish | Baseline duration | Constraint | Resources | Work | Actual work | Text1 | Text2 | Text4 | Text5 | Text6 | Text7 | Text8 | Text11 |
| --- | --- | --- | --- | --- | --- | --- | --- | --- | --- | --- | --- | --- | --- | --- | --- | --- | --- | --- | --- | --- | --- |
| 1083 | 406 | **Enhanced Home NodeB / eNodeB** | 921d? | 2008-06-05 A | 2011-12-09 A | 100% | 2008-06-05 | 2011-12-09 | 921d? |  | S1,S2,S3,S5,C1,C6,R2,R3,R4,R5,GP | 39456h | 39456h | EHNB | PCG-21 | T-Mobile | michael.kurz@t-mobile.at | Rel-9 | SP-40 | Alain |  |
| 1084 | 406.1 | Stage 1 for EHNB | 261d? | 2008-06-05 A | 2009-06-04 A | 100% | 2008-06-05 | 2009-06-04 | 261d? | finish no earlier than 2009-06-04 | S1 | 2088h | 2088h | EHNB | PCG-21 | T-Mobile | michael.kurz@t-mobile.at | Rel-9 | SP-40 | Alain |  |
| 1085 | 406.2 | Architecture aspects of EHNB | 266d? | 2008-09-18 A | 2009-09-24 A | 100% | 2008-09-18 | 2009-09-24 | 266d? | finish no earlier than 2009-09-22 | S2 | 2128h | 2128h | EHNB | PCG-21 | T-Mobile | sebastian.speicher@telekom.de | Rel-9 | SP-41 | Maurice |  |
| 1086 | 406.3 | Security aspects of Enhanced Home NodeB / eNodeB | 262d? | 2008-12-11 A | 2009-12-10 A | 100% | 2008-12-11 | 2009-12-10 | 262d? | finish no earlier than 2009-12-10 | S3 | 2096h | 2096h | EHNB-Sec | PCG-22 | Huawei | Marcus Wong (mwong@huawei.com) | Rel-9 | SP-42 | Dionisio |  |
| 1087 | 406.4 | CT1 aspects - Support of Home NB and Home eNB enhancements | 321d? | 2009-09-18 A | 2010-12-10 A | 100% | 2009-09-18 | 2010-12-10 | 321d? | finish no earlier than 2010-12-10 | C1 | 2568h | 2568h | EHNB-CT1 | PCG-23 | Qualcomm | Ramachandran Subramanian (rsubrama@qualcomm.com) | Rel-9 | CP-45 | Frederic |  |
| 1088 | 406.5 | CT6 aspects - Support of Home NB and Home eNB enhancements | 131d? | 2009-09-18 A | 2010-03-19 A | 100% | 2009-09-18 | 2010-03-19 | 131d? | finish no earlier than 2010-03-19 | C6 | 1048h | 1048h | EHNB-CT6 | PCG-23 | Qualcomm | Ramachandran Subramanian (rsubrama@qualcomm.com) | Rel-9 | CP-45 | Xavier |  |
| 1089 | 406.6 | 3G HNB Gateway and LTE HeNB Gateway OAM&P | 336d? | 2008-12-11 A | 2010-03-25 A | 100% | 2008-12-11 | 2010-03-25 | 336d? | finish no earlier than 2010-03-25 | S5 | 2688h | 2688h | HNB-OAM_GW | PCG-22 | China Mobile | GangChen (chengang@chinamobile.com) | Rel-9 | SP-42 | Dionisio |  |
| 1090 | 406.7 | 3G HNB and LTE HeNB OAM&P Type 1 Interface | 272d? | 2009-03-12 A | 2010-03-25 A | 100% | 2009-03-12 | 2010-03-25 | 272d? | finish no earlier than 2010-03-25 | S5 | 2168h | 2168h | HNB_eHNB-OAM_Type1 | PCG-22 | Huawei | Zou Lan (zlan@huawei.com) | Rel-9 | SP-43 | Dionisio |  |
| 1091 | 406.8 | 3G HNB and LTE HeNB OAM&P Type 2 Interface | 225d? | 2009-05-15 A | 2010-03-25 A | 100% | 2009-05-15 | 2010-03-25 | 225d? | finish no earlier than 2010-03-25 | S5 | 1800h | 1800h | HNB_eHNB-OAM_Type2 | PCG-23 | Ericsson | edwin.tse@ericsson.com | Rel-9 | SP-44 | Dionisio |  |
| 1092 | 406.9 | LTE FDD Home eNodeB RF Requirements | 336d? | 2008-12-05 A | 2010-03-19 A | 100% | 2008-12-05 | 2010-03-19 | 336d? | finish no earlier than 2010-03-19 | R4 | 2688h | 2688h | HeNB-RF_FDD | PCG-22 | Motorola | Ying Cai (yingcai@motorola.com) | Rel-9 | RP-42 | Issam | RP-100035 |
| 1093 | 406.10 | LTE TDD Home eNodeB RF Requirements | 271d? | 2009-03-06 A | 2010-03-19 A | 100% | 2009-03-06 | 2010-03-19 | 271d? | finish no earlier than 2010-03-19 | R4 | 2168h | 2168h | HeNB-RF_TDD | PCG-22 | China Mobile | Nan Li (linan@chinamobile.com) | Rel-9 | RP-43 | Issam | RP-100036 |
| 1094 | 406.11 | Home NB and Home eNB enhancements - RAN3 aspects | 197d? | 2009-03-06 A | 2009-12-04 A | 100% | 2009-03-06 | 2009-12-04 | 197d? | finish no earlier than 2009-12-04 | R3 | 1576h | 1576h | EHNB-RAN3 | PCG-22 | Alcatel-Lucent | Martin Warner (mw15@alcatel-lucent.com) | Rel-9 | RP-43 | Juha | RP-091050 |
| 1095 | 406.12 | Home NB and Home eNB enhancements - RAN2 aspects | 271d? | 2009-03-06 A | 2010-03-19 A | 100% | 2009-03-06 | 2010-03-19 | 271d? | finish no earlier than 2010-03-19 | R2 | 2168h | 2168h | EHNB-RAN2 | PCG-22 | Huawei | Yang Xudong (yangxudong@huawei.com) | Rel-9 | RP-43 | Joern | RP-100037 |
| 1096 | 406.13 | Conformance Test Aspects – Home NB enhancements for FDD | 322d? | 2010-09-17 A | 2011-12-09 A | 100% | 2010-09-17 | 2011-12-09 | 322d? | finish no earlier than 2011-12-09 | R5 | 2568h | 2568h | EHNB-UTRA_FDD_UEConTest | PCG-25 | Huawei | trica_li@huawei.com | Rel-9 | RP-49 | Ingbert | RP-111679 |
| 1097 | 406.14 | Conformance Test Aspects – Home eNB enhancements | 201d? | 2010-12-10 A | 2011-09-16 A | 100% | 2010-12-10 | 2011-09-16 | 201d? | finish no earlier than 2011-09-16 | R5 | 1608h | 1608h | EHNB-LTE_UEConTest | PCG-26 | Qualcomm | Mrs Lena Chaponniere (lchaponn@qualcomm.com) | Rel-9 | RP-50 | Ingbert | RP-110972 |
| 1098 | 406.15 | Home NB and Home eNB enhancements - GERAN aspects | 341d? | 2009-05-18 A | 2010-09-03 A | 100% | 2009-05-18 | 2010-09-03 | 341d? | finish no earlier than 2010-09-03 | GP | 2728h | 2728h | EHNB-GERAN | PCG-23 | Nokia Siemens Networks | leonardo.provvedi@roke.co.uk | Rel-9 | GP-42 | Paolo |  |
| 1099 | 407 | **Value-Added Services for Short Message Service** | 586d? | 2007-09-10 A | 2009-12-04 A | 100% | 2007-09-10 | 2009-12-04 | 586d? |  | S1,C4,C1 | 10888h | 10888h | VAS4SMS |  | China Mobile | Wu Bin (wubin@chinamobile.com) | Rel-9 | SP-37 | Alain |  |
| 1100 | 407.1 | Stage 1 for VAS4SMS | 133d? | 2007-09-10 A | 2008-03-12 A | 100% | 2007-09-10 | 2008-03-12 | 133d? | finish no earlier than 2008-03-21 | S1 | 1064h | 1064h | VAS4SMS |  | China Mobile | Wu Bin (wubin@chinamobile.com) | Rel-9 | SP-37 | Alain |  |
| 1101 | 407.2 | CT4 aspects of VAS4SMS Interface and Signalling Flow | 322d? | 2008-09-12 A | 2009-12-04 A | 100% | 2008-09-12 | 2009-12-04 | 322d? | finish no earlier than 2009-12-04 | C4 | 2568h | 2568h | VAS4SMS | PCG-21 | China Mobile | Wu Bin (wubin@chinamobile.com) | Rel-9 | CP-41 | Kimmo |  |
| 1102 | 407.3 | CT1 aspects of VAS4SMS Interface and Signalling Flow | 321d? | 2008-09-09 A | 2009-12-04 A | 100% | 2008-09-09 | 2009-12-04 | 321d? | finish no earlier than 2009-12-04 | C1 | 2568h | 2568h | VAS4SMS | PCG-21 | China Mobile | Wu Bin (wubin@chinamobile.com) | Rel-9 | CP-41 | Frederic |  |
| 1103 | 408 | **Definition of End-User Identity** | 334d? | 2007-09-03 A | 2008-12-11 A | 100% | 2007-09-03 | 2008-12-11 | 334d? |  | S1 | 5344h | 5344h | EUI |  | Nokia Siemens Networks | Juergen.Merkel@nsn.com | Rel-9 | SP-38 | Alain |  |
| 1104 | 408.1 | Stage 1 for Definition of End-User Identity | 334d? | 2007-09-03 A | 2008-12-11 A | 100% | 2007-09-03 | 2008-12-11 | 334d? | finish no earlier than 2008-12-11 | S1 | 2672h | 2672h | EUI | PCG-21 | Nokia Siemens Networks | Juergen.Merkel@NSN.com | Rel-9 | SP-38 | Alain |  |
| 1105 | 409 | **Customized Ringing Signal** | 522d? | 2007-12-06 A | 2009-12-03 A | 100% | 2007-12-06 | 2009-12-03 | 522d? |  | S1,C1 | 7120h | 7120h | CRS | PCG-21 | SK Telecom, China Mobile | Donghee Shim (SK Telecom), Jianping Zheng (China Mobile) | Rel-9 | SP-38 | Alain |  |
| 1106 | 409.1 | Stage 1 for Customized Ringing Signal | 266d? | 2007-12-06 A | 2008-12-11 A | 100% | 2007-12-06 | 2008-12-11 | 266d? | finish no earlier than 2008-12-11 | S1 | 2128h | 2128h | CRS | PCG-21 | SK Telecom, China Mobile | Donghee Shim (SK Telecom), Jianping Zheng (China Mobile) | Rel-9 | SP-38 | Alain |  |
| 1107 | 409.2 | Stage 3 for IMS Customized Ringing Signal (CRS) Service | 136d? | 2009-05-29 A | 2009-12-03 A | 100% | 2009-05-29 | 2009-12-03 | 136d? | finish no earlier than 2010-06-04 | C1 | 816h | 816h | CRS | PCG-23 | China Mobile | wangzhao | Rel-9 | CP-44 | Frederic |  |

Notes:
- 1083: RP#54 Testing completed / Text3: UTRA, LTE
- 1084: CP#49 the SA1-reqs are moving. CT1 will align when the work in SA1 is clear. (was SP#44 completed.) / Text3: 22.220, 22.011
- 1085: SP#45 completed / Text3: 23.401, 23.402, 23.060, new 23.830
- 1086: SP#46 completed / Text3: new 33.320
- 1087: CP#50 completed (Roaming aspects for manual CSG selection, Support of temporary users and CSG membership changes, Support of user controlled and operator controlled lists) / Text3: 23.122, 24.008, 24.285, 24.301
- 1088: CP#47 completed. Storing of CSG related data items on the USIM / Text3: 31.102
- 1089: SP#47 completed / Text3: 32.632, 32.633, 32.635, new (32.771, 32.772, 32.773, 32.775, 32.781, 32.782, 32.783, 32.785)
- 1090: SP#47 completed / Text3: 32.581, 32.582, 32.583, 32.584, new (32.591, 32.592, 32.593, 32.594)
- 1091: SP#47 completed / Text3: new (32.571, 32.572)
- 1092: RP#47 completed / Text3: 36.104, 36.141, new TR 36.921
- 1093: RP#47 completed / Text3: 36.104, 36.141, 36.300, 36.331, 36.413, new TR 36.922
- 1094: RP#46 completed (based on high priority items specified in RP-090995) / Text3: 25.413, 25.467, 25.467, 25.468, 25.469, 25.469, 36.401, 36.413, new 25.444
- 1095: RP#47 completed / Text3: 25.304, 25.331, 25.367, 36.300, 36.304, 36.331
- 1096: UTRA. RP#54 completed. Testing for UID_430026 Support of Home NB and Home eNB enhancements RAN2 aspects (25.304, 25.331, 25.367) / Text3: 34.108, 34.121-1, 34.121-2, 34.123-1, 34.123-2, 34.123-3
- 1097: RP#53 completed / Text3: 36.508, 36.523-1, 36.523-2, 36.523-3
- 1098: GP#47 completed. GP#42 WID approved / Text3: 43.055, 43.129, 44.018, 44.060, 45.008, 48.008, 48.018
- 1099: CP#46 completed
- 1100: SP#39 completed. SP#43 Feature moved to Rel-9 / Text3: new 22.142
- 1101: CP#46 completed / Text3: new 23.142
- 1102: CP#46 completed / Text3: 23.040
- 1103: SP#42 closed. Stage 1 work closed at 5% completion due to lack of input (added only the EUI definition in 21.905)
- 1104: SP#42 closed. Stage 1 work closed at 5% completion due to lack of input (added only the EUI definition in 21.905) / Text3: 21.905
- 1105: CP#48 completed
- 1106: SP#42 completed. / Text3: 22.173, new 22.183
- 1107: CP#48 completed / Text3: 24.173, new 24.183

| ID | WBS | Task | Type | Duration | Start | Finish | Complete | Remaining | Baseline start | Baseline finish | Baseline duration | Total slack | Constraint | Resources | Work | Actual work | Text1 | Text2 | Text3 | Text4 | Text6 | Text7 | Text8 | Text11 |
| --- | --- | --- | --- | --- | --- | --- | --- | --- | --- | --- | --- | --- | --- | --- | --- | --- | --- | --- | --- | --- | --- | --- | --- | --- |
| 1108 | 410 | **Public Warning System** |  | 1313d? | 2007-12-06 A | 2012-12-07 | 98% | 19.71d? | 2007-12-06 | 2012-12-07 | 1313d? | 463d |  | S1,C1,C4,R2,R3,R5 | 18680h | 10197.6h | PWS | PCG-21 | LTE | T-Mobile | Rel-9 | SP-38 | Alain |  |
| 1109 | 410.1 | Stage 1 for Public Warning System |  | 266d? | 2007-12-06 A | 2008-12-11 A | 100% |  | 2007-12-06 | 2008-12-11 | 266d? |  | finish no earlier than 2008-12-11 | S1 | 2128h | 2128h | PWS | PCG-21 | 22.268 | T-Mobile | Rel-9 | SP-38 | Alain |  |
| 1110 | 410.2 | **Stage 3 for Public Warning System** |  | 137d? | 2009-05-29 A | 2009-12-04 A | 100% |  | 2009-05-29 | 2009-12-04 | 137d? |  |  | C1,C4 | 3272h | 3272h | PWS-St3 | PCG-23 |  | Qualcomm | Rel-9 | CP-44 | Frederic |  |
| 1111 | 410.2.1 | CT1 aspects of Stage 3 for Public Warning System |  | 137d? | 2009-05-29 A | 2009-12-04 A | 100% |  | 2009-05-29 | 2009-12-04 | 137d? |  | finish no earlier than 2009-12-04 | C1 | 1088h | 1088h | PWS-St3 | PCG-23 | 23.041 | Qualcomm | Rel-9 | CP-44 | Frederic |  |
| 1112 | 410.2.2 | CT4 aspects of Stage 3 for Public Warning System |  | 136d? | 2009-05-30 A | 2009-12-04 A | 100% |  | 2009-05-30 | 2009-12-04 | 136d? |  | finish no earlier than 2009-12-04 | C4 | 1088h | 1088h | PWS-St3 | PCG-23 | 29.168 | Qualcomm | Rel-9 | CP-44 | Kimmo |  |
| 1113 | 410.3 | Public Warning System (PWS) – RAN aspects |  | 81d? | 2009-05-30 A | 2009-12-04 A | 100% |  | 2009-05-30 | 2009-12-04 | 81d? |  | finish no earlier than 2009-12-04 | R2,R3 | 648h | 648h | PWS-RAN | PCG-23 | LTE 36.300, 36.302, 36.331, 36.413 | AT&T | Rel-9 | RP-44 | Joern | RP-091052 |
| 1114 | 410.4 | Conformance Test Aspects – Public Warning System (PWS) – RAN aspects for LTE |  | 266d? | 2011-12-02 A | 2012-12-07 | 95% | 13.3d? | 2011-12-02 | 2012-12-07 | 266d? | 463d | finish no earlier than 2012-12-07 | R5 | 2128h | 2021.6h | PWS-RAN_UEConTest | PCG-28 | 36.508, 36.523-1, 36.523-2, 36.523-3 | Qualcomm | Rel-9 | RP-54 |  | RP-120955 |
| 1115 | 411 | **Support of Personal Area Networks and Enhancements to Personal Network Management** |  | 523d? | 2008-06-05 A | 2010-06-04 A | 100% |  | 2008-06-05 | 2010-06-04 | 523d? |  |  | S1,C1 | 8360h | 8360h | PAN_EPNM | PCG-21 |  | Vodafone | Rel-9 | SP-40 | Alain |  |
| 1116 | 411.1 | Stage 1 for Support of Personal Area Networks and Enhancements to Personal Network Management | milestone | 0d? | 2008-06-05 A | 2008-06-05 A | 100% |  | 2008-06-05 | 2008-06-05 | 0d? |  | finish no earlier than 2008-06-05 | S1 |  |  | PAN_EPNM | PCG-21 | 22.259 | Vodafone | Rel-9 | SP-40 | Alain |  |
| 1117 | 411.2 | Stage 2 for Support of Personal Area Networks and Enhancements to Personal Network Management |  | 196d? | 2009-03-06 A | 2009-12-04 A | 100% |  | 2009-03-06 | 2009-12-04 | 196d? |  | finish no earlier than 2009-12-04 | C1 | 1568h | 1568h | PAN_EPNM | PCG-22 | 23.259 | Huawei | Rel-9 | CP-43 | Frederic |  |
| 1118 | 411.3 | Stage 3 for Support of Personal Area Networks and Enhancements to Personal Network Management |  | 326d? | 2009-03-09 A | 2010-06-04 A | 100% |  | 2009-03-09 | 2010-06-04 | 326d? |  | finish no earlier than 2010-06-04 | C1 | 2608h | 2608h | PAN_EPNM | PCG-22 | 24.259 | Huawei | Rel-9 | CP-43 | Frederic |  |
| 1119 | 412 | **Multi-Media Telephony Service enhancements** |  | 472d? | 2008-06-05 A | 2010-03-25 A | 100% |  | 2008-06-05 | 2010-03-25 | 472d? |  |  | S1,S5,C1 | 10288h | 10288h | eMMTel | PCG-21 |  | France Telecom | Rel-9 | SP-40 | Alain |  |
| 1120 | 412.1 | Stage 1 for eMMTel |  | 136d? | 2008-06-05 A | 2008-12-11 A | 100% |  | 2008-06-05 | 2008-12-11 | 136d? |  | start no earlier than 2008-06-05 | S1 | 1088h | 1088h | eMMTel | PCG-21 | 22.173 | France Telecom | Rel-9 | SP-40 | Alain |  |
| 1121 | 412.2 | Multimedia Telephony (MMTel) Service and Supplementary Services - Online Charging and completion for Offline Charging (all supplementary services) |  | 272d? | 2009-03-12 A | 2010-03-25 A | 100% |  | 2009-03-12 | 2010-03-25 | 272d? |  | finish no earlier than 2010-03-25 | S5 | 2168h | 2168h | eMMTel-SS-CH | PCG-22 | 32.275, 32.298, 32.299 | Alcatel-Lucent | Rel-9 | SP-43 | Dionisio |  |
| 1122 | 412.3 | Support of Real-time Transfer of Tariff Information (RTTI) in IMS charging |  | 271d? | 2009-03-12 A | 2010-03-25 A | 100% |  | 2009-03-12 | 2010-03-25 | 271d? |  | finish no earlier than 2010-03-25 | S5 | 2168h | 2168h | IMSTSS-RTTI-CH | PCG-22 | 32.240, 32.280, 32.298, 32.299 | Orange | Rel-9 | SP-43 | Dionisio |  |
| 1123 | 412.4 | Stage 3 - Enhancements for Completion of Communications Supplementary service |  | 136d? | 2009-05-30 A | 2009-12-04 A | 100% |  | 2009-05-30 | 2009-12-04 | 136d? |  | finish no earlier than 2009-12-04 | C1 | 1088h | 1088h | eMMTel-CC | PCG-23 | 24.642 | France Telecom | Rel-9 | CP-44 | Frederic |  |
| 1124 | 413 | **User Data Convergence (UDC)** |  | 527d? | 2008-06-05 A | 2010-06-10 A | 100% |  | 2008-06-05 | 2010-06-10 | 527d? |  |  | S1,S5,C4 | 14456h | 14456h | UDC | PCG-21 |  | Nokia Siemens Networks | Rel-9 | SP-40 | Alain |  |
| 1125 | 413.1 | Stage 1 for User Data Convergence (UDC) |  | 136d? | 2008-06-05 A | 2008-12-11 A | 100% |  | 2008-06-05 | 2008-12-11 | 136d? |  | start no earlier than 2008-06-05 | S1 | 1088h | 1088h | UDC | PCG-21 | 22.101, new 22.985 | Nokia Siemens Networks | Rel-9 | SP-40 | Alain |  |
| 1126 | 413.2 | User Data Convergence (UDC) Technical Realization (Stage 2) |  | 271d? | 2009-03-06 A | 2010-03-19 A | 100% |  | 2009-03-06 | 2010-03-19 | 271d? |  | finish no earlier than 2010-03-19 | C4 | 2168h | 2168h | UDC-CN | PCG-22 | new 23.335 | Ericsson | Rel-9 | CP-43 | Kimmo |  |
| 1127 | 413.3 | User Data Convergence (UDC) Protocol Description |  | 130d? | 2009-09-18 A | 2010-03-19 A | 100% |  | 2009-09-18 | 2010-03-19 | 130d? |  | finish no earlier than 2010-03-19 | C4 | 1040h | 1040h | UDC-CN | PCG-23 | new 29.335 | China Mobile, Ericsson | Rel-9 | CP-45 | Kimmo |  |
| 1128 | 413.4 | **User Data Convergence (UDC) Modelling and Management** |  | 266d? | 2009-06-04 A | 2010-06-10 A | 100% |  | 2009-06-04 | 2010-06-10 | 266d? |  |  | S5 | 5944h | 5944h | UDC-MMAN | PCG-23 |  | T-Mobile, China Mobile, Ericsson | Rel-9 | SP-44 | Dionisio |  |
| 1129 | 413.4.1 | UDC – Framework for Model Handling and Management |  | 266d? | 2009-06-04 A | 2010-06-10 A | 100% |  | 2009-06-04 | 2010-06-10 | 266d? |  | finish no earlier than 2010-06-10 | S5 | 2128h | 2128h | UDC-MMAN-MFRM | PCG-23 | 32.172, new 32.181 | T-Mobile | Rel-9 | SP-44 | Dionisio |  |
| 1130 | 413.4.2 | UDC – Common Baseline Information Model |  | 211d? | 2009-06-04 A | 2010-03-25 A | 100% |  | 2009-06-04 | 2010-03-25 | 211d? |  | finish no earlier than 2010-03-25 | S5 | 1688h | 1688h | UDC-MMAN-CBIM | PCG-23 | 32.172, new 32.182 | China Mobile, Ericsson | Rel-9 | SP-44 | Dionisio |  |
| 1131 | 414 | **IMS Services Centralization and Continuity** |  | 393d? | 2008-09-18 A | 2010-03-19 A | 100% |  | 2008-09-18 | 2010-03-19 | 393d? |  |  | S1,S2,C1 | 12160h | 12160h | IMS_SCC | PCG-21 |  | NEC | Rel-9 | SP-41 | Alain |  |
| 1132 | 414.1 | Stage 1 - Inter-Device Transfer – Requirements |  | 61d? | 2008-09-18 A | 2008-12-11 A | 100% |  | 2008-09-18 | 2008-12-11 | 61d? |  | finish no earlier than 2009-06-18 | S1 | 488h | 488h | IMS_SCC-IDT | PCG-21 | 22.101, 22.228 | NEC | Rel-9 | SP-41 | Alain |  |
| 1133 | 414.2 | Stage 2 - IMS Service Continuity Enhancements: Service, Policy and Interactions |  | 186d? | 2008-09-18 A | 2009-06-04 A | 100% |  | 2008-09-18 | 2009-06-04 | 186d? |  | finish no earlier than 2009-06-04 | S2 | 1488h | 1488h | IMS_SCC-SPI | PCG-21 | 23.237, 23.292, 23.216, new 23.838 | Huawei | Rel-9 | SP-41 | Maurice |  |
| 1134 | 414.3 | Stage 3 - IMS Service Continuity Enhancements: Service, Policy, Interactions and Inter UE Transfer |  | 212d? | 2009-05-29 A | 2010-03-19 A | 100% |  | 2009-05-29 | 2010-03-19 | 212d? |  | finish no earlier than 2010-03-19 | C1 | 1696h | 1696h | IMS_SCC-SPI | PCG-23 | 24.216, 24.229, 24.237 | Qualcomm | Rel-9 | CP-44 | Frederic |  |
| 1135 | 414.4 | Stage 2 - IMS Centralized Services |  | 186d? | 2008-09-18 A | 2009-06-04 A | 100% |  | 2008-09-18 | 2009-06-04 | 186d? |  | finish no earlier than 2009-06-04 | S2 | 1488h | 1488h | IMS_SCC-ICS | PCG-21 | 23.292, new 23.883 | Alcatel-Lucent | Rel-9 | SP-41 | Maurice |  |
| 1136 | 414.5 | Stage 3 - Enhancements to IMS Centralized Services |  | 212d? | 2009-05-29 A | 2010-03-19 A | 100% |  | 2009-05-29 | 2010-03-19 | 212d? |  | finish no earlier than 2010-03-19 | C1 | 1688h | 1688h | IMS_SCC-ICS | PCG-23 | 24.292, 24.604, 24.607, 24.608, 24.611, 24.623 | Nokia Siemens Networks | Rel-9 | CP-44 | Frederic |  |
| 1137 | 414.6 | Stage 3 - IMS Centralized Services support via I1 interface |  | 271d? | 2009-03-06 A | 2010-03-19 A | 100% |  | 2009-03-06 | 2010-03-19 | 271d? |  | finish no earlier than 2010-03-19 | C1 | 2168h | 2168h | IMS_SCC-ICS_I1 | PCG-22 | 24.237, 24.292, new 24.294 | Huawei | Rel-9 | CP-43 | Frederic |  |

Notes:
- 1108: TSG#46 completed. Larger scope than Rel-8 Feature UID_370051 (ETWS). Triggered by TR 22.968 Study UID_320025 (FS_PWS) / Text5: Mark.Younge@t-mobile.com
- 1109: SP#42 completed / Text5: Mark.Younge@t-mobile.com
- 1110: RP#46 completed / Text5: Ramachandran Subramanian (rsubrama@qualcomm.com)
- 1111: CP#46 completed / Text5: Ramachandran Subramanian (rsubrama@qualcomm.com)
- 1112: CP#46 completed / Text5: Ramachandran Subramanian (rsubrama@qualcomm.com)
- 1113: RP#46 completed / Text5: don.zelmer@att.com
- 1114: - / Text5: Shubhang Vora (svora@qualcomm.com)
- 1115: CP#48 completed / Text5: armin.toepfer@vodafone.com
- 1116: SP#40 completed / Text5: armin.toepfer@vodafone.com
- 1117: CP#46 completed / Text5: Lili Yang (kadyyang@huawei.com)
- 1118: CP#48 completed / Text5: Lili Yang (kadyyang@huawei.com)
- 1119: SP#47 completed / Text5: Philippe Lottin
- 1120: SP#42 completed / Text5: Philippe Lottin
- 1121: SA#47 completed / Text5: maryse.gardella@alcatel-lucent.com
- 1122: SA#47 completed. Linked to SA5 Rel-8 UID_380042 AoC support in IMS Charging (IMSTSS) / Text5: Jean-Luc Garcia (jl.garcia@orange-ftgroup.com)
- 1123: CP#46 completed / Text5: Youssef.chadli@orange-ftgroup.com
- 1124: SP#48 completed. Triggered by Rel-8 SA5 Study of Common Profile Storage Framework of User Data for network services and management (UID_320006) TR 32.808 / Text5: juergen.merkel@nsn.com
- 1125: SP#42 completed / Text5: juergen.merkel@nsn.com
- 1126: CP#47 completed / Text5: emiliano.merino@ericsson.com
- 1127: CP#47 completed / Text5: Lan Si Zhong (lansizhong@chinamobile.com), emiliano.merino@ericsson.com
- 1128: SP#48 completed / Text5: istvan.aba@t-mobile.at, lansizhong@chinamobile.com, miguel.a.garcia@ericsson.com
- 1129: SP#48 completed / Text5: istvan.aba@t-mobile.at
- 1130: SP#47 completed / Text5: Lan Si Zhong, Miguel Garcia
- 1131: CP#47 completed / Text5: Joerg Swetina (joerg.swetina@nw.neclab.eu)
- 1132: SP#42 completed / Text5: Joerg Swetina (joerg.swetina@nw.neclab.eu)
- 1133: SP#57 Removal of the MSC server assisted mid-call feature from Rel-9 by 23.237CR#0433 (CT1 proposed moving this feature to Rel-10). SP#44 completed. TR 23.838 for Approval / Text5: HengLiang Zhang (hl_zhang@huawei.com)
- 1134: CP#47 completed / Text5: Roozbeh Atarius (ratarius@qualcomm.com)
- 1135: SP#44 completed. TR 23.883 for Information + Approval / Text5: andy.bennett@alcatel-lucent.com
- 1136: CP#47 completed / Text5: Peter.Leis@nsn.com
- 1137: CP#47 completed / Text5: Lili Yang(kadyyang@huawei.com)

| ID | WBS | Task | Duration | Start | Finish | Complete | Remaining | Baseline start | Baseline finish | Baseline duration | Total slack | Constraint | Resources | Work | Actual work | Text1 | Text2 | Text4 | Text5 | Text6 | Text7 | Text8 | Text11 |
| --- | --- | --- | --- | --- | --- | --- | --- | --- | --- | --- | --- | --- | --- | --- | --- | --- | --- | --- | --- | --- | --- | --- | --- |
| 1138 | 415 | **Service Specific Access Control in EPS** | 922d? | 2008-12-11 A | 2012-06-15 A | 100% |  | 2008-12-11 | 2012-06-15 | 922d? |  |  | S1,C1,R5 | 11240h | 11240h | SSAC | PCG-22 | NTT DoCoMo | Frederic Thepot (thepot@docomolab-euro.com) | Rel-9 | SP-42 | Alain |  |
| 1139 | 415.1 | Stage 1 for Service Specific Access Control in EPS | 1d? | 2008-12-11 A | 2008-12-11 A | 100% |  | 2008-12-11 | 2008-12-11 | 1d? |  | start no earlier than 2008-12-11 | S1 | 8h | 8h | SSAC | PCG-22 | NTT DoCoMo | Frederic Thepot (thepot@docomolab-euro.com) | Rel-9 | SP-42 | Alain |  |
| 1140 | 415.2 | Stage 3 for Service Specific Access Control in EPS | 212d? | 2009-05-29 A | 2010-03-19 A | 100% |  | 2009-05-29 | 2010-03-19 | 212d? |  | finish no earlier than 2010-03-19 | C1 | 1696h | 1696h | SSAC | PCG-23 | NTT DoCoMo | Hideyuki Yamashita (yamashitahi@s1.nttdocomo.co.jp) | Rel-9 | CP-44 | Frederic |  |
| 1141 | 415.3 | Conformance Test Aspects - Service Specific Access Control | 272d? | 2011-06-07 A | 2012-06-15 A | 100% |  | 2011-06-07 | 2012-06-15 | 272d? |  | finish no earlier than 2012-06-15 | R5 | 2168h | 2168h | SSAC_UEConTest | PCG-27 | NTT DoCoMo | Takao.Shimizu.rp@nttdocomo.com | Rel-9 | RP-52 | Ingbert | RP-120447 |
| 1142 | 416 | **Support for IMS Emergency Calls over GPRS and EPS** | 1286d? | 2008-01-14 A | 2012-12-07 | 99% | 17.34d? | 2008-01-14 | 2012-12-07 | 1286d? | 463d |  | S1,S2,S3,C1,C3,C4,R2,R3,R5,IETF | 57875.7h | 56215.2h | IMS_EMER_GPRS_EPS | PCG-21 | Alcatel-Lucent | Deborah Barclay | Rel-9 | SP-38 | Maurice |  |
| 1143 | 416.1 | Stage 1 for IMS Emergency Calls over GPRS and EPS | 239d? | 2008-01-14 A | 2008-12-11 A | 100% |  | 2008-01-14 | 2008-12-11 | 239d? |  | finish no earlier than 2008-12-11 | S1 | 1912h | 1912h | IMS_EMER_GPRS_EPS | PCG-21 | Alcatel-Lucent | Deborah Barclay | Rel-9 | SP-38 | Alain |  |
| 1144 | 416.2 | Stage 2 for IMS Emergency Calls over GPRS and EPS | 364d? | 2008-01-14 A | 2009-06-04 A | 100% |  | 2008-01-14 | 2009-06-04 | 364d? |  | finish no earlier than 2009-06-04 | S2 | 2912h | 2912h | IMS_EMER_GPRS_EPS | PCG-21 | Alcatel-Lucent | Deborah Barclay | Rel-9 | SP-38 | Maurice |  |
| 1145 | 416.3 | Security aspects for IMS Emergency Calls over GPRS and EPS | 391d? | 2008-12-12 A | 2010-06-10 A | 100% |  | 2008-12-12 | 2010-06-10 | 391d? |  | finish no earlier than 2010-03-25 | S3 | 3128h | 3128h | IMS_EMER_GPRS_EPS-Sec | PCG-22 | Alcatel-Lucent | Deborah Barclay | Rel-9 | SP-42 | Dionisio |  |
| 1146 | 416.4 | **Stage 3 for IMS Emergency Calls over GPRS and EPS** | 801d? | 2009-05-29 A | 2012-06-15 A | 100% |  | 2009-05-29 | 2012-06-15 | 801d? |  |  | C1,C3,C4,R5 | 14107.7h | 14107.7h | IMS_EMER_GPRS_EPS | PCG-23 | Alcatel-Lucent | Frank Alfano (falfano@alcatel-lucent.com) | Rel-9 | CP-44 | Frederic |  |
| 1147 | 416.4.1 | CT1 aspects - Stage 3 for IMS Emergency Calls over GPRS and EPS | 212d? | 2009-05-29 A | 2010-03-19 A | 100% |  | 2009-05-29 | 2010-03-19 | 212d? |  | finish no earlier than 2010-03-19 | C1 | 1696h | 1696h | IMS_EMER_GPRS_EPS | PCG-23 | Alcatel-Lucent | Frank Alfano (falfano@alcatel-lucent.com) | Rel-9 | CP-44 | Frederic |  |
| 1148 | 416.4.2 | Conformance Test Aspects - CT1 aspects for IMS Emergency Calls over GPRS and EPS | 532d? | 2010-06-04 A | 2012-06-15 A | 100% |  | 2010-06-04 | 2012-06-15 | 532d? |  | finish no earlier than 2012-06-15 | R5 | 4256h | 4256h | IMS_EMER_GPRS_EPS_UEConTest | PCG-25 | Samsung | stoyan.baev@partner.samsung.com | Rel-9 | RP-48 | Ingbert | RP-120445 |
| 1149 | 416.4.3 | CT3 aspects - Stage 3 for IMS Emergency Calls over GPRS and EPS | 82d? | 2009-05-29 A | 2009-09-18 A | 100% |  | 2009-05-29 | 2009-09-18 | 82d? |  | start no earlier than 2009-05-29 | C3 | 651.68h | 651.68h | IMS_EMER_GPRS_EPS | PCG-23 | Alcatel-Lucent | Frank Alfano (falfano@alcatel-lucent.com) | Rel-9 | CP-44 | Jiwan |  |
| 1150 | 416.4.4 | CT4 aspects - Stage 3 for IMS Emergency Calls over GPRS and EPS | 137d? | 2009-05-29 A | 2009-12-04 A | 100% |  | 2009-05-29 | 2009-12-04 | 137d? |  | finish no earlier than 2009-12-04 | C4 | 1096h | 1096h | IMS_EMER_GPRS_EPS | PCG-23 | Alcatel-Lucent | Frank Alfano (falfano@alcatel-lucent.com) | Rel-9 | CP-44 | Kimmo |  |
| 1151 | 416.5 | Support for IMS Emergency Calls over LTE | 206d? | 2008-12-05 A | 2009-09-18 A | 100% |  | 2008-12-05 | 2009-09-18 | 206d? |  |  | R2,R3 | 1648h | 1648h | IMS_EMER_LTE | PCG-22 | Alcatel-Lucent | Sudeep Palat (spalat@alcatel-lucent.com) | Rel-9 | RP-42 | Joern | RP-090698 |
| 1152 | 416.6 | Conformance Test Aspects – Support for IMS Emergency Calls over LTE | 187d? | 2010-03-25 A | 2010-12-10 A | 100% |  | 2010-03-25 | 2010-12-10 | 187d? |  | finish no earlier than 2010-12-10 | R5 | 1496h | 1496h | IMS_EMER_LTE_UEConTest | PCG-24 | Ericsson | leif.mattisson@ericsson.com | Rel-9 | RP-47 | Ingbert | RP-101068 |
| 1153 | 416.7 | **Single Radio Voice Call Continuity (SRVCC) support for IMS Emergency Calls** | 1108d? | 2008-09-18 A | 2012-12-07 | 95% | 60.83d? | 2008-09-18 | 2012-12-07 | 1108d? | 463d |  | S2,C1,C4,C3,IETF | 22384h | 20862.2h | IMS_EMER_GPRS_EPS-SRVCC | PCG-21 | China Mobile | Yu Qing (Yuqing@chinamobile.com) | Rel-9 | SP-41 | Maurice |  |
| 1154 | 416.7.1 | SRVCC support for IMS Emergency Calls | 322d? | 2008-09-18 A | 2009-12-10 A | 100% |  | 2008-09-18 | 2009-12-10 | 322d? |  | finish no earlier than 2009-12-10 | S2 | 2576h | 2576h | IMS_EMER_GPRS_EPS-SRVCC | PCG-21 | China Mobile | Yu Qing (Yuqing@chinamobile.com) | Rel-9 | SP-41 | Maurice |  |
| 1155 | 416.7.2 | **CT aspects of SRVCC support for IMS Emergency Calls** | 927d? | 2009-05-29 A | 2012-12-07 | 91% | 87.89d? | 2009-05-29 | 2012-12-07 | 927d? | 463d |  | C1,C4,C3,IETF | 10944h | 9908.9h | IMS_EMER_GPRS_EPS-SRVCC | PCG-24 | China Mobile | jiangyi@chinamobile.com | Rel-9 | CP-46 | Frederic |  |
| 1156 | 416.7.2.1 | CT1 aspects of SRVCC support for IMS Emergency Calls | 137d? | 2009-05-29 A | 2009-12-04 A | 100% |  | 2009-05-29 | 2009-12-04 | 137d? |  | finish no earlier than 2009-12-04 | C1 | 1096h | 1096h | IMS_EMER_GPRS_EPS-SRVCC | PCG-23 | China Mobile | jiangyi@chinamobile.com | Rel-9 | CP-44 | Frederic |  |
| 1157 | 416.7.2.2 | CT4 aspects of SRVCC support for IMS Emergency Calls | 137d? | 2009-05-29 A | 2009-12-04 A | 100% |  | 2009-05-29 | 2009-12-04 | 137d? |  | finish no earlier than 2009-12-04 | C4 | 1096h | 1096h | IMS_EMER_GPRS_EPS-SRVCC | PCG-23 | China Mobile | jiangyi@chinamobile.com | Rel-9 | CP-44 | Kimmo |  |
| 1158 | 416.7.2.3 | CT3 aspects of SRVCC support for IMS Emergency Calls | 1d? | 2009-12-04 A | 2009-12-04 A | 100% |  | 2009-12-04 | 2009-12-04 | 1d? |  | finish no earlier than 2009-12-04 | C3 | 8h | 8h | IMS_EMER_GPRS_EPS-SRVCC | PCG-24 | China Mobile | jiangyi@chinamobile.com | Rel-9 | CP-46 | Kimmo |  |
| 1159 | 416.7.2.4 | (IETF) CT3 aspects of SRVCC support for IMS Emergency Calls | 168d? | 2012-04-20 A | 2012-12-07 | 75% | 42d? | 2012-04-20 | 2012-12-07 | 168d? | 463d | finish no earlier than 2012-09-20 | C3-IETF | 1328h | 996h | IMS_EMER_GPRS_EPS_SRVCC | PCG-29 | Andrew Allen |  | Rel-9 | CP-56 |  |  |
| 1160 | 417 | **LCS for LTE and EPS** | 981d? | 2008-06-05 A | 2012-03-02 A | 100% |  | 2008-06-05 | 2012-03-02 | 981d? |  |  | S2,C1,C4,R2,R1,R3,R4,R5 | 24304h | 24304h | LCS_LTE_EPS | PCG-22 |  |  | Rel-9 | SP-43 | Maurice |  |
| 1161 | 417.1 | **LCS Control Plane Solution for EPS** | 468d? | 2008-06-05 A | 2010-03-19 A | 100% |  | 2008-06-05 | 2010-03-19 | 468d? |  |  | S2,C4,C1 | 9224h | 9224h | LCS_EPS-CPS | PCG-21 | Polaris Wireless | Robert Gross (rgross@polariswireless.com) | Rel-9 | SP-40 | Maurice |  |
| 1162 | 417.1.1 | Stage 2 for LCS Control Plane Solution for EPS | 261d? | 2008-06-05 A | 2009-06-04 A | 100% |  | 2008-06-05 | 2009-06-04 | 261d? |  | finish no earlier than 2009-06-04 | S2 | 2088h | 2088h | LCS_EPS-CPS | PCG-21 | Polaris Wireless | Robert Gross (rgross@polariswireless.com) | Rel-9 | SP-40 | Maurice |  |
| 1163 | 417.1.2 | CT4 aspects of Control Plane LCS in the EPC | 212d? | 2009-05-29 A | 2010-03-19 A | 100% |  | 2009-05-29 | 2010-03-19 | 212d? |  | finish no earlier than 2010-03-19 | C4 | 1696h | 1696h | LCS_EPS-CPS | PCG-23 | Polaris Wireless | Robert Gross (rgross@polariswireless.com) | Rel-9 | CP-44 | Kimmo |  |
| 1164 | 417.1.3 | CT1 aspects of Control Plane LCS in the EPC | 212d? | 2009-05-29 A | 2010-03-19 A | 100% |  | 2009-05-29 | 2010-03-19 | 212d? |  | finish no earlier than 2010-03-19 | C1 | 1696h | 1696h | LCS_EPS-CPS | PCG-23 | Polaris Wireless | Robert Gross (rgross@polariswireless.com) | Rel-9 | CP-44 | Frederic |  |
| 1165 | 417.2 | Positioning Support for LTE | 392d? | 2008-12-05 A | 2010-06-04 A | 100% |  | 2008-12-05 | 2010-06-04 | 392d? |  | finish no earlier than 2010-06-04 | R2,R1,R3,R4 | 3136h | 3136h | LCS_LTE | PCG-22 | Qualcomm | Nathan Tenny (ntenny@qualcomm.com) | Rel-9 | RP-42 | Joern | RP-100442 |
| 1166 | 417.3 | Conformance Test Aspects – Positioning Support for LTE | 512d? | 2010-03-19 A | 2012-03-02 A | 100% |  | 2010-03-19 | 2012-03-02 | 512d? |  | finish no earlier than 2012-03-02 | R5 | 4096h | 4096h | LCS_LTE_UEConTest | PCG-24 | Qualcomm | Shubhang Vora (svoral@qualcomm.com) | Rel-9 | RP-47 | Ingbert | RP-120034 |

Notes:
- 1138: CP#47 completed. Triggered by TR 22.986 Study on Service Specific Access Control in EPS. As EPS is a PS-Domain only system, Domain Specific Access Control (DSAC) doesn't apply, hence SSAC allows restriction of voice and non-voice calls separately
- 1139: SP#42 completed. If UE supports E-UTRA and IMS, SSAC is a mandatory Rel-9 function (during congestion in emergency case earthquake/tsunami improves mobile communications). / Text3: 22.011 CR0136
- 1140: CP#47 completed / Text3: 24.173, 27.007
- 1141: RP#56 completed. Testing for Stage 3 for Service Specific Access Control in EPS (24.173, 27.007) UID_440040 / Text3: 34.229-1, 34.229-2, 34.229-3
- 1142: RP#56 completed testing. CP#47 completed. SP#48 completed / Text3: GERAN, LTE
- 1143: SP#42 completed / Text3: 22.101
- 1144: SP#44 completed / Text3: 23.869, 23.060, 23.167, 23.203, 23.221, 23.228, 23.271, 23.401, 23.402
- 1145: SP#48 completed / Text3: 33.401, 33.402
- 1146: RP#56 completed testing. CP#47 completed / Text3: GERAN, LTE
- 1147: CP#47 completed / Text3: 23.122, 24.008, 24.229, 24.301, 24.302
- 1148: RP#56 completed / Text3: 34.108, 34.123-1, 34.123-2, 34.123-3, 34.229-1, 34.229-2, 34.229-3, 36.508, 36.523-1, 36.523-2, 36.523-3
- 1149: CP#45 completed / Text3: 29.212, 29.213, 29.214, 29.215
- 1150: CP#46 completed / Text3: 23.003, 23.008, 29.060, 29.272, 29.273, 29.274, 29.275, 29.276
- 1151: RP#45 completed / Text3: 36.331, 36.413
- 1152: RP#50 completed / Text3: 36.508, 36.523-1, 36.523-2, 36.523-3
- 1153: CP#56 added IETF dependency
- 1154: SP#46 completed / Text3: 23.870, 23.216, 23.237
- 1155: CP#46 completed
- 1156: CP#46 completed / Text3: 24.229, 24.237
- 1157: CP#46 completed / Text3: 29.205, 29.280
- 1158: CP#46 completed / Text3: 29.163
- 1159: Not completed internet-draft, (29.163) / Text3: draft-montemurro-gsma-imei-urn
- 1160: - / Text3: LTE
- 1161: Triggered by abandoned Study UID_380068 (FS_LCS_EPS). Linked to Feature UID_380064 Support for IMS Emergency Calls over GPRS and EPS
- 1162: SP#44 completed / Text3: 23.891, 23.271, 23.401, 23.402
- 1163: CP#47 completed (IANA registrations outstanding). Stage 3 SLs and SLg interfaces & transport of positioning messages between E-SMLC and MME in the scope of UID_420006 (Positioning Support for LTE) / Text3: 24.080, 29.002, 29.272, 29.230, new 24.171, 29.171, 29.172, 29.173
- 1164: CP#47 completed / Text3: 24.301
- 1165: RP#48 completed. UID_400038 (LCS Control Plane Solution for EPS) depends on this WI / Text3: 34.213, 36.133, 36.211, 36.214, 36.300, 36.305, 36.331, 36.355, 36.410, 36.413, 36.455, new 36.171
- 1166: RP#55 completed. RP#56 TS 37.571-4 v200 for Approval / Text3: 36.508, 36.509, new (37.571-1, 37.571-2, 37.571-3, 37.571-4, 37.571-5)

| ID | WBS | Task | Duration | Start | Finish | Complete | Baseline start | Baseline finish | Baseline duration | Constraint | Resources | Work | Actual work | Text1 | Text2 | Text4 | Text5 | Text6 | Text7 | Text8 | Text11 |
| --- | --- | --- | --- | --- | --- | --- | --- | --- | --- | --- | --- | --- | --- | --- | --- | --- | --- | --- | --- | --- | --- |
| 1167 | 418 | **MBMS support in EPS** | 921d? | 2008-06-05 A | 2011-12-09 A | 100% | 2008-06-05 | 2011-12-09 | 921d? |  | S2,S3,S5,C3,C4,R2,R3,R4,R5 | 19592h | 19592h | MBMS_EPS | PCG-21 | China Mobile | Liu Hong (liuhongyfw@chinamobile.com) | Rel-9 | SP-40 | Maurice |  |
| 1168 | 418.1 | Stage 2 for MBMS support in EPS | 261d? | 2008-06-05 A | 2009-06-04 A | 100% | 2008-06-05 | 2009-06-04 | 261d? | finish no earlier than 2009-06-04 | S2 | 2088h | 2088h | MBMS_EPS | PCG-21 | China Mobile | Liu Hong (liuhongyfw@chinamobile.com) | Rel-9 | SP-40 | Maurice |  |
| 1169 | 418.2 | Security for MBMS support in EPS | 261d? | 2008-12-11 A | 2009-12-10 A | 100% | 2008-12-11 | 2009-12-10 | 261d? | finish no earlier than 2009-12-10 | S3 | 2088h | 2088h | MBMS_EPS | PCG-22 | China Mobile | Liu Hong (liuhongyfw@chinamobile.com) | Rel-9 | SP-42 | Dionisio |  |
| 1170 | 418.3 | MBMS Charging in EPS | 201d? | 2009-03-06 A | 2009-12-10 A | 100% | 2009-03-06 | 2009-12-10 | 201d? | finish no earlier than 2009-12-10 | S5 | 1600h | 1600h | MBMS_EPS | PCG-22 | ZTE | guo.wenjie1@zte.com.cn | Rel-9 | SP-43 | Dionisio |  |
| 1171 | 418.4 | CT4 aspects of MBMS support in EPS (Stage 3) | 137d? | 2009-05-29 A | 2009-12-04 A | 100% | 2009-05-29 | 2009-12-04 | 137d? | finish no earlier than 2009-12-04 | C4 | 1096h | 1096h | MBMS_EPS | PCG-23 | China Mobile, ZTE | wangjingyf@chinamobile.com, lu.fei1@zte.com.cn | Rel-9 | CP-44 | Kimmo |  |
| 1172 | 418.5 | CT3 aspects of MBMS support in EPS (Stage 3) | 137d? | 2009-05-29 A | 2009-12-04 A | 100% | 2009-05-29 | 2009-12-04 | 137d? | start no earlier than 2009-05-29 | C3 | 1096h | 1096h | MBMS_EPS | PCG-23 | ZTE, China Mobile | zhou.xiaoyun@zte.com.cn, wangjingyf@chinamobile.com | Rel-9 | CP-44 | Jiwan |  |
| 1173 | 418.6 | MBMS support in LTE | 271d? | 2009-03-06 A | 2010-03-19 A | 100% | 2009-03-06 | 2010-03-19 | 271d? | finish no earlier than 2010-03-19 | R2,R3,R4 | 2168h | 2168h | MBMS_LTE | PCG-22 | Huawei | arnaud.meylan@huawei.com | Rel-9 | RP-43 | Joern | RP-100033 |
| 1174 | 418.7 | Conformance Test Aspects – MBMS support in LTE | 262d? | 2010-12-10 A | 2011-12-09 A | 100% | 2010-12-10 | 2011-12-09 | 262d? | finish no earlier than 2011-12-09 | R5 | 2088h | 2088h | MBMS_LTE-UEConTest | PCG-26 | Huawei | Zhang Xin (zhangxin0208@huawei.com) | Rel-9 | RP-50 | Ingbert | RP-111437 |
| 1175 | 419 | **Access Network Discovery and Selection Function enhancements** | 333d? | 2008-12-11 A | 2010-03-19 A | 100% | 2008-12-11 | 2010-03-19 | 333d? |  | S2,C1 | 4720h | 4720h | eANDSF | PCG-22 | Motorola | Apostolis Salkintzis (salki@motorola.com) | Rel-9 | SP-42 | Maurice |  |
| 1176 | 419.1 | Stage 2 for Access Network Discovery and Selection Function enhancements | 126d? | 2008-12-11 A | 2009-06-04 A | 100% | 2008-12-11 | 2009-06-04 | 126d? | finish no earlier than 2009-06-04 | S2 | 1008h | 1008h | eANDSF | PCG-22 | Motorola | Apostolis Salkintzis (salki@motorola.com) | Rel-9 | SP-42 | Maurice |  |
| 1177 | 419.2 | CT1 aspects of Access Network Discovery and Selection Function enhancements | 131d? | 2009-09-18 A | 2010-03-19 A | 100% | 2009-09-18 | 2010-03-19 | 131d? | finish no earlier than 2010-03-19 | C1 | 1048h | 1048h | eANDSF | PCG-23 | Panasonic | benjamin.limck@sg.panasonic.com | Rel-9 | CP-45 | Frederic |  |
| 1178 | 420 | **Multiple PDN Connection to the Same APN for PMIP-based Interfaces** | 267d? | 2009-03-13 A | 2010-03-19 A | 100% | 2009-03-13 | 2010-03-19 | 267d? |  | S2,C4,C1 | 4120h | 4120h | MUPSAP | PCG-22 | Samsung | erik.guttman@partner.samsung.com | Rel-9 | SP-43 | Maurice |  |
| 1179 | 420.1 | Stage 2 for Multiple PDN Connection to the Same APN for PMIP-based Interfaces | 61d? | 2009-03-13 A | 2009-06-04 A | 100% | 2009-03-13 | 2009-06-04 | 61d? | finish no earlier than 2009-06-04 | S2 | 488h | 488h | MUPSAP | PCG-22 | Samsung | erik.guttman@partner.samsung.com | Rel-9 | SP-43 | Maurice |  |
| 1180 | 420.2 | CT4 aspects of Multiple PDN Connection to the Same APN for PMIP-based Interfaces | 56d? | 2009-09-18 A | 2009-12-04 A | 100% | 2009-09-18 | 2009-12-04 | 56d? | finish no earlier than 2009-12-04 | C4 | 448h | 448h | MUPSAP | PCG-23 | Samsung | Surjyakanta Mohapatra (surjya.kanta@samsung.com) | Rel-9 | CP-45 | Kimmo |  |
| 1181 | 420.3 | CT1 aspects of Multiple PDN Connection to the Same APN for PMIP-based Interfaces | 131d? | 2009-09-18 A | 2010-03-19 A | 100% | 2009-09-18 | 2010-03-19 | 131d? | finish no earlier than 2010-03-19 | C1 | 1048h | 1048h | MUPSAP | PCG-23 | Samsung | Surjyakanta Mohapatra (surjya.kanta@samsung.com) | Rel-9 | CP-45 | Frederic |  |
| 1182 | 421 | **System aspects of vocoder rate adaptation for LTE** | 1403.68d? | 2007-05-07 A | 2012-09-12 A | 100% | 2007-05-07 | 2012-09-12 | 1403.68d? |  | S2,S4,C1,C3,R2,IETF | 23783h | 23783h | LTEimp-Vocoder | PCG-23 | Qualcomm | AC Mahendran (ac@qualcomm.com) | Rel-9 | SP-45 | Maurice |  |
| 1183 | 421.1 | SA2 system aspects of vocoder rate adaptation for LTE | 81d? | 2009-06-04 A | 2009-09-24 A | 100% | 2009-06-04 | 2009-09-24 | 81d? | start no earlier than 2009-06-04 | S2 | 648h | 648h | LTEimp-Vocoder | PCG-23 | Qualcomm | AC Mahendran (ac@qualcomm.com) | Rel-9 | SP-45 | Maurice |  |
| 1184 | 421.2 | SA4 system aspects of vocoder rate adaptation for LTE | 136d? | 2009-06-04 A | 2009-12-10 A | 100% | 2009-06-04 | 2009-12-10 | 136d? | finish no earlier than 2009-12-07 | S4 | 1088h | 1088h | LTEimp-Vocoder | PCG-23 | Qualcomm | Nikolai Leung | Rel-9 | SP-45 | Paolo |  |
| 1185 | 421.3 | Vocoder rate adaptation for LTE | 81d? | 2009-05-30 A | 2009-09-18 A | 100% | 2009-05-30 | 2009-09-18 | 81d? | finish no earlier than 2009-09-18 | R2 | 648h | 648h | LTEimp-Vocoder | PCG-23 | Alcatel-Lucent | Sudeep Palat (spalat@alcatel-lucent.com) | Rel-9 | RP-44 | Joern | RP-090704 |
| 1186 | 421.4 | (IETF) SA4 system aspects of vocoder rate adaptation for LTE | 677.6d? | 2009-06-04 A | 2012-09-12 A | 100% | 2009-06-04 | 2012-09-12 | 677.6d? | finish no earlier than 2012-09-14 | S4-IETF | 5420.8h | 5420.8h | LTEimp-Vocoder | PCG-27 | Lionel Morand |  | Rel-9 | SP-52 | Paolo |  |
| 1187 | 421.5 | (IETF) CT aspects of vocoder rate adaptation for LTE | 675.6d? | 2007-05-07 A | 2012-09-07 A | 100% | 2007-05-07 | 2012-09-07 | 675.6d? | finish no earlier than 2012-09-07 | C1-IETF,C3-IETF,C4-IETF | 5396.8h | 5396.8h | LTEimp-Vocoder | PCG-27 | Lionel Morand |  | Rel-9 | CP-52 | Frederic |  |
| 1188 | 422 | Access Security Enhancements | 505d? | 2007-07-02 A | 2009-06-04 A | 100% | 2007-07-02 | 2009-06-04 | 505d? | finish no earlier than 2009-06-03 | S3 | 4040h | 4040h | ACCSEC2 |  | Ericsson | Bengt.Sahlin@ericsson.com | Rel-9 | SP-26 | Dionisio |  |
| 1189 | 423 | **Protection against Unsolicited Communication for IMS (PUCI)** | 322d? | 2008-09-18 A | 2009-12-10 A | 100% | 2008-09-18 | 2009-12-10 | 322d? |  | S3,S1 | 5640h | 5640h | PUCI | PCG-21 | NEC | Anand R. Prasad (anand@bq.jp.nec.com) | Rel-9 | SP-41 | Alain |  |
| 1190 | 423.1 | Stage 1 for PUCI | 61d? | 2008-09-18 A | 2008-12-11 A | 100% | 2008-09-18 | 2008-12-11 | 61d? | finish no earlier than 2009-06-18 | S1 | 488h | 488h | PUCI | PCG-21 | NEC | Anand R. Prasad (anand@bq.jp.nec.com) | Rel-9 | SP-41 | Alain |  |
| 1191 | 423.2 | SA3 work on PUCI | 322d? | 2008-09-18 A | 2009-12-10 A | 100% | 2008-09-18 | 2009-12-10 | 322d? | finish no earlier than 2009-12-10 | S3 | 2576h | 2576h | PUCI | PCG-21 | NEC | Anand R. Prasad (anand@bq.jp.nec.com) | Rel-9 | SP-41 | Dionisio |  |

Notes:
- 1167: RP#47 completed. SP#46, CP#46 completed / Text3: LTE
- 1168: SP#44 completed / Text3: 23.246
- 1169: SP#46 completed / Text3: 33.246
- 1170: SP#46 completed / Text3: 32.273, 32.251, 32.298, 32.299
- 1171: CP#46 completed / Text3: 29.274, 29.281, 23.007, 23.008
- 1172: CP#46 completed / Text3: 29.061
- 1173: RP#47 completed / Text3: 25.446, 36.101, 36.104, 36.141, 36.300, 36.304, 36.321, 36.322, 36.323, 36.331, 36.440, 36.441, 36.442, 36.444, 36.445
- 1174: RP#54 completed / Text3: 36.508, 36.521-1, 36.521-2, 36.523-1, 36.523-2, 36.523-3
- 1175: CP#47 completed. No new Rel-9 use cases defined. Implement service requirements not covered in Rel-8 / Text3: 22.278, SA3 33.402 CR#0055
- 1176: SP#44 completed / Text3: 23.402, 23.002
- 1177: CP#47 completed / Text3: 24.302, 24.312
- 1178: CP#47 completed. Continues Rel-8 SAES Stage 2 UID_320005. Stage 1 in 22.278 (EPS Service requirements)
- 1179: SP#44 completed / Text3: 23.060, 23.203, 23.401, 23.402
- 1180: CP#46 completed / Text3: 29.275, 23.008, 29.282
- 1181: CP#47 completed / Text3: 24.302
- 1182: Triggered by RAN2 UID_440013 Vocoder rate adaptation for LTE / Text3: LTE
- 1183: SP#45 completed (CR adding support for Explicit Congestion Notification) / Text3: 23.401 CR#1103r3
- 1184: SP#46 completed / Text3: 26.114
- 1185: RP#45 completed / Text3: 36.300 CR#0114
- 1186: SP#57 completed / Text3: RFC 6679 (was draft-ietf-avtcore-ecn-for-rtp)
- 1187: CP#57 completed / Text3: RFC 6679 (was draft-ietf-avtcore-ecn-for-rtp)
- 1188: SP#44 completed. Stopped TR 33.801. CRs 33.102,43.020 on A5/2 removal done long time ago. A5/4 introduction CRs will be done under UID_440057 128 bit encryption for GSM and GPRS. SP#26 approved WID (improved GERAN security) / Text3: 33.102, 43.020
- 1189: SP#46 TR 33.937 completed but no specification work done in Rel-9. Related work in OMA Categorization Based Content Screening
- 1190: SP#42 completed / Text3: 22.228
- 1191: SP#46 completed. No normative work done in Rel-9 / Text3: new 33.937

| ID | WBS | Task | Duration | Start | Finish | Complete | Remaining | Baseline start | Baseline finish | Baseline duration | Total slack | Constraint | Resources | Work | Actual work | Text1 | Text2 | Text4 | Text5 | Text6 | Text7 | Text8 | Text3 | Text9 | Text12 |
| --- | --- | --- | --- | --- | --- | --- | --- | --- | --- | --- | --- | --- | --- | --- | --- | --- | --- | --- | --- | --- | --- | --- | --- | --- | --- |
| 1192 | 424 | **IMS Media Plane Security** | 920d? | 2009-03-13 A | 2012-09-12 A | 100% |  | 2009-03-13 | 2012-09-12 | 920d? |  |  | S3,C1,C4,C3,IETF | 17747.2h | 17747.2h | MEDIASEC | PCG-22 | Vodafone | Peter.Howard@vodafone.com | Rel-9 | SP-43 | Dionisio |  |  |  |
| 1193 | 424.1 | SA3 aspects of IMS Media Plane Security | 271d? | 2009-03-13 A | 2010-03-25 A | 100% |  | 2009-03-13 | 2010-03-25 | 271d? |  | finish no earlier than 2010-03-25 | S3 | 2168h | 2168h | MEDIASEC | PCG-22 | Vodafone | Peter.Howard@vodafone.com | Rel-9 | SP-43 | Dionisio | new 33.828, 33.328 |  |  |
| 1194 | 424.2 | (IETF) SA3, CT1, CT3 aspects of IMS Media Plane Security | 918d? | 2009-03-16 A | 2012-09-12 A | 100% |  | 2009-03-16 | 2012-09-12 | 918d? |  | finish no earlier than 2012-09-14 | S3-IETF,C1-IETF,C3-IETF | 7344h | 7344h | MEDIASEC | PCG-27 | Peter Dawes |  | Rel-9 | SP-52 | Dionisio | draft-dawes-dispatch-mediasec-parameter |  |  |
| 1195 | 424.3 | **CN aspects of IMS Media Plane Security** | 186d? | 2009-09-18 A | 2010-06-04 A | 100% |  | 2009-09-18 | 2010-06-04 | 186d? |  |  | C1,C4,C3 | 3011.2h | 3011.2h | MEDIASEC_CORE | PCG-23 | Vodafone | peter.dawes@vodafone.com | Rel-9 | CP-45 | Frederic |  |  |  |
| 1196 | 424.3.1 | CT1 aspects of IMS Media Plane Security | 33d? | 2009-09-18 A | 2010-03-19 A | 100% |  | 2009-09-18 | 2010-03-19 | 33d? |  | finish no earlier than 2010-03-19 | C1 | 264h | 264h | MEDIASEC_CORE | PCG-23 | Vodafone | peter.dawes@vodafone.com | Rel-9 | CP-45 | Frederic | 23.218, 24.229 |  |  |
| 1197 | 424.3.2 | CT4 aspects of IMS Media Plane Security | 131d? | 2009-09-18 A | 2010-03-19 A | 100% |  | 2009-09-18 | 2010-03-19 | 131d? |  | finish no earlier than 2010-03-19 | C4 | 1048h | 1048h | MEDIASEC_CORE | PCG-23 | Vodafone | peter.dawes@vodafone.com | Rel-9 | CP-45 | Kimmo | 29.238, 23.334, 29.334 |  |  |
| 1198 | 424.3.3 | CT3 aspects of IMS Media Plane Security | 131d? | 2009-12-04 A | 2010-06-04 A | 100% |  | 2009-12-04 | 2010-06-04 | 131d? |  | finish no earlier than 2010-06-04 | C3 | 1048h | 1048h | MEDIASEC_CORE | PCG-24 | Vodafone | peter.dawes@vodafone.com | Rel-9 | CP-46 | Jiwan | 29.162 |  |  |
| 1199 | 425 | **GBAPush enhancements (Generic push layer)** | 533d? | 2008-03-12 A | 2010-03-25 A | 100% |  | 2008-03-12 | 2010-03-25 | 533d? |  |  | S3 | 8528h | 8528h | eGBAPush | PCG-23 | Ericsson | Rolf Blom | Rel-9 | SP-44 | Dionisio | new 33.224 |  |  |
| 1200 | 425.1 | SA3 part of eGBAPush (Generic push layer) | 533d? | 2008-03-12 A | 2010-03-25 A | 100% |  | 2008-03-12 | 2010-03-25 | 533d? |  | finish no earlier than 2010-03-25 | S3 | 4264h | 4264h | eGBAPush | PCG-21 | Ericsson | Rolf Blom | Rel-9 | SP-39 | Dionisio | new 33.224 |  |  |
| 1201 | 426 | Extended Identity Management | 136d? | 2009-06-04 A | 2009-12-10 A | 100% |  | 2009-06-04 | 2009-12-10 | 136d? |  | finish no earlier than 2009-12-10 | S3 | 1088h | 1088h | GBA-IdM | PCG-23 | Nokia | Silke.Holtmanns@nokia.com | Rel-9 | SP-44 | Dionisio | new 33.924, CT4 29.109 (added service code) |  |  |
| 1202 | 427 | **Network Domain Security (NDS) enhancements to support backhaul security** | 922d? | 2009-06-04 A | 2012-12-07 | 97% | 31.51d? | 2009-06-04 | 2012-12-07 | 922d? | 463d |  | S3,IETF | 16044.8h | 9428.56h | NDS_Backhaul | PCG-23 | Vodafone | Peter.Howard@vodafone.com | Rel-9 | SP-44 | Dionisio |  |  |  |
| 1203 | 427.1 | SA3 part of Network Domain Security (NDS) enhancements to support backhaul security | 211d? | 2009-06-04 A | 2010-03-25 A | 100% |  | 2009-06-04 | 2010-03-25 | 211d? |  | finish no earlier than 2010-03-25 | S3 | 1688h | 1688h | NDS_Backhaul | PCG-23 | Vodafone | Peter.Howard@vodafone.com | Rel-9 | SP-44 | Dionisio | 33.102, 33.210, 33.310, 33.401, 33.402 |  |  |
| 1204 | 427.2 | (IETF) SA3 part of Network Domain Security (NDS) enhancements to support backhaul security | 740.6d? | 2009-06-04 A | 2012-12-07 | 95% | 37.03d? | 2009-06-04 | 2012-12-07 | 740.6d? | 463d | finish no earlier than 2012-12-07 | S3-IETF | 5924.8h | 5628.56h | NDS_Backhaul | PCG-27 | Bengt Sahlin |  | Rel-9 | SP-52 | Dionisio | draft-ietf-pkix-cmp-transport-protocols |  |  |
| 1205 | 427.3 | Deleted - CT4 part of Network Domain Security (NDS) enhancements to support backhaul security | 132d? | 2009-06-04 A | 2009-12-04 A | 100% |  | 2009-06-04 | 2009-12-04 | 132d? |  | finish no earlier than 2009-12-04 | C4 | 1056h | 1056h | NDS_Backhaul | PCG-23 | Vodafone | Peter.Howard@vodafone.com | Rel-9 | SP-44 | Kimmo |  | PCG-24 | CP-46 |
| 1206 | 428 | **128 bit encryption for GSM and GPRS** | 136d? | 2009-06-04 A | 2009-12-10 A | 100% |  | 2009-06-04 | 2009-12-10 | 136d? |  |  | S3,C1,C4,G2,G3new | 6040h | 6040h | A5/4-GEA4 | PCG-23 | Ericsson | Karl Norrman | Rel-9 | SP-44 | Dionisio |  |  |  |
| 1207 | 428.1 | SA3 part of 128 bit encryption for GSM and GPRS | 136d? | 2009-06-04 A | 2009-12-10 A | 100% |  | 2009-06-04 | 2009-12-10 | 136d? |  | finish no earlier than 2010-01-06 | S3 | 1088h | 1088h | A5/4-GEA4 | PCG-23 | Ericsson | Karl Norrman | Rel-9 | SP-44 | Dionisio | 33.102,43.020, new 55.226 |  |  |
| 1208 | 428.2 | CT1 part of 128 bit encryption for GSM and GPRS | 77d? | 2009-06-04 A | 2009-09-18 A | 100% |  | 2009-06-04 | 2009-09-18 | 77d? |  | start no earlier than 2009-06-04 | C1 | 616h | 616h | A5/4-GEA4 | PCG-23 | Ericsson | Karl Norrman | Rel-9 | SP-44 | Frederic | 24.008,44.064 |  |  |
| 1209 | 428.3 | CT4 part of 128 bit encryption for GSM and GPRS | 136d? | 2009-06-04 A | 2009-12-10 A | 100% |  | 2009-06-04 | 2009-12-10 | 136d? |  | start no earlier than 2009-06-04 | C4 | 1088h | 1088h | A5/4-GEA4 | PCG-23 | Ericsson | Karl Norrman | Rel-9 | SP-44 | Kimmo |  |  |  |
| 1210 | 428.4 | GERAN2 part of 128 bit encryption for GSM and GPRS | 67d? | 2009-06-04 A | 2009-09-04 A | 100% |  | 2009-06-04 | 2009-09-04 | 67d? |  | finish no earlier than 2009-09-04 | G2 | 536h | 536h | A5/4-GEA4 | PCG-23 | Ericsson | Karl Norrman | Rel-9 | SP-44 | Gert | 44.018,48.008,48.018,48.058 |  |  |
| 1211 | 428.5 | GERAN3new (testing) part of 128 bit encryption for GSM and GPRS | 122d? | 2009-06-04 A | 2009-11-20 A | 100% |  | 2009-06-04 | 2009-11-20 | 122d? |  | finish no earlier than 2009-11-20 | G3new | 976h | 976h | A5/4-GEA4 | PCG-23 | Ericsson | Karl Norrman | Rel-9 | SP-44 | Ingbert | 51.010 |  |  |
| 1212 | 428.6 | Deleted - SA2 part of 128 bit encryption for GSM and GPRS | 81d? | 2009-06-04 A | 2009-09-24 A | 100% |  | 2009-06-04 | 2009-09-24 | 81d? |  | finish no earlier than 2009-09-24 | S2 | 648h | 648h | A5/4-GEA4 | PCG-23 | Ericsson | Karl Norrman | Rel-9 | SP-44 | Maurice | 23.060 | PCG-23 | SP-45 |
| 1213 | 429 | Timed Graphics | 337d? | 2008-12-11 A | 2010-03-25 A | 100% |  | 2008-12-11 | 2010-03-25 | 337d? |  | finish no earlier than 2010-03-25 | S4 | 2696h | 2696h | TG | PCG-22 | Ericsson | clinton.priddle@ericsson.com | Rel-9 | SP-42 | Paolo | 26.114, 26.140, 26.234, 26.244, 26.245, 26.346, new 26.430 |  |  |
| 1214 | 430 | Managing MTSI Media Adaptation | 197d? | 2009-03-12 A | 2009-12-10 A | 100% |  | 2009-03-12 | 2009-12-10 | 197d? |  | finish no earlier than 2009-12-10 | S4 | 1568h | 1568h | M3A | PCG-22 | Samsung | kyunghun.jung@samsung.com | Rel-9 | SP-43 | Paolo | 26.114 |  |  |
| 1215 | 431 | **PSS and MBMS Aspects** | 272d? | 2009-03-12 A | 2010-03-25 A | 100% |  | 2009-03-12 | 2010-03-25 | 272d? |  |  | S4 | 6512h | 6512h | PMA | PCG-23 | Ericsson, Nokia | Clinton.Priddle@ericsson.com, imed.bouazizi@nokia.com | Rel-9 | SP-44 | Paolo |  |  |  |
| 1216 | 431.1 | PSS and MBMS extensions | 271d? | 2009-03-12 A | 2010-03-25 A | 100% |  | 2009-03-12 | 2010-03-25 | 271d? |  | finish no earlier than 2010-03-25 | S4 | 2168h | 2168h | PMA-MBS_Ext | PCG-22 | Ericsson | Clinton.Priddle@ericsson.com | Rel-9 | SP-43 | Paolo | 26.234, 26.346 |  |  |
| 1217 | 431.2 | Improved Video Support for PSS and MBMS | 271d? | 2009-03-12 A | 2010-03-25 A | 100% |  | 2009-03-12 | 2010-03-25 | 271d? |  | finish no earlier than 2010-03-25 | S4 | 2168h | 2168h | PMA-IVS | PCG-22 | Nokia | imed.bouazizi@nokia.com | Rel-9 | SP-43 | Paolo | 26.234, 26.244, 26.346, new 26.903 |  |  |
| 1218 | 432 | IMS based PSS and MBMS User Service extensions | 197d? | 2009-03-12 A | 2009-12-10 A | 100% |  | 2009-03-12 | 2009-12-10 | 197d? |  | finish no earlier than 2009-12-10 | S4 | 1576h | 1576h | IMS_PSS_MBMS_US_EXT | PCG-22 | Ericsson | Markus Kampmann | Rel-9 | SP-43 | Paolo | 26.237 |  |  |
| 1219 | 433 | Syndicated Feed Reception within 3GPP environments | 136d? | 2009-06-04 A | 2009-12-10 A | 100% |  | 2009-06-04 | 2009-12-10 | 136d? |  | start no earlier than 2009-06-04 | S4 | 1088h | 1088h | SFR | PCG-23 | Ericsson | Thorsten.Lohmar@ericsson.com | Rel-9 | SP-44 | Paolo | new 26.150 |  |  |
| 1220 | 434 | Distortion Measurement Test Methods and Requirements | 131d? | 2009-09-24 A | 2010-03-25 A | 100% |  | 2009-09-24 | 2010-03-25 | 131d? |  | finish no earlier than 2010-03-25 | S4 | 1048h | 1048h | DTMR | PCG-23 | Motorola | Stephen Kendall (wcsk01@motorola.com) | Rel-9 | SP-45 | Paolo | 26.131, 26.132 |  |  |

Notes:
- 1192: -
- 1193: SP#47 completed
- 1194: CP#57 completed, ietf-draft discontinued, documented within 3GPP
- 1195: CP#48 completed
- 1196: CP#47 completed
- 1197: CP#47 completed
- 1198: CP#48 completed
- 1199: SP#43 umbrella to host 33.224, moved from Rel-8 to Rel-9. SP#47 completed
- 1200: SP#47 completed
- 1201: SP#46 completed. Stage 1 not identified (GBA Liberty Interworking has been outlined and GBAOpenID interworking is analogous)
- 1202: SP#47 completed. Continuation of Rel-8 UID_390044 SAE security architecture. Covers gaps in backhaul security in SAE (also applicable to UTRAN and GERAN backhaul)
- 1203: SP#47 completed
- 1204: RFC Ed-queue
- 1205: CP#46 completed. No impact on CT4 specs
- 1206: Allow 128 as an alternative to 64 bit keys (Stage 2/3 + Test spec)
- 1207: SP#46 completed
- 1208: CP#45 completed
- 1209: CP#46 completed. Kc128 enhancements are carried as UMTS keys => no impact on CT4 29.002, 29.060
- 1210: GP#43 WID approved + completed
- 1211: GP#44 completed. GP#43 WID approved
- 1212: SP#45 work stopped/abandoned
- 1213: SP#47 completed. Provide graphics in parallel to a video stream (without requiring an umbrella scene descriptor such as 3GPP DIMS in TS 26.142)
- 1214: SP#46 completed. Work extending Rel-8 UID_34041 MTSI Video - Dynamic Rate Adaptation/Signalling of Image Size. Update speech/video adaptation algorithms used by network to control MTSI client terminal in congestion or poor transmission conditions.
- 1215: Umbrella WI
- 1216: SP#47 completed. Extends Rel-8 UID_34043 (PSS_MBMS_OMTV) & ensures compatibility with UID_34046 (IMS_PSS_MBMS_US)
- 1217: SP#47 completed
- 1218: SP#46 completed. Work extending Rel-8 UID_34046 (IMS_PSS_MBMS_US), SA2 UID_410034 IMSSCC-SPI (IMS Service Continuity Enhancements: Service, Policy and Interactions)
- 1219: SP#46 completed. TS 26.150v100 for Approval. RSS optimized for mobile use. Reuse/reference OMA's enabler DCD.
- 1220: SP#47 completed

| ID | WBS | Task | Duration | Start | Finish | Complete | Baseline start | Baseline finish | Baseline duration | Constraint | Resources | Work | Actual work | Text1 | Text2 | Text6 | Text7 | Text8 | Text4 | Text9 | Text12 |
| --- | --- | --- | --- | --- | --- | --- | --- | --- | --- | --- | --- | --- | --- | --- | --- | --- | --- | --- | --- | --- | --- |
| 1221 | 435 | **Rel-9 Operations, Administration, Maintenance and Provisioning (OAM&P)** | 601d? | 2008-02-22 A | 2010-06-10 A | 100% | 2008-02-22 | 2010-06-10 | 601d? |  | S5 | 36890.4h | 36890.4h | OAM9 | PCG-22 | Rel-9 | SP-42 | Dionisio |  |  |  |
| 1222 | 435.1 | **Rel-9 Network Infrastructure Management** | 337d? | 2008-12-11 A | 2010-03-25 A | 100% | 2008-12-11 | 2010-03-25 | 337d? |  | S5 | 8760h | 8760h | OAM9-NIM | PCG-22 | Rel-9 | SP-42 | Dionisio |  |  |  |
| 1223 | 435.1.1 | Software Management for Network Elements | 336d? | 2008-12-11 A | 2010-03-25 A | 100% | 2008-12-11 | 2010-03-25 | 336d? | finish no earlier than 2010-03-25 | S5 | 2688h | 2688h | OAM9-NE_SWM | PCG-22 | Rel-9 | SP-42 | Dionisio | Huawei, Nokia Siemens Networks |  |  |
| 1224 | 435.1.2 | Service Oriented Architecture (SOA) for IRP | 211d? | 2009-06-04 A | 2010-03-25 A | 100% | 2009-06-04 | 2010-03-25 | 211d? | finish no earlier than 2010-03-25 | S5 | 1688h | 1688h | OAM9 | PCG-23 | Rel-9 | SP-44 | Dionisio | Ericsson, Nokia Siemens Networks |  |  |
| 1225 | 435.1.3 | IRP SOAP Solution Sets continuation from Rel-8 | 211d? | 2009-06-04 A | 2010-03-25 A | 100% | 2009-06-04 | 2010-03-25 | 211d? | finish no earlier than 2010-03-25 | S5 | 1688h | 1688h | OAM9 | PCG-23 | Rel-9 | SP-44 | Dionisio | Ericsson |  |  |
| 1226 | 435.2 | **Rel-9 Performance Management** | 327d? | 2009-03-12 A | 2010-06-10 A | 100% | 2009-03-12 | 2010-06-10 | 327d? |  | S5 | 7890.41h | 7890.41h | OAM9-PM | PCG-22 | Rel-9 | SP-42 | Dionisio |  |  |  |
| 1227 | 435.2.1 | Enhancement of UTRAN Performance Measurements | 136d? | 2009-06-04 A | 2009-12-10 A | 100% | 2009-06-04 | 2009-12-10 | 136d? | start no earlier than 2009-06-04 | S5 | 1088h | 1088h | OAM9 | PCG-23 | Rel-9 | SP-44 | Dionisio | China Mobile |  |  |
| 1228 | 435.2.2 | Enhancement of E-UTRAN Performance Measurements | 327d? | 2009-03-12 A | 2010-06-10 A | 100% | 2009-03-12 | 2010-06-10 | 327d? | finish no earlier than 2010-06-10 | S5 | 2616h | 2616h | OAM9 | PCG-22 | Rel-9 | SP-43 | Dionisio | Motorola, Huawei |  |  |
| 1229 | 435.2.3 | Enhancement of EPC Performance Measurements | 197d? | 2009-03-12 A | 2009-12-10 A | 100% | 2009-03-12 | 2009-12-10 | 197d? | finish no earlier than 2010-03-25 | S5 | 1570.41h | 1570.41h | OAM9 | PCG-22 | Rel-9 | SP-43 | Dionisio | China Mobile |  |  |
| 1230 | 435.3 | **Rel-9 Self-Organizing Networks (SON) - OAM aspects** | 601d? | 2008-02-22 A | 2010-06-10 A | 100% | 2008-02-22 | 2010-06-10 | 601d? |  | S5 | 11736h | 11736h | OAM9-SON | PCG-22 | Rel-9 | SP-43 | Dionisio |  |  |  |
| 1231 | 435.3.1 | SON self-optimization management | 600d? | 2008-02-22 A | 2010-06-10 A | 100% | 2008-02-22 | 2010-06-10 | 600d? | finish no earlier than 2010-06-10 | S5 | 4800h | 4800h | LTE_SON-OAM | PCG-21 | Rel-9 | SP-39 | Dionisio | Huawei |  |  |
| 1232 | 435.3.2 | Automatic Radio Network Configuration Data Preparation | 266d? | 2009-06-04 A | 2010-06-10 A | 100% | 2009-06-04 | 2010-06-10 | 266d? | finish no earlier than 2010-06-10 | S5 | 2128h | 2128h | OAM9 | PCG-23 | Rel-9 | SP-44 | Dionisio | Nokia Siemens Networks |  |  |
| 1233 | 435.4 | Rel-9 Subscription Management (SuM) evolution | 266d? | 2009-06-04 A | 2010-06-10 A | 100% | 2009-06-04 | 2010-06-10 | 266d? | finish no earlier than 2010-06-10 | S5 | 2128h | 2128h | OAM9-SuM | PCG-23 | Rel-9 | SP-44 | Dionisio | Ericsson |  |  |
| 1234 | 435.5 | Deleted - Rel-9 Trace | 196d? | 2009-03-13 A | 2009-12-10 A | 100% | 2009-03-13 | 2009-12-10 | 196d? | finish no earlier than 2009-12-10 | S5 | 1568h | 1568h | OAM9-Trace | PCG-22 | Rel-9 | SP-42 | Dionisio |  | PCG-24 | SP-46 |
| 1235 | 436 | Rel-9 Charging Management small Enhancements | 211d? | 2009-06-04 A | 2010-03-25 A | 100% | 2009-06-04 | 2010-03-25 | 211d? |  | S5 | 1688h | 1688h | CH9 | PCG-23 | Rel-9 | SP-44 | Dionisio |  |  |  |
| 1236 | 437 | **CS-IBCF and CS-TrGW definition in 3GPP specifications** | 472d? | 2008-05-30 A | 2010-03-19 A | 100% | 2008-05-30 | 2010-03-19 | 472d? |  | C3,C4 | 10714.3h | 10714.3h | CS-IBCF | PCG-21 | Rel-9 | CP-40 | Jiwan | Telecom Italia |  |  |
| 1237 | 437.1 | CT3 aspects of CS-IBCF and CS-TrGW definition in 3GPP specifications | 472d? | 2008-05-30 A | 2010-03-19 A | 100% | 2008-05-30 | 2010-03-19 | 472d? | finish no earlier than 2009-12-04 | C3 | 3770.34h | 3770.34h | CS-IBCF | PCG-21 | Rel-9 | CP-40 | Jiwan | Telecom Italia |  |  |
| 1238 | 437.2 | CT4 aspects of CS-IBCF and CS-TrGW definition in 3GPP specifications | 396d? | 2008-05-30 A | 2009-12-04 A | 100% | 2008-05-30 | 2009-12-04 | 396d? | finish no earlier than 2009-12-04 | C4 | 3168h | 3168h | CS-IBCF | PCG-21 | Rel-9 | CP-40 | Kimmo | Telecom Italia |  |  |
| 1239 | 438 | **IMS – Interconnection Border Control Function (IBCF) – Transition Gateway (TrGW); Ix Interface; Stage 3** | 322d? | 2008-09-12 A | 2009-12-04 A | 100% | 2008-09-12 | 2009-12-04 | 322d? |  | C4,C3 | 6858.4h | 6858.4h | IMS_IBCF | PCG-21 | Rel-9 | CP-41 | Kimmo | Alcatel-Lucent |  |  |
| 1240 | 438.1 | CT4 part of IMS – Interconnection Border Control Function (IBCF) – Transition Gateway (TrGW); Ix Interface; Stage 3 | 321d? | 2008-09-12 A | 2009-12-04 A | 100% | 2008-09-12 | 2009-12-04 | 321d? | finish no earlier than 2009-12-04 | C4 | 2568h | 2568h | IMS_IBCF | PCG-21 | Rel-9 | CP-41 | Kimmo | Alcatel-Lucent |  |  |
| 1241 | 438.2 | CT3 part of IMS – Interconnection Border Control Function (IBCF) – Transition Gateway (TrGW); Ix Interface; Stage 3 | 295.8d? | 2008-09-12 A | 2009-12-04 A | 100% | 2008-09-12 | 2009-12-04 | 295.8d? | finish no earlier than 2010-03-19 | C3 | 2366.4h | 2366.4h | IMS_IBCF | PCG-21 | Rel-9 | CP-41 | Jiwan | Alcatel-Lucent |  |  |
| 1242 | 439 | IMS Application Level Gateway Control Function (ALGCF) – IMS Access Media Gateway (IMA-MGW); Iq Interface; Stage 2 and Stage 3 | 321d? | 2008-09-12 A | 2009-12-04 A | 100% | 2008-09-12 | 2009-12-04 | 321d? | finish no earlier than 2009-12-04 | C4 | 2568h | 2568h | IMS_AGCF | PCG-21 | Rel-9 | CP-41 | Kimmo | Alcatel-Lucent |  |  |
| 1243 | 440 | **Enhancements of IMS Customized Alerting Tone (CAT) Service** | 392d? | 2008-12-05 A | 2010-06-04 A | 100% | 2008-12-05 | 2010-06-04 | 392d? |  | C1 | 5846.4h | 5846.4h | eCAT | PCG-22 | Rel-9 | CP-42 | Frederic | China Mobile |  |  |
| 1244 | 440.1 | Stage 3 for Enhancements of IMS Customized Alerting Tone (CAT) Service | 391d? | 2008-12-05 A | 2010-06-04 A | 100% | 2008-12-05 | 2010-06-04 | 391d? | finish no earlier than 2010-06-04 | C1 | 3128h | 3128h | eCAT-SS | PCG-22 | Rel-9 | CP-42 | Frederic | China Mobile |  |  |

Notes:
- 1221: OAM9 is an umbrella Feature also for OAM&P related TEI9 type of changes that are not part of any other dedicated feature/WI / Text3: TR 30.819
- 1222: SP#42 umbrella BB created to host OAM WIs
- 1223: SP#47 completed / Text3: 32.531, 32.532, 32.533, new 32.537 / Text5: Bidipta Das (bidipta@huawei.com), Clemens Suerbaum (clemens.suerbaum@nsn.com)
- 1224: SP#47 completed (covering SOA Architecture & SOA-supporting Solution Set). Triggered by UID_400029 Study on Service Oriented Architecture (SOA) for IRP (TR 32.824) / Text3: 32.101, 32.102, 32.150 / Text5: edwin.tse@ericsson.com, Jörg Schmidt (joerg@cox.net)
- 1225: SP#47 completed. Continuation of Rel-8 UID_400030 IRP SOAP Solution Sets / Text3: New (32.127/ 327/ 337/ 357/ 387/ 397/ 447/ 397/ 447/ 507/ 537), 32.121,32.122,32.123,32,32.321,32.322,32.323,32.325,32.331,32.332,32.333,32.335,32.351,32.352,32.353,32.381,32.382,32.383,32.385,32.391,32.392,32.393,32.395,32.441,32.442,32.443 / Text5: John Power
- 1226: SP#42 umbrella BB created to host OAM WIs
- 1227: SP#46 completed / Text3: 32.405 / Text5: Liang Shuangchun (liangshuangchun@cmdi.chinamobile.com), Li Jian (lijian@chinamobile.com), Bao Haitao
- 1228: SP#48 completed / Text3: 32.425 / Text5: Yizhi Yao (yzyao@motorola.com),Lan Zou (zlan@huawei.com)
- 1229: SP#46 completed / Text3: 32.426 / Text5: Li Jian (lijian@chinamobile.com), Liang Shuangchun (liangshuangchun@cmdi.chinamobile.com)
- 1230: SP#43 umbrella BB created to host OAM WIs
- 1231: SP#48 completed / Text3: 32.425, new (32.521, 32.522, 32.523, 32.525) / Text5: Lan Zou (zlan@huawei.com)
- 1232: SP#48 completed / Text3: 32.501, 32.502, 32.503, 32.505, new 32.507 / Text5: clemens.suerbaum@nsn.com
- 1233: SP#48 completed / Text3: 32.140, 32.141, 32.152, 32.172, 32.175 / Text5: frode.nergard@ericsson.com
- 1234: SP#46 stopped (no work in Rel-9)
- 1235: CH9 is an umbrella Feature also for OAM&P related TEI9 type of changes that are not part of any other dedicated feature/WI / Text3: TR 30.819
- 1236: CP#47 completed. Rel-8 UID_380061 (Ipinterc) covers Stage 1 in SA1 22.101, 22.228 / Text5: mauro.ficaccio@telecomitalia.it
- 1237: CP#47 completed / Text3: 29.235 / Text5: mauro.ficaccio@telecomitalia.it
- 1238: CP#46 completed / Text3: 23.231, 29.232, new 29.238 / Text5: mauro.ficaccio@telecomitalia.it
- 1239: CP#46 completed / Text5: bruno.landais@alcatel-lucent.fr
- 1240: CP#46 completed / Text3: new 29.238 / Text5: bruno.landais@alcatel-lucent.fr
- 1241: CP#46 completed / Text3: 29.162, 29.235 / Text5: bruno.landais@alcatel-lucent.fr
- 1242: CP#46 completed / Text3: new 23.334, 29.334 / Text5: bruno.landais@alcatel-lucent.fr
- 1243: CP#48 completed. Stage 1 in 22.182 / Text5: Jiang Yi
- 1244: CP#48 completed / Text3: 24.182 / Text5: Jiang Yi

| ID | WBS | Task | Duration | Start | Finish | Complete | Remaining | Baseline start | Baseline finish | Baseline duration | Total slack | Constraint | Resources | Work | Actual work | Text1 | Text2 | Text4 | Text5 | Text6 | Text7 | Text8 | Text11 |
| --- | --- | --- | --- | --- | --- | --- | --- | --- | --- | --- | --- | --- | --- | --- | --- | --- | --- | --- | --- | --- | --- | --- | --- |
| 1245 | 441 | **Completion of IMS Restoration Procedures** | 212d? | 2009-05-29 A | 2010-03-19 A | 100% |  | 2009-05-29 | 2010-03-19 | 212d? |  |  | C3, C4,C1 | 6784h | 6784h | eIMS_RP | PCG-23 | Ericsson | Emiliano Merino (emiliano.merino@ericsson.com) | Rel-9 | CP-44 | Kimmo |  |
| 1246 | 441.1 | CT4 aspects of Completion of IMS Restoration Procedures | 212d? | 2009-05-29 A | 2010-03-19 A | 100% |  | 2009-05-29 | 2010-03-19 | 212d? |  | finish no earlier than 2010-03-19 | C4 | 1696h | 1696h | eIMS_RP | PCG-23 | Ericsson | Emiliano Merino (emiliano.merino@ericsson.com) | Rel-9 | CP-44 | Kimmo |  |
| 1247 | 441.2 | CT1 aspects of Completion of IMS Restoration Procedures | 212d? | 2009-05-29 A | 2010-03-19 A | 100% |  | 2009-05-29 | 2010-03-19 | 212d? |  | finish no earlier than 2010-03-19 | C1 | 1696h | 1696h | eIMS_RP | PCG-23 | Ericsson | Emiliano Merino (emiliano.merino@ericsson.com) | Rel-9 | CP-44 | Kimmo |  |
| 1248 | 441.3 | CT3 aspects of Completion of IMS Restoration Procedures | 212d? | 2009-05-29 A | 2010-03-19 A | 100% |  | 2009-05-29 | 2010-03-19 | 212d? |  | finish no earlier than 2010-03-19 | C3 | 1696h | 1696h | eIMS_RP | PCG-24 | Ericsson | Emiliano Merino (emiliano.merino@ericsson.com) | Rel-9 | CP-46 | Kimmo |  |
| 1249 | 442 | **IMS Stage 3 IETF Protocol Alignment - phase 3** | 927d? | 2009-05-29 A | 2012-12-07 | 79% | 192.54d? | 2009-05-29 | 2012-12-07 | 927d? | 463d |  | C1,IETF | 15736h | 7934h | IMSProtoc3 | PCG-23 | Alcatel-Lucent | Keith Drage (drage@alcatel-lucent.com) | Rel-9 | CP-44 | Frederic |  |
| 1250 | 442.1 | CT1 aspects of IMS Stage 3 - IETF Protocol Alignment - phase 3 | 212d? | 2009-05-29 A | 2010-03-19 A | 100% |  | 2009-05-29 | 2010-03-19 | 212d? |  | finish no earlier than 2010-03-19 | C1 | 1696h | 1696h | IMSProtoc3 | PCG-23 | Alcatel-Lucent | Keith Drage (drage@alcatel-lucent.com) | Rel-9 | CP-44 | Frederic |  |
| 1251 | 442.2 | (IETF) CT1 IMS Stage 3 - IETF Protocol Alignment (draft-kaplan) | 715d? | 2009-05-29 A | 2012-12-07 | 75% | 178.75d? | 2009-05-29 | 2012-12-07 | 715d? | 463d | finish no earlier than 2012-12-07 | C1-IETF | 5720h | 4290h | IMSProtoc3 | PCG-27 | Christer Holmberg | christer.holmberg@ericsson.com | Rel-9 | CP-52 | Frederic |  |
| 1252 | 442.3 | (IETF) CT1 IMS Stage 3 - IETF Protocol Alignment (rfc4244bis) | 326d? | 2011-09-13 A | 2012-12-07 | 75% | 81.5d? | 2011-09-13 | 2012-12-07 | 326d? | 463d | finish no earlier than 2012-12-07 | C1-IETF | 2600h | 1948h | IMSProtoc3 | PCG-27 | Christer Holmberg | christer.holmberg@ericsson.com | Rel-9 | CP-53 |  |  |
| 1253 | 443 | **Operational description of the Inter-IMS Network to Network Interface (II-NNI)** | 927d? | 2009-05-29 A | 2012-12-07 | 80% | 183.07d? | 2009-05-29 | 2012-12-07 | 927d? | 463d |  | C3,IETF | 17568h | 10280h | II-NNI | PCG-23 | Orange | sebastien.daudet@orange-ftgroup.com | Rel-9 | CP-44 | Jiwan |  |
| 1254 | 443.1 | Operational description of the Inter-IMS Network to Network Interface | 267d? | 2009-05-29 A | 2010-06-04 A | 100% |  | 2009-05-29 | 2010-06-04 | 267d? |  | start no earlier than 2009-05-29 | C3 | 2136h | 2136h | II-NNI | PCG-23 | Orange |  | Rel-9 | CP-44 |  |  |
| 1255 | 443.2 | (IETF) Operational description of the Inter-IMS Network to Network Interface | 167d? | 2012-04-20 A | 2012-12-07 | 75% | 41.75d? | 2012-04-20 | 2012-12-07 | 167d? | 463d | finish no earlier than 2012-12-07 | C3-IETF | 1336h | 1002h | II-NNI | PCG-29 | Christer Holmberg |  | Rel-9 | CP-56 |  |  |
| 1256 | 443.3 | (IETF) Operational description of the Inter-IMS Network to Network Interface | 167d? | 2012-04-20 A | 2012-12-07 | 75% | 41.75d? | 2012-04-20 | 2012-12-07 | 167d? | 463d | finish no earlier than 2012-12-07 | C3-IETF | 1336h | 1002h | II-NNI | PCG-29 | Keith Drage |  | Rel-9 | CP-56 |  |  |
| 1257 | 443.4 | (IETF) Operational description of the Inter-IMS Network to Network Interface | 167d? | 2012-04-20 A | 2012-12-07 | 75% | 41.75d? | 2012-04-20 | 2012-12-07 | 167d? | 463d | finish no earlier than 2012-12-07 | C3-IETF | 1336h | 1002h | II-NNI | PCG-29 | Roland Jesske |  | Rel-9 | CP-56 |  |  |
| 1258 | 443.5 | (IETF) Operational description of the Inter-IMS Network to Network Interface | 168d? | 2012-04-20 A | 2012-12-07 | 75% | 42d? | 2012-04-20 | 2012-12-07 | 168d? | 463d | finish no earlier than 2012-12-07 | C3-IETF | 1336h | 1000h | II-NNI | PCG-29 | Roland Jesske |  | Rel-9 | CP-56 |  |  |
| 1259 | 443.6 | (IETF) Operational description of the Inter-IMS Network to Network Interface | 168d? | 2012-04-20 A | 2012-12-07 | 75% | 42d? | 2012-04-20 | 2012-12-07 | 168d? | 463d | finish no earlier than 2012-12-07 | C3-IETF | 1336h | 1000h | II-NNI | PCG-29 | Keith Drage |  | Rel-9 | CP-56 |  |  |
| 1260 | 443.7 | (IETF) Operational description of the Inter-IMS Network to Network Interface | 167d? | 2012-04-20 A | 2012-12-07 | 75% | 41.75d? | 2012-04-20 | 2012-12-07 | 167d? | 463d | finish no earlier than 2012-12-07 | C3-IETF | 1336h | 1002h | II-NNI | PCG-29 |  |  | Rel-9 | CP-56 |  |  |
| 1261 | 444 | Definition of Ml interface for Control Plane LCS (Stage 3) | 131d? | 2009-09-18 A | 2010-03-19 A | 100% |  | 2009-09-18 | 2010-03-19 | 131d? |  | finish no earlier than 2010-03-19 | C1 | 1048h | 1048h | EMC2 | PCG-23 | Alcatel-Lucent | Keith Drage (drage@alcatel-lucent.com) | Rel-9 | CP-45 | Frederic |  |
| 1262 | 445 | PCC enhancements | 56d? | 2009-09-18 A | 2009-12-04 A | 100% |  | 2009-09-18 | 2009-12-04 | 56d? |  | finish no earlier than 2009-12-04 | C3 | 448h | 448h | PCC-Enh | PCG-23 | Huawei | Wei Weihua (weiwh@huawei.com) | Rel-9 | CP-45 | Jiwan |  |
| 1263 | 446 | 3GPP IMS Conferencing Management Object (MO) | 2d? | 2009-12-03 A | 2009-12-04 A | 100% |  | 2009-12-03 | 2009-12-04 | 2d? |  | start no earlier than 2009-12-03 | C1 | 16h | 16h | IMS_ConfMO | PCG-24 |  |  | Rel-9 | CP-46 | Frederic |  |
| 1264 | 447 | In Case of Emergency (ICE) Graphics | 3d? | 2010-03-17 A | 2010-03-19 A | 100% |  | 2010-03-17 | 2010-03-19 | 3d? |  | finish no earlier than 2010-03-19 | C6 | 24h | 24h | ICE_Graphics | PCG-24 | Sagem-Orga | heiko.kruse@sagem-orga.com | Rel-9 | CP-47 | Xavier |  |
| 1265 | 448 | **Rel-9 Improvements of the Radio Interface** | 397d? | 2008-09-12 A | 2010-03-19 A | 100% |  | 2008-09-12 | 2010-03-19 | 397d? |  |  | RP,GP | 19147.6h | 19147.6h | RInImp9 | PCG-21 |  |  | Rel-9 | RP-41 | Issam |  |
| 1266 | 448.1 | LCR TDD UE OTA Performance Requirements | 186d? | 2008-09-12 A | 2009-05-29 A | 100% |  | 2008-09-12 | 2009-05-29 | 186d? |  | finish no earlier than 2009-05-29 | R4 | 1488h | 1488h | RInImp9-RFLCROTA | PCG-21 | RITT | Wu Xiang (wuxiang@chinattl.com) | Rel-9 | RP-41 | Issam | RP-090389 |
| 1267 | 448.2 | **RF requirements for Multicarrier and Multi-RAT BS** | 347d? | 2008-11-21 A | 2010-03-19 A | 100% |  | 2008-11-21 | 2010-03-19 | 347d? |  |  | R4,G1 | 7403.6h | 7403.6h | RInImp9-RFmulti | PCG-21 | Ericsson | Johan.skold@ericsson.com | Rel-9 | RP-41 | Issam |  |
| 1268 | 448.2.1 | RAN4 part of RF requirements for Multicarrier and Multi RAT BS | 337d? | 2008-12-05 A | 2010-03-19 A | 100% |  | 2008-12-05 | 2010-03-19 | 337d? |  | finish no earlier than 2010-03-19 | R4 | 2696h | 2696h | RInImp9-Rfmulti | PCG-22 | Ericsson | johan.skold@ericsson.com | Rel-9 | RP-42 | Issam | RP-100027 |
| 1269 | 448.2.2 | GERAN part of RF requirements for Multicarrier and Multi RAT BS | 261d? | 2008-11-21 A | 2009-11-20 A | 100% |  | 2008-11-21 | 2009-11-20 | 261d? |  | finish no earlier than 2009-11-20 | G1 | 2088h | 2088h | RInImp9-RFmulti-GERAN | PCG-22 | Ericsson | mats.y.samuelsson@ericsson.com | Rel-9 | GP-40 | Paolo |  |
| 1270 | 448.3 | Extended UMTS/LTE 800 MHz | 207d? | 2008-12-05 A | 2009-09-18 A | 100% |  | 2008-12-05 | 2009-09-18 | 207d? |  |  | R4,R2,R3 | 1648h | 1648h | RInImp9-UMTSLTE800 | PCG-22 | NTT DoCoMo | Shingo Suwa (suwas@nttdocomo.co.jp) | Rel-9 | RP-42 | Issam | RP-090687 |
| 1271 | 448.4 | UMTS/LTE 800 MHz for Europe | 272d? | 2009-03-06 A | 2010-03-19 A | 100% |  | 2009-03-06 | 2010-03-19 | 272d? |  | finish no earlier than 2010-03-19 | R4,R2,R3 | 2176h | 2176h | RInImp9-UMTSLTE800EU | PCG-22 | Ericsson | olav.queseth@ericsson.com | Rel-9 | RP-43 | Issam | RP-100028 |
| 1272 | 448.5 | Performance requirement for LCR TDD with UE speeds up to 350 km/h | 196d? | 2009-03-06 A | 2009-12-04 A | 100% |  | 2009-03-06 | 2009-12-04 | 196d? |  | finish no earlier than 2009-12-04 | R4 | 1568h | 1568h | RInImp9-LCRTDD350 | PCG-22 | CATT | Yuexia Song (songyuexia@datangmobile.cn) | Rel-9 | RP-43 | Issam | RP-091035 |
| 1273 | 448.6 | Extended UMTS/LTE 1500 MHz | 211d? | 2009-05-30 A | 2010-03-19 A | 100% |  | 2009-05-30 | 2010-03-19 | 211d? |  | finish no earlier than 2010-03-19 | R4,R2,R3 | 1688h | 1688h | UMTSLTE1500 | PCG-23 | NTT DoCoMo | Shingo Suwa (suwas@nttdocomo.co.jp) | Rel-9 | RP-44 | Issam | RP-100029 |

Notes:
- 1245: CP#47 completed. Continuation of Rel-8 Feature UID_400012 IMS Restoration Procedures
- 1246: CP#47 completed / Text3: 23.380, 23.820
- 1247: CP#47 completed / Text3: 24.229
- 1248: CP#47 completed / Text3: 29.061, 29.212, 29.213, 29.214, 29.215
- 1249: CP#47 completed / Text3: 23.218, 24.229, 24.930
- 1250: CP#47 completed / Text3: 23.218, 24.229, 24.930
- 1251: Expired, work continue in draft-jones-insipid-session-id, but this is not referenced in our specifications yet / Text3: draft-kaplan-dispatch-session-id
- 1252: passed WGLC / Text3: draft-ietf-sipcore-rfc4244bis
- 1253: CP#56 added IETF dependency
- 1254: CP#48 completed / Text3: 29.165
- 1255: Expired, work continue in draft-jones-insipid-session-id (29.165) / Text3: draft-kaplan-dispatch-session-id
- 1256: Expired, (29.165) / Text3: draft-vanelburg-dispatch-private-network-ind
- 1257: Not completed internet-draft, (29.165) / Text3: draft-ietf-salud-alert-info-urns
- 1258: Passed WGLC / Text3: draft-ietf-cuss-sip-uui
- 1259: Passed WGLC / Text3: draft-ietf-cuss-sip-uui-isdn
- 1260: Not completed internet-draft, (29.165) / Text3: draft-dawes-sipping-debug
- 1261: CP#47 completed [Stage 3 for Rel-7 Emergency Calls (EMC1)]. Related to Rel-9 UID_400038 LCS Control Plane Solution for EPS. Stage 2 in Rel-9 UID_400038 (23.271), UID_410037 (23.167) / Text3: 24.229
- 1262: CP#46 completed / Text3: 29.212, 29.213, 29.215
- 1263: CP#46 completed. Linked to Rel-6 UID_11051 (IMS Management objects) under the Feature UID_32021 (IMS Phase 2). MO compatible with OMA DM v1.2 & upwards and defined using OMA DM Device Description Framework (OMA-ERELD _DM-V1_2) / Text3: new 24.166
- 1264: CP#47 approved WID and completed. Added capability to store ICE graphical information (picture). Linked to CT6 Rel-8 ICE Feature UID_380059 In Case of Emergency numbers storage and easy access on UICC / Text3: 31.102 CR#0433
- 1265: RP#41 umbrella Feature created to host Rel-9 WIs / Text3: GERAN, UTRA, LTE
- 1266: RP#44 completed technical work (RAN4 internal TR abandoned) / Text3: UTRA (no TR 25.8xy produced)
- 1267: RP#47 completed. RF requirements specification applicable to Multi-Standard Radio (MSR) Base Station with multiple carriers and/or multiple 3GPP Radio Access Technologies (RAT) / Text3: GERAN, UTRA, LTE
- 1268: RP#48 completed / Text3: UTRA, LTE 25.104, 25.105, 36.104, new 37.104, 37.113, 37.141, 37.900
- 1269: GP#44 Core spec completed. GP#40 WID approved / Text3: GERAN 45.005, 51.021
- 1270: RP#45 completed / Text3: UTRA, LTE 25.101, 25.104, 25.113, 25.133, 34.124, 36.101, 36.104, 36.113, 36.124, 36.133, 36.141, 25.306, 25.307, 25.331, 36.331, 25.461, 25.466, new 36.800
- 1271: RP#47 completed / Text3: UTRA, LTE 25.101, 25.104, 25.113, 25.133, 25.141, 34.124, 36.101, 36.104, 36.113, 36.124, 36.133, 36.141, new 36.810, 25.306, 25.307, 25.331, 36.331, 25.461, 25.466
- 1272: RP#46 completed / Text3: UTRA 25.102, 25.105, 25.142
- 1273: RP#47 completed. For potential deployment in Japan / Text3: UTRA, LTE 25.101, 25.104, 25.113, 25.133, 25.141, 25.306, 25.307, 25.331, 25.461, 25.466, 34.124, 36.101, 36.104, 36.113, 36.124, 36.133, 36.141, 36.331, new (36.821, 36.307)

| ID | WBS | Task | Duration | Start | Finish | Complete | Remaining | Baseline start | Baseline finish | Baseline duration | Total slack | Constraint | Resources | Work | Actual work | Text1 | Text2 | Text6 | Text7 | Text8 | Text4 | Text5 | Text11 |
| --- | --- | --- | --- | --- | --- | --- | --- | --- | --- | --- | --- | --- | --- | --- | --- | --- | --- | --- | --- | --- | --- | --- | --- |
| 1274 | 449 | **Rel-9 Improvements of the Radio Interface - UE Conformance Testing** | 350d? | 2009-05-19 A | 2010-09-17 A | 100% |  | 2009-05-19 | 2010-09-17 | 350d? |  |  | R5 | 8184h | 8184h | RInImp-UEConTest | PCG-23 | Rel-9 | RP-44 | Ingbert |  |  |  |
| 1275 | 449.1 | Conformance Test Aspects – UMTS/LTE in 800 MHz for Europe | 350d? | 2009-05-19 A | 2010-09-17 A | 100% |  | 2009-05-19 | 2010-09-17 | 350d? |  | finish no earlier than 2010-09-17 | R5 | 2800h | 2800h | RInImp-UEConTest-UMTSLTE800EU | PCG-23 | Rel-9 | RP-44 | Ingbert | Ericsson | fredrik.sundstrom@ericsson.com | RP-100736 |
| 1276 | 449.2 | Conformance Test Aspects – Extended UMTS/LTE 1500 MHz | 186d? | 2009-09-18 A | 2010-06-04 A | 100% |  | 2009-09-18 | 2010-06-04 | 186d? |  | finish no earlier than 2010-06-04 | R5 | 1488h | 1488h | UMTSLTE1500_UEConTest | PCG-23 | Rel-9 | RP-45 | Ingbert | NTT DoCoMo | Nguyen Dung Dao (dao@nttdocomo.co.jp) | RP-100487 |
| 1277 | 449.3 | TDD UE Over The Air (Antenna) conformance testing methodology | 81d? | 2009-05-30 A | 2009-09-18 A | 100% |  | 2009-05-30 | 2009-09-18 | 81d? |  | finish no earlier than 2009-09-18 | R5 | 648h | 648h | UEAnt_TDDTest | PCG-23 | Rel-9 | RP-44 | Ingbert | CATR | Qu Yan (quyan@emcite.com) | RP-090727 |
| 1278 | 449.4 | Conformance Test Aspects – Performance requirement for LCR TDD with UE speeds up to 350 km/h | 56d? | 2010-03-19 A | 2010-06-04 A | 100% |  | 2010-03-19 | 2010-06-04 | 56d? |  | finish no earlier than 2010-06-04 | R5 | 448h | 448h | RInImp9-LCRTDD350_UEConTest | PCG-24 | Rel-9 | RP-47 | Ingbert | CATT | Xiaozhong Chen (chexiaozhong@datangmobile.cn) | RP-100496 |
| 1279 | 450 | Conformance Test Aspects – SMS over IMS in E-UTRAN | 131d? | 2009-09-18 A | 2010-03-19 A | 100% |  | 2009-09-18 | 2010-03-19 | 131d? |  | finish no earlier than 2010-06-18 | R5 | 1048h | 1048h | SMSoverIMS_UEConTest | PCG-23 | Rel-9 | RP-45 | Ingbert | Alcatel-Lucent | Nidal Khrais (khrais@alcatel-lucent.com) | RP-100072 |
| 1280 | 451 | **Rel-9 RAN improvements** | 272d? | 2009-03-06 A | 2010-03-19 A | 100% |  | 2009-03-06 | 2010-03-19 | 272d? |  |  | RP | 9536h | 9536h | RANimp | PCG-22 | Rel-9 | RP-43 | Issam |  |  |  |
| 1281 | 451.1 | Dual-Cell HSUPA | 272d? | 2009-03-06 A | 2010-03-19 A | 100% |  | 2009-03-06 | 2010-03-19 | 272d? |  | finish no earlier than 2010-03-19 | R1,R2,R3,R4 | 1568h | 1568h | RANimp-DC_HSUPA | PCG-22 | Rel-9 | RP-43 | Patrick | Nokia Siemens Networks | Karri Ranta-aho (karri.ranta-aho@nsn.com) | RP-100030 |
| 1282 | 451.2 | Support for different bands for Dual-Cell HSDPA | 197d? | 2009-03-06 A | 2009-12-04 A | 100% |  | 2009-03-06 | 2009-12-04 | 197d? |  |  | R4,R2,R3 | 1568h | 1568h | RANimp-MultiBand_DC_HSDPA | PCG-22 | Rel-9 | RP-43 | Issam | Nokia Siemens Networks | Tuomo Säynäjäkangas (tuomo.saynajakangas@nsn.com) | RP-091038 |
| 1283 | 451.3 | Combination of DC-HSDPA with MIMO | 197d? | 2009-03-06 A | 2009-12-04 A | 100% |  | 2009-03-06 | 2009-12-04 | 197d? |  |  | R1,R2,R3,R4 | 1568h | 1568h | RANimp-DC_MIMO | PCG-22 | Rel-9 | RP-43 | Patrick | Ericsson | johan.bergman@ericsson.com | RP-091039 |
| 1284 | 451.4 | Transmit Antenna Array (TxAA) extension for non-MIMO UEs | 197d? | 2009-03-06 A | 2009-12-04 A | 100% |  | 2009-03-06 | 2009-12-04 | 197d? |  |  | R1,R2,R3,R4 | 1568h | 1568h | RANimp-TxAA_nonMIMO | PCG-22 | Rel-9 | RP-43 | Patrick | Nokia | Arto Lehti (arto.lehti@nokia.com) | RP-091040 |
| 1285 | 451.5 | Cell Portion for 1.28 Mcps TDD | 136d? | 2009-05-30 A | 2009-12-04 A | 100% |  | 2009-05-30 | 2009-12-04 | 136d? |  |  | R3,R1,R4 | 1088h | 1088h | CP_LCRTDD | PCG-23 | Rel-9 | RP-44 | Juha | CATT | Ying Zhang (zhangying2@datangmobile.cn) | RP-091041 |
| 1286 | 452 | **Rel-9 RAN improvements - UE Conformance Testing** | 586d? | 2010-09-17 A | 2012-12-07 | 97% | 14.86d? | 2010-09-17 | 2012-12-07 | 586d? | 463d |  | R5 | 11832h | 11531.9h |  | PCG-25 | Rel-9 | RP-49 | Ingbert |  |  |  |
| 1287 | 452.1 | Conformance Test Aspects – Combination of DC-HSDPA with MIMO | 186d? | 2010-09-17 A | 2011-06-03 A | 100% |  | 2010-09-17 | 2011-06-03 | 186d? |  | finish no earlier than 2011-06-03 | R5 | 1488h | 1488h | RANimp-DC_MIMO_UEConTest | PCG-25 | Rel-9 | RP-49 | Ingbert | Ericsson | leif.mattisson@ericsson.com | RP-110510 |
| 1288 | 452.2 | Conformance Test Aspects – Dual-Cell HSUPA | 453d? | 2011-03-18 A | 2012-12-07 | 95% | 22.65d? | 2011-03-18 | 2012-12-07 | 453d? | 463d | finish no earlier than 2012-12-07 | R5 | 3624h | 3442.8h | RANimp-DC_HSUPA_UEConTest | PCG-26 | Rel-9 | RP-51 | Ingbert | Ericsson | leif.mattisson@ericsson.com | RP-120954 |
| 1289 | 452.3 | Conformance Test Aspects – Support for different bands for Dual-Cell HSDPA | 254d? | 2011-03-18 A | 2012-03-02 A | 100% |  | 2011-03-18 | 2012-03-02 | 254d? |  | finish no earlier than 2012-03-02 | R5 | 2032h | 2032h | RANimp-MultiBand_DC_HSDPA_UEConTest | PCG-26 | Rel-9 | RP-51 | Ingbert | Ericsson | leif.mattisson@ericsson.com | RP-120036 |
| 1290 | 453 | **LTE improvements** | 587d? | 2009-03-06 A | 2011-06-03 A | 100% |  | 2009-03-06 | 2011-06-03 | 587d? |  |  | R1,R2,R4,R5 | 9928h | 9928h | LTEimp | PCG-22 | Rel-9 | RP-42 | Patrick |  |  |  |
| 1291 | 453.1 | LTE Pico NodeB RF Requirements | 196d? | 2009-03-06 A | 2009-12-04 A | 100% |  | 2009-03-06 | 2009-12-04 | 196d? |  | finish no earlier than 2010-03-05 | R4 | 1568h | 1568h | LTEimp-Pico_eNB-RF | PCG-22 | Rel-9 | RP-43 | Issam | Huawei | Liyan Yin (yinliyan@huawei.com) | RP-091045 |
| 1292 | 453.2 | Enhanced Dual-Layer transmission for LTE | 272d? | 2009-03-06 A | 2010-03-19 A | 100% |  | 2009-03-06 | 2010-03-19 | 272d? |  | finish no earlier than 2010-03-18 | R1,R2,R4 | 2176h | 2176h | LTEimp-eDL | PCG-22 | Rel-9 | RP-43 | Patrick | China Mobile | Xu Xiaodong (xuxiaodong@chinamobile.com) | RP-100034 |
| 1293 | 453.3 | UE Conformance Test Aspects – Enhanced Dual-layer transmission for LTE TDD | 186d? | 2010-09-17 A | 2011-06-03 A | 100% |  | 2010-09-17 | 2011-06-03 | 186d? |  | finish no earlier than 2011-06-03 | R5 | 1488h | 1488h | LTEimp-eDL_UEConTest | PCG-25 | Rel-9 | RP-49 | Ingbert | China Mobile | Shanpeng Xiao (xiaoshanpeng@chinamobile.com) | RP-110509 |
| 1294 | 454 | Rel-9 Self-Organizing Networks (SON) | 272d? | 2009-03-06 A | 2010-03-19 A | 100% |  | 2009-03-06 | 2010-03-19 | 272d? |  | finish no earlier than 2010-03-19 | R3,R2 | 2176h | 2176h | SON | PCG-22 | Rel-9 | SP-42 | Juha | Nokia Siemens Networks | krzysztof.kordybach@nsn.com | RP-100038 |
| 1295 | 455 | **AGNSS Performances and Testing Procedures** | 787d? | 2008-05-16 A | 2011-05-20 A | 100% |  | 2008-05-16 | 2011-05-20 | 787d? |  |  | G1,G3new | 16368h | 16368h | AGNSSPTP |  | Rel-9 |  | Paolo | Thales | Michel.monnerat@thalesaleniaspace.com |  |
| 1296 | 455.1 | AGNSS Minimum Performances | 472d? | 2008-05-16 A | 2010-03-05 A | 100% |  | 2008-05-16 | 2010-03-05 | 472d? |  | finish no earlier than 2010-03-05 | G1 | 3776h | 3776h | AGNSSPTP-Perfreq |  | Rel-9 |  | Paolo | Thales | Michel.monnerat@thalesaleniaspace.com |  |
| 1297 | 455.2 | AGNSS Testing Procedures | 787d? | 2008-05-16 A | 2011-05-20 A | 100% |  | 2008-05-16 | 2011-05-20 | 787d? |  | finish no earlier than 2011-05-20 | G3new | 6296h | 6296h | AGNSSPTP-MStest |  | Rel-9 |  | Ingbert | Thales | Michel.monnerat@thalesaleniaspace.com |  |

Notes:
- 1274: - / Text3: UTRA, LTE
- 1275: RP#49 completed. Testing for UID_430009 UMTS/LTE 800 MHz for Europe / Text3: UTRA, LTE 34.108, 34.121-1, 34.121-2, 36.508, 36.521-1, 36.521-2, 36.521-3
- 1276: RP#48 completed / Text3: UTRA, LTE 34.108, 34.121-1, 34.121-2, 34.123-1, 34.123-2, 36.508, 36.521-1, 36.521-2, 36.521-3, 36.523-1, 36.523-2, 36.523-3
- 1277: RP#45 completed. Finalized TDD UE test methodology based on R4 TR 25.914 (UE and MS antenna performance evaluation method) and TS 25.144 Over the Air (Antenna) minimum performance requirements for the speech mode (terminal close to head) / Text3: UTRA 34.114
- 1278: RP#48 completed. Testing for UID_430010 Performance requirement for LCR TDD with UE speeds up to 350 km/h / Text3: UTRA 34.122
- 1279: RP#47 completed / Text3: LTE 34.229-1, 34.229-2, 34.229-3
- 1280: RP#47 completed / Text3: UTRA
- 1281: RP#47 completed / Text3: 25.101, 25.104, 25.133, 25.211, 25.212, 25.213, 25.214, 25.215, 25.319, 25.306, 25.321, 25.331, 25.423, 25.433
- 1282: RP#46 completed / Text3: 25.101, 25.104, 25.133, 25.306, 25.308, 25.331, 25.423, 25.433, new 25.317 (Requirements on Ues supporting a release-independent frequency band combination)
- 1283: RP#46 completed / Text3: 25.101, 25.104, 25.133, 25.211, 25.212, 25.213, 25.214, 25.215, 25.308, 25.321, 25.331, 26.306, 25.423, 25.433
- 1284: RP#46 completed / Text3: 25.101, 25.104, 25.211, 25.212, 25.213, 25.214, 25.215, 25.308, 25.306, 25.321, 25.331, 25.423, 25.433
- 1285: RP#46 completed / Text3: 25.102, 25.105, 25.123, 25.225, 25.423, 25.433
- 1286: -
- 1287: UTRA. RP#52 completed. Testing for Rel-9 UID_430016 Combination of DC-HSDPA with MIMO / Text3: UTRA 34.108, 34.121-1, 34.121-2, 34.123-1, 34.123-2, 34.123-3
- 1288: RP#57 completion 09/12=>12/12. Testing for Rel-9 UID_430014 Dual-Cell HSUPA / Text3: UTRA 34.108, 34.121-1, 34.121-2, 34.123-1, 34.123-2, 34.123-3
- 1289: RP#55 completed. Testing for Rel-9 UID_430015 Support for different bands for Dual-Cell HSDPA / Text3: UTRA 34.108, 34.121-1, 34.121-2, 34.123-1, 34.123-2, 34.123-3
- 1290: - / Text3: LTE
- 1291: RP#46 completed / Text3: 36.104, 36.141, new 36.931
- 1292: RP#47 completed / Text3: 36.101, 36.211, 36.212, 36.213, 36.331
- 1293: RP#52 completed. Testing for UID_430029 (Enhanced Dual-Layer transmission for LTE) / Text3: 36.508, 36.521-1, 36.521-2
- 1294: RP#47 completed / Text3: LTE 25.413, 36.300, 36.413, 36.423, 48.018, new 36.902
- 1295: GP#46 still ongoing MS testing. Linked to Rel-10 RAN4 UID_450027 (AGNSS Minimum Performance for UTRAN)
- 1296: GP#45 completed (open performance requirements alignment GPS/Galileo) / Text3: 45.005
- 1297: GP#50 completed / Text3: 51.010-1, new 51.010-7

| ID | WBS | Task | Type | Duration | Start | Finish | Complete | Baseline start | Baseline finish | Baseline duration | Constraint | Resources | Work | Actual work | Text1 | Text2 | Text4 | Text5 | Text6 | Text7 | Text8 | Text9 | Text12 | Text11 |
| --- | --- | --- | --- | --- | --- | --- | --- | --- | --- | --- | --- | --- | --- | --- | --- | --- | --- | --- | --- | --- | --- | --- | --- | --- |
| 1298 | 456 | **Voice services over Adaptive Multi-user channels on One Slot** |  | 860d? | 2008-11-21 A | 2012-03-02 A | 100% | 2008-11-21 | 2012-03-02 | 860d? |  | GP,G1,G2,G3new | 24728h | 24728h | VAMOS | PCG-22 | Nokia Siemens Networks, China Mobile | juergen.hofmann@nsn.com, liuxiaoyu@chinamobile.com | Rel-9 | SP-42 | Paolo |  |  |  |
| 1299 | 456.1 | Stage 2 for Voice services over Adaptive Multi-user channels on One Slot |  | 392d? | 2008-11-21 A | 2010-05-21 A | 100% | 2008-11-21 | 2010-05-21 | 392d? | finish no earlier than 2010-05-21 | GP,G1,G2 | 3136h | 3136h | VAMOS | PCG-22 | Nokia Siemens Networks, China Mobile | juergen.hofmann@nsn.com, liuxiaoyu@chinamobile.com | Rel-9 | GP-40 | Paolo |  |  |  |
| 1300 | 456.2 | Stage 3 for Voice services over Adaptive Multi-user channels on One Slot |  | 596d? | 2008-11-24 A | 2011-03-04 A | 100% | 2008-11-24 | 2011-03-04 | 596d? | finish no earlier than 2011-03-04 | GP,G1,G2 | 4768h | 4768h | VAMOS | PCG-22 | Nokia Siemens Networks, China Mobile | juergen.hofmann@nsn.com, liuxiaoyu@chinamobile.com | Rel-9 | GP-40 | Paolo |  |  |  |
| 1301 | 456.3 | VAMOS Radio Performance Requirements |  | 651d? | 2008-11-24 A | 2011-05-20 A | 100% | 2008-11-24 | 2011-05-20 | 651d? | finish no earlier than 2011-05-20 | GP,G1,G2 | 5208h | 5208h | VAMOS | PCG-22 | Nokia Siemens Networks, China Mobile | juergen.hofmann@nsn.com, liuxiaoyu@chinamobile.com | Rel-9 | GP-40 | Paolo |  |  |  |
| 1302 | 456.4 | VAMOS - MS conformance testing |  | 392d? | 2010-09-03 A | 2012-03-02 A | 100% | 2010-09-03 | 2012-03-02 | 392d? | finish no earlier than 2012-03-02 | G3new | 3128h | 3128h | VAMOS_MStest | PCG-25 | Research In Motion | Raveendra Seetharam (rseetharam@rim.com) | Rel-9 | GP-47 | Ingbert |  |  |  |
| 1303 | 456.5 | VAMOS - BTS conformance testing |  | 201d? | 2010-11-26 A | 2011-09-02 A | 100% | 2010-11-26 | 2011-09-02 | 201d? | finish no earlier than 2011-09-02 | G1 | 1608h | 1608h | VAMOS_BTStest | PCG-26 | Nokia Siemens Networks | eddie.riddington@nsn.com | Rel-9 | GP-48 | Paolo |  |  |  |
| 1304 | 457 | **Cell Broadcast protocol Base Station Controller – Cell Broadcast Centre (BSC-CBC)** |  | 222d? | 2009-05-15 A | 2010-03-19 A | 100% | 2009-05-15 | 2010-03-19 | 222d? |  | GP,C1 | 5248h | 5248h | CEBRO | PCG-23 | Ericsson | claes-goran.persson@ericsson.com | Rel-9 | GP-42 | Paolo |  |  |  |
| 1305 | 457.1 | GERAN part of Cell Broadcast protocol Base Station Controller – Cell Broadcast Centre |  | 212d? | 2009-05-15 A | 2010-03-05 A | 100% | 2009-05-15 | 2010-03-05 | 212d? | finish no earlier than 2010-03-05 | GP | 1696h | 1696h | CEBRO | PCG-23 | Ericsson | claes-goran.persson@ericsson.com | Rel-9 | GP-42 | Paolo |  |  |  |
| 1306 | 457.2 | CT1 part of Cell Broadcast protocol Base Station Controller – Cell Broadcast Centre |  | 222d? | 2009-05-15 A | 2010-03-19 A | 100% | 2009-05-15 | 2010-03-19 | 222d? | finish no earlier than 2010-03-19 | C1 | 1776h | 1776h | CEBRO | PCG-23 | Ericsson | claes-goran.persson@ericsson.com | Rel-9 | GP-42 | Frederic |  |  |  |
| 1307 | 458 | Hybrid Location |  | 136d? | 2009-05-18 A | 2009-11-20 A | 100% | 2009-05-18 | 2009-11-20 | 136d? | finish no earlier than 2009-11-20 | GP | 1088h | 1088h | HILT | PCG-23 | TruePosition | Matt Ward (mward@trueposition.com) | Rel-9 | GP-42 | Paolo |  |  |  |
| 1308 | 459 | (Small) Technical Enhancements and Improvements for Rel-9 |  | 325d? | 2008-09-15 A | 2009-12-10 A | 100% | 2008-09-15 | 2009-12-10 | 325d? | finish no earlier than 2009-12-10 | All | 2600h | 2600h | TEI9 | PCG-22 |  |  | Rel-9 | SP-42 | All |  |  |  |
| 1309 | 460 | Test - (Small) Technical Enhancements and Improvements for Rel-9 |  | 286d? | 2009-11-20 A | 2010-12-24 A | 100% | 2009-11-20 | 2010-12-24 | 286d? | finish no earlier than 2010-12-24 | R5,G3new | 2288h | 2288h | TEI9_Test | PCG-24 |  |  | Rel-9 | GP-44 | Ingbert |  |  |  |
| 1310 | 461 | **Deleted - Services Alignment and Migration** |  | 467d? | 2006-12-06 A | 2008-09-18 A | 100% | 2006-12-06 | 2008-09-18 | 467d? |  | S1 | 7472h | 7472h | ServAl |  | Telefónica O2 | chris.friel@O2.com | Rel-9 | SP-33 | Alain |  |  |  |
| 1311 | 461.1 | Deleted - Stage 1 for ServAl |  | 467d? | 2006-12-06 A | 2008-09-18 A | 100% | 2006-12-06 | 2008-09-18 | 467d? | finish no earlier than 2008-12-11 | S1 | 3736h | 3736h | ServAl | PCG-21 | Telefónica O2 | chris.friel@O2.com | Rel-9 | SP-33 | Alain |  |  |  |
| 1312 | 462 | Deleted - Harmonization of Gq'/Rx for Common IMS |  | 304d? | 2008-01-14 A | 2009-03-12 A | 100% | 2008-01-14 | 2009-03-12 | 304d? | finish no earlier than 2009-03-12 | S2 | 2432h | 2432h | IMS_Comm_GqRx_Harm | PCG-21 | Alcatel-Lucent | geoffrey.cristallo@alcatel-lucent.be | Rel-9 | SP-38 | Maurice | PCG-22 | SP-43 |  |
| 1313 | 463 | Deleted - Support of WiMAX - LTE Mobility |  | 407d? | 2008-06-06 A | 2009-12-25 A | 100% | 2008-06-06 | 2009-12-25 | 407d? | start no earlier than 2008-06-06 | R2 | 3248h | 3248h | WiMAX_LTE_Mobility | PCG-21 | Samsung |  | Rel-9 | RP-38 | Joern | PCG-21 | SP-39 |  |
| 1314 | 464 | Deleted - Support of WiMAX - UMTS Mobility |  | 407d? | 2008-06-06 A | 2009-12-25 A | 100% | 2008-06-06 | 2009-12-25 | 407d? | start no earlier than 2008-06-06 | R2 | 3248h | 3248h | WiMAX_UMTS_Mobility | PCG-21 | Intel |  | Rel-9 | RP-38 | Joern | PCG-21 | SP-39 |  |
| 1315 | 465 | Deleted - Definition of 3GPP UICC services over the new high-speed interface | milestone | 0d? | 2010-03-19 A | 2010-03-19 A | 100% | 2010-03-19 | 2010-03-19 | 0d? |  | C6 |  |  | UICCHS | PCG-21 | Gemalto | Denis.Lheriteau@gemalto.com | Rel-9 | CP-38 | Xavier | PCG-24 | CP-47 |  |
| 1316 | 466 | **Deleted - SAES Enhancements (non RAN aspects)** |  | 381d? | 2007-06-25 A | 2008-12-08 A | 100% | 2007-06-25 | 2008-12-08 | 381d? |  | S2 | 11664h | 11664h | SAES_Ph2 | PCG-21 | Nokia Siemens Networks |  | Rel-9 | SP-39 | Maurice | PCG-21 | SP-39 |  |
| 1317 | 466.1 | Deleted - Functions and procedures for SAE to support LTE MBMS |  | 381d? | 2007-06-25 A | 2008-12-08 A | 100% | 2007-06-25 | 2008-12-08 | 381d? | finish no earlier than 2008-12-08 | S2 | 3048h | 3048h | SAES_Ph2 |  |  |  | Rel-9 | SP-35 | Maurice | PCG-21 | SP-39 |  |
| 1318 | 466.2 | Deleted - CS over EPS |  | 194d? | 2008-03-12 A | 2008-12-08 A | 100% | 2008-03-12 | 2008-12-08 | 194d? | finish no earlier than 2008-12-08 | S2 | 1552h | 1552h | SAES_Ph2 | PCG-21 |  |  | Rel-9 | SP-39 | Maurice | PCG-21 | SP-39 |  |
| 1319 | 466.3 | **Deleted - SAE for generic support for non-3GPP accesses** |  | 251d? | 2007-06-25 A | 2008-06-09 A | 100% | 2007-06-25 | 2008-06-09 | 251d? |  | S2 | 4016h | 4016h | SAES_Ph2 | PCG-21 |  |  | Rel-9 | SP-39 | Maurice | PCG-21 | SP-39 |  |
| 1320 | 466.3.1 | Deleted - Single Radio Aspects of SAE for Optimized Handover with WiMAX |  | 251d? | 2007-06-25 A | 2008-06-09 A | 100% | 2007-06-25 | 2008-06-09 | 251d? | finish no earlier than 2008-06-09 | S2 | 2008h | 2008h | SAES_Ph2 | PCG-21 |  |  | Rel-9 | SP-39 | Maurice | PCG-21 | SP-39 |  |
| 1321 | 467 | Deleted - Lawful Interception in the 3GPP Rel-9 |  | 211d? | 2009-06-04 A | 2010-03-25 A | 100% | 2009-06-04 | 2010-03-25 | 211d? | finish no earlier than 2010-03-25 | S3 | 1688h | 1688h | LI9 | PCG-23 | PIDS, Nortel | Koen Jaspers, Ronald Ryan | Rel-9 | SP-44 | Dionisio | PCG-24 | SP-47 |  |
| 1322 | 468 | Release 9 Studies |  | 468d? | 2008-06-05 A | 2010-03-19 A | 100% | 2008-06-05 | 2010-03-19 | 468d? |  | CP,RP,SP | 3744h | 3744h |  |  |  |  | Rel-9 |  |  |  |  |  |
| 1323 | 469 | Study on Service Specific Access Control in EPS |  | 136d? | 2008-06-05 A | 2008-12-11 A | 100% | 2008-06-05 | 2008-12-11 | 136d? | start no earlier than 2008-06-05 | S1 | 1088h | 1088h | FS_SSAC | PCG-21 | NTT DoCoMo | Shin-ichi Isobe (isobes@nttdocomo.co.jp) | Rel-9 | SP-40 | Alain |  |  |  |
| 1324 | 470 | Study on CS Domain Services over EPS access |  | 492d? | 2007-04-25 A | 2009-03-12 A | 100% | 2007-04-25 | 2009-03-12 | 492d? | finish no earlier than 2009-03-12 | S2 | 3936h | 3936h | FS_CSoPS |  | T-Mobile | Karl-Heinz.Nenner@T-Mobile.net | Rel-9 | SP-35 | Maurice |  |  |  |
| 1325 | 471 | Study on Extended Support of IMS Emergency Calls |  | 319d? | 2007-09-24 A | 2008-12-11 A | 100% | 2007-09-24 | 2008-12-11 | 319d? | finish no earlier than 2009-06-18 | S2 | 2552h | 2552h | FS_IMS-eCall |  | Qualcomm | Stephen Edge | Rel-9 | SP-37 | Maurice |  |  |  |
| 1326 | 472 | Study on Service Continuity for Emergency Voice Calls |  | 721d? | 2006-06-08 A | 2009-03-12 A | 100% | 2006-06-08 | 2009-03-12 | 721d? | finish no earlier than 2009-03-12 | S2 | 5768h | 5768h | FS_VCCEm |  | Nortel | Ricky Kaura (rkaura@nortel.com) | Rel-9 | SP-32 | Maurice |  |  |  |
| 1327 | 473 | Study on Security Aspects of Remote Provisioning and Change of Subscription for M2M Equipment |  | 582d? | 2004-04-06 A | 2009-12-10 A | 100% | 2004-04-06 | 2009-12-10 | 582d? | finish no earlier than 2009-12-10 | S3,C6 | 4656h | 4656h | FS_UM2M |  | Ericsson | vesa.lehtovirta@ericsson.com | Rel-9 | SP-37 | Dionisio |  |  |  |
| 1328 | 474 | Study on System Maintenance over Itf-N |  | 602d? | 2007-06-07 A | 2009-09-24 A | 100% | 2007-06-07 | 2009-09-24 | 602d? | finish no earlier than 2009-09-24 | S5 | 4808h | 4808h | FS_OAM-Maint-Itf-N |  | ZTE | Shuqiang Huang (huangsq@zte.com.cn) | Rel-9 | SP-36 | Dionisio |  |  |  |
| 1329 | 475 | Study on Self-Organizing Networks (SON) related OAM interfaces for Home NodeB |  | 522d? | 2007-06-07 A | 2009-06-04 A | 100% | 2007-06-07 | 2009-06-04 | 522d? | finish no earlier than 2009-12-10 | S5 | 4168h | 4168h | FS_OAM-SON-HNB |  | Huawei | Zou Lan (zlan@huawei.com) | Rel-9 | SP-36 | Dionisio |  |  |  |
| 1330 | 476 | Study on Self-healing of Self-Organizing Networks (SON) |  | 416d? | 2008-02-22 A | 2009-09-24 A | 100% | 2008-02-22 | 2009-09-24 | 416d? | finish no earlier than 2009-09-24 | S5 | 3320.15h | 3320.15h | FS_OAM-SON-SH | PCG-21 | ZTE | zhu.weihong@zte.com.cn | Rel-9 | SP-39 | Dionisio |  |  |  |
| 1331 | 477 | Study on Service Oriented Architecture (SOA) for IRP |  | 262d? | 2008-06-05 A | 2009-06-04 A | 100% | 2008-06-05 | 2009-06-04 | 262d? | finish no earlier than 2009-05-20 | S5 | 2088h | 2088h | FS_OAM_SOA_IRP | PCG-21 | Ericsson | edwin.tse@ericsson.com | Rel-9 | SP-40 | Dionisio |  |  |  |
| 1332 | 478 | Study on Evaluation of the inclusion of Path Loss Based Technology in the UTRAN |  | 516d? | 2007-12-17 A | 2009-12-04 A | 100% | 2007-12-17 | 2009-12-04 | 516d? | finish no earlier than 2009-09-18 | R4 | 4120h | 4120h | FS_RAN-Pathloss | PCG-21 | Polaris Wireless | Norman Shaw (nshaw@polariswireless.com) | Rel-9 | RP-38 | Issam |  |  | RP-091080 |
| 1333 | 479 | Study on LTE-Advanced |  | 461d? | 2007-03-23 A | 2010-03-19 A | 100% | 2007-03-23 | 2010-03-19 | 461d? | finish no earlier than 2010-03-19 | R1,R2,R3,R4 | 3688h | 3688h | FS_RAN_LTEA | PCG-21 | NTT DoCoMo | Tetsushi Abe | Rel-9 | RP-39 | Patrick |  |  | RP-100080 |
| 1334 | 480 | Study on 1.28 Mcps TDD Home NodeB |  | 387d? | 2008-02-20 A | 2009-12-04 A | 100% | 2008-02-20 | 2009-12-04 | 387d? | finish no earlier than 2009-12-04 | R4 | 3096h | 3096h | FS_RAN-HNBLCRTDD | PCG-21 | TD Tech | Li Rong (lirong@td-tech.com) | Rel-9 | RP-41 | Issam |  |  | RP-091081 |
| 1335 | 481 | Study on E-UTRAN Mobility Evaluation and Enhancement |  | 126d? | 2008-12-05 A | 2009-05-29 A | 100% | 2008-12-05 | 2009-05-29 | 126d? | finish no earlier than 2009-05-29 | R1 | 1008h | 1008h | FS_EUTRAN_mob | PCG-22 | Qualcomm | Rajat Prakash (rprakash@qualcomm.com) | Rel-9 | RP-42 | Patrick |  |  | RP-090426 |
| 1336 | 482 | Study on Minimization of drive-tests in Next Generation Networks |  | 196d? | 2009-03-06 A | 2009-12-04 A | 100% | 2009-03-06 | 2009-12-04 | 196d? | finish no earlier than 2009-12-04 | R2 | 1568h | 1568h | FS_NGN_min_drive-tests | PCG-22 | Qualcomm | Masato Kitazoe (mkitazoe@qualcomm.com) | Rel-9 | RP-43 | Joern |  |  | RP-091084 |
| 1337 | 483 | Study on Enhanced Interference Management for HNBs |  | 61d? | 2009-03-06 A | 2009-05-29 A | 100% | 2009-03-06 | 2009-05-29 | 61d? | start no earlier than 2009-03-06 | R4 | 488h | 488h | FS_eInterfMgmt_HNB | PCG-22 | Qualcomm | Farhad Meshkati (fmeshkat@qualcomm.com) | Rel-9 | RP-43 | Issam |  |  | RP-090429 |
| 1338 | 484 | Study on Enhanced Interference Management Mechanisms for HNBs |  | 81d? | 2009-05-30 A | 2009-09-18 A | 100% | 2009-05-30 | 2009-09-18 | 81d? | finish no earlier than 2009-09-18 | R3 | 648h | 648h | FS_eInterfMgmtMchsm_HNB | PCG-23 | Qualcomm | Farhad Meshkati (fmeshkat@qualcomm.com) | Rel-9 | RP-44 | Juha |  |  | RP-090733 |
| 1339 | 485 | Deleted - Study on Protection against SMS and MMS spam |  | 862d? | 2006-06-08 A | 2009-09-24 A | 100% | 2006-06-08 | 2009-09-24 | 862d? | finish no earlier than 2009-09-24 | S3 | 6896h | 6896h | FS_CPSMal |  | Orange | eric.gauthier@orange.ch | Rel-9 | SP-32 | Dionisio | PCG-23 | SP-45 |  |
| 1340 | 486 | Release 8 Features |  | 914.3d? | 2006-09-19 A | 2010-03-19 A | 100% | 2006-09-19 | 2010-03-19 | 914.3d? | start no earlier than 2000-01-03 | CP,GP,RP,SP | 7314.4h | 7314.4h |  |  |  |  | Rel-8 |  |  |  |  |  |

Notes:
- 1298: Triggered by UID_50590 (MUROS) Study on Multi-User Reusing-One-Slot
- 1299: GP#46 completed. GP#40 WID approved / Text3: 45.001
- 1300: GP#49 completed. GP#40 WID approved / Text3: 24.008, 44.018, 45.002, 45.003, 45.004, 45.008, 48.008, 48.058
- 1301: GP#50 completed. GP#40 WID approved / Text3: 45.005
- 1302: GP#53 completed. GP#47 WID approved / Text3: 51.010-1, 51.010-2
- 1303: GP#51 completed. GP#48 WID approved / Text3: 51.021
- 1304: CP#47 completed. GP#45 completed. GP#42 WID approved
- 1305: GP#45 completed. GP#42 WID approved / Text3: new 48.049
- 1306: CP#47 completed / Text3: 23.041
- 1307: GP#44 completed. GP#42 WID approved (Hybrid Integrated Location Technology=HILT) / Text3: 43.059, 48.071
- 1308: SP#46 completed
- 1309: GP#44 created
- 1310: SP#41 closed (no tangible result of this work; no CR against TR 22.983). Triggered by Study UID_370086 (FSServAl)
- 1311: SP#41 closed (no tangible result of this work; no CR against TR 22.983) / Text3: 22.983
- 1312: SP#43 stopped. LS_out to TISPAN informs about stopping this activity / Text3: 23.822, 23.203
- 1313: RP#39: No agreed WID / Text3: 36.306, 36.331, 36.413, 36.300, 36.214, 36.133, 36.304
- 1314: RP#39: No agreed WID / Text3: 25.306, 25.331, 25.413
- 1315: CP#47 work stopped/abandoned / Text3: 31.xyz
- 1316: SP#39 created to host Rel-9 Wis. BUT no agreed WID
- 1317: SP#39 SAE functionality moved to Rel-9. WID returned to SA2 for re-consideration & remove MBMS for EPS from Rel 8
- 1318: SP#39 SAE functionality moved to Rel-9. BUT no agreed WID
- 1319: SP#39 SAE functionality moved to Rel-9. BUT no agreed WID
- 1320: SP#39 SAE functionality moved to Rel-9. BUT no agreed WID
- 1321: SP#47 stopped. WI + new topics moved to Rel-10 / Text3: 33.106, 33.107, 33.108
- 1322: -
- 1323: SP#42 completed. Spin-off Feature UID_420020 (SSAC) / Text3: 22.986
- 1324: SP#43 completed. Linked to Combinational Services UID_31064, Services Alignment and Migration (ServAl) UID_330017 and 3GPP System Architecture Evolution (SAES) UID_3208 / Text3: 23.879
- 1325: SP#42 completed / Text3: 23.868
- 1326: SP#43 completed / Text3: 23.826
- 1327: SP#46 completed. Triggered by the SA1 Rel-8 Study on Facilitating Machine to Machine Communication in GSM and UMTS (FS_M2M) UID_7027 in TR 22.868. / Text3: 33.812
- 1328: SP#45 completed / Text3: 32.822
- 1329: SP#44 completed. Linked to SA5 TR 32.816 Study of Management for LTE and SAE (UID_340036) / Text3: 32.821
- 1330: SP#45 completed. Linked to SA5 TR 32.816 Study of Management for LTE and SAE (UID_340036) / Text3: 32.823
- 1331: SP#44 completed. Spin-off implementation WI UID_440064 Service Oriented Architecture (SOA) for IRP / Text3: 32.824
- 1332: RP#46 completed / Text3: 25.907
- 1333: RP#47 completed / Text3: 36.913 , new 36.814, 36.912, R2 36.806 (Relay architectures for E-UTRA), R4 36.815 (LTE-Advanced feasibility studies in RAN4)
- 1334: RP#46 completed / Text3: 25.866
- 1335: RP#44 closed (RP-090452 R1 LS to RAN on Conclusions for LTE Mobility Study Item - no further Rel-9 action / no TR needed) / Text3: none
- 1336: RP#46 completed / Text3: 36.805
- 1337: RP#44 completed. Linked to UID_420008 LTE FDD Home eNodeB RF Requirements. Spin-off RAN3 UID_440015 Study on Enhanced Interference Management Mechanisms for HNBs / Text3: 25.967
- 1338: RP#45 completed. Triggered by RAN4 UID_430027 Study on Enhanced Interference Management for HNBs / Text3: 25.967
- 1339: SP#45 work stopped/abandoned / Text3: 33.9xx
- 1340: -

| ID | WBS | Task | Duration | Start | Finish | Complete | Baseline start | Baseline finish | Baseline duration | Constraint | Resources | Work | Actual work | Text1 | Text4 | Text5 | Text6 | Text8 | Text7 | Text2 |
| --- | --- | --- | --- | --- | --- | --- | --- | --- | --- | --- | --- | --- | --- | --- | --- | --- | --- | --- | --- | --- |
| 1341 | 487 | **3GPP System Architecture Evolution Specification - Evolved Packet System (non RAN aspects)** | 1618d? | 2006-04-12 A | 2012-06-15 A | 100% | 2006-04-12 | 2012-06-15 | 1618d? |  | S1,S2,S3,S5,C1,C3,C4,C6,IETF | 286040h | 286040h | SAES | T-Mobile | michael.kurz@t-mobile.at | Rel-8 | Alain |  |  |
| 1342 | 487.1 | Requirements for evolution of the 3GPP system architecture | 395d? | 2006-06-08 A | 2007-12-12 A | 100% | 2006-06-08 | 2007-12-12 | 395d? | finish no earlier than 2007-11-30 | S1 | 3160h | 3160h | AIPN-SAE | T-Mobile | michael.kurz@t-mobile.at | Rel-8 | Alain |  |  |
| 1343 | 487.2 | **High level and common (for all accesses) functions** | 629d? | 2007-01-02 A | 2009-05-29 A | 100% | 2007-01-02 | 2009-05-29 | 629d? |  | S2,S3,C1,C3,C4 | 37504h | 37504h | EPS-ComF | Nokia Siemens Networks | balazs.bertenyi@nsn.com | Rel-8 | Maurice | SP-37 |  |
| 1344 | 487.2.1 | Stage 2 for High level functions | 370d? | 2007-01-02 A | 2008-06-02 A | 100% | 2007-01-02 | 2008-06-02 | 370d? | finish no earlier than 2008-06-02 | S2 | 2960h | 2960h | SAES-SA-HLF | Motorola | Irfan.Ali@motorola.com | Rel-8 | Maurice |  |  |
| 1345 | 487.2.2 | Stage 2 Security Architecture | 197d? | 2008-03-12 A | 2008-12-11 A | 100% | 2008-03-12 | 2008-12-11 | 197d? | finish no earlier than 2008-12-11 | S3 | 1576h | 1576h | SAES | Nokia Siemens Networks | marc.blommaert.ext@nsn.com | Rel-8 | Dionisio | SP-39 | PCG-21 |
| 1346 | 487.2.3 | Stage 3 (CT1) for SAE impact on services, network functions and capabilities | 545d? | 2007-02-05 A | 2009-03-06 A | 100% | 2007-02-05 | 2009-03-06 | 545d? | finish no earlier than 2009-03-06 | C1 | 4360h | 4360h | SAES | Nokia Siemens Networks | robert.zaus@nsn.com | Rel-8 | Frederic |  |  |
| 1347 | 487.2.4 | Stage 3 SAE impact on existing capabilities | 480d? | 2007-02-05 A | 2008-12-05 A | 100% | 2007-02-05 | 2008-12-05 | 480d? | finish no earlier than 2008-12-12 | C3 | 3840h | 3840h | SAES | Huawei | Wei Weihua (weiwh@huawei.com) | Rel-8 | Jiwan |  |  |
| 1348 | 487.2.5 | Stage 3 (CT4) of SAE impact on existing capabilities | 545d? | 2007-02-05 A | 2009-03-06 A | 100% | 2007-02-05 | 2009-03-06 | 545d? | finish no earlier than 2009-03-06 | C4 | 4360h | 4360h | SAES | Huawei | shahab.lavasani@huawei.com | Rel-8 | Kimmo |  |  |
| 1349 | 487.2.6 | Stage 2/3 for Network selection procedures | 480d? | 2007-02-05 A | 2008-12-05 A | 100% | 2007-02-05 | 2008-12-05 | 480d? | finish no earlier than 2009-03-06 | C1 | 3840h | 3840h | SAES | Nokia Siemens Networks | robert.zaus@nsn.com | Rel-8 | Frederic |  |  |
| 1350 | 487.2.7 | Stage 3 EPC interworking with external PDNs (SGi) | 605d? | 2007-02-05 A | 2009-05-29 A | 100% | 2007-02-05 | 2009-05-29 | 605d? | finish no earlier than 2009-05-29 | C3 | 4840h | 4840h | SAES-St3-intwk | Huawei | Wei Weihua (weiwh@huawei.com) | Rel-8 | Jiwan |  |  |
| 1351 | 487.2.8 | Stage 3 PCC within SAE | 605d? | 2007-02-05 A | 2009-05-29 A | 100% | 2007-02-05 | 2009-05-29 | 605d? | finish no earlier than 2009-05-29 | C3 | 4840h | 4840h | SAES-St3-PCC | Ericsson | j.javier.pastor@ericsson.com | Rel-8 | Jiwan |  |  |
| 1352 | 487.2.9 | Stage 3 for SAE / LTE identities | 545d? | 2007-02-05 A | 2009-03-06 A | 100% | 2007-02-05 | 2009-03-06 | 545d? | finish no earlier than 2009-03-06 | C4 | 4360h | 4360h | SAES | Huawei | shahab.lavasani@huawei.com | Rel-8 | Kimmo |  |  |
| 1353 | 487.2.10 | Unified guidelines for Diameter usage within 3GPP | 316d? | 2007-09-21 A | 2008-12-05 A | 100% | 2007-09-21 | 2008-12-05 | 316d? | finish no earlier than 2008-12-05 | C3 | 2528h | 2528h | SAES-DIAM | Huawei | Javier Gonzalez Gallego | Rel-8 | Jiwan | CP-37 |  |
| 1354 | 487.3 | **SAE for LTE access** | 569d? | 2007-01-02 A | 2009-03-06 A | 100% | 2007-01-02 | 2009-03-06 | 569d? |  | S2,C1,C3,C4 | 57824h | 57824h | SAES-LTE | Motorola | Irfan.Ali@motorola.com | Rel-8 | Maurice |  |  |
| 1355 | 487.3.1 | CT4 Stage 3 for protocol between EPCs | 545d? | 2007-02-05 A | 2009-03-06 A | 100% | 2007-02-05 | 2009-03-06 | 545d? | finish no earlier than 2009-03-06 | C4 | 4360h | 4360h | SAES | Huawei | shahab.lavasani@huawei.com | Rel-8 | Kimmo |  |  |
| 1356 | 7.2.2.1 | **SAES-SA-FP_LTE with GTP variant** | 569d? | 2007-01-02 A | 2009-03-06 A | 100% | 2007-01-02 | 2009-03-06 | 569d? |  | S2,C4 | 11896h | 11896h | SAES-SA-FP_LTE-GTP | Nokia Siemens Networks | balazs.bertenyi@nsn.com | Rel-8 | Maurice |  |  |
| 1357 | 487.3.2.1 | Stage 2 for SAES-SA-FP_LTE with GTP variant | 373d? | 2007-01-02 A | 2008-06-05 A | 100% | 2007-01-02 | 2008-06-05 | 373d? | finish no earlier than 2008-06-02 | S2 | 2984h | 2984h | SAES-SA-FP_LTE-GTP-St2 | Nokia Siemens Networks | balazs.bertenyi@nsn.com | Rel-8 | Maurice |  |  |
| 1358 | 487.3.2.2 | CT4 Stage 3 for GTP v2 protocol | 545d? | 2007-02-05 A | 2009-03-06 A | 100% | 2007-02-05 | 2009-03-06 | 545d? | finish no earlier than 2009-03-06 | C4 | 4360h | 4360h | SAES | Huawei | shahab.lavasani@huawei.com | Rel-8 | Kimmo |  |  |
| 1359 | 7.2.2.2 | **SAES-SA-FP_LTE with PMIP variant** | 569d? | 2007-01-02 A | 2009-03-06 A | 100% | 2007-01-02 | 2009-03-06 | 569d? |  | S2,C4 | 15736h | 15736h | SAES-SA-FP_LTE-IETF | Nokia Siemens Networks | balazs.bertenyi@nsn.com | Rel-8 | Maurice |  |  |
| 1360 | 487.3.3.1 | Stage 2 for SAES-SA-FP_LTE with PMIP variant | 373d? | 2007-01-02 A | 2008-06-05 A | 100% | 2007-01-02 | 2008-06-05 | 373d? | finish no earlier than 2008-06-02 | S2 | 2984h | 2984h | SAES-SA-FP_LTE-IETF-St2 | Nokia Siemens Networks | balazs.bertenyi@nsn.com | Rel-8 | Maurice |  |  |
| 1361 | 487.3.3.2 | CT4 Stage 3 for PMIP protocol within EPC | 545d? | 2007-02-05 A | 2009-03-06 A | 100% | 2007-02-05 | 2009-03-06 | 545d? | finish no earlier than 2009-03-06 | C4 | 4360h | 4360h | SAES | Huawei | shahab.lavasani@huawei.com | Rel-8 | Kimmo | CP-37 |  |
| 1362 | 487.3.3.3 | Mobile IPv4 (MIPv4) based Mobility protocols | 480d? | 2007-02-05 A | 2008-12-05 A | 100% | 2007-02-05 | 2008-12-05 | 480d? | finish no earlier than 2008-12-05 | C4 | 3840h | 3840h | SAES | Motorola | Lewis Milton | Rel-8 | Kimmo | CP-41 |  |
| 1363 | 487.3.4 | Stage 3 for UE Non-Access-Stratum (NAS) mobility procedures in idle and active mode | 545d? | 2007-02-05 A | 2009-03-06 A | 100% | 2007-02-05 | 2009-03-06 | 545d? | finish no earlier than 2009-03-06 | C1 | 4360h | 4360h | SAES | Nokia Siemens Networks | robert.zaus@nsn.com | Rel-8 | Frederic |  |  |
| 1364 | 487.3.5 | Stage 3 for Session management, bearer control and QoS aspects | 545d? | 2007-02-05 A | 2009-03-06 A | 100% | 2007-02-05 | 2009-03-06 | 545d? | finish no earlier than 2009-03-06 | C1 | 4360h | 4360h | SAES | Nokia Siemens Networks | robert.zaus@nsn.com | Rel-8 | Frederic |  |  |
| 1365 | 487.3.6 | Stage 3 for security aspects of LTE Access | 545d? | 2007-02-05 A | 2009-03-06 A | 100% | 2007-02-05 | 2009-03-06 | 545d? | finish no earlier than 2009-03-06 | C1 | 4360h | 4360h | SAES | Nokia Siemens Networks | robert.zaus@nsn.com | Rel-8 | Frederic |  |  |
| 1366 | 487.3.7 | Stage 3 for QoS mechanisms | 480d? | 2007-02-05 A | 2008-12-05 A | 100% | 2007-02-05 | 2008-12-05 | 480d? | finish no earlier than 2008-12-12 | C3 | 3840h | 3840h | SAES | Ericsson | j.javier.pastor@ericsson.com | Rel-8 | Jiwan |  |  |
| 1367 | 487.3.8 | Stage 3 for EPC - HSS interface | 545d? | 2007-02-05 A | 2009-03-06 A | 100% | 2007-02-05 | 2009-03-06 | 545d? | finish no earlier than 2009-03-06 | C4 | 4360h | 4360h | SAES | Huawei | shahab.lavasani@huawei.com | Rel-8 | Kimmo |  |  |

Notes:
- 1341: Role model for SAE/LTE system wide project management by SA2 in SP-060166
- 1342: SP#38 completed / Text3: 22.011, 22.246, new 22.278
- 1343: CP#44 completed
- 1344: SP#40 completed / Text3: new 23.402
- 1345: SP#42 completed / Text3: 33.210, 33.310, new 33.401
- 1346: CP#43 completed / Text3: 24.229, 27.007, new 24.305
- 1347: CP#42 completed / Text3: 29.061
- 1348: CP#43 completed / Text3: new (29.274, 29.275)
- 1349: CP#42 completed / Text3: 23.122, new 24.302
- 1350: CP#44 completed / Text3: 29.061
- 1351: CP#44 completed / Text3: 29.212, 29.213, 29.214, new 29.215
- 1352: CP#43 completed / Text3: 23.003
- 1353: CP#42 completed / Text3: new 29.909
- 1354: CP#43 completed
- 1355: CP#43 completed / Text3: 29.274, 29.275
- 1356: CP#43 completed
- 1357: SP#40 completed / Text3: 23.401, 23.060, 23.002, 23.246, 23.203, 23.107, 23.234, 23.271
- 1358: CP#43 completed / Text3: 29.274
- 1359: CP#43 completed
- 1360: SP#40 completed
- 1361: CP#43 completed / Text3: 29.275, 29.282
- 1362: CP#42 completed / Text3: 29.279
- 1363: CP#43 completed / Text3: 24.007, 24.301
- 1364: CP#43 completed / Text3: 24.007, 24.301
- 1365: CP#43 completed / Text3: 24.008, 24.301
- 1366: CP#42 completed / Text3: 29.213
- 1367: CP#43 completed / Text3: 29.272

| ID | WBS | Task | Type | Duration | Start | Finish | Complete | Baseline start | Baseline finish | Baseline duration | Constraint | Resources | Work | Actual work | Text1 | Text4 | Text5 | Text6 | Text8 | Text3 | Text7 | Text2 | Text12 |
| --- | --- | --- | --- | --- | --- | --- | --- | --- | --- | --- | --- | --- | --- | --- | --- | --- | --- | --- | --- | --- | --- | --- | --- |
| 1368 | 487.4 | **SAE for Interoperation between LTE and legacy cellular PS accesses** |  | 545d? | 2007-02-05 A | 2009-03-06 A | 100% | 2007-02-05 | 2009-03-06 | 545d? |  | S2,C1,C4 | 40152h | 40152h | SAES-SA-FP_3GPP | Motorola | Irfan.Ali@motorola.com | Rel-8 | Maurice |  |  |  |  |
| 1369 | 487.4.1 | Stage 2 for Interoperation between LTE and 2G/3G |  | 424d? | 2007-02-05 A | 2008-09-18 A | 100% | 2007-02-05 | 2008-09-18 | 424d? | finish no earlier than 2008-09-11 | S2 | 3392h | 3392h | EPSto2_3G | Motorola | Irfan.Ali@motorola.com | Rel-8 | Maurice | 23.401, 23.402 | SP-37 |  |  |
| 1370 | 487.4.2 | Stage 3 for Inter-system mobility between E-UTRAN and 2G/3G |  | 545d? | 2007-02-05 A | 2009-03-06 A | 100% | 2007-02-05 | 2009-03-06 | 545d? | finish no earlier than 2009-03-06 | C1 | 4360h | 4360h | SAES | Nokia Siemens Networks | robert.zaus@nsn.com | Rel-8 | Frederic | 24.008, 24.301 | CP-38 | PCG-21 |  |
| 1371 | 487.4.3 | Stage 2 GPRS enhancements for LTE access |  | 272d? | 2007-09-04 A | 2008-09-18 A | 100% | 2007-09-04 | 2008-09-18 | 272d? | start no earlier than 2007-09-04 | S2 | 2176h | 2176h | SAES-GPRS_LTE | Vodafone | chris.pudney@vodafone.com | Rel-8 | Maurice | 23.401 |  |  |  |
| 1372 | 487.4.4 | Stage 2 GPRS for EPC (23.060, etc.) |  | 179d? | 2008-01-14 A | 2008-09-18 A | 100% | 2008-01-14 | 2008-09-18 | 179d? | finish no earlier than 2008-09-18 | S2 | 1432h | 1432h | SAES | Nokia Siemens Networks | balazs.bertenyi@nsn.com | Rel-8 | Maurice | 23.060 | SP-39 | PCG-21 |  |
| 1373 | 487.4.5 | Stage 3 for EPC - GPRS |  | 545d? | 2007-02-05 A | 2009-03-06 A | 100% | 2007-02-05 | 2009-03-06 | 545d? | finish no earlier than 2009-03-06 | C4 | 4360h | 4360h | SAES | Huawei | shahab.lavasani@huawei.com | Rel-8 | Kimmo | 29.274, 29.275, 29.281 |  |  |  |
| 1374 | 487.4.6 | Stage 3 for EPC to UTRAN |  | 545d? | 2007-02-05 A | 2009-03-06 A | 100% | 2007-02-05 | 2009-03-06 | 545d? | finish no earlier than 2009-03-06 | C4 | 4360h | 4360h | SAES | Huawei | shahab.lavasani@huawei.com | Rel-8 | Kimmo | 29.274, 29.275, 29.281 | CP-38 | PCG-21 |  |
| 1375 | 487.4.7 | Stage 3 for EPC to 3GPP2 |  | 545d? | 2007-02-05 A | 2009-03-06 A | 100% | 2007-02-05 | 2009-03-06 | 545d? | finish no earlier than 2009-03-06 | C4 | 4360h | 4360h | SAES | Huawei | shahab.lavasani@huawei.com | Rel-8 | Kimmo | 29.277, 29.276 | CP-38 | PCG-21 |  |
| 1376 | 487.4.8 | Stage 2 for Interoperation between LTE and CDMA2000 |  | 329d? | 2007-06-18 A | 2008-09-18 A | 100% | 2007-06-18 | 2008-09-18 | 329d? | finish no earlier than 2008-04-25 | S2 | 2632h | 2632h | EPStoC2k | Motorola, Vodafone | Irfan.Ali@motorola.com, chris.pudney@vodafone.com | Rel-8 | Maurice | 23.401, 23.402 | CP-37 |  |  |
| 1377 | 487.4.9 | Stage 3 for Inter-system mobility between E-UTRAN and CDMA2000 |  | 545d? | 2007-02-05 A | 2009-03-06 A | 100% | 2007-02-05 | 2009-03-06 | 545d? | finish no earlier than 2009-03-06 | C1 | 4360h | 4360h | SAES | Nokia Siemens Networks | robert.zaus@nsn.com | Rel-8 | Frederic | 24.301, 24.302 |  |  |  |
| 1378 | 487.4.10 | Stage 3 for MME - SGSN signalling free protocol |  | 545d? | 2007-02-05 A | 2009-03-06 A | 100% | 2007-02-05 | 2009-03-06 | 545d? | finish no earlier than 2009-03-06 | C4 | 4360h | 4360h | SAES | Huawei | shahab.lavasani@huawei.com | Rel-8 | Kimmo | 29.272, 29.274 |  |  |  |
| 1379 | 487.5 | **SAE for support for non-3GPP accesses** |  | 1429d? | 2007-01-02 A | 2012-06-15 A | 100% | 2007-01-02 | 2012-06-15 | 1429d? |  | S2,S3,C1,C4,IETF | 77108.8h | 77108.8h | SAES-SA-FP_n3GPP | Motorola | Irfan.Ali@motorola.com | Rel-8 | Maurice |  |  |  |  |
| 1380 | 7.2.4.1 | Stage 2 for Host-based Mobility aspects |  | 373d? | 2007-01-02 A | 2008-06-05 A | 100% | 2007-01-02 | 2008-06-05 | 373d? | finish no earlier than 2008-04-11 | S2 | 2984h | 2984h | SAES-SA-FP_n3GPP-HBMob | Motorola | Irfan.Ali@motorola.com | Rel-8 | Maurice | 23.402 |  |  |  |
| 1381 | 7.2.4.2 | Stage 2 for Network-based Mobility aspects |  | 448d? | 2007-01-02 A | 2008-09-18 A | 100% | 2007-01-02 | 2008-09-18 | 448d? | finish no earlier than 2008-09-18 | S2 | 3584h | 3584h | SAES-SA-FP_n3GPP-NBMob | Motorola | Irfan.Ali@motorola.com | Rel-8 | Maurice | 23.402 |  |  |  |
| 1382 | 487.5.3 | Stage 3 for Mobility management based on DSMIPv6 |  | 480d? | 2007-02-05 A | 2008-12-05 A | 100% | 2007-02-05 | 2008-12-05 | 480d? | finish no earlier than 2008-12-05 | C1 | 3840h | 3840h | SAES | Nokia Siemens Networks | robert.zaus@nsn.com | Rel-8 | Frederic | 24.303 |  |  |  |
| 1383 | 487.5.4 | (IETF) Stage 3 for Mobility management based on DSMIPv6 (draft-ietf-mip6-hiopt) |  | 589d? | 2007-02-05 A | 2012-06-15 A | 100% | 2007-02-05 | 2012-06-15 | 589d? | finish no earlier than 2012-09-14 | C1-IETF | 4712h | 4712h | SAES | Mark Jones |  | Rel-8 | Frederic | RFC 6610 (was draft-ietf-mip6-hiopt) | CP-52 | PCG-27 |  |
| 1384 | 487.5.5 | (IETF) Stage 3 for Mobility management based on DSMIPv6 (RFC6275) |  | 356d? | 2007-02-05 A | 2011-07-29 A | 100% | 2007-02-05 | 2011-07-29 | 356d? | finish no earlier than 2011-07-29 | C1-IETF | 2848h | 2848h | SAES |  |  | Rel-8 | Frederic | RFC 6275 (was draft-ietf-mext-rfc3775bis) | CP-52 | PCG-27 |  |
| 1385 | 487.5.6 | Stage 3 for Mobility management based on MIP v4 |  | 480d? | 2007-02-05 A | 2008-12-05 A | 100% | 2007-02-05 | 2008-12-05 | 480d? | start no earlier than 2007-02-05 | C1 | 3840h | 3840h | SAES | Nokia Siemens Networks | robert.zaus@nsn.com | Rel-8 | Frederic | 24.304 | CP-39 | PCG-21 |  |
| 1386 | 487.5.7 | Stage 3 for Inter-system mobility between E-UTRAN and non 3GPP accesses |  | 545d? | 2007-02-05 A | 2009-03-06 A | 100% | 2007-02-05 | 2009-03-06 | 545d? | finish no earlier than 2009-03-06 | C1 | 4360h | 4360h | SAES | Nokia Siemens Networks | robert.zaus@nsn.com | Rel-8 | Frederic | 24.008, 24.301 | CP-38 | PCG-21 |  |
| 1387 | 487.5.8 | Stage 2 for Optimized Dual-Radio Handover with WiMAX |  | 249d? | 2007-06-25 A | 2008-06-05 A | 100% | 2007-06-25 | 2008-06-05 | 249d? | finish no earlier than 2008-06-09 | S2 | 1992h | 1992h | SAES-SA-FP_n3GPP-OptWIMAX | Motorola | Irfan.Ali@motorola.com | Rel-8 | Maurice | 23.402 |  |  |  |
| 1388 | 487.5.9 | Stage 2 Security aspects for non-3GPP Access |  | 197d? | 2008-03-12 A | 2008-12-11 A | 100% | 2008-03-12 | 2008-12-11 | 197d? | finish no earlier than 2008-12-11 | S3 | 1576h | 1576h | SAES | Nokia Siemens Networks | marc.blommaert.ext@nsn.com | Rel-8 | Dionisio | 33.402, 33.210, 33.310 | SP-39 | PCG-21 |  |
| 1389 | 487.5.10 | Stage 3 security aspects for DSMIPv6 Access |  | 480d? | 2007-02-05 A | 2008-12-05 A | 100% | 2007-02-05 | 2008-12-05 | 480d? | finish no earlier than 2008-12-05 | C1 | 3840h | 3840h | SAES | Nokia Siemens Networks | robert.zaus@nsn.com | Rel-8 | Frederic | 24.303 | CP-37 |  |  |
| 1390 | 487.5.11 | Stage 3 security aspects for MIPv4 Access |  | 480d? | 2007-02-05 A | 2008-12-05 A | 100% | 2007-02-05 | 2008-12-05 | 480d? | finish no earlier than 2008-12-05 | C1 | 3840h | 3840h | SAES | Nokia Siemens Networks | robert.zaus@nsn.com | Rel-8 | Frederic | 24.304 | CP-39 | PCG-21 |  |
| 1391 | 487.5.12 | Stage 3 for Access to the EPC via non-3GPP access networks |  | 545d? | 2007-02-05 A | 2009-03-06 A | 100% | 2007-02-05 | 2009-03-06 | 545d? | finish no earlier than 2009-03-06 | C1 | 4360h | 4360h | SAES | Nokia Siemens Networks | robert.zaus@nsn.com | Rel-8 | Frederic | 24.302, 24.312 |  |  |  |
| 1392 | 487.5.13 | Stage 3 for interfaces within EPC |  | 383d? | 2007-09-19 A | 2009-03-06 A | 100% | 2007-09-19 | 2009-03-06 | 383d? | finish no earlier than 2009-03-06 | C4 | 3064h | 3064h | SAES | Huawei | shahab.lavasani@huawei.com | Rel-8 | Kimmo | 29.274, 29.281 | CP-37 |  |  |
| 1393 | 487.5.14 | Stage 3 for Interfaces EPC - non-3GPP IP access |  | 545d? | 2007-02-05 A | 2009-03-06 A | 100% | 2007-02-05 | 2009-03-06 | 545d? | finish no earlier than 2009-03-06 | C4 | 4360h | 4360h | SAES | Huawei | shahab.lavasani@huawei.com | Rel-8 | Kimmo | 29.273, 29.275 |  |  |  |
| 1394 | 487.5.15 | (IETF) Stage 3 for Interfaces EPC - non-3GPP IP access |  | 1224.6d? | 2007-02-05 A | 2012-06-15 A | 100% | 2007-02-05 | 2012-06-15 | 1224.6d? | finish no earlier than 2012-06-15 | C4-IETF | 9788.8h | 9788.8h | SAES | Lionel Morand |  | Rel-8 | Kimmo | RFC 6611 (was draft-ietf-mip6-bootstrapping-integrated) | CP-52 | PCG-27 |  |
| 1395 | 487.5.16 | Stage 3 for AAA/HSS related |  | 480d? | 2007-02-05 A | 2008-12-05 A | 100% | 2007-02-05 | 2008-12-05 | 480d? | finish no earlier than 2008-12-05 | C4 | 3840h | 3840h | SAES | Huawei | shahab.lavasani@huawei.com | Rel-8 | Kimmo | 29.273 |  |  |  |
| 1396 | 487.5.17 | Stage 3 for EPC - AAA interface |  | 480d? | 2007-02-05 A | 2008-12-05 A | 100% | 2007-02-05 | 2008-12-05 | 480d? | finish no earlier than 2008-12-05 | C4 | 3840h | 3840h | SAES | Huawei | shahab.lavasani@huawei.com | Rel-8 | Kimmo | 29.273 |  |  |  |
| 1397 | 487.5.18 | Deleted (already covered) SAES-SA-FP_n3GPP Optimized Handover with CDMA | milestone | 0d? | 2007-06-25 A | 2007-06-25 A | 100% | 2007-06-25 | 2007-06-25 | 0d? | finish no earlier than 2007-06-25 | S2 |  |  | SAES-SA-FP_n3GPP-OptCDMA | Nokia Siemens Networks |  | Rel-8 | Maurice |  |  |  | SP-37 |

Notes:
- 1368: CP#43 completed
- 1369: SP#41 completed
- 1370: CP#43 completed
- 1371: SP#41 completed
- 1372: SP#41 completed
- 1373: CP#43 completed
- 1374: CP#43 completed
- 1375: CP#43 completed
- 1376: SP#41 completed (except: Handover of multiple PDNs=>Rel-9)
- 1377: CP#43 completed
- 1378: CP#43 completed
- 1379: CP#43 completed. SP#39 retained in Rel-8 (in addition to the essential functionality defined in SP-070699). Replaces UID_340037
- 1380: SP#40 completed
- 1381: SP#41 completed
- 1382: CP#42 completed
- 1383: CP#56 RFC 6610 completed
- 1384: SP#53/IETF#81: RFC 6275 completed
- 1385: CP#42 completed
- 1386: CP#43 completed
- 1387: SP#40 completed
- 1388: SP#42 completed
- 1389: CP#42 completed
- 1390: CP#42 completed
- 1391: CP#43 completed
- 1392: CP#43 completed
- 1393: CP#43 completed
- 1394: CP#56 RFC6611 completed
- 1395: CP#42 completed
- 1396: CP#42 completed
- 1397: SP#37 stopped

| ID | WBS | Task | Type | Duration | Start | Finish | Complete | Baseline start | Baseline finish | Baseline duration | Constraint | Resources | Work | Actual work | Text1 | Text4 | Text6 | Text8 | Text2 | Text7 | Text9 | Text12 | Text11 |
| --- | --- | --- | --- | --- | --- | --- | --- | --- | --- | --- | --- | --- | --- | --- | --- | --- | --- | --- | --- | --- | --- | --- | --- |
| 1398 | 487.6 | **Single Radio Voice Call Continuity for 3GPP (SRVCC)** |  | 569d? | 2007-01-02 A | 2009-03-06 A | 100% | 2007-01-02 | 2009-03-06 | 569d? |  | S2,C1,C4 | 10752h | 10752h | SAES-SRVCC | Nokia Siemens Networks | Rel-8 | Maurice |  |  |  |  |  |
| 1399 | 487.6.1 | Stage 2 for 2G/3G SRVCC |  | 448d? | 2007-01-02 A | 2008-09-18 A | 100% | 2007-01-02 | 2008-09-18 | 448d? | finish no earlier than 2008-09-15 | S2 | 3584h | 3584h | SAES-SRVCC | Nokia Siemens Networks | Rel-8 | Maurice |  |  |  |  |  |
| 1400 | 487.6.2 | Stage 3 for SRVCC in EPS |  | 201d? | 2008-05-30 A | 2009-03-06 A | 100% | 2008-05-30 | 2009-03-06 | 201d? | finish no earlier than 2009-03-06 | C1 | 1608h | 1608h | SAES-SRVCC | Nokia Siemens Networks | Rel-8 | Frederic | PCG-21 | CP-41 |  |  |  |
| 1401 | 487.6.3 | MME to MSC interface for SRVCC |  | 126d? | 2008-09-12 A | 2009-03-06 A | 100% | 2008-09-12 | 2009-03-06 | 126d? | finish no earlier than 2009-03-06 | C4 | 1008h | 1008h | SAES-SRVCC | Nokia Siemens Networks | Rel-8 | Kimmo | PCG-21 | CP-41 |  |  |  |
| 1402 | 487.7 | Voice Call Continuity for CDMA2000 1X |  | 249d? | 2007-06-25 A | 2008-06-05 A | 100% | 2007-06-25 | 2008-06-05 | 249d? | finish no earlier than 2008-06-13 | S2 | 1992h | 1992h | SAES-VCC_1X | Nokia Siemens Networks | Rel-8 | Maurice |  |  |  |  |  |
| 1403 | 487.8 | SAE impacts on IMS |  | 373d? | 2007-01-02 A | 2008-06-05 A | 100% | 2007-01-02 | 2008-06-05 | 373d? | finish no earlier than 2008-06-13 | S2 | 2984h | 2984h | SAES-SA_IMS | Nokia Siemens Networks | Rel-8 | Maurice |  |  |  |  |  |
| 1404 | 487.9 | **CS Fallback in EPS** |  | 258d? | 2008-03-12 A | 2009-03-06 A | 100% | 2008-03-12 | 2009-03-06 | 258d? |  | S2,C1,C4 | 4800h | 4800h | SAES-CSFB | T-Mobile, Vodafone | Rel-8 | Maurice | PCG-21 | SP-39 |  |  |  |
| 1405 | 487.9.1 | Stage 2 for CS Fallback in EPS |  | 62d? | 2008-03-12 A | 2008-06-05 A | 100% | 2008-03-12 | 2008-06-05 | 62d? | finish no earlier than 2008-12-05 | S2 | 496h | 496h | SAES-CSFB | T-Mobile, Vodafone | Rel-8 | Maurice | PCG-21 | SP-40 |  |  |  |
| 1406 | 487.9.2 | CT1 part of Stage 3 for CS Fallback in EPS |  | 201d? | 2008-05-30 A | 2009-03-06 A | 100% | 2008-05-30 | 2009-03-06 | 201d? | finish no earlier than 2009-03-06 | C1 | 1608h | 1608h | SAES-CSFB | NEC | Rel-8 | Frederic | PCG-21 | CP-40 |  |  |  |
| 1407 | 487.9.3 | CT4 part of Stage 3 for CS Fallback in EPS |  | 136d? | 2008-05-30 A | 2008-12-05 A | 100% | 2008-05-30 | 2008-12-05 | 136d? | finish no earlier than 2008-12-05 | C4 | 1088h | 1088h | SAES-CSFB | NEC | Rel-8 | Kimmo | PCG-21 | CP-40 |  |  |  |
| 1408 | 487.10 | System enhancements for the use of IMS services in local breakout |  | 62d? | 2008-03-12 A | 2008-06-05 A | 100% | 2008-03-12 | 2008-06-05 | 62d? | finish no earlier than 2008-06-05 | S2 | 496h | 496h | SAES-IMS_LBO | Telecom Italia | Rel-8 | Maurice | PCG-21 | SP-39 |  |  |  |
| 1409 | 487.11 | **EPC Data Definitions** |  | 309d? | 2008-01-07 A | 2009-03-12 A | 100% | 2008-01-07 | 2009-03-12 | 309d? |  | S5 | 7144h | 7144h | EPC-OAM |  | Rel-8 | Dionisio | PCG-21 | SP-39 |  |  |  |
| 1410 | 487.11.1 | EPC Network Resource Model (NRM) Integration Reference Point (IRP) |  | 309d? | 2008-01-07 A | 2009-03-12 A | 100% | 2008-01-07 | 2009-03-12 | 309d? | finish no earlier than 2009-03-12 | S5 | 2472h | 2472h | EPC-OAM | Huawei | Rel-8 | Dionisio | PCG-21 | SP-38 |  |  |  |
| 1411 | 487.11.2 | Performance measurements for EPC |  | 275d? | 2008-02-22 A | 2009-03-12 A | 100% | 2008-02-22 | 2009-03-12 | 275d? | finish no earlier than 2009-03-12 | S5 | 2200h | 2200h | EPC-OAM | China Mobile | Rel-8 | Dionisio | PCG-21 | SP-39 |  |  |  |
| 1412 | 487.12 | EPC Charging |  | 309d? | 2008-01-07 A | 2009-03-12 A | 100% | 2008-01-07 | 2009-03-12 | 309d? | finish no earlier than 2009-03-12 | S5 | 2472h | 2472h | EPC-CH | Nokia Siemens Networks | Rel-8 | Dionisio | PCG-21 | SP-38 |  |  |  |
| 1413 | 487.13 | Domain Name System Procedures for Evolved Packet System (DEPS) |  | 179.75d? | 2008-05-30 A | 2009-03-06 A | 100% | 2008-05-30 | 2009-03-06 | 179.75d? | finish no earlier than 2009-03-06 | C4 | 1438h | 1438h | SAES-DEPS | TeliaSonera | Rel-8 | Kimmo | PCG-21 | CP-40 |  |  |  |
| 1414 | 487.14 | InterWorking Function (IWF) between MAP based and Diameter based interfaces |  | 126d? | 2008-09-12 A | 2009-03-06 A | 100% | 2008-09-12 | 2009-03-06 | 126d? | finish no earlier than 2009-03-06 | C4 | 1008h | 1008h | SAES-MAP2Diam | Huawei | Rel-8 | Kimmo | PCG-21 | CP-41 |  |  |  |
| 1415 | 487.15 | **CT6 aspects of SAE** |  | 847d? | 2008-03-07 A | 2011-06-03 A | 100% | 2008-03-07 | 2011-06-03 | 847d? |  | C6 | 13480h | 13480h | SAES | Nokia | Rel-8 | Xavier | PCG-21 | SP-39 |  |  |  |
| 1416 | 487.15.1 | Core specification for CT6 aspects of SAE |  | 321d? | 2008-03-07 A | 2009-05-29 A | 100% | 2008-03-07 | 2009-05-29 | 321d? | finish no earlier than 2009-05-29 | C6 | 2568h | 2568h | SAES | Nokia | Rel-8 | Xavier | PCG-21 | CP-39 |  |  |  |
| 1417 | 487.15.2 | Test interworking of LTE Terminals with the USIM |  | 526d? | 2008-12-05 A | 2010-12-10 A | 100% | 2008-12-05 | 2010-12-10 | 526d? | finish no earlier than 2010-12-10 | C6 | 4208h | 4208h | SAES-USIM_LTE-Test | Comprion | Rel-8 | Xavier | PCG-22 | CP-42 |  |  |  |
| 1418 | 487.15.3 | Test interworking of IP Multimedia Services Identity Module (ISIM) terminals with IP Multimedia Subsystem (IMS) |  | 186d? | 2010-09-17 A | 2011-06-03 A | 100% | 2010-09-17 | 2011-06-03 | 186d? | finish no earlier than 2011-06-03 | C6 | 1488h | 1488h | SAES-ISIM_IMS_Test | Comprion | Rel-8 | Xavier | PCG-25 | CP-49 |  |  |  |
| 1419 | 487.16 | Issues for CT1 TR 24.801 |  | 420d? | 2007-01-04 A | 2008-12-05 A | 100% | 2007-01-04 | 2008-12-05 | 420d? | finish no earlier than 2008-12-05 | C1 | 3360h | 3360h | SAES | Nokia Siemens Networks | Rel-8 | Frederic | PCG-21 | CP-39 |  |  |  |
| 1420 | 487.17 | Issues for CT3 TR 29.804 |  | 420d? | 2007-02-05 A | 2008-09-12 A | 100% | 2007-02-05 | 2008-09-12 | 420d? | finish no earlier than 2008-12-12 | C3 | 3360h | 3360h | SAES | Ericsson | Rel-8 | Jiwan | PCG-21 | CP-39 |  |  |  |
| 1421 | 487.18 | Deleted - Issues for CT4 TR 29.803 |  | 420d? | 2007-01-04 A | 2008-09-12 A | 100% | 2007-01-04 | 2008-09-12 | 420d? | finish no earlier than 2008-12-11 | C4 | 3360h | 3360h | SAES | Huawei | Rel-8 | Kimmo | PCG-21 | CP-39 | PCG-21 | CP-41 |  |
| 1422 | 487.19 | Deleted (covered by 380068): Functions and procedures for SAE to support LCS | milestone | 0d? | 2008-03-03 A | 2008-03-03 A | 100% | 2008-03-03 | 2008-03-03 | 0d? | finish no earlier than 2008-03-03 | S2 |  |  | SAES-SA-FP_LCS | Nokia Siemens Networks | Rel-8 | Maurice |  |  |  | SP-37 |  |
| 1423 | 487.20 | Deleted (covered by 380064): SAE aspects of Emergency Calls | milestone | 0d? | 2008-03-03 A | 2008-03-03 A | 100% | 2008-03-03 | 2008-03-03 | 0d? | start no earlier than 2008-03-03 | S2 |  |  | SAES-SA-EmCall | Nokia Siemens Networks | Rel-8 | Maurice |  |  |  | SP-37 |  |
| 1424 | 487.21 | Deleted - CT1 aspects of SAES |  | 16.7d? | 2007-09-04 A | 2007-09-27 A | 100% | 2007-09-04 | 2007-09-27 | 16.7d? | start no earlier than 2007-09-04 | CP,C1 | 133.62h | 133.62h | SAES-St3 |  | Rel-8 | Frederic |  |  |  | SP-37 |  |
| 1425 | 487.22 | Deleted - CT1 aspects of SAES | milestone | 0d? | 2007-09-04 A | 2007-09-04 A | 100% | 2007-09-04 | 2007-09-04 | 0d? | start no earlier than 2007-09-04 | C1 |  |  | SAES-St3 |  | Rel-8 | Frederic |  |  |  | SP-37 |  |
| 1426 | 487.23 | Deleted - Interoperability | milestone | 0d? | 2008-03-14 A | 2008-03-14 A | 100% | 2008-03-14 | 2008-03-14 | 0d? | start no earlier than 2008-03-14 | C1 |  |  | SAES-St3-interop |  | Rel-8 | Frederic |  |  |  | SP-37 |  |
| 1427 | 487.24 | Deleted - CT3 aspects of SAES | milestone | 0d? | 2007-09-04 A | 2007-09-04 A | 100% | 2007-09-04 | 2007-09-04 | 0d? | start no earlier than 2007-09-04 | C3 |  |  | SAES-St3 |  | Rel-8 | Jiwan |  |  |  | SP-37 |  |
| 1428 | 487.25 | Deleted - CT4 aspects of SAES | milestone | 0d? | 2007-09-04 A | 2007-09-04 A | 100% | 2007-09-04 | 2007-09-04 | 0d? | start no earlier than 2007-09-04 | C4 |  |  | SAES-St3 |  | Rel-8 | Kimmo |  |  |  | SP-37 |  |
| 1429 | 487.26 | Deleted - UE to EPC NAS signalling (incl. MBMS and QoS aspects) | milestone | 0d? | 2008-03-14 A | 2008-03-14 A | 100% | 2008-03-14 | 2008-03-14 | 0d? | start no earlier than 2008-03-14 | C1 |  |  | SAES-St3-sig |  | Rel-8 | Frederic |  |  |  | SP-37 |  |
| 1430 | 487.27 | Deleted - User and Control plane protocols | milestone | 0d? | 2007-09-21 A | 2007-09-21 A | 100% | 2007-09-21 | 2007-09-21 | 0d? | start no earlier than 2007-09-21 | C4 |  |  | SAES-St3-prot |  | Rel-8 | Kimmo |  |  |  | SP-37 |  |
| 1431 | 487.28 | Deleted - Architecture enhancements for non-3GPP accesses | milestone | 0d? | 2007-09-04 A | 2007-09-04 A | 100% | 2007-09-04 | 2007-09-04 | 0d? | start no earlier than 2007-09-04 | S2 |  |  | SAES-non_3GPP | Motorola | Rel-8 | Maurice |  |  |  | SP-34 |  |
| 1432 | 487.29 | Deleted - Stage 2 of architecture for the 3GPP System Architecture Evolution | milestone | 0d? | 2007-10-02 A | 2007-10-02 A | 100% | 2007-10-02 | 2007-10-02 | 0d? | start no earlier than 2007-10-02 | S2 |  |  | SAES-St2 | Vodafone | Rel-8 | Maurice |  |  |  | SP-34 |  |
| 1433 | 487.30 | Deleted - SA aspects of System Architecture Evolution |  | 384d? | 2006-04-12 A | 2007-10-01 A | 100% | 2006-04-12 | 2007-10-01 | 384d? | finish no earlier than 2007-10-02 | S2 | 3072h | 3072h | SAES-SA |  | Rel-8 | Maurice |  |  |  | SP-34 |  |
| 1434 | 488 | Conformance Test Aspects – Mobility management based on DSMIPv6 (Dual-Stack Mobile IPv6) |  | 261d? | 2009-09-18 A | 2010-09-17 A | 100% | 2009-09-18 | 2010-09-17 | 261d? | finish no earlier than 2010-09-17 | R5 | 2088h | 2088h | DSMIPv6_UEConTest | Qualcomm | Rel-8 | Ingbert | PCG-23 | RP-45 |  |  | RP-100738 |

Notes:
- 1398: CP#43 completed. SP#38 WID approved (extract from SAE WID SP-070817). / Text5: curt.c.wong@nokia.com
- 1399: SP#41 completed. SP#38 WID approved / Text3: new 23.216 / Text5: curt.c.wong@nokia.com
- 1400: CP#43 completed / Text3: 23.009, 24.008, new 24.301 / Text5: robert.zaus@nsn.com
- 1401: CP#43 completed / Text3: 23.003, 23.008, new (29.274, 29.277, 29.280) / Text5: Giorgi Gulbani
- 1402: SP#40 completed / Text5: balazs.bertenyi@nsn.com
- 1403: SP#40 completed / Text5: balazs.bertenyi@nsn.com
- 1404: CP#43 completed / Text5: sabine.demel@t-mobile.at, chris.pudney@vodafone.com
- 1405: SP#40 completed / Text3: new (23.272, 23.401) / Text5: sabine.demel@t-mobile.at, chris.pudney@vodafone.com
- 1406: CP#43 completed / Text3: 24.007, 24.008, 24.011, 29.018, new (24.301, 24.801, 29.118) / Text5: yannick.lair@nectech.fr
- 1407: CP#42 completed / Text3: 23.007, 23.008, 29.274, new 29.277 / Text5: yannick.lair@nectech.fr
- 1408: SP#40 completed / Text3: 23.228, 23.221, 23.203 / Text5: mario.madella@telecomitalia.it
- 1409: SP#43 completed
- 1410: SP#43 completed / Text3: new (32.751, 32.752, 32.753, 32.755) / Text5: WANG, Xuelong
- 1411: SP#43 completed / Text3: new 32.426 / Text5: Li Jian (lijian@chinamobile.com), Liang Shuangchun (liangshuangchun@cmdi.chinamobile.com)
- 1412: SP#43 completed / Text3: 32.240, 32.296, 32.251, 32.252, 32.298, 32.299 / Text5: Gerald.Goermer@nsn.com
- 1413: CP#43 completed / Text3: 23.003, new 29.303 / Text5: jouni.korhonen@teliasonera.com
- 1414: CP#43 completed. Triggered by UID_380023 (FS_MAP2Diam) / Text3: new 29.305 / Text5: liming49985@huawei.com
- 1415: CP#44 completed core specification / Text5: Rune Lindholm
- 1416: CP#44 completed (specified Network Measurement Results collection via USAT) / Text3: 31.102, 31.111 / Text5: Rune Lindholm
- 1417: CP#50 completed. Steering of Roaming test cases have been introduced. Remaining issues CSG display testing (Provide Local Information, Call Control for EPS/PDN, Event Download (Access Technology Change - Multiple Access Technologies) / Text3: 31.121, 31.124 / Text5: Udo Willenbrink (uwillenbrink@comprion.com )
- 1418: CP#52 completed. Linked to R5 UID_1273 Provisioning of IP-based multimedia services (24.229, 31.103), R8 UID_390021 CT6 aspects of SAE, UID_420018 Test interworking of LTE Terminals with the USIM, R UID_450018 Testing SMS over IMS in E-UTRAN (34.229). / Text3: 31.121, 31.124, new TS 31.134 / Text5: Udo Willenbrink (uwillenbrink@comprion.com )
- 1419: CP#43 completed / Text3: 24.801 / Text5: robert.zaus@nsn.com
- 1420: CP#41 completed / Text3: 29.804 / Text5: j.javier.pastor@ericsson.com
- 1421: CP#41 Work stopped and continued in Normative specifications / Text3: 29.803
- 1422: SP#37 stopped
- 1423: SP#37 stopped
- 1424: SP#37 stopped
- 1425: SP#37 stopped
- 1426: SP#37 stopped
- 1427: SP#37 stopped
- 1428: SP#37 stopped / Text3: 29.803
- 1429: SP#37 stopped
- 1430: SP#37 stopped
- 1431: SP#34 stopped. Replaced by UID_350027 and its children / Text3: 23.402 / Text5: Irfan.Ali@motorola.com
- 1432: SP#34 stopped. Replaced by UIDs 340018 and 340037. (SP#34 report discussion of SP-060917.) / Text3: 23.002, 23.060, 23.107, 23.203, 23.228, 23.234, 23.246, 23.271, 23.279 / Text5: chris.pudney@vodafone.com
- 1433: SP#34 stopped
- 1434: RP#49 completed. Testing for CT1's UID_360022 (24.303) under Rel-8 Feature SAES / Text3: 36.508, 36.523-1, 36.523-2, 36.523-3 / Text5: Lena Chaponniere (lchaponn@qualcomm.com)

| ID | WBS | Task | Duration | Start | Finish | Complete | Remaining | Baseline start | Baseline finish | Baseline duration | Total slack | Constraint | Resources | Work | Actual work | Text1 | Text4 | Text5 | Text6 | Text7 | Text8 | Text2 | Text9 | Text12 |
| --- | --- | --- | --- | --- | --- | --- | --- | --- | --- | --- | --- | --- | --- | --- | --- | --- | --- | --- | --- | --- | --- | --- | --- | --- |
| 1435 | 489 | **IMS Centralized Service Control (ICSRA)** | 1381d? | 2007-09-03 A | 2012-12-07 | 80% | 275.98d? | 2007-09-03 | 2012-12-07 | 1381d? | 463d |  | S1,S2,C1,C3,C4,IETF | 54406.4h | 27978.8h | ICSRA | AT&T | Randolph Wohlert (rwohlert@tri.sbc.com) | Rel-8 | SP-37 | Alain |  |  |  |
| 1436 | 489.1 | Stage 1 for ICSRA | 138d? | 2007-09-03 A | 2008-03-12 A | 100% |  | 2007-09-03 | 2008-03-12 | 138d? |  | finish no earlier than 2007-12-14 | S1 | 1104h | 1104h | ICSRA | AT&T | Randolph Wohlert (rwohlert@tri.sbc.com) | Rel-8 | SP-38 | Alain | PCG-21 |  |  |
| 1437 | 489.2 | Stage 2 for ICSRA | 125d? | 2007-12-14 A | 2008-06-05 A | 100% |  | 2007-12-14 | 2008-06-05 | 125d? |  | start no earlier than 2007-12-14 | S2 | 1000h | 1000h | ICSRA-St2 | Alcatel-Lucent |  | Rel-8 | SP-38 | Maurice | PCG-21 |  |  |
| 1438 | 489.3 | **Stage 3 for ICSRA – Protocol, Addressing, Subscriber Data** | 1187d? | 2008-05-30 A | 2012-12-07 | 79% | 252.39d? | 2008-05-30 | 2012-12-07 | 1187d? | 463d |  | C1,C3,C4,IETF | 42358.4h | 25874.8h | ICSRA | Ericsson | sean.schneyer@ericsson.com | Rel-8 |  | Frederic |  |  |  |
| 1439 | 489.3.1 | CT1 aspects - Stage 3 for ICSRA | 201d? | 2008-05-30 A | 2009-03-06 A | 100% |  | 2008-05-30 | 2009-03-06 | 201d? |  | finish no earlier than 2009-03-06 | C1 | 1608h | 1608h | ICSRA | Ericsson | Sean Schneyer | Rel-8 | CP-40 | Frederic | PCG-21 |  |  |
| 1440 | 489.3.2 | (IETF) CT1 aspects - Stage 3 for ICSRA (draft-ietf-salud-alert-info-urns) | 715d? | 2008-05-30 A | 2012-12-07 | 75% | 178.75d? | 2008-05-30 | 2012-12-07 | 715d? | 463d | finish no earlier than 2012-12-07 | C1-IETF | 5720h | 4290h | ICSRA | Roland Jesske |  | Rel-8 | CP-52 | Frederic | PCG-27 |  |  |
| 1441 | 489.3.3 | (IETF) CT1 aspects - Stage 3 for ICSRA (draft-ietf-mmusic-sdp-media-capabilities) | 716d? | 2008-05-30 A | 2012-12-07 | 75% | 179d? | 2008-05-30 | 2012-12-07 | 716d? | 463d | finish no earlier than 2012-12-07 | C1-IETF | 5728h | 4296h | ICSRA | Andrew Allen |  | Rel-8 | CP-52 | Frederic | PCG-27 |  |  |
| 1442 | 489.3.4 | (IETF) CT1 aspects - Stage 3 for ICSRA (draft-ietf-mmusic-sdp-cs) | 715d? | 2008-05-30 A | 2012-12-07 | 75% | 178.75d? | 2008-05-30 | 2012-12-07 | 715d? | 463d | finish no earlier than 2012-12-07 | C1-IETF | 5720h | 4290h | ICSRA | Andrew Allen |  | Rel-8 | CP-52 | Frederic | PCG-27 |  |  |
| 1443 | 489.3.5 | (IETF) CT1 aspects - Stage 3 for ICSRA (draft-garcia-mmusic-sdp-miscellaneous-caps) | 713d? | 2008-06-03 A | 2012-12-07 | 75% | 178.25d? | 2008-06-03 | 2012-12-07 | 713d? | 463d | finish no earlier than 2012-12-07 | C1-IETF | 5704h | 4278h | ICSRA | Andrew Allen |  | Rel-8 | CP-52 | Frederic | PCG-27 |  |  |
| 1444 | 489.3.6 | CT3 aspects - Stage 3 for ICSRA | 201d? | 2008-05-30 A | 2009-03-06 A | 100% |  | 2008-05-30 | 2009-03-06 | 201d? |  | finish no earlier than 2009-03-06 | C3 | 1608h | 1608h | ICSRA | Mavenir | Brett Wallis ( brett@mavenir.com) | Rel-8 | CP-40 | Jiwan | PCG-21 |  |  |
| 1445 | 489.3.7 | CT4 aspects - Stage 3 for ICSRA | 136d? | 2008-05-30 A | 2008-12-05 A | 100% |  | 2008-05-30 | 2008-12-05 | 136d? |  | start no earlier than 2008-05-30 | C4 | 1088h | 1088h | ICSRA | Ericsson | Sean Schneyer | Rel-8 | CP-40 | Kimmo | PCG-21 |  |  |
| 1446 | 489.3.8 | (IETF) CT4 aspects - Stage 3 for ICSRA | 634.8d? | 2008-05-30 A | 2012-12-07 | 75% | 158.7d? | 2008-05-30 | 2012-12-07 | 634.8d? | 463d | finish no earlier than 2012-12-07 | C1-IETF,C4-IETF | 5078.4h | 3808.8h | ICSRA | Andrew Allen |  | Rel-8 | CP-52 | Kimmo | PCG-27 |  |  |
| 1447 | 489.3.9 | Deleted - Stage 3 for ICSRA – I1 interface | 76d? | 2008-05-30 A | 2008-09-12 A | 100% |  | 2008-05-30 | 2008-09-12 | 76d? |  | finish no earlier than 2008-09-12 | C1 | 608h | 608h | ICSRA | Huawei | xupeili@huawei.com | Rel-8 | CP-40 | Frederic | PCG-21 | PCG-21 | CP-41 |
| 1448 | 490 | **IMS Multimedia Telephony and Supplementary Services** | 1898.5d? | 2007-05-02 A | 2014-08-01 | 93% | 133.09d? | 2007-05-02 | 2014-08-01 | 1898.5d? | 33.5d |  | S1,S5,C1,C3,C4,IETF | 80734.4h | 43812.4h | IMSTSS |  |  | Rel-8 | SP-37 | Alain |  |  |  |
| 1449 | 490.1 | **General aspects of IMS Sup Services** | 395d? | 2007-09-03 A | 2009-03-06 A | 100% |  | 2007-09-03 | 2009-03-06 | 395d? |  |  | S1,C1,C3,C4 | 9752h | 9752h | IMSSS-Gal | Ericsson | Susana Sabater | Rel-8 | SP-37 | Alain |  |  |  |
| 1450 | 490.1.1 | Service and Capability for Core IMS - inclusion of TISPAN requirements | 75d? | 2007-09-03 A | 2007-12-14 A | 100% |  | 2007-09-03 | 2007-12-14 | 75d? |  | finish no earlier than 2007-12-14 | S1 | 600h | 600h | TISCAPR8 | Ericsson | Susana Sabater | Rel-8 | SP-37 | Alain |  |  |  |
| 1451 | 490.1.2 | Documentation of TISPAN R1 and R2 in CT1 | 208d? | 2007-11-28 A | 2008-09-12 A | 100% |  | 2007-11-28 | 2008-09-12 | 208d? |  | finish no earlier than 2008-09-12 | C1 | 1664h | 1664h | REDOC_TIS-C1 | Nokia Siemens Networks | peter.leis@nsn.com | Rel-8 | CP-38 | Frederic | PCG-21 |  |  |
| 1452 | 490.1.3 | Documentation of TISPAN R1 and R2 in CT3 | 333d? | 2007-11-28 A | 2009-03-06 A | 100% |  | 2007-11-28 | 2009-03-06 | 333d? |  | finish no earlier than 2009-03-06 | C3 | 2664h | 2664h | REDOC_TIS-C3 | Nokia Siemens Networks | peter.leis@nsn.com | Rel-8 | CP-38 | Jiwan | PCG-21 |  |  |
| 1453 | 490.1.4 | Documentation of TISPAN R1 and R2 in CT4 | 208d? | 2007-11-28 A | 2008-09-12 A | 100% |  | 2007-11-28 | 2008-09-12 | 208d? |  | finish no earlier than 2008-09-12 | C4 | 1664h | 1664h | REDOC_TIS-C4 | Nokia Siemens Networks | peter.leis@nsn.com | Rel-8 | CP-38 | Kimmo | PCG-21 |  |  |
| 1454 | 490.2 | **IMS Multimedia Telephony Service** | 394d? | 2007-09-10 A | 2009-03-12 A | 100% |  | 2007-09-10 | 2009-03-12 | 394d? |  |  | S1,S5 | 5096h | 5096h | IMS-MMTel |  |  | Rel-8 | SP-37 | Alain |  |  |  |
| 1455 | 490.2.1 | Merging TISPAN MMTel [requirements] for Common IMS | 65d? | 2007-09-10 A | 2007-12-07 A | 100% |  | 2007-09-10 | 2007-12-07 | 65d? |  | finish no earlier than 2007-12-07 | S1 | 520h | 520h | TMMTEL | Nokia Siemens Networks |  | Rel-8 | SP-37 | Alain |  |  |  |
| 1456 | 490.2.2 | Multimedia Telephony Service and Supplementary Services (MMTel) offline Charging | 309d? | 2008-01-07 A | 2009-03-12 A | 100% |  | 2008-01-07 | 2009-03-12 | 309d? |  | finish no earlier than 2009-03-12 | S5 | 2472h | 2472h | MMTel-CH | Alcatel-Lucent | Maryse.Gardella@alcatel.fr | Rel-8 | SP-38 | Dionisio | PCG-21 |  |  |
| 1457 | 490.3 | **Call Completion on Busy Subscriber (CCBS)/Call Completion on Non-Reachable (CCNR) on IMS** | 1898.5d? | 2007-05-02 A | 2014-08-01 | 89% | 199.49d? | 2007-05-02 | 2014-08-01 | 1898.5d? | 33.5d |  | C1,C3,IETF | 24284h | 11132h | CCBS_CCNR | Deutsche Telekom | martin.huelsemann@telekom.de | Rel-8 | SP-38 | Frederic | PCG-21 |  |  |
| 1458 | 490.3.1 | CT1 part of Stage 3 CCBS_CCNR | 483d? | 2007-05-02 A | 2009-03-06 A | 100% |  | 2007-05-02 | 2009-03-06 | 483d? |  | finish no earlier than 2009-03-06 | C1 | 3864h | 3864h | CCBS_CCNR | Deutsche Telekom | martin.huelsemann@telekom.de | Rel-8 | CP-38 | Frederic | PCG-21 |  |  |
| 1459 | 490.3.2 | CT3 part of Stage 3 CCBS_CCNR | 418d? | 2007-05-02 A | 2008-12-05 A | 100% |  | 2007-05-02 | 2008-12-05 | 418d? |  | finish no earlier than 2008-12-05 | C3 | 3344h | 3344h | CCBS_CCNR | Deutsche Telekom | martin.huelsemann@telekom.de | Rel-8 | CP-38 | Jiwan | PCG-21 |  |  |
| 1460 | 490.3.3 | (IETF) Stage 3 CCBS_CCNR | 655d? | 2007-05-02 A | 2014-08-01 | 75% | 163.5d? | 2007-05-02 | 2014-08-01 | 655d? | 33.5d | finish no earlier than 2012-09-14 | C1-IETF,C3-IETF | 5232h | 3924h | CCBS_CCNR | Roland Jesske |  | Rel-8 | CP-52 | Frederic | PCG-27 |  |  |

Notes:
- 1435: CP#46 completed
- 1436: SP#39 completed / Text3: 22.101
- 1437: SP#40 completed / Text3: 23.292, 23.206
- 1438: CP#46 completed
- 1439: CP#46 completed / Text3: 24.229, new (24.292, 24.286)
- 1440: Not completed internet-draft / Text3: draft-ietf-salud-alert-info-urns
- 1441: passed WGLC, Waiting for Write-Up / Text3: draft-ietf-mmusic-sdp-media-capabilities
- 1442: passed WGLC, Waiting for Write-Up / Text3: draft-ietf-mmusic-sdp-cs
- 1443: Not completed internet-draft / Text3: draft-ietf-mmusic-sdp-miscellaneous-caps
- 1444: CP#43 completed / Text3: new 29.292
- 1445: CP#42 completed / Text3: 23.003, 29.232, 23.018, 29.002
- 1446: Not completed internet-draft / Text3: draft-montemurro-gsma-imei-urn
- 1447: CP#41 work stopped / Text3: 24.293
- 1448: SP#43 completed
- 1449: CP#43 completed
- 1450: SP#39 completed / Text3: 22.228, 22.115, 22.101
- 1451: CP#41 completed / Text3: 24.141, 24.147, 24.173, 24.229, 24.247, 24.341, 24.604, 24.605, 24.606, 24.607, 24.608, 24.610, 24.611, 24.616, 24.623, 24.628, 24.629, 24.647, 24.654
- 1452: CP#43 completed / Text3: 29.162, 29.163, 29.658
- 1453: CP#41 completed / Text3: 29.228, 29.229
- 1454: SP#43 completed
- 1455: SP#38 completed / Text3: 22.173
- 1456: CP#43 completed / Text3: 32.275, 32.298/299
- 1457: CP#43 completed
- 1458: CP#43 completed / Text3: 24.642, 24.229, 24.173
- 1459: CP#42 completed / Text3: 29.163
- 1460: Seems near publication / Text3: draft-ietf-bliss-call-completion

| ID | WBS | Task | Duration | Start | Finish | Complete | Remaining | Baseline start | Baseline finish | Baseline duration | Total slack | Constraint | Resources | Work | Actual work | Text1 | Text2 | Text4 | Text5 | Text6 | Text7 | Text8 |
| --- | --- | --- | --- | --- | --- | --- | --- | --- | --- | --- | --- | --- | --- | --- | --- | --- | --- | --- | --- | --- | --- | --- |
| 1461 | 490.4 | **Flexible Alerting** | 288d? | 2008-01-30 A | 2009-03-06 A | 100% |  | 2008-01-30 | 2009-03-06 | 288d? |  |  | S1,C1 | 5278.4h | 5278.4h | FA | PCG-21 | Nortel | milanpa@nortel.com | Rel-8 | SP-39 | Alain |
| 1462 | 490.4.1 | Stage 1 FA | 92d? | 2008-01-30 A | 2008-06-05 A | 100% |  | 2008-01-30 | 2008-06-05 | 92d? |  |  | S1 | 670.4h | 670.4h | FA | PCG-21 | Telecom Italia |  | Rel-8 | SP-39 | Alain |
| 1463 | 490.4.2 | Stage 3 FA | 288d? | 2008-01-30 A | 2009-03-06 A | 100% |  | 2008-01-30 | 2009-03-06 | 288d? |  | finish no earlier than 2009-03-06 | C1 | 2304h | 2304h | FA | PCG-21 | Nortel | milanpa@nortel.com | Rel-8 | CP-39 | Frederic |
| 1464 | 490.5 | **Communication Wait on IMS** | 1432d? | 2007-06-22 A | 2012-12-07 | 86% | 195.25d? | 2007-06-22 | 2012-12-07 | 1432d? | 463d |  | C1,C3,IETF | 18904h | 9058h | CW_IMS | PCG-21 | Deutsche Telekom | martin.huelsemann@telekom.de | Rel-8 | SP-38 | Frederic |
| 1465 | 490.5.1 | CT1 part of Stage 3 CW-IMS | 331d? | 2007-11-30 A | 2009-03-06 A | 100% |  | 2007-11-30 | 2009-03-06 | 331d? |  | finish no earlier than 2009-03-06 | C1 | 2648h | 2648h | CW_IMS | PCG-21 | Deutsche Telekom | martin.huelsemann@telekom.de | Rel-8 | CP-38 | Frederic |
| 1466 | 490.5.2 | (IETF) Stage 3 CW-IMS | 715d? | 2007-06-22 A | 2012-12-07 | 75% | 178.75d? | 2007-06-22 | 2012-12-07 | 715d? | 463d | finish no earlier than 2012-12-07 | C1-IETF | 5720h | 4290h | CW_IMS | PCG-27 | Roland Jesske |  | Rel-8 | CP-52 | Frederic |
| 1467 | 490.5.3 | CT3 part of Stage 3 CW-IMS | 265d? | 2007-11-30 A | 2008-12-04 A | 100% |  | 2007-11-30 | 2008-12-04 | 265d? |  | finish no earlier than 2008-12-05 | C3 | 2120h | 2120h | CW_IMS | PCG-21 | Deutsche Telekom | martin.huelsemann@telekom.de | Rel-8 | CP-38 | Jiwan |
| 1468 | 490.6 | Advice of Charge (AoC) support in IMS Charging | 309d? | 2008-01-07 A | 2009-03-12 A | 100% |  | 2008-01-07 | 2009-03-12 | 309d? |  | finish no earlier than 2009-03-12 | S5 | 2472h | 2472h | IMSTSS | PCG-21 | Nokia Siemens Networks | Gerald.Goermer@nsn.com | Rel-8 | SP-38 | Dionisio |
| 1469 | 490.7 | Add Interconnection Border Control Function (IBCF) to IMS Charging | 128d? | 2007-09-17 A | 2008-03-12 A | 100% |  | 2007-09-17 | 2008-03-12 | 128d? |  | finish no earlier than 2008-03-12 | S5 | 1024h | 1024h | IMSTSS |  | Alcatel-Lucent | Maryse.Gardella@alcatel.fr | Rel-8 | SP-37 | Dionisio |
| 1470 | 491 | **3GPP2 Input to Common IMS** | 200d? | 2008-03-07 A | 2008-12-11 A | 100% |  | 2008-03-07 | 2008-12-11 | 200d? |  |  | S1,S2,S3,C1,C3,C4 | 8653.2h | 8653.2h | CIMS_3GPP2 | PCG-21 | Nortel | Amar Deol (deola@nortelnetworks.com) | Rel-8 | SP-39 | Alain |
| 1471 | 491.1 | Stage 1 CIMS_3GPP2 (SA1) | 30.65d? | 2008-03-12 A | 2008-06-05 A | 100% |  | 2008-03-12 | 2008-06-05 | 30.65d? |  | finish no earlier than 2008-06-12 | S1 | 245.2h | 245.2h | CIMS_3GPP2 | PCG-21 | Nortel | Amar Deol (deola@nortelnetworks.com) | Rel-8 | SP-39 | Alain |
| 1472 | 491.2 | Stage 2 CIMS_3GPP2 (SA2) | 62d? | 2008-03-12 A | 2008-06-05 A | 100% |  | 2008-03-12 | 2008-06-05 | 62d? |  | finish no earlier than 2008-09-11 | S2 | 496h | 496h | IMS_Common | PCG-21 | Nortel | Amar Deol (deola@nortelnetworks.com) | Rel-8 | SP-39 | Maurice |
| 1473 | 491.3 | Security CIMS_3GPP2 (SA3) | 197d? | 2008-03-12 A | 2008-12-11 A | 100% |  | 2008-03-12 | 2008-12-11 | 197d? |  | finish no earlier than 2008-12-11 | S3 | 1576h | 1576h | IMS_Common | PCG-21 | Nortel | Amar Deol (deola@nortelnetworks.com) | Rel-8 | SP-39 | Dionisio |
| 1474 | 491.4 | Stage 3 CIMS_3GPP2 (CT1) | 196d? | 2008-03-07 A | 2008-12-05 A | 100% |  | 2008-03-07 | 2008-12-05 | 196d? |  | finish no earlier than 2008-12-11 | C1 | 1568h | 1568h | REDOC_3GPP2 | PCG-21 | Alcatel-Lucent | orsic@alcatel-lucent.com | Rel-8 | CP-39 | Frederic |
| 1475 | 491.5 | Stage 3 CIMS_3GPP2 (CT3) | 196d? | 2008-03-07 A | 2008-12-05 A | 100% |  | 2008-03-07 | 2008-12-05 | 196d? |  | finish no earlier than 2008-12-05 | C3 | 1568h | 1568h | REDOC_3GPP2 | PCG-21 | Alcatel-Lucent | orsic@alcatel-lucent.com | Rel-8 | CP-39 | Jiwan |
| 1476 | 491.6 | Stage 3 CIMS_3GPP2 (CT4) | 200d? | 2008-03-07 A | 2008-12-11 A | 100% |  | 2008-03-07 | 2008-12-11 | 200d? |  | finish no earlier than 2008-12-11 | C4 | 1600h | 1600h | REDOC_3GPP2 | PCG-21 | Alcatel-Lucent | orsic@alcatel-lucent.com | Rel-8 | CP-39 | Kimmo |
| 1477 | 492 | **IMS Enhancements for support of Packet Cable access** | 388d? | 2006-12-06 A | 2008-05-30 A | 100% |  | 2006-12-06 | 2008-05-30 | 388d? |  |  | S2,S3,C1,C3,C4 | 27448h | 27448h | PktCbl |  | Cablelabs | Bernie McKibben (b.mckibben@cablelabs.com) | Rel-8 |  | Maurice |
| 1478 | 492.1 | **IMS Enhancements for Cable Client Types and Deployment Models** | 345d? | 2007-02-05 A | 2008-05-30 A | 100% |  | 2007-02-05 | 2008-05-30 | 345d? |  |  | S2,C1 | 6992h | 6992h | PktCbl-Deploy |  | Cablelabs | Bernie McKibben (b.mckibben@cablelabs.com) | Rel-8 |  | Maurice |
| 1479 | 492.1.1 | Architecture aspects of PktCbl-Deploy | 219d? | 2007-02-05 A | 2007-12-06 A | 100% |  | 2007-02-05 | 2007-12-06 | 219d? |  | finish no earlier than 2007-12-03 | S2 | 1752h | 1752h | PktCbl-Deploy |  | Cablelabs | Bernie McKibben (b.mckibben@cablelabs.com) | Rel-8 |  | Maurice |
| 1480 | 492.1.2 | CT1 aspects of PktCbl-Deploy | 310d? | 2007-03-26 A | 2008-05-30 A | 100% |  | 2007-03-26 | 2008-05-30 | 310d? |  | finish no earlier than 2008-06-15 | C1 | 2480h | 2480h | PktCbl-Deploy |  | Cablelabs | D.Hancock@CableLabs.com | Rel-8 |  | Frederic |
| 1481 | 492.2 | **IMS Inter-working aspects in Support of Cable Regulatory requirements** | 290d? | 2007-02-05 A | 2008-03-14 A | 100% |  | 2007-02-05 | 2008-03-14 | 290d? |  |  | S2,C1,C3 | 5640h | 5640h | PktCbl-Intw |  | Cablelabs | B.McKibben@CableLabs.com | Rel-8 |  | Maurice |
| 1482 | 492.2.1 | Architecture aspects of PktCbl-Interwork | 160d? | 2007-02-05 A | 2007-09-14 A | 100% |  | 2007-02-05 | 2007-09-14 | 160d? |  | start no earlier than 2007-02-05 | S2 | 1280h | 1280h | PktCbl-Intw |  | Cablelabs | B.McKibben@CableLabs.com | Rel-8 |  | Maurice |
| 1483 | 492.2.2 | CT1,CT3 aspects of PktCbl-Interwork | 255d? | 2007-03-26 A | 2008-03-14 A | 100% |  | 2007-03-26 | 2008-03-14 | 255d? |  | finish no earlier than 2008-03-15 | C1,C3 | 2040h | 2040h | PktCbl-Intw |  | Cablelabs | D.Hancock@CableLabs.com | Rel-8 |  | Frederic |
| 1484 | 492.3 | **IMS Enhancements for Security Requirements in Support of Cable Deployments** | 388d? | 2006-12-06 A | 2008-05-30 A | 100% |  | 2006-12-06 | 2008-05-30 | 388d? |  |  | S3,C1,C3,C4 | 11712h | 11712h | PktCbl-Sec |  | Cablelabs | s.dotson@cablelabs.com | Rel-8 |  | Dionisio |
| 1485 | 492.3.1 | SA3 aspects of PktCbl-Sec | 331d? | 2006-12-06 A | 2008-03-12 A | 100% |  | 2006-12-06 | 2008-03-12 | 331d? |  | finish no earlier than 2007-12-20 | S3 | 2648h | 2648h | PktCbl-Sec |  | Cablelabs | s.dotson@cablelabs.com | Rel-8 |  | Dionisio |
| 1486 | 492.3.2 | CT1 aspects of PktCbl-Sec | 310d? | 2007-03-26 A | 2008-05-30 A | 100% |  | 2007-03-26 | 2008-05-30 | 310d? |  | finish no earlier than 2008-06-06 | C1 | 2480h | 2480h | PktCbl-Sec |  | Cablelabs | D.Hancock@CableLabs.com | Rel-8 |  | Frederic |
| 1487 | 492.3.3 | CT3 aspects of PktCbl-Sec | 180d? | 2007-03-26 A | 2007-11-30 A | 100% |  | 2007-03-26 | 2007-11-30 | 180d? |  | finish no earlier than 2008-03-15 | C3 | 1440h | 1440h | PktCbl-Intw | PCG-21 | Cablelabs | D.Hancock@CableLabs.com | Rel-8 | CP-38 | Jiwan |
| 1488 | 492.3.4 | CT4 aspects of PktCbl-Sec | 255d? | 2007-03-26 A | 2008-03-14 A | 100% |  | 2007-03-26 | 2008-03-14 | 255d? |  | finish no earlier than 2008-03-14 | C4 | 2040h | 2040h | PktCbl-Sec |  | Cablelabs | D.Hancock@CableLabs.com | Rel-8 |  | Kimmo |

Notes:
- 1461: CP#43 completed
- 1462: SP#40 completed / Text3: 22.173
- 1463: CP#43 completed / Text3: 24.239, 24.173
- 1464: CP#43 completed
- 1465: CP#43 completed / Text3: 24.615, 24.229, 24.173
- 1466: Not completed internet-draft / Text3: draft-ietf-salud-alert-info-urns
- 1467: CP#42 completed / Text3: 29.163
- 1468: SP#43 completed / Text3: 32.240, 32.260, 32.296, 32.298, 32.299, new 32.280
- 1469: SP#39 completed / Text3: 32.260, 32.298
- 1470: TSG#42 completed
- 1471: SP#40 completed / Text3: 22.228, 22.173, 22.101, 22.153
- 1472: SP#40 completed / Text3: 23.002, 23.141, 23.203, 23.167, 23.228
- 1473: SP#42 completed [issues addressed under UID_370078 (IMS-Sec)] / Text3: 33.141, 33.203, 33.210
- 1474: CP#42 completed / Text3: 23.218, 24.141, 24.147, 24.173, 24.229, 24.238, 24.247, 24.604, 24.605, 24.606, 24.607, 24.608, 24.610, 24.611, 24.629, 24.930
- 1475: CP#42 completed / Text3: 29.163, 29.212, 29.213, 29.214
- 1476: CP#42 completed / Text3: 29.228, 29.229, 29.328, 29.329
- 1477: CP#40 completed
- 1478: CP#40 completed
- 1479: SP#38 completed / Text3: 23.228
- 1480: CP#40 completed
- 1481: CP#39 completed
- 1482: SP#37 completed / Text3: 23.228
- 1483: CP#39 completed / Text3: 24.229
- 1484: CP#40 completed
- 1485: SP#39 completed / Text3: 33.203, 33.210, 33.220
- 1486: CP#40 completed / Text3: 24.229
- 1487: CP#38 completed / Text3: 29.163
- 1488: CP#39 completed / Text3: 29.228, 29.229, 23.008

| ID | WBS | Task | Type | Duration | Start | Finish | Complete | Remaining | Baseline start | Baseline finish | Baseline duration | Total slack | Constraint | Resources | Work | Actual work | Text1 | Text4 | Text5 | Text6 | Text8 | Text2 | Text7 |
| --- | --- | --- | --- | --- | --- | --- | --- | --- | --- | --- | --- | --- | --- | --- | --- | --- | --- | --- | --- | --- | --- | --- | --- |
| 1489 | 493 | **IMS System enhancements for corporate network access** |  | 1432d? | 2007-06-22 A | 2012-12-07 | 94% | 89.34d? | 2007-06-22 | 2012-12-07 | 1432d? | 463d |  | S2,S1,C1,C4 | 22920.9h | 16479.6h | IMS_Corp | Orange | Delphin Barankanira | Rel-8 | Maurice |  |  |
| 1490 | 493.1 | SA1 aspects of IMS_Corp |  | 23.6d? | 2008-03-12 A | 2008-06-05 A | 100% |  | 2008-03-12 | 2008-06-05 | 23.6d? |  | finish no earlier than 2008-06-05 | S1 | 188.8h | 188.8h | IMS_Corp | Telecom Italia |  | Rel-8 | Alain | PCG-21 | SP-39 |
| 1491 | 493.2 | SA2 aspects of IMS_Corp |  | 325d? | 2007-06-22 A | 2008-09-18 A | 100% |  | 2007-06-22 | 2008-09-18 | 325d? |  | finish no earlier than 2008-12-25 | S2 | 2600h | 2600h | IMS_Corp | Orange | Delphin Barankanira | Rel-8 | Maurice |  |  |
| 1492 | 493.3 | CT1 aspects of IMS_Corp |  | 532d? | 2008-03-07 A | 2010-03-19 A | 100% |  | 2008-03-07 | 2010-03-19 | 532d? |  | finish no earlier than 2010-03-19 | C1 | 4244.09h | 4244.09h | IMS_Corp | Alcatel-Lucent | Keith Drage (drage@alcatel-lucent.com) | Rel-8 | Frederic | PCG-21 | CP-39 |
| 1493 | 493.4 | (IETF) CT1 aspects of IMS_Corp |  | 358d? | 2011-06-29 A | 2012-12-07 | 75% | 89.5d? | 2011-06-29 | 2012-12-07 | 358d? | 463d | finish no earlier than 2012-12-07 | C1-IETF | 2864h | 2148h | IMS_Corp | Keith Drage | Keith Drage (drage@alcatel-lucent.com) | Rel-8 |  | PCG-27 | CP-53 |
| 1494 | 493.5 | CT4 aspects of IMS_Corp |  | 196d? | 2008-02-26 A | 2008-12-05 A | 100% |  | 2008-02-26 | 2008-12-05 | 196d? |  | finish no earlier than 2008-12-11 | C4 | 1568h | 1568h | IMS_Corp | Alcatel-Lucent | Keith Drage (drage@alcatel-lucent.com) | Rel-8 | Kimmo | PCG-21 | CP-39 |
| 1495 | 494 | **Maintenance of TISPAN documentation** |  | 1426d? | 2007-07-02 A | 2012-12-07 | 82% | 250.14d? | 2007-07-02 | 2012-12-07 | 1426d? | 463d |  | S2,C1,C3,C4,IETF | 18648h | 6722h | MAINTISP |  |  | Rel-8 | Maurice | PCG-21 | SP-38 |
| 1496 | 494.1 | Maintenance of TISPAN R2 |  | 86d? | 2007-11-09 A | 2008-03-07 A | 100% |  | 2007-11-09 | 2008-03-07 | 86d? |  | start no earlier than 2007-11-09 | C1,C3,C4 | 688h | 688h | MAINT_R2 | Alcatel-Lucent | Keith Drage (drage@alcatel-lucent.com) | Rel-8 | Frederic | PCG-21 | CP-38 |
| 1497 | 494.2 | (IETF) Maintenance of TISPAN R2 |  | 715d? | 2007-11-09 A | 2012-12-07 | 75% | 178.75d? | 2007-11-09 | 2012-12-07 | 715d? | 463d | finish no earlier than 2012-12-07 | C1-IETF | 5720h | 4290h | MAINT_R2 | Andrew Allen |  | Rel-8 | Frederic | PCG-27 | CP-52 |
| 1498 | 494.3 | Documentation of TISPAN NGN R1 and R2 in 3GPP SA2 |  | 104d? | 2008-01-14 A | 2008-06-05 A | 100% |  | 2008-01-14 | 2008-06-05 | 104d? |  | finish no earlier than 2008-06-20 | S2 | 832h | 832h | IMS_Comm_Doc | Nokia Siemens Networks | jozsef.varga@nsn.com | Rel-8 | Maurice | PCG-21 | SP-38 |
| 1499 | 494.4 | Maintenance of TISPAN release 2 common IMS |  | 114d? | 2007-07-02 A | 2007-12-06 A | 100% |  | 2007-07-02 | 2007-12-06 | 114d? |  | finish no earlier than 2007-12-06 | S2 | 912h | 912h | IMS_Comm_Mtce8 | Telecom Italia | antonio.ascolese@telecomitalia.it | Rel-8 | Maurice | PCG-21 | SP-38 |
| 1500 | 495 | **IMS Service Continuity** |  | 318d? | 2008-03-12 A | 2009-05-29 A | 100% |  | 2008-03-12 | 2009-05-29 | 318d? |  |  | S2,S1,C1 | 5624h | 5624h | IMS-Cont | LG Electronics | JaeSeung SONG (anthonys@lge.com) | Rel-8 | Maurice | PCG-21 | SP-39 |
| 1501 | 495.1 | Stage 1 IMS Service Continuity |  | 62d? | 2008-03-12 A | 2008-06-05 A | 100% |  | 2008-03-12 | 2008-06-05 | 62d? |  | start no earlier than 2008-03-12 | S1 | 496h | 496h | IMS-Cont | LG Electronics | JaeSeung SONG (anthonys@lge.com) | Rel-8 | Alain | PCG-21 | SP-39 |
| 1502 | 495.2 | Stage 2 IMS Service Continuity |  | 62d? | 2008-03-12 A | 2008-06-05 A | 100% |  | 2008-03-12 | 2008-06-05 | 62d? |  | finish no earlier than 2008-06-05 | S2 | 496h | 496h | IMS-Cont | LG Electronics | JaeSeung SONG (anthonys@lge.com) | Rel-8 | Maurice | PCG-21 | SP-39 |
| 1503 | 495.3 | Stage 3 IMS Service Continuity |  | 261d? | 2008-05-30 A | 2009-05-29 A | 100% |  | 2008-05-30 | 2009-05-29 | 261d? |  | finish no earlier than 2009-05-29 | C1 | 2088h | 2088h | IMS-Cont | Huawei | Lili Yang (kadyyang@huawei.com) | Rel-8 | Frederic | PCG-21 | CP-40 |
| 1504 | 496 | **Security Enhancements for IMS** |  | 643.3d? | 2006-09-19 A | 2009-03-06 A | 100% |  | 2006-09-19 | 2009-03-06 | 643.3d? |  |  | S3,C1,C4 | 18624h | 18624h | IMS-Sec | Ericsson | Bengt.Sahlin@ericsson.com | Rel-8 | Dionisio |  | SP-37 |
| 1505 | 496.1 | Stage 2 for IMS-Sec |  | 466d? | 2007-03-01 A | 2008-12-11 A | 100% |  | 2007-03-01 | 2008-12-11 | 466d? |  | finish no earlier than 2008-12-11 | S3 | 3728h | 3728h | IMS-Sec | Ericsson | Bengt.Sahlin@ericsson.com | Rel-8 | Dionisio |  |  |
| 1506 | 496.2 | CT1 part of Stage 3 for IMS-Sec |  | 392d? | 2006-09-19 A | 2008-12-05 A | 100% |  | 2006-09-19 | 2008-12-05 | 392d? |  | finish no earlier than 2008-12-05 | C1 | 3136h | 3136h | IMS-Sec | Ericsson |  | Rel-8 | Frederic | PCG-21 | CP-39 |
| 1507 | 496.3 | CT4 part of Stage 3 for IMS-Sec |  | 457d? | 2007-06-07 A | 2009-03-06 A | 100% |  | 2007-06-07 | 2009-03-06 | 457d? |  | finish no earlier than 2009-03-06 | C4 | 3656h | 3656h | IMS-Sec | Ericsson |  | Rel-8 | Kimmo | PCG-21 | CP-39 |
| 1508 | 496.4 | CT1 part of Network Attachment Subsystem (NASS) Bundled Authentication |  | 343d? | 2007-11-14 A | 2009-03-06 A | 100% |  | 2007-11-14 | 2009-03-06 | 343d? |  | finish no earlier than 2009-03-06 | C1 | 2744h | 2744h | NBA | Alcatel-Lucent | Keith Drage (drage@alcatel-lucent.com) | Rel-8 | Frederic | PCG-21 | CP-39 |
| 1509 | 496.5 | CT4 part of Network Attachment Subsystem (NASS) Bundled Authentication |  | 143d? | 2007-11-14 A | 2008-05-30 A | 100% |  | 2007-11-14 | 2008-05-30 | 143d? |  | start no earlier than 2007-11-14 | C4 | 1144h | 1144h | NBA-CT4 | Alcatel-Lucent |  | Rel-8 | Kimmo | PCG-21 | CP-39 |
| 1510 | 497 | **IMS initiated and controlled PSS and MBMS User Service** |  | 924d? | 2008-03-12 A | 2011-09-21 A | 100% |  | 2008-03-12 | 2011-09-21 | 924d? |  |  | S4,S3,IETF | 13324.8h | 13324.8h | IMS_PSS_MBMS_US | FT, Ericsson | olle.franceschi@ericsson.com | Rel-8 | Paolo |  |  |
| 1511 | 497.1 | SA4, SA3 part of IMS initiated and controlled PSS and MBMS User Service | milestone | 0d? | 2008-03-12 A | 2008-03-12 A | 100% |  | 2008-03-12 | 2008-03-12 | 0d? |  | finish no earlier than 2009-03-12 | S4,S3 |  |  | IMS_PSS_MBMS_US | FT, Ericsson | olle.franceschi@ericsson.com | Rel-8 | Paolo |  |  |
| 1512 | 497.2 | (IETF) IMS initiated and controlled PSS and MBMS User Service |  | 743.6d? | 2008-03-12 A | 2011-09-21 A | 100% |  | 2008-03-12 | 2011-09-21 | 743.6d? |  | finish no earlier than 2011-09-21 | S4-IETF | 5932.8h | 5932.8h | IMS_PSS_MBMS_US |  |  | Rel-8 | Paolo | PCG-27 | SP-52 |

Notes:
- 1489: CP#47 completed
- 1490: SP#40 completed
- 1491: no Stage 2 impacts / Text3: 23.228
- 1492: CP#47 completed / Text3: 24.229, 24.503
- 1493: Expired / Text3: draft-vanelburg-dispatch-private-network-ind
- 1494: CP#42 completed / Text3: 29.228, 29.229, 23.003, 23.008, 29.433
- 1495: SP#40 completed
- 1496: CP#39 completed / Text3: 24.406, 24.407, 24.410, 24.411, 24.423, 24.430, 24.447, 24.451, 24.454, 24.503, 24.505, 24.508, 24.516, 24.528, 24.529, 29.412, 29.421, 29.433, 29.458, 29.527, 29.624
- 1497: Not completed internet-draft / Text3: draft-avasarala-dispatch-comm-div-notification
- 1498: SP#40 completed / Text3: 23.228, 23.204, 23.167
- 1499: SP#38 completed / Text3: 23.506, 23.507,23.517, 23.521
- 1500: CP#44 completed
- 1501: SP#40 completed
- 1502: SP#40 completed / Text3: 23.237, 23.292
- 1503: CP#44 completed / Text3: 24.237, 24.229, 24.216
- 1504: CP#43 completed
- 1505: SP#42 completed. SP#46 withdrawn draft 33.178-100 and 33.978 from Rel-8 onwards / Text3: 33.203, 33.141, 33.803
- 1506: CP#42 completed
- 1507: CP#43 completed
- 1508: CP#43 completed / Text3: 24.229
- 1509: CP#40 completed / Text3: 29.229, 29.228, 23.008
- 1510: SP#39 WID approved
- 1511: SP#43 completed / Text3: 26.234, 26.346, 33.246, new 26.237
- 1512: SP#53/IETF#81: RFC 6080 included in 26.237 / Text3: draft-ietf-sipping-config-framework

| ID | WBS | Task | Duration | Start | Finish | Complete | Remaining | Baseline start | Baseline finish | Baseline duration | Total slack | Constraint | Resources | Work | Actual work | Text1 | Text4 | Text5 | Text6 | Text8 | Text3 | Text2 | Text7 |
| --- | --- | --- | --- | --- | --- | --- | --- | --- | --- | --- | --- | --- | --- | --- | --- | --- | --- | --- | --- | --- | --- | --- | --- |
| 1513 | 498 | **Multimedia interworking between IMS and CS networks** | 836d? | 2005-09-23 A | 2008-12-05 A | 100% |  | 2005-09-23 | 2008-12-05 | 836d? |  |  | C3,C4 | 16112h | 16112h | MIW-IMS | Vodafone | nico.gabriele@vodafone.com | Rel-8 | Jiwan |  |  |  |
| 1514 | 498.1 | Stage 1 and 2 defined in earlier Releases | 49d? | 2005-09-23 A | 2005-11-30 A | 100% |  | 2005-09-23 | 2005-11-30 | 49d? |  | start no earlier than 2005-09-23 | S2 | 392h | 392h | MIW-IMS | Vodafone | nico.gabriele@vodafone.com | Rel-8 | Maurice |  |  |  |
| 1515 | 498.2 | Stage 3 of MW-IMS | 571d? | 2005-09-23 A | 2007-11-30 A | 100% |  | 2005-09-23 | 2007-11-30 | 571d? |  | finish no earlier than 2007-09-14 | C3 | 4568h | 4568h | MIW-IMS-St3 | Vodafone | nico.gabriele@vodafone.com | Rel-8 | Jiwan | 29.863, 29.163 |  |  |
| 1516 | 498.3 | Stage 3 for MW-IMS, MONA extension | 285d? | 2007-11-05 A | 2008-12-05 A | 100% |  | 2007-11-05 | 2008-12-05 | 285d? |  | finish no earlier than 2008-12-05 | C3 | 2280h | 2280h | MIW-IMS | Vodafone | Christer.Holmberg@ericsson.com | Rel-8 | Jiwan | 29.863, 29.163 | PCG-21 | CP-38 |
| 1517 | 498.4 | Mn interface (MGCF – IM MGW) | 273d? | 2007-11-21 A | 2008-12-05 A | 100% |  | 2007-11-21 | 2008-12-05 | 273d? |  | finish no earlier than 2008-12-19 | C4 | 2184h | 2184h | MIW-IMS | Vodafone | Christer.Holmberg@ericsson.com | Rel-8 | Kimmo | 29.332 | PCG-21 | CP-38 |
| 1518 | 499 | **IMS Stage 3 IETF Protocol Alignment - phase 2** | 1432d? | 2007-06-22 A | 2012-12-07 | 85% | 207.85d? | 2007-06-22 | 2012-12-07 | 1432d? | 463d |  | C1,IETF | 27584h | 16836h | IMSProtoc2 | Alcatel-Lucent | Keith Drage (drage@alcatel-lucent.com) | Rel-8 | Frederic | 23.218, 24.229, 24.930 |  |  |
| 1519 | 499.1 | CT1 aspects of IMS Stage 3 IETF Protocol Alignment - phase 2 | 446d? | 2007-06-22 A | 2009-03-06 A | 100% |  | 2007-06-22 | 2009-03-06 | 446d? |  | finish no earlier than 2009-03-06 | C1 | 3568h | 3568h | IMSProtoc2 | Alcatel-Lucent | Keith Drage (drage@alcatel-lucent.com) | Rel-8 | Frederic | 23.218, 24.229, 24.930 |  |  |
| 1520 | 499.2 | (IETF) IMS Stage 3 IETF Protocol Alignment (draft-bakker-sipping-3gpp-ims-xml-body-handling) | 715d? | 2007-06-22 A | 2012-12-07 | 75% | 178.75d? | 2007-06-22 | 2012-12-07 | 715d? | 463d | finish no earlier than 2012-12-07 | C1-IETF | 5720h | 4290h | IMSProtoc2 | Andrew Allen |  | Rel-8 | Frederic | draft-bakker-sipping-3gpp-ims-xml-body-handling | PCG-27 | CP-52 |
| 1521 | 499.3 | (IETF) IMS Stage 3 IETF Protocol Alignment (draft-ietf-mmusic-ice-tcp) | 587d? | 2007-06-22 A | 2012-06-15 A | 100% |  | 2007-06-22 | 2012-06-15 | 587d? |  | finish no earlier than 2012-04-20 | C1-IETF | 4688h | 4688h | IMSProtoc2 | Keith Drage |  | Rel-8 | Frederic | RFC 6544 (was draft-ietf-mmusic-ice-tcp) | PCG-27 | CP-52 |
| 1522 | 499.4 | (IETF) IMS Stage 3 IETF Protocol Alignment (draft-ietf-salud-alert-info-urns) | 715d? | 2007-06-22 A | 2012-12-07 | 75% | 178.75d? | 2007-06-22 | 2012-12-07 | 715d? | 463d | finish no earlier than 2012-12-07 | C1-IETF | 5720h | 4290h | IMSProtoc2 | Roland Jesske |  | Rel-8 | Frederic | draft-ietf-salud-alert-info-urns | PCG-27 | CP-52 |
| 1523 | 500 | **Interworking between User-to-User Signalling (UUS) and SIP** | 1317d? | 2007-11-30 A | 2012-12-07 | 81% | 250.67d? | 2007-11-30 | 2012-12-07 | 1317d? | 463d |  | C1,C3,IETF | 28554h | 16311.5h | UUSIW | Huawei | Lili Yang (kadyyang@huawei.com) | Rel-8 | Kimmo |  | PCG-21 | CP-38 |
| 1524 | 500.1 | CT1 part of Stage 3 MGCF UUSIW | 266d? | 2007-11-30 A | 2008-12-05 A | 100% |  | 2007-11-30 | 2008-12-05 | 266d? |  | finish no earlier than 2008-12-05 | C1 | 2128h | 2128h | UUSIW | Huawei | Lili Yang (kadyyang@huawei.com) | Rel-8 | Frederic | 24.279, 24.229 | PCG-21 | CP-38 |
| 1525 | 500.2 | (IETF) Stage 3 MGCF UUSIW (sip-uui) | 600.25d? | 2007-11-30 A | 2012-12-07 | 75% | 150.06d? | 2007-11-30 | 2012-12-07 | 600.25d? | 463d | finish no earlier than 2012-12-07 | C1-IETF,C3-IETF | 4802h | 3601.5h | UUSIW | Roland Jesske |  | Rel-8 | Frederic | draft-ietf-cuss-sip-uui | PCG-27 | CP-52 |
| 1526 | 500.3 | (IETF) Stage 3 MGCF UUSIW (sip-uui-isdn) | 1317d? | 2007-11-30 A | 2012-12-07 | 75% | 329.25d? | 2007-11-30 | 2012-12-07 | 1317d? | 463d | finish no earlier than 2012-12-07 | C1-IETF,C3-IETF | 10536h | 7902h | UUSIW | Keith Drage |  | Rel-8 |  | draft-ietf-cuss-sip-uui-isdn | PCG-28 | CP-55 |
| 1527 | 500.4 | CT3 part of Stage 3 MGCF UUSIW | 335d? | 2007-11-30 A | 2009-03-12 A | 100% |  | 2007-11-30 | 2009-03-12 | 335d? |  | finish no earlier than 2009-03-12 | C3 | 2680h | 2680h | UUSIW | Huawei | Lili Yang (kadyyang@huawei.com) | Rel-8 | Jiwan | 29.163 | PCG-21 | CP-38 |
| 1528 | 501 | **Support of Overlap signalling** | 331d? | 2007-11-30 A | 2009-03-06 A | 100% |  | 2007-11-30 | 2009-03-06 | 331d? |  |  | C3,C1,C4 | 10008.2h | 10008.2h | Overlap | Deutsche Telekom | r.jesske@telekom.de | Rel-8 | Jiwan |  | PCG-21 | CP-38 |
| 1529 | 501.1 | Stage 3 Overlap (CT1) | 331d? | 2007-11-30 A | 2009-03-06 A | 100% |  | 2007-11-30 | 2009-03-06 | 331d? |  | finish no earlier than 2009-03-06 | C1 | 2648h | 2648h | Overlap | Deutsche Telekom | r.jesske@telekom.de | Rel-8 | Frederic | 24.229 | PCG-21 | CP-38 |
| 1530 | 501.2 | Stage 3 Overlap (CT3) | 331d? | 2007-11-30 A | 2009-03-06 A | 100% |  | 2007-11-30 | 2009-03-06 | 331d? |  | finish no earlier than 2009-03-06 | C3 | 2648h | 2648h | Overlap | Deutsche Telekom | r.jesske@telekom.de | Rel-8 | Jiwan | 29.163 | PCG-21 | CP-38 |
| 1531 | 501.3 | Stage 3 Overlap (CT4) | 258.02d? | 2007-11-30 A | 2008-12-05 A | 100% |  | 2007-11-30 | 2008-12-05 | 258.02d? |  | start no earlier than 2007-11-30 | C4 | 2064.16h | 2064.16h | Overlap | Deutsche Telekom | r.jesske@telekom.de | Rel-8 | Kimmo | 29.228, 29.229 | PCG-21 | CP-38 |
| 1532 | 502 | **AS/MRFC Stage 2 and 3** | 1203d? | 2007-11-14 A | 2012-06-15 A | 100% |  | 2007-11-14 | 2012-06-15 | 1203d? |  |  | C1,IETF | 16536h | 16536h | MRFC_TS | Hewlett-Packard | mark.syrett@hp.com | Rel-8 | Frederic |  | PCG-21 | CP-38 |
| 1533 | 502.1 | AS/MRFC Stage 2 | 278d? | 2007-11-14 A | 2008-12-05 A | 100% |  | 2007-11-14 | 2008-12-05 | 278d? |  | finish no earlier than 2008-12-05 | C1 | 2224h | 2224h | MRFC_TS | Hewlett-Packard | mark.syrett@hp.com | Rel-8 | Frederic | 23.218 | PCG-21 | CP-38 |
| 1534 | 502.2 | AS/MRFC Stage 3 | 278d? | 2007-11-14 A | 2008-12-05 A | 100% |  | 2007-11-14 | 2008-12-05 | 278d? |  | finish no earlier than 2008-12-05 | C1 | 2224h | 2224h | MRFC_TS | Hewlett-Packard | mark.syrett@hp.com | Rel-8 | Frederic | 24.229, 24.147, 24.247 | PCG-21 | CP-38 |
| 1535 | 502.3 | (IETF) AS/MRFC Stage 2 and 3 | 590d? | 2007-11-14 A | 2012-06-15 A | 100% |  | 2007-11-14 | 2012-06-15 | 590d? |  | finish no earlier than 2012-06-15 | C1-IETF | 4688h | 4688h | MRFC_TS | Keith Drage |  | Rel-8 | Frederic | RFC 6505 (was draft-ietf-mediactrl-mixer-control-package) | PCG-27 | CP-52 |
| 1536 | 503 | **IMS Restoration Procedures** | 201d? | 2008-05-30 A | 2009-03-06 A | 100% |  | 2008-05-30 | 2009-03-06 | 201d? |  |  | C4,C1 | 4824h | 4824h | IMS_RP | Ericsson | german.blanco@ericsson.com | Rel-8 | Kimmo |  | PCG-21 | SP-40 |
| 1537 | 503.1 | IMS Restoration Procedures (CT4) | 201d? | 2008-05-30 A | 2009-03-06 A | 100% |  | 2008-05-30 | 2009-03-06 | 201d? |  | finish no earlier than 2009-03-06 | C4 | 1608h | 1608h | IMS_RP | Ericsson | german.blanco@ericsson.com | Rel-8 | Kimmo | 23.380, 29.228, 29.229, 29.230, 23.008 | PCG-21 | SP-40 |
| 1538 | 503.2 | IMS Restoration Procedures (CT1) | 201d? | 2008-05-30 A | 2009-03-06 A | 100% |  | 2008-05-30 | 2009-03-06 | 201d? |  | finish no earlier than 2009-03-06 | C1 | 1608h | 1608h | IMS_RP | Ericsson | german.blanco@ericsson.com | Rel-8 | Frederic | 24.229 | PCG-21 | SP-40 |
| 1539 | 504 | IMS Application Server Service Data Descriptions for AS interoperability | 125d? | 2008-09-12 A | 2009-03-06 A | 100% |  | 2008-09-12 | 2009-03-06 | 125d? |  | finish no earlier than 2009-03-06 | C4 | 1000h | 1000h | IMS_ASIO | Alcatel-Lucent | nhberry@alcatel-lucent.com | Rel-8 | Kimmo | 29.328, 29.329, 29.364 | PCG-21 | CP-41 |

Notes:
- 1513: CP#42 completed
- 1514: SP#31 Moved from FS section Feb 2006
- 1515: Moved from Rel-7. Feature extended in Rel-8 by including Stage 3 covering MONA UID_380021
- 1516: CP#42 completed
- 1517: CP#42 completed
- 1518: CP#43 completed
- 1519: CP#43 completed
- 1520: Not completed internet-draft
- 1521: CP#56 RFC 6544 completed
- 1522: Not completed internet-draft, CT3 has used the WI IMS-CCR-IWCS
- 1523: CP#43 completed
- 1524: CP#42 completed
- 1525: passed WGLC
- 1526: passed WGLC
- 1527: CP#43 completed
- 1528: CP#43 completed
- 1529: CP#43 completed
- 1530: CP#43 completed
- 1531: CP#42 completed
- 1532: Triggered by Study UID_7048 (MRFC)
- 1533: CP#42 completed
- 1534: CP#42 completed
- 1535: CP#56 RFC 6505 completed
- 1536: CP#43 completed. Triggered by Study TR 23.820 (FS_IMS_RP) UID_350018
- 1537: CP#43 completed
- 1538: CP#43 completed
- 1539: CP#43 completed. Triggered by UID_360030 (FS_IMS_ASIO)

| ID | WBS | Task | Type | Duration | Start | Finish | Complete | Baseline start | Baseline finish | Baseline duration | Constraint | Resources | Work | Actual work | Text1 | Text4 | Text5 | Text6 | Text8 | Text2 | Text3 | Text7 | Text11 | Text12 |
| --- | --- | --- | --- | --- | --- | --- | --- | --- | --- | --- | --- | --- | --- | --- | --- | --- | --- | --- | --- | --- | --- | --- | --- | --- |
| 1540 | 505 | **I-WLAN Network Selection Principle (NSP)** |  | 451d? | 2007-06-14 A | 2009-03-06 A | 100% | 2007-06-14 | 2009-03-06 | 451d? |  | S1,C1,C6 | 6643.2h | 6643.2h | IWLANNSP | Telefónica O2 | chris.friel@O2.com | Rel-8 | Alain |  |  |  |  |  |
| 1541 | 505.1 | Stage 1 for I-WLAN NSP | milestone | 0d? | 2007-06-14 A | 2007-06-14 A | 100% | 2007-06-14 | 2007-06-14 | 0d? |  | S1 |  |  | IWLANNSP | Telefónica O2 | chris.friel@O2.com | Rel-8 | Alain | PCG-21 | 22.234 | SP-39 |  |  |
| 1542 | 505.2 | CT1 part of Stage 3 for I-WLAN NSP |  | 261d? | 2008-03-07 A | 2009-03-06 A | 100% | 2008-03-07 | 2009-03-06 | 261d? | finish no earlier than 2008-12-05 | C1 | 2088h | 2088h | IWLANNSP | Research In Motion | Adrian Buckley (abuckley@rim.com) | Rel-8 | Frederic | PCG-21 | 24.234 | CP-39 |  |  |
| 1543 | 505.3 | CT6 part of Stage 3 for I-WLAN NSP |  | 118.4d? | 2008-03-07 A | 2008-12-11 A | 100% | 2008-03-07 | 2008-12-11 | 118.4d? | finish no earlier than 2008-12-11 | C6 | 947.2h | 947.2h | IWLANNSP | Research In Motion | Adrian Buckley (abuckley@rim.com) | Rel-8 | Xavier | PCG-21 | 31.102, 31.111 | CP-39 |  |  |
| 1544 | 506 | **Mobility between 3GPP-WLAN Interworking and 3GPP Systems** |  | 386d? | 2007-09-14 A | 2009-03-06 A | 100% | 2007-09-14 | 2009-03-06 | 386d? |  | S2,C1 | 6216h | 6216h | IWLAN_Mob | Orange | xiaobao.chen@orange-ftgroup.com | Rel-8 | Maurice |  |  | SP-37 |  |  |
| 1545 | 506.1 | Stage 2 for Mobility between 3GPP-WLAN Interworking and 3GPP Systems |  | 190d? | 2007-09-14 A | 2008-06-05 A | 100% | 2007-09-14 | 2008-06-05 | 190d? | finish no earlier than 2008-09-08 | S2 | 1520h | 1520h | IWLAN_Mob | Orange | xiaobao.chen@orange-ftgroup.com | Rel-8 | Maurice | PCG-21 | new 23.327 | SP-38 |  |  |
| 1546 | 506.2 | CT1 aspects of Mobility between 3GPP-WLAN Interworking and 3GPP Systems |  | 201d? | 2008-05-30 A | 2009-03-06 A | 100% | 2008-05-30 | 2009-03-06 | 201d? | finish no earlier than 2009-03-06 | C1 | 1608h | 1608h | IWLAN_Mob | Orange | reina.nader@orange-ftgroup.com | Rel-8 | Frederic | PCG-21 | 24.303, new 24.327 | CP-40 |  |  |
| 1547 | 507 | Conformance Test Aspects – Mobility between 3GPP WLAN Interworking and 3GPP Systems |  | 206d? | 2009-12-04 A | 2010-09-17 A | 100% | 2009-12-04 | 2010-09-17 | 206d? | finish no earlier than 2010-09-17 | R5 | 1648h | 1648h | IWLAN_Mob_UEConTest | Qualcomm | Patrick Stupar (pstupar@qualcomm.com) | Rel-8 | Ingbert | PCG-24 | 34.108, 34.123-1, 34.123-2, 34.123-3 | RP-46 | RP-100740 |  |
| 1548 | 508 | **Enhancements for Voice Group Call Service (VGCS) Applications (EVA)** |  | 919d? | 2006-03-15 A | 2009-09-18 A | 100% | 2006-03-15 | 2009-09-18 | 919d? |  | S1,C1,C4,G2 | 23503.5h | 23503.5h | EVA | Nortel | Amar Deol (deola@nortelnetworks.com) | Rel-8 | Alain |  |  |  |  |  |
| 1549 | 508.1 | SA1 aspects of EVA |  | 191d? | 2006-03-15 A | 2006-12-06 A | 100% | 2006-03-15 | 2006-12-06 | 191d? | finish no earlier than 2006-12-06 | S1 | 1528h | 1528h | EVA | Nortel | Amar Deol (deola@nortelnetworks.com) | Rel-8 | Alain |  | 42.068 |  |  |  |
| 1550 | 508.2 | VGCS/VBS and GPRS Interactions |  | 145d? | 2007-09-03 A | 2008-03-21 A | 100% | 2007-09-03 | 2008-03-21 | 145d? | finish no earlier than 2008-03-21 | S1 | 1160h | 1160h | EVA | Huawei | Ling Liu | Rel-8 | Alain |  | 42.068, 42.069 | SP-37 |  |  |
| 1551 | 508.3 | CT1 aspects of EVA |  | 862d? | 2006-06-02 A | 2009-09-18 A | 100% | 2006-06-02 | 2009-09-18 | 862d? | finish no earlier than 2009-12-04 | C1 | 6887.53h | 6887.53h | EVA | Nortel | milanpa@nortel.com | Rel-8 | Frederic |  | 43.068, 44.068 |  |  |  |
| 1552 | 508.4 | CT4 aspects of EVA |  | 391d? | 2006-06-02 A | 2007-11-30 A | 100% | 2006-06-02 | 2007-11-30 | 391d? | finish no earlier than 2007-06-01 | C4 | 3128h | 3128h | EVA | Nortel |  | Rel-8 | Kimmo |  | 29.002 |  |  |  |
| 1553 | 508.5 | GERAN2 aspects of EVA |  | 431d? | 2006-06-30 A | 2008-02-22 A | 100% | 2006-06-30 | 2008-02-22 | 431d? | finish no earlier than 2008-02-22 | G2 | 3448h | 3448h | EVA | Nortel | frank.billenkamp@nortel.com | Rel-8 | Gert |  | 44.018, 48.008 |  |  |  |
| 1554 | 509 | **Personal Network Management** |  | 955d? | 2005-07-11 A | 2009-03-06 A | 100% | 2005-07-11 | 2009-03-06 | 955d? |  | S1,C1,S3 | 27008h | 27008h | PNM | Vodafone | armin.toepfer@vodafone.com | Rel-8 | Alain |  |  |  |  |  |
| 1555 | 509.1 | Stage 1 for PNM |  | 276d? | 2005-07-11 A | 2006-07-31 A | 100% | 2005-07-11 | 2006-07-31 | 276d? | start no earlier than 2005-07-11 | S1 | 2208h | 2208h | PNM | Vodafone | armin.toepfer@vodafone.com | Rel-8 | Alain |  | 22.259 |  |  |  |
| 1556 | 509.2 | Stage 2 for PNM |  | 445d? | 2007-03-26 A | 2008-12-05 A | 100% | 2007-03-26 | 2008-12-05 | 445d? | finish no earlier than 2008-12-05 | C1 | 3560h | 3560h | PNM | Vodafone | yang.lu@vodafone.com | Rel-8 | Frederic |  | 23.259 |  |  |  |
| 1557 | 509.3 | **Stage 3 for PNM** |  | 510d? | 2007-03-26 A | 2009-03-06 A | 100% | 2007-03-26 | 2009-03-06 | 510d? |  | C1,C4 | 11720h | 11720h | PNM | Vodafone | yang.lu@vodafone.com | Rel-8 | Frederic |  |  |  |  |  |
| 1558 | 509.3.1 | CT1 aspects of Stage 3 PNM |  | 510d? | 2007-03-26 A | 2009-03-06 A | 100% | 2007-03-26 | 2009-03-06 | 510d? | finish no earlier than 2008-12-05 | C1 | 4080h | 4080h | PNM | Vodafone | yang.lu@vodafone.com | Rel-8 | Frederic |  | 24.259, 24.229 |  |  |  |
| 1559 | 509.3.2 | Deleted - CT4 aspects of Stage 3 PNM |  | 445d? | 2007-03-26 A | 2008-12-05 A | 100% | 2007-03-26 | 2008-12-05 | 445d? | finish no earlier than 2008-12-11 | C4 | 3560h | 3560h | PNM | Vodafone | yang.lu@vodafone.com | Rel-8 | Kimmo |  |  |  |  | CP-42 |
| 1560 | 509.4 | Key establishment between a UICC hosting device and a remote device |  | 235d? | 2006-12-06 A | 2007-10-30 A | 100% | 2006-12-06 | 2007-10-30 | 235d? | finish no earlier than 2007-10-30 | S3 | 1880h | 1880h | PNM | Ericsson | Vesa.Lehtovirta@ericsson.com | Rel-8 | Dionisio |  | 33.259 |  |  |  |
| 1561 | 509.5 | Deleted - Actual Requirements of PNM | milestone | 0d? | 2007-03-26 A | 2007-03-26 A | 100% | 2007-03-26 | 2007-03-26 | 0d? | finish no earlier than 2007-03-26 | C1 |  |  | PNM | Ericsson |  | Rel-8 | Frederic |  |  |  |  | SP-37 |
| 1562 | 510 | **eCall Data Transfer** |  | 637d? | 2006-09-28 A | 2009-03-06 A | 100% | 2006-09-28 | 2009-03-06 | 637d? |  | S1,C1 | 9744h | 9744h | EData | Airbiquity | rrobinson@airbiquity.com | Rel-8 | Alain |  |  |  |  |  |
| 1563 | 510.1 | eData Requirements |  | 380d? | 2006-09-28 A | 2008-03-12 A | 100% | 2006-09-28 | 2008-03-12 | 380d? | finish no earlier than 2006-12-07 | S1 | 3040h | 3040h | EData | Airbiquity | rrobinson@airbiquity.com | Rel-8 | Alain |  | 22.101, 22.105 | SP-37 |  |  |
| 1564 | 510.2 | Transfer of data during an emergency call |  | 201d? | 2008-05-30 A | 2009-03-06 A | 100% | 2008-05-30 | 2009-03-06 | 201d? | finish no earlier than 2009-03-06 | C1 | 1608h | 1608h | EData | T-Mobile | Dieter Jacobsohn | Rel-8 | Frederic | PCG-21 | 24.008 | SP-40 |  |  |
| 1565 | 511 | eCall data transfer Phase 2: Comparison of alternative in-band modem solutions and standardization of one in-band modem solution |  | 472d? | 2007-12-06 A | 2009-09-24 A | 100% | 2007-12-06 | 2009-09-24 | 472d? | finish no earlier than 2009-09-24 | S4 | 3768.09h | 3768.09h | eCall_Phase2 | Airbiquity | lhong@airbiquity.com & rrobinson@airbiquity.com | Rel-8 | Paolo |  | 26.267, 26.268, 26.269, 26.967, 26.969 |  |  |  |
| 1566 | 512 | eCall Conformance Testing |  | 261d? | 2009-09-04 A | 2010-09-03 A | 100% | 2009-09-04 | 2010-09-03 | 261d? | finish no earlier than 2010-09-03 | G3new | 2088h | 2088h | eCall_MSTest | Ericsson, Qualcomm | Vikrant Jain (vikrantj@qualcomm.com) | Rel-8 | Ingbert | PCG-23 | 51.010-1, 51.010-2 | GP-45 |  |  |
| 1567 | 513 | Conformance Test Aspects – non-modem procedures of eCall sessions in UTRA |  | 186d? | 2009-09-18 A | 2010-06-04 A | 100% | 2009-09-18 | 2010-06-04 | 186d? | finish no earlier than 2010-06-04 | R5 | 1488h | 1488h | UMTS_eCall_UEConTest | Ericsson, Qualcomm | Shubhang Vora (svora@qualcomm.com) | Rel-8 | Ingbert | PCG-23 | 34.108, 34.123-1, 34.123-2, 34.123-3 | RP-45 | RP-100489 |  |

Notes:
- 1540: CP#43 completed
- 1541: SP#36 completed
- 1542: CP#43 completed
- 1543: CP#42 completed
- 1544: CP#43 completed
- 1545: SP#40 completed
- 1546: CP#43 completed
- 1547: RP#49 completed. Testing for Rel-8 UID_400013 CT1 aspects of mobility between 3GPP WLAN Interworking and 3GPP Systems (24.327)
- 1548: CP#45 completed
- 1549: SP#38 completed
- 1550: SP#39 completed
- 1551: CP#45 completed
- 1552: CP#38 completed
- 1553: GP#37 completed
- 1554: CP#43 completed
- 1555: SP#31 completed
- 1556: CP#42 completed
- 1557: CP#43 completed
- 1558: CP#43 completed
- 1559: CP#42 no impact on CT4 specs
- 1560: SP#37 completed
- 1561: SP#37 stopped
- 1562: SP#39 completed. Linked to SA4 Feature UID_34042 (eCall_Phase2)
- 1563: SP#39 completed
- 1564: CP#43 completed
- 1565: SP#45 completed. Triggered by Study UID_360015 (eCALLIBMS). Linked to SA1 Feature UID_330005 (EData)
- 1566: GP#47 completed. GP#43 WID approved. Testing for Rel-8 eCall_Phase2 (UID_34042) and EData (UID_330005)
- 1567: RP#48 completed. Testing for Rel-8 eCall_Phase2 (UID_34042) and Edata (UID_330005)

| ID | WBS | Task | Type | Duration | Start | Finish | Complete | Baseline start | Baseline finish | Baseline duration | Constraint | Resources | Work | Actual work | Text1 | Text2 | Text4 | Text5 | Text6 | Text7 | Text8 | Text3 | Text12 | Text11 |
| --- | --- | --- | --- | --- | --- | --- | --- | --- | --- | --- | --- | --- | --- | --- | --- | --- | --- | --- | --- | --- | --- | --- | --- | --- |
| 1568 | 514 | **IP Interconnection of Services** |  | 668d? | 2006-08-16 A | 2009-03-06 A | 100% | 2006-08-16 | 2009-03-06 | 668d? |  | S1,S2,S5,C3 | 17520h | 17520h | IPinterc | PCG-21 | Telefónica O2 | chris.friel@O2.com | Rel-8 | SP-38 | Alain |  |  |  |
| 1569 | 514.1 | Stage 1 for IPinterc |  | 70d? | 2007-12-06 A | 2008-03-12 A | 100% | 2007-12-06 | 2008-03-12 | 70d? | start no earlier than 2007-12-06 | S1 | 560h | 560h | IPinterc | PCG-21 | Telefónica O2 | chris.friel@O2.com | Rel-8 | SP-38 | Alain | 22.101, 22.228 |  |  |
| 1570 | 514.2 | **System enhancements for interconnection interfaces between two IMSs** |  | 668d? | 2006-08-16 A | 2009-03-06 A | 100% | 2006-08-16 | 2009-03-06 | 668d? |  | S2,S5,C3 | 11616h | 11616h | IMS_NNI |  | Telecom Italia | Mario Madella (mario.madella@telecomitalia.it) | Rel-8 |  | Maurice |  |  |  |
| 1571 | 514.2.1 | Stage 2 for IMS_NNI |  | 120d? | 2007-06-22 A | 2007-12-06 A | 100% | 2007-06-22 | 2007-12-06 | 120d? | finish no earlier than 2007-12-21 | S2 | 960h | 960h | IMS_NNI |  | Telecom Italia | Mario Madella (mario.madella@telecomitalia.it) | Rel-8 |  | Maurice | 23.002, 23.228 |  |  |
| 1572 | 514.2.2 | IMS inter-operator service interconnection interface |  | 461d? | 2007-06-01 A | 2009-03-06 A | 100% | 2007-06-01 | 2009-03-06 | 461d? | finish no earlier than 2009-03-06 | C3 | 3688h | 3688h | FBI2-IOPSI |  | Telecom Italia | antonio.ascolese@telecomitalia.it | Rel-8 |  | Jiwan | 29.865, 29.165 |  |  |
| 1573 | 514.2.3 | Charging harmonization for NGN between 3GPP and ATIS-TMOC |  | 51d? | 2006-09-28 A | 2006-12-07 A | 100% | 2006-09-28 | 2006-12-07 | 51d? | finish no earlier than 2006-12-07 | S5 | 408h | 408h | FBI2-TISP2-CH |  | Amdocs | yishai.brown@amdocs.com | Rel-8 |  | Dionisio | 32.297 |  |  |
| 1574 | 514.2.4 | Deleted - Protocol impact of FBI for TISPAN R2 |  | 152d? | 2006-08-16 A | 2007-03-15 A | 100% | 2006-08-16 | 2007-03-15 | 152d? | finish no earlier than 2007-03-15 | C1 | 1216h | 1216h | FBI2-TISP2-c1 |  | Ericsson |  | Rel-8 |  | Frederic |  | SP-38 |  |
| 1575 | 514.2.5 | Deleted (never approved) - Stage 2 of FBI for TISPAN R2 - Rel 8 | milestone | 0d? | 2007-11-30 A | 2007-11-30 A | 100% | 2007-11-30 | 2007-11-30 | 0d? | finish no earlier than 2007-11-30 | S2 |  |  | FBI2-TISP2-s2 |  | Nokia Siemens Networks |  | Rel-8 |  | Maurice |  | SP-36 |  |
| 1576 | 515 | **Support of (G)MSC-S – (G)MSC-S Nc Interface based on the SIP-I protocol** |  | 386d? | 2007-09-14 A | 2009-03-06 A | 100% | 2007-09-14 | 2009-03-06 | 386d? |  | C4,C3 | 11872h | 11872h | SIP_Nc |  | Vodafone | David.Hutton@vodafone.com | Rel-8 |  | Kimmo |  |  |  |
| 1577 | 515.1 | Stage 1 for SIP_Nc (covered by Feature IPinterc) |  | 70d? | 2007-12-06 A | 2008-03-12 A | 100% | 2007-12-06 | 2008-03-12 | 70d? | start no earlier than 2007-12-06 | S1 | 560h | 560h | IPinterc | PCG-21 | Telefónica O2 | chris.friel@O2.com | Rel-8 | CP-41 | Alain | 22.101, 22.228 |  |  |
| 1578 | 515.2 | SIP-I based circuit-switched core network; Stage 2 |  | 321d? | 2007-09-14 A | 2008-12-05 A | 100% | 2007-09-14 | 2008-12-05 | 321d? | finish no earlier than 2008-12-11 | C4 | 2568h | 2568h | SIP_Nc-St2 |  | Vodafone | David.Hutton@vodafone.com | Rel-8 |  | Kimmo | 23.231, 23.153, 23.205 |  |  |
| 1579 | 515.3 | Application of SIP-I Protocols to Circuit Switched (CS) core network architecture; Stage 3 |  | 321d? | 2007-09-14 A | 2008-12-05 A | 100% | 2007-09-14 | 2008-12-05 | 321d? | finish no earlier than 2008-12-11 | C4 | 2568h | 2568h | SIP_Nc-St3 |  | Vodafone | David.Hutton@vodafone.com | Rel-8 |  | Kimmo | 29.231, 29.232, 29.332 |  |  |
| 1580 | 515.4 | Interworking between the 3GPP CS domain with SIP-I as signalling protocol and other networks |  | 386d? | 2007-09-14 A | 2009-03-06 A | 100% | 2007-09-14 | 2009-03-06 | 386d? | finish no earlier than 2009-03-06 | C3 | 3088h | 3088h | SIP_Nc |  | Nokia Siemens Networks | Thomas.Belling@nsn.com | Rel-8 |  | Jiwan | 29.235, 23.172, 23.202, 29.007, 29.163, 29.414 |  |  |
| 1581 | 516 | **Earthquake and Tsunami Warning System** |  | 440d? | 2007-09-10 A | 2009-05-15 A | 100% | 2007-09-10 | 2009-05-15 | 440d? |  | S1,S2,C1,C4,G2 | 7200h | 7200h | ETWS |  | NTT DoCoMo | kitaharar@nttdocomo.co.jp | Rel-8 | SP-37 | Alain |  |  |  |
| 1582 | 516.1 | Stage 1 for ETWS |  | 133d? | 2007-09-10 A | 2008-03-12 A | 100% | 2007-09-10 | 2008-03-12 | 133d? | finish no earlier than 2008-03-12 | S1 | 1064h | 1064h | ETWS |  | NTT DoCoMo | kitaharar@nttdocomo.co.jp | Rel-8 | SP-37 | Alain | 22.168 |  |  |
| 1583 | 516.2 | SA2 aspects of ETWS |  | 179d? | 2008-01-14 A | 2008-09-18 A | 100% | 2008-01-14 | 2008-09-18 | 179d? | finish no earlier than 2008-09-08 | S2 | 1432h | 1432h | ETWS | PCG-21 | NTT DoCoMo | tanakai@nttdocomo.co.jp | Rel-8 | SP-38 | Maurice | 23.828, 23.401 |  |  |
| 1584 | 516.3 | CT1 aspects of ETWS |  | 50.5d? | 2008-05-30 A | 2008-12-05 A | 100% | 2008-05-30 | 2008-12-05 | 50.5d? | finish no earlier than 2008-12-05 | C1 | 404h | 404h | ETWS | PCG-21 | NTT DoCoMo | yamashitahi@s1.nttdocomo.co.jp | Rel-8 | CP-40 | Frederic | 23.041 |  |  |
| 1585 | 516.4 | CT4 aspects of ETWS |  | 50.5d? | 2008-09-26 A | 2008-12-05 A | 100% | 2008-09-26 | 2008-12-05 | 50.5d? | finish no earlier than 2008-12-05 | C4 | 404h | 404h | ETWS | PCG-21 | NTT DoCoMo | yamashitahi@s1.nttdocomo.co.jp | Rel-8 | CP-40 | Kimmo | 29.168 |  |  |
| 1586 | 516.5 | ETWS primary notification message definition in GERAN |  | 47d? | 2009-03-12 A | 2009-05-15 A | 100% | 2009-03-12 | 2009-05-15 | 47d? | finish no earlier than 2009-05-15 | G2 | 376h | 376h | ETWS | PCG-22 | Ericsson | claes-goran.persson@ericsson.com | Rel-8 | SP-43 | Gert | 44.018, 44.060 |  |  |
| 1587 | 517 | Conformance Test Aspects – UMTS Earthquake and Tsunami Warning System (ETWS) FDD |  | 207d? | 2009-05-29 A | 2010-03-12 A | 100% | 2009-05-29 | 2010-03-12 | 207d? | finish no earlier than 2010-03-12 | R5 | 1656h | 1656h | ETWS_UMTS_UEConTestFDD | PCG-23 | NTT DoCoMo | Makoto Ito (itohm@nttdocomo.co.jp) | Rel-8 | RP-44 | Ingbert | 34.108, 34.123-1, 34.123-2 |  | RP-100068 |
| 1588 | 518 | **In Case of Emergency numbers storage and easy access on UICC** |  | 519d? | 2007-03-13 A | 2009-03-06 A | 100% | 2007-03-13 | 2009-03-06 | 519d? |  | S1,C6 | 8864h | 8864h | ICE | PCG-21 | Vodafone | armin.toepfer@vodafone.com | Rel-8 | SP-38 | Alain |  |  |  |
| 1589 | 518.1 | Stage 1 for ICE |  | 262d? | 2007-03-13 A | 2008-03-12 A | 100% | 2007-03-13 | 2008-03-12 | 262d? | finish no earlier than 2008-03-12 | S1 | 2096h | 2096h | ICE | PCG-21 | Vodafone | armin.toepfer@vodafone.com | Rel-8 | SP-38 | Alain | 22.030, 22.101 |  |  |
| 1590 | 518.2 | CT6 aspects of ICE |  | 519d? | 2007-03-13 A | 2009-03-06 A | 100% | 2007-03-13 | 2009-03-06 | 519d? | finish no earlier than 2009-03-06 | C6 | 4152h | 4152h | ICE | PCG-21 | Vodafone | armin.toepfer@vodafone.com | Rel-8 | SP-38 | Xavier | 31.102 |  |  |
| 1591 | 519 | Local Charging Zone Requirements |  | 380d? | 2006-09-28 A | 2008-03-12 A | 100% | 2006-09-28 | 2008-03-12 | 380d? | finish no earlier than 2006-12-07 | S1 | 3040h | 3040h | LCZR |  | China Mobile | liuhongyfw@chinamobile.com | Rel-8 |  | Alain | 22.115 |  |  |

Notes:
- 1568: SP#43 completed
- 1569: SP#39 completed.
- 1570: CP#43 completed
- 1571: SP#38 completed
- 1572: CP#43 completed
- 1573: SP#34 completed
- 1574: SP#38 stopped
- 1575: SP#36 stopped
- 1576: CP#43 completed. Stage 1 in Feature UID_380060 (IPinterc). CP#40 updated WID CP-070517=>CP-080282
- 1577: 22/07/08 Created. Stage 1 for SIP_Nc (covered by SA1 Feature UID_380060 Ipinterc)
- 1578: CP#42 completed
- 1579: CP#42 completed
- 1580: CP#43 completed. CP#42 target 12/08=>03/09
- 1581: SP#43 Larger scope Feature UID_380057 (PWS) moved to Rel-9
- 1582: SP#39 completed
- 1583: SP#41 completed
- 1584: CP#42 completed
- 1585: CP#42 completed
- 1586: SP#44 completed with CT1 help (GERAN2 LS_in SP-090154)
- 1587: RP#47 completed. Testing for Rel-8 ETWS UID_370051
- 1588: CP#43 completed (ICE Graphics not included in Rel-8)
- 1589: SP#39 Stage 1 completed
- 1590: CP#43 completed (ICE Graphics not in Rel-8 / not explicitly in SA1 WID either)
- 1591: SP#39 Stage 1 completed

| ID | WBS | Task | Type | Duration | Start | Finish | Complete | Baseline start | Baseline finish | Baseline duration | Constraint | Resources | Work | Actual work | Text1 | Text4 | Text5 | Text6 | Text8 | Text3 | Text7 | Text2 | Text9 | Text12 |
| --- | --- | --- | --- | --- | --- | --- | --- | --- | --- | --- | --- | --- | --- | --- | --- | --- | --- | --- | --- | --- | --- | --- | --- | --- |
| 1592 | 520 | **Customized Alerting Tone (CAT) service** |  | 729d? | 2006-12-06 A | 2009-09-18 A | 100% | 2006-12-06 | 2009-09-18 | 729d? |  | S1,C1,C3,C4 | 13310h | 13310h | CAT | China Mobile | fenglingjuan@chinamobile.com | Rel-8 | Alain |  |  |  |  |  |
| 1593 | 520.1 | Stage 1 for CAT |  | 207d? | 2006-12-06 A | 2007-09-20 A | 100% | 2006-12-06 | 2007-09-20 | 207d? | start no earlier than 2006-12-06 | S1 | 1656h | 1656h | CAT | China Mobile | fenglingjuan@chinamobile.com | Rel-8 | Alain | 22.182 | SP-37 |  |  |  |
| 1594 | 520.2 | TISPAN requirements for customized multimedia information services |  | 71d? | 2007-09-03 A | 2007-12-10 A | 100% | 2007-09-03 | 2007-12-10 | 71d? | finish no earlier than 2007-12-10 | S1 | 568h | 568h | TISCMI | China Mobile | fenglingjuan@chinamobile.com | Rel-8 | Alain | 22.182 | SP-37 |  |  |  |
| 1595 | 520.3 | IMS CAT Supplementary Service |  | 164d? | 2008-04-21 A | 2008-12-04 A | 100% | 2008-04-21 | 2008-12-04 | 164d? | finish no earlier than 2008-12-05 | C1 | 1312h | 1312h | CAT-SS | Nortel | milanpa@nortel.com | Rel-8 | Frederic | 24.182 | CP-39 | PCG-21 |  |  |
| 1596 | 520.4 | CAT solution for voice and video call in CS domain |  | 389.8d? | 2008-03-12 A | 2009-09-18 A | 100% | 2008-03-12 | 2009-09-18 | 389.8d? | finish no earlier than 2009-09-11 | C3 | 3118.4h | 3118.4h | CAT-SS | Nortel | milanpa@nortel.com | Rel-8 | Jiwan | 29.163 | CP-39 | PCG-21 |  |  |
| 1597 | 520.5 | **CAT Service in 3GPP CS domain** |  | 126d? | 2008-09-12 A | 2009-03-06 A | 100% | 2008-09-12 | 2009-03-06 | 126d? |  | C4,C1 | 2479.6h | 2479.6h | CAT-3G_CS | China Mobile | zhaoyuyi@chinamobile.com | Rel-8 | Kimmo | 23.205, 23.231, 29.002 | CP-41 | PCG-21 |  |  |
| 1598 | 520.5.1 | CT4 part of CAT Service in 3GPP CS domain |  | 126d? | 2008-09-12 A | 2009-03-06 A | 100% | 2008-09-12 | 2009-03-06 | 126d? | finish no earlier than 2009-03-06 | C4 | 1008h | 1008h | CAT-3G_CS | China Mobile | zhaoyuyi@chinamobile.com | Rel-8 | Kimmo | 23.205, 23.231, 29.002 | CP-41 | PCG-21 |  |  |
| 1599 | 520.5.2 | CT1 part of CAT Service in 3GPP CS domain |  | 57.95d? | 2008-09-12 A | 2008-12-05 A | 100% | 2008-09-12 | 2008-12-05 | 57.95d? | start no earlier than 2008-09-12 | C1 | 463.6h | 463.6h | CAT-3G_CS | China Mobile | zhaoyuyi@chinamobile.com | Rel-8 | Frederic | 24.008, 23.014 | CP-41 | PCG-21 |  |  |
| 1600 | 521 | **Service-Level Interworking for Messaging Services** |  | 509d? | 2007-03-26 A | 2009-03-06 A | 100% | 2007-03-26 | 2009-03-06 | 509d? |  | S1,S2,C3,C1 | 8584h | 8584h | MESSIW | Huawei | ling.liu@huawei.com; duanxiaoqin@huawei.com | Rel-8 | Alain |  |  |  |  |  |
| 1601 | 521.1 | Stage 1 for MESSIW | milestone | 0d? | 2007-03-26 A | 2007-03-26 A | 100% | 2007-03-26 | 2007-03-26 | 0d? | finish no earlier than 2007-12-01 | S1 |  |  | MESSIW | Huawei | ling.liu@huawei.com | Rel-8 | Alain | 22.105, 22.340 |  |  |  |  |
| 1602 | 521.2 | Stage 2 for MESSIW |  | 227d? | 2007-04-26 A | 2008-03-07 A | 100% | 2007-04-26 | 2008-03-07 | 227d? | finish no earlier than 2008-03-07 | S2 | 1816h | 1816h | MESSIW | Huawei | patrice.hede@huawei.com | Rel-8 | Maurice | 23.811, 23.204 |  |  |  |  |
| 1603 | 521.3 | CT3 part of Stage 3 for MESSIW |  | 201d? | 2008-05-30 A | 2009-03-06 A | 100% | 2008-05-30 | 2009-03-06 | 201d? | finish no earlier than 2008-12-05 | C3 | 1608h | 1608h | MESSIW | Huawei | xupeili@huawei.com | Rel-8 | Jiwan | 29.311 | CP-40 | PCG-21 |  |  |
| 1604 | 521.4 | CT1 part of Stage 3 for MESSIW |  | 136d? | 2008-05-30 A | 2008-12-05 A | 100% | 2008-05-30 | 2008-12-05 | 136d? | finish no earlier than 2008-12-12 | C1 | 1088h | 1088h | MESSIW | Huawei | xupeili@huawei.com | Rel-8 | Frederic | 24.229 | CP-40 | PCG-21 |  |  |
| 1605 | 522 | **Multimedia Priority Service** |  | 858d? | 2006-06-08 A | 2009-09-18 A | 100% | 2006-06-08 | 2009-09-18 | 858d? |  | S1,C1,C3,C4 | 22424h | 22424h | PRIOR | Telcordia | jgarraha@telcordia.com | Rel-8 | Alain |  | SP-34 |  |  |  |
| 1606 | 522.1 | Service Requirements for PRIOR |  | 391d? | 2006-06-08 A | 2007-12-06 A | 100% | 2006-06-08 | 2007-12-06 | 391d? | finish no earlier than 2007-11-30 | S1 | 3128h | 3128h | PRIOR-EMR | Telcordia | jgarraha@telcordia.com | Rel-8 | Alain | 22.153 | SP-32 |  |  |  |
| 1607 | 522.2 | CT1 part of Stage 3 for PRIOR |  | 732d? | 2006-12-01 A | 2009-09-18 A | 100% | 2006-12-01 | 2009-09-18 | 732d? | finish no earlier than 2009-09-18 | C1 | 5856h | 5856h | PRIOR | Alcatel-Lucent | Keith Drage (drage@alcatel-lucent.com) | Rel-8 | Frederic | 24.229 | CP-34 |  |  |  |
| 1608 | 522.3 | CT4 part of Stage 3 for PRIOR |  | 381d? | 2007-09-21 A | 2009-03-06 A | 100% | 2007-09-21 | 2009-03-06 | 381d? | finish no earlier than 2009-03-06 | C4 | 3048h | 3048h | PRIOR | Alcatel-Lucent | Keith Drage (drage@alcatel-lucent.com) | Rel-8 | Kimmo | 23.008, 29.228, 29.229 | CP-37 |  |  |  |
| 1609 | 522.4 | Deleted - Stage 3 for PRIOR |  | 441d? | 2007-09-21 A | 2009-05-29 A | 100% | 2007-09-21 | 2009-05-29 | 441d? | finish no earlier than 2009-05-29 | C3 | 3528h | 3528h | PRIOR | Alcatel-Lucent | Keith Drage (drage@alcatel-lucent.com) | Rel-8 | Jiwan | 29.212, 29.213, 29.214, 29.163 | CP-37 |  | PCG-23 | CP-44 |
| 1610 | 523 | **Open Service Access (OSA) Rel-8** |  | 202d? | 2007-08-23 A | 2008-05-30 A | 100% | 2007-08-23 | 2008-05-30 | 202d? |  | S1,C5 | 23552h | 23552h | OSA8 | Orange | Song Dong | Rel-8 | Alain |  |  |  |  |  |
| 1611 | 523.1 | OSA Stage 1 - Service Requirements |  | 145d? | 2007-08-23 A | 2008-03-12 A | 100% | 2007-08-23 | 2008-03-12 | 145d? | finish no earlier than 2007-12-04 | S1 | 1160h | 1160h | OSA8 | Orange, AePONA | Song Dong | Rel-8 | Alain | 22.127 |  |  |  |  |
| 1612 | 523.2 | OSA Stage 1 - NGN Service Requirement |  | 140d? | 2007-09-03 A | 2008-03-14 A | 100% | 2007-09-03 | 2008-03-14 | 140d? | finish no earlier than 2008-03-14 | S1 | 1120h | 1120h | OSA8-IMS | Orange | Song Dong | Rel-8 | Alain | 22.127 | SP-37 |  |  |  |
| 1613 | 523.3 | **Rel-8 OSA Stage 2/3 enhancements** |  | 157d? | 2007-10-25 A | 2008-05-30 A | 100% | 2007-10-25 | 2008-05-30 | 157d? |  | C5 | 20016h | 20016h | OSA8 | Alcatel-Lucent | unmehopa@alcatel-lucent.com | Rel-8 | Kimmo | 23.198, 29.198, 29.199 |  |  |  |  |
| 1614 | 523.3.1 | Deleted - Ensure Parlay-X composable with identity management frameworks, in particular Liberty Alliance |  | 157d? | 2007-10-25 A | 2008-05-30 A | 100% | 2007-10-25 | 2008-05-30 | 157d? | finish no earlier than 2008-12-25 | C5 | 1256h | 1256h | OSA8 | Ericsson | catherine.mulligan@ericsson.com | Rel-8 | Kimmo | existing 29.199-xy | CP-37 | PCG-21 | PCG-21 | CP-40 |
| 1615 | 523.3.2 | Parlay-X Content Management web service (store/manage meta-data) |  | 157d? | 2007-10-25 A | 2008-05-30 A | 100% | 2007-10-25 | 2008-05-30 | 157d? | finish no earlier than 2008-12-04 | C5 | 1256h | 1256h | OSA8 | Alcatel-Lucent | unmehopa@alcatel-lucent.com | Rel-8 | Kimmo | 29.199-21 | CP-37 |  |  |  |
| 1616 | 523.3.3 | Parlay-X Policy web service |  | 157d? | 2007-10-25 A | 2008-05-30 A | 100% | 2007-10-25 | 2008-05-30 | 157d? | finish no earlier than 2008-12-04 | C5 | 1256h | 1256h | OSA8 | Alcatel-Lucent | unmehopa@alcatel-lucent.com | Rel-8 | Kimmo | 29.199-22 | CP-37 |  |  |  |
| 1617 | 523.3.4 | Parlay-X Terminal status web service |  | 157d? | 2007-10-25 A | 2008-05-30 A | 100% | 2007-10-25 | 2008-05-30 | 157d? | finish no earlier than 2008-05-30 | C5 | 1256h | 1256h | OSA8 | Alcatel-Lucent | unmehopa@alcatel-lucent.com | Rel-8 | Kimmo | 29.199-08 | CP-37 |  |  |  |
| 1618 | 523.3.5 | Deleted - Identify communication format used by a particular application |  | 157d? | 2007-10-25 A | 2008-05-30 A | 100% | 2007-10-25 | 2008-05-30 | 157d? | finish no earlier than 2008-05-30 | C5 | 1256h | 1256h | OSA8 | Ericsson | catherine.mulligan@ericsson.com | Rel-8 | Kimmo | existing 29.199-xy | CP-37 | PCG-21 | PCG-21 | CP-40 |
| 1619 | 523.3.6 | Deleted - Security on User Profile Management - reuse GUP API (22.127 CR 0084 S1-071794) |  | 128d? | 2007-12-05 A | 2008-05-30 A | 100% | 2007-12-05 | 2008-05-30 | 128d? | finish no earlier than 2008-12-25 | C5 | 1024h | 1024h | OSA8 | Telecom Italia | vincenzo.amorino@telecomitalia.it | Rel-8 | Kimmo | PXWS Framework | CP-38 | PCG-21 | PCG-21 | CP-40 |
| 1620 | 523.3.7 | Deleted - Privacy on Subscriber Identity (Liberty Alliance, OASIS) (22.127 CR 0085 S1-071835) |  | 128d? | 2007-12-05 A | 2008-05-30 A | 100% | 2007-12-05 | 2008-05-30 | 128d? | finish no earlier than 2008-12-25 | C5 | 1024h | 1024h | OSA8 | Telecom Italia | vincenzo.amorino@telecomitalia.it | Rel-8 | Kimmo | PXWS Framework | CP-38 | PCG-21 | PCG-21 | CP-40 |
| 1621 | 523.3.8 | Deleted - Topology Hiding (22.127 CR 0086 S1-071838) |  | 128d? | 2007-12-05 A | 2008-05-30 A | 100% | 2007-12-05 | 2008-05-30 | 128d? | finish no earlier than 2008-12-25 | C5 | 1024h | 1024h | OSA8 | Telecom Italia | vincenzo.amorino@telecomitalia.it | Rel-8 | Kimmo | PXWS Framework | CP-38 | PCG-21 | PCG-21 | CP-40 |
| 1622 | 523.3.9 | Deleted - Subscriber event notification (22.127 CR 0087 S1-071836) |  | 128d? | 2007-12-05 A | 2008-05-30 A | 100% | 2007-12-05 | 2008-05-30 | 128d? | finish no earlier than 2008-12-25 | C5 | 1024h | 1024h | OSA8 | Telecom Italia | vincenzo.amorino@telecomitalia.it | Rel-8 | Kimmo | PXWS Framework | CP-38 | PCG-21 | PCG-21 | CP-40 |
| 1623 | 523.3.10 | Deleted - Event notification (22.127 CR 0088 S1-071762) |  | 128d? | 2007-12-05 A | 2008-05-30 A | 100% | 2007-12-05 | 2008-05-30 | 128d? | finish no earlier than 2008-12-25 | C5 | 1024h | 1024h | OSA8 | Telecom Italia | vincenzo.amorino@telecomitalia.it | Rel-8 | Kimmo | PXWS Framework | CP-38 | PCG-21 | PCG-21 | CP-40 |
| 1624 | 523.3.11 | Deleted - Access policy (22.127 CR 0089 S1-071763) |  | 128d? | 2007-12-05 A | 2008-05-30 A | 100% | 2007-12-05 | 2008-05-30 | 128d? | finish no earlier than 2008-12-25 | C5 | 1024h | 1024h | OSA8 | Telecom Italia | vincenzo.amorino@telecomitalia.it | Rel-8 | Kimmo | PXWS Framework | CP-38 | PCG-21 | PCG-21 | CP-40 |
| 1625 | 523.3.12 | Deleted - API usage accounting (22.127 CR 0090 S1-071792) |  | 128d? | 2007-12-05 A | 2008-05-30 A | 100% | 2007-12-05 | 2008-05-30 | 128d? | finish no earlier than 2008-12-25 | C5 | 1024h | 1024h | OSA8 | Telecom Italia | vincenzo.amorino@telecomitalia.it | Rel-8 | Kimmo | PXWS Framework | CP-38 | PCG-21 | PCG-21 | CP-40 |
| 1626 | 523.3.13 | Presence alignment with OMA and IETF (22.127 CR 0092 S1-071764) |  | 128d? | 2007-12-05 A | 2008-05-30 A | 100% | 2007-12-05 | 2008-05-30 | 128d? | finish no earlier than 2008-05-30 | C5 | 1024h | 1024h | OSA8 | Alcatel-Lucent | unmehopa@alcatel-lucent.com | Rel-8 | Kimmo | 29.199-14/13 | CP-38 | PCG-21 |  |  |
| 1627 | 523.3.14 | Deleted - Service identification (22.127 CR 0095 S1-071837) |  | 128d? | 2007-12-05 A | 2008-05-30 A | 100% | 2007-12-05 | 2008-05-30 | 128d? | finish no earlier than 2008-05-30 | C5 | 1024h | 1024h | OSA8 | Ericsson | catherine.mulligan@ericsson.com | Rel-8 | Kimmo | existing 29.199-xy | CP-38 | PCG-21 | PCG-21 | CP-40 |
| 1628 | 523.3.15 | Framework Enterprise Operator (Service Subscription function) |  | 102d? | 2008-01-10 A | 2008-05-30 A | 100% | 2008-01-10 | 2008-05-30 | 102d? | finish no earlier than 2008-05-30 | C5 | 816h | 816h | OSA8 | Alcatel-Lucent | unmehopa@alcatel-lucent.com | Rel-8 | Kimmo | 29.198-03 | CP-39 | PCG-21 |  |  |
| 1629 | 523.3.16 | Mobility Emergency Location |  | 102d? | 2008-01-10 A | 2008-05-30 A | 100% | 2008-01-10 | 2008-05-30 | 102d? | finish no earlier than 2008-05-30 | C5 | 816h | 816h | OSA8 | Alcatel-Lucent | unmehopa@alcatel-lucent.com | Rel-8 | Kimmo | 29.198-06 | CP-39 | PCG-21 |  |  |
| 1630 | 523.3.17 | Connectivity Manager SCF |  | 102d? | 2008-01-10 A | 2008-05-30 A | 100% | 2008-01-10 | 2008-05-30 | 102d? |  | C5 | 816h | 816h | OSA8 | Alcatel-Lucent | unmehopa@alcatel-lucent.com | Rel-8 | Kimmo | 29.198-10 | CP-39 | PCG-21 |  |  |
| 1631 | 523.3.18 | PAM Presence Agent |  | 102d? | 2008-01-10 A | 2008-05-30 A | 100% | 2008-01-10 | 2008-05-30 | 102d? | finish no earlier than 2008-05-30 | C5 | 816h | 816h | OSA8 | Alcatel-Lucent | unmehopa@alcatel-lucent.com | Rel-8 | Kimmo | 29.198-14 | CP-39 | PCG-21 |  |  |

Notes:
- 1592: CP#45 completed
- 1593: -
- 1594: SP#38 completed
- 1595: CP#42 completed
- 1596: CP#45 completed. Triggered by Study UID_360031 (TR 29.882)
- 1597: -
- 1598: CP#43 completed. Triggered by Study UID_360031 (TR 29.882)
- 1599: CP#42 completed. Triggered by Study UID_360031 (TR 29.882)
- 1600: CP#43 completed
- 1601: SP#35 completed
- 1602: SP#39 completed
- 1603: CP#43 completed
- 1604: CP#42 completed
- 1605: CP#45 completed
- 1606: SP#38 completed
- 1607: CP#45 completed
- 1608: CP#43 completed
- 1609: CP#44 stopped (Reason: No Rel-8 solution expected (LS sent to SA2, but not prioritized in SA2)
- 1610: SP#40 maintenance & new OSA work moved to OMA. Rel-9 onwards 3GPP references to 22.127 changed to OMA Parlay Service Access Requirements (OMA-RD-Parlay_Service_Access-V1_0-20100427-A).
- 1611: SP#40 maintenance & new OSA work moved to OMA. Rel-9 onwards 3GPP references to 22.127 changed to OMA Parlay Service Access Requirements (OMA-RD-Parlay_Service_Access-V1_0-20100427-A).
- 1612: SP#40 maintenance & new OSA work moved to OMA
- 1613: SP#40 maintenance & new OSA work moved to OMA
- 1614: CP#40: Work moved to OMA
- 1615: CP#40 completed
- 1616: CP#40 completed
- 1617: CP#40 completed
- 1618: CP#40: Work moved to OMA
- 1619: SP#38 SP-070853 R8 CRs 22.127 OSA Stage 1. CP#40: Work moved to OMA
- 1620: SP#38 SP-070853 R8 CRs 22.127 OSA Stage 1. CP#40: Work moved to OMA
- 1621: SP#38 SP-070853 R8 CRs 22.127 OSA Stage 1. CP#40: Work moved to OMA
- 1622: SP#38 SP-070853 R8 CRs 22.127 OSA Stage 1. CP#40: Work moved to OMA
- 1623: SP#38 SP-070853 R8 CRs 22.127 OSA Stage 1. CP#40: Work moved to OMA
- 1624: SP#38 SP-070853 R8 CRs 22.127 OSA Stage 1. CP#40: Work moved to OMA
- 1625: SP#38 SP-070853 R8 CRs 22.127 OSA Stage 1. CP#40: Work moved to OMA
- 1626: CP#40 completed
- 1627: SP#38 SP-070853 R8 CRs 22.127 OSA Stage 1. CP#40: Work moved to OMA
- 1628: CP#40 completed
- 1629: CP#40 completed
- 1630: CP#40 completed
- 1631: CP#40 completed

| ID | WBS | Task | Duration | Start | Finish | Complete | Baseline start | Baseline finish | Baseline duration | Constraint | Resources | Work | Actual work | Text1 | Text4 | Text6 | Text8 | Text7 | Text2 | Text11 |
| --- | --- | --- | --- | --- | --- | --- | --- | --- | --- | --- | --- | --- | --- | --- | --- | --- | --- | --- | --- | --- |
| 1632 | 524 | **Paging Permission with Access Control (PPACR)** | 389d? | 2007-06-12 A | 2008-12-05 A | 100% | 2007-06-12 | 2008-12-05 | 389d? |  | S1,C1 | 5888h | 5888h | PPACR | NTT DoCoMo | Rel-8 | Alain |  |  |  |
| 1633 | 524.1 | Stage 1 for PPACR | 69d? | 2007-06-12 A | 2007-09-14 A | 100% | 2007-06-12 | 2007-09-14 | 69d? | finish no earlier than 2007-09-14 | S1 | 552h | 552h | PPACR-S1 | NTT DoCoMo | Rel-8 | Alain | SP-37 |  |  |
| 1634 | 524.2 | Stage 3 for PPACR (CT1) | 278d? | 2007-11-14 A | 2008-12-05 A | 100% | 2007-11-14 | 2008-12-05 | 278d? | finish no earlier than 2008-12-05 | C1 | 2224h | 2224h | PPACR-CT1 | NTT DoCoMo | Rel-8 | Frederic | CP-38 | PCG-21 |  |
| 1635 | 525 | Conformance Test Aspects – Paging Permission with Access Control (PPAC) | 61d? | 2010-09-17 A | 2010-12-10 A | 100% | 2010-09-17 | 2010-12-10 | 61d? | finish no earlier than 2010-12-10 | R5 | 488h | 488h | PPAC_UEConTest | NTT DoCoMo | Rel-8 | Ingbert | RP-49 | PCG-25 | RP-101074 |
| 1636 | 526 | **Charging for multi-phases services** | 70d? | 2007-12-06 A | 2008-03-12 A | 100% | 2007-12-06 | 2008-03-12 | 70d? |  | S1 | 560h | 560h | CHRGMPH | Telecom Italia | Rel-8 | Alain | SP-38 | PCG-21 |  |
| 1637 | 526.1 | Stage 1 for CHRGMPH | 70d? | 2007-12-06 A | 2008-03-12 A | 100% | 2007-12-06 | 2008-03-12 | 70d? | start no earlier than 2007-12-06 | S1 | 560h | 560h | CHRGMPH-s1 | Telecom Italia | Rel-8 | Alain | SP-38 | PCG-21 |  |
| 1638 | 527 | **Home NodeB / eNodeB** | 327d? | 2007-12-06 A | 2009-03-06 A | 100% | 2007-12-06 | 2009-03-06 | 327d? |  | S1,C1,C4 | 5720h | 5720h | HomeNB | Vodafone | Rel-8 | Alain | SP-38 | PCG-21 |  |
| 1639 | 527.1 | Stage 1 for Home NodeB / eNodeB | 70d? | 2007-12-06 A | 2008-03-12 A | 100% | 2007-12-06 | 2008-03-12 | 70d? | start no earlier than 2007-12-06 | S1 | 560h | 560h | HomeNB-S1 | Vodafone | Rel-8 | Alain | SP-38 | PCG-21 |  |
| 1640 | 527.2 | Support of Closed Subscriber Group (CSG) | 66d? | 2008-12-05 A | 2009-03-06 A | 100% | 2008-12-05 | 2009-03-06 | 66d? | finish no earlier than 2009-03-06 | C4 | 528h | 528h | HomeNB | CT#42 | Rel-8 | Kimmo | CP-42 | PCG-22 |  |
| 1641 | 527.3 | CSG and Idle Mode Mobility for LTE Home eNodeB | 126d? | 2008-09-12 A | 2009-03-06 A | 100% | 2008-09-12 | 2009-03-06 | 126d? | finish no earlier than 2009-03-06 | C1 | 1008h | 1008h | HomeNB-LTE | Huawei | Rel-8 | Frederic | CP-41 | PCG-21 |  |
| 1642 | 527.4 | CSG and Idle Mode Mobility for 3G Home NodeB | 126d? | 2008-09-12 A | 2009-03-06 A | 100% | 2008-09-12 | 2009-03-06 | 126d? | finish no earlier than 2009-03-06 | C1 | 1008h | 1008h | HomeNB-3G | Qualcomm | Rel-8 | Frederic | CP-41 | PCG-21 |  |
| 1643 | 528 | **UTRA HNB** | 326d? | 2008-03-07 A | 2009-06-04 A | 100% | 2008-03-07 | 2009-06-04 | 326d? |  | RP,S5 | 6832h | 6832h | HNB |  | Rel-8 | Issam | SP-39 | PCG-21 |  |
| 1644 | 528.1 | Support of UTRA HNB | 201d? | 2008-05-30 A | 2009-03-06 A | 100% | 2008-05-30 | 2009-03-06 | 201d? | finish no earlier than 2009-03-06 | R2 | 1608h | 1608h | HNB-supp | Huawei | Rel-8 | Joern | SP-40 | PCG-21 | RP-090040 |
| 1645 | 528.2 | UTRAN Architecture for 3G HNB | 136d? | 2008-05-30 A | 2008-12-05 A | 100% | 2008-05-30 | 2008-12-05 | 136d? | finish no earlier than 2008-12-05 | R3 | 1088h | 1088h | HNB-arch | Alcatel-Lucent | Rel-8 | Juha | SP-40 | PCG-21 | RP-090042 |
| 1646 | 528.3 | FDD Home NodeB RF requirements | 261d? | 2008-03-07 A | 2009-03-06 A | 100% | 2008-03-07 | 2009-03-06 | 261d? | finish no earlier than 2009-03-06 | R4 | 2088h | 2088h | HNB-RF | Motorola | Rel-8 | Issam | SP-39 | PCG-21 | RP-090041 |
| 1647 | 528.4 | 3G Home NodeB OAM&P Type 1 Management Interface | 127d? | 2008-12-11 A | 2009-06-04 A | 100% | 2008-12-11 | 2009-06-04 | 127d? | finish no earlier than 2009-06-04 | S5 | 1008h | 1008h | HNB-3G_OAM | Huawei | Rel-8 | Dionisio | SP-42 | PCG-22 |  |
| 1648 | 529 | **UTRA HNB – UE Conformance Testing** | 327d? | 2009-03-06 A | 2010-06-04 A | 100% | 2009-03-06 | 2010-06-04 | 327d? |  | R5 | 5224h | 5224h | HNB-UEConTest |  | Rel-8 | Ingbert | RP-43 | PCG-22 |  |
| 1649 | 529.1 | Conformance Test Aspects – UTRA HNB (FDD) | 326d? | 2009-03-06 A | 2010-06-04 A | 100% | 2009-03-06 | 2010-06-04 | 326d? | finish no earlier than 2010-06-04 | R5 | 2608h | 2608h | HNB-UEConTestFDD | Huawei | Rel-8 | Ingbert | RP-43 | PCG-22 | RP-100482 |
| 1650 | 530 | Lawful Interception in the 3GPP Rel-8 | 524d? | 2007-03-12 A | 2009-03-12 A | 100% | 2007-03-12 | 2009-03-12 | 524d? | finish no earlier than 2009-03-12 | S3 | 4192h | 4192h | LI8 | BMWI, Verizon | Rel-8 | Dionisio |  |  |  |
| 1651 | 531 | **Generic Bootstrapping Architecture Push Function** | 258d? | 2008-03-12 A | 2009-03-06 A | 100% | 2008-03-12 | 2009-03-06 | 258d? |  | S3,C1,C4 | 6468.8h | 6468.8h | GBAPush | Ericsson | Rel-8 | Dionisio | SP-39 | PCG-21 |  |
| 1652 | 531.1 | SA3 part of GBAPush (33.223) | 193d? | 2008-03-12 A | 2008-12-05 A | 100% | 2008-03-12 | 2008-12-05 | 193d? | finish no earlier than 2008-12-05 | S3 | 1544h | 1544h | GBAPush | Ericsson | Rel-8 | Dionisio | SP-39 | PCG-21 |  |
| 1653 | 531.2 | CT1 part of GBAPush | 178.8d? | 2008-03-12 A | 2009-03-06 A | 100% | 2008-03-12 | 2009-03-06 | 178.8d? | finish no earlier than 2009-03-06 | C1 | 1430.4h | 1430.4h | GBAPush | Ericsson | Rel-8 | Frederic | SP-39 | PCG-21 |  |
| 1654 | 531.3 | CT4 part of GBAPush | 178.8d? | 2008-03-12 A | 2009-03-06 A | 100% | 2008-03-12 | 2009-03-06 | 178.8d? | finish no earlier than 2009-03-06 | C4 | 1430.4h | 1430.4h | GBAPush | Ericsson | Rel-8 | Kimmo | SP-39 | PCG-21 |  |
| 1655 | 532 | Requirements and Test methods for Wideband Terminals | 197d? | 2008-03-12 A | 2008-12-11 A | 100% | 2008-03-12 | 2008-12-11 | 197d? | start no earlier than 2008-03-12 | S4 | 1576h | 1576h | RETEM_WB_T | FT, Ericsson | Rel-8 | Paolo |  |  |  |
| 1656 | 533 | Extending PSS and MBMS User Services for optimized Mobile TV | 266d? | 2007-12-06 A | 2008-12-11 A | 100% | 2007-12-06 | 2008-12-11 | 266d? | finish no earlier than 2008-12-11 | S4 | 2128h | 2128h | PSS_MBMS_OMTV | Ericsson | Rel-8 | Paolo |  |  |  |

Notes:
- 1632: CP#42 completed. Triggered by Study UID_330016 (PPAC). / Text5: Morita Takashi
- 1633: SP#37 completed / Text3: 22.011 / Text5: Morita Takashi
- 1634: CP#42 completed / Text3: 24.008, 23.122, 24.301
- 1635: RP#50 completed / Text3: UTRA 34.108, 34.123-1, 34.123-2, 34.123-3 / Text5: Takao.Shimizu.rp@nttdocomo.com
- 1636: SP#39 Stage 1 completed / Text3: 22.115 / Text5: Marco.DeLuca1@telecomitalia.it
- 1637: SP#39 completed / Text3: 22.115 / Text5: Marco.DeLuca1@telecomitalia.it
- 1638: CP#43 completed / Text5: John Watson
- 1639: SP#39 completed / Text3: 22.011, 22.115 / Text5: John Watson
- 1640: CP#43 completed. SP#42 SP-080874 22.011CR0141 confirmed Requirement to support roaming subscribers with CSG home network subscription but did NOT confirmed requirement for home network independent support of roamers in CSG / Text3: 29.002, 29.272, 23.008, 23.003 / Text5: Hannu Hietalahti
- 1641: CP#43 completed / Text3: 23.122, new (24.285, 24.301, 24.801) / Text5: zhang.peng@huawei.com
- 1642: CP#43 completed / Text3: 23.122, 24.008, new 24.285 / Text5: Osok Song
- 1643: SP#44 completed
- 1644: RP#43 completed / Text3: 25.304, 25.306, 25.331, new 25.367 / Text5: Yang Xudong (yangxudong@huawei.com)
- 1645: RP#42 completed / Text3: 25.401, 25.410, 25.412, 25.413, 25.414, 25.415, new (25.467, 25.468, 25.469) / Text5: Martin Warner (mw15@alcatel-lucent.com)
- 1646: RP#43 completed / Text3: 25.104, 25.141, new 25.967 / Text5: Ying Cai (yingcai@motorola.com)
- 1647: SP#44 completed. Complements work in BroadBand Forum / Text3: new (32.581, 32.582, 32.583, 32.584) / Text5: Zou Lan (zlan@huawei.com)
- 1648: RP#48 FDD completed. Testing for Feature UID_390033 UTRA HNB
- 1649: RP#48 completed / Text3: 34.108, 34.123-1, 34.123-2, 34.123-3 / Text5: Trica Li (trica_li@huawei.com)
- 1650: SP#43 completed / Text3: 33.106, 33.107, 33.108 / Text5: berthold.wilhelm@bnetza.de, ron_ryan@verizon.net
- 1651: CP#43 completed / Text5: Rolf Blom
- 1652: SP#42 completed 33.223 as Rel-8. TS 33.224 moved to Rel-9 under new UID_420039 / Text3: 33.223 / Text5: Rolf Blom
- 1653: CP#43 completed / Text3: 24.109 / Text5: Rolf Blom
- 1654: CP#43 completed / Text3: 29.109 / Text5: Rolf Blom
- 1655: SP#42 completed. SP#39 WID approved. / Text3: 26.131, 26.132 / Text5: stephane.ragot@orange-ftgroup.com, wanqing.shi@sonyericsson.com
- 1656: SP#42 completed. SP#38 WID approved. / Text3: 26.234, 26.346, 26.946 / Text5: thorsten.lohmar@ericsson.com

| ID | WBS | Task | Duration | Start | Finish | Complete | Remaining | Baseline start | Baseline finish | Baseline duration | Total slack | Constraint | Resources | Work | Actual work | Text1 | Text2 | Text4 | Text6 | Text7 | Text8 | Text12 | Text9 |
| --- | --- | --- | --- | --- | --- | --- | --- | --- | --- | --- | --- | --- | --- | --- | --- | --- | --- | --- | --- | --- | --- | --- | --- |
| 1657 | 534 | **Encoding formats, transport formats and media description signalling for interworking, QoE, and other enhancements to MTSI-MHI** | 331d? | 2007-12-06 A | 2009-03-12 A | 100% |  | 2007-12-06 | 2009-03-12 | 331d? |  |  | S4,C3,C4 | 9640h | 9640h | MTSI_eMHI | PCG-21 | Ericsson, Qualcomm | Rel-8 | SP-40 | Paolo |  |  |
| 1658 | 534.1 | MTSI Video - Dynamic Rate Adaptation/Signalling of Image Size | 331d? | 2007-12-06 A | 2009-03-12 A | 100% |  | 2007-12-06 | 2009-03-12 | 331d? |  | finish no earlier than 2009-03-12 | S4 | 2648h | 2648h | MTSI_eMHI-DRASIS |  | Qualcomm, Samsung | Rel-8 |  | Paolo |  |  |
| 1659 | 534.2 | CT3 part of Enhancement of interworking between MTSI and CS networks | 201d? | 2008-05-30 A | 2009-03-06 A | 100% |  | 2008-05-30 | 2009-03-06 | 201d? |  | finish no earlier than 2009-03-06 | C3 | 1608h | 1608h | MTSI_eMHI | PCG-21 | Huawei | Rel-8 | CP-40 | Jiwan |  |  |
| 1660 | 534.3 | CT4 part of Enhancement of interworking between MTSI and CS networks | 201d? | 2008-05-30 A | 2009-03-06 A | 100% |  | 2008-05-30 | 2009-03-06 | 201d? |  | finish no earlier than 2009-03-06 | C4 | 1608h | 1608h | MTSI_eMHI | PCG-21 | Huawei | Rel-8 | CP-40 | Kimmo |  |  |
| 1661 | 534.4 | Deleted - CT1 part of Enhancement of interworking between MTSI and CS networks | 141d? | 2008-05-30 A | 2008-12-12 A | 100% |  | 2008-05-30 | 2008-12-12 | 141d? |  | start no earlier than 2008-05-30 | C1 | 1128h | 1128h | MTSI_eMHI | PCG-21 | Huawei | Rel-8 | CP-40 | Frederic | CP-42 |  |
| 1662 | 535 | **Rel-8 Operations, Administration, Maintenance and Provisioning (OAM&P)** | 1443d? | 2007-06-07 A | 2012-12-07 | 96% | 58.72d? | 2007-06-07 | 2012-12-07 | 1443d? | 463d |  | S5,C1,C4,IETF | 61862.4h | 42608.4h | OAM8 |  |  | Rel-8 |  | Dionisio |  |  |
| 1663 | 535.1 | **Rel-8 Network Infrastructure Management** | 653d? | 2007-06-07 A | 2009-12-04 A | 100% |  | 2007-06-07 | 2009-12-04 | 653d? |  |  | S5 | 19464h | 19464h | OAM8-NIM |  |  | Rel-8 |  | Dionisio |  |  |
| 1664 | 535.1.1 | Telecom Management Methodology | 461d? | 2007-06-07 A | 2009-03-12 A | 100% |  | 2007-06-07 | 2009-03-12 | 461d? |  | finish no earlier than 2009-03-12 | S5 | 3688h | 3688h | OAM8 |  | Ericsson | Rel-8 |  | Dionisio |  |  |
| 1665 | 535.1.2 | Advanced Alarming on Itf-N | 266d? | 2007-06-07 A | 2008-06-12 A | 100% |  | 2007-06-07 | 2008-06-12 | 266d? |  | finish no earlier than 2008-12-11 | S5 | 2128h | 2128h | OAM8 |  | Nokia Siemens Networks | Rel-8 |  | Dionisio |  |  |
| 1666 | 535.1.3 | CN CS Bearer Transport Network (BTN) relative NRM | 266d? | 2007-06-07 A | 2008-06-12 A | 100% |  | 2007-06-07 | 2008-06-12 | 266d? |  | finish no earlier than 2008-12-11 | S5 | 2128h | 2128h | OAM8 |  | China Mobile | Rel-8 |  | Dionisio |  |  |
| 1667 | 535.1.4 | Alignment with eTOM and M.3060 architectural concepts | 210d? | 2008-02-22 A | 2008-12-11 A | 100% |  | 2008-02-22 | 2008-12-11 | 210d? |  | start no earlier than 2008-02-22 | S5 | 1680h | 1680h | OAM8 | PCG-21 | TeliaSonera | Rel-8 | SP-39 | Dionisio |  |  |
| 1668 | 535.1.5 | IRP SOAP Solution Sets | 201d? | 2008-06-05 A | 2009-03-12 A | 100% |  | 2008-06-05 | 2009-03-12 | 201d? |  | finish no earlier than 2009-03-12 | S5 | 1608h | 1608h | OAM8 | PCG-21 | Ericsson | Rel-8 | SP-40 | Dionisio |  |  |
| 1669 | 535.1.6 | Create missing specifications for IRP XML definitions | 52d? | 2009-09-24 A | 2009-12-04 A | 100% |  | 2009-09-24 | 2009-12-04 | 52d? |  | finish no earlier than 2010-03-12 | S5 | 416h | 416h | OAM8 | PCG-23 | ZTE | Rel-8 | SP-45 | Dionisio |  |  |
| 1670 | 535.1.7 | Deleted - End point modelling for reference point | 324d? | 2007-09-17 A | 2008-12-11 A | 100% |  | 2007-09-17 | 2008-12-11 | 324d? |  | finish no earlier than 2008-12-11 | S5 | 2592h | 2592h | OAM8 |  | Motorola | Rel-8 | SP-37 | Dionisio | SP-41 | PCG-21 |
| 1671 | 535.2 | **Rel-8 Performance Management** | 461d? | 2007-06-07 A | 2009-03-12 A | 100% |  | 2007-06-07 | 2009-03-12 | 461d? |  |  | S5 | 13712h | 13712h | OAM8-PM |  |  | Rel-8 |  | Dionisio |  |  |
| 1672 | 535.2.1 | IP bearer network Performance measurement definitions | 396d? | 2007-06-07 A | 2008-12-11 A | 100% |  | 2007-06-07 | 2008-12-11 | 396d? |  | finish no earlier than 2008-12-11 | S5 | 3168h | 3168h | OAM8 |  | China Mobile | Rel-8 |  | Dionisio |  |  |
| 1673 | 535.2.2 | HSUPA performance measurements | 396d? | 2007-06-07 A | 2008-12-11 A | 100% |  | 2007-06-07 | 2008-12-11 | 396d? |  | finish no earlier than 2008-12-11 | S5 | 3168h | 3168h | OAM8 |  | China Mobile | Rel-8 |  | Dionisio |  |  |
| 1674 | 535.2.3 | Key Performance Indicators (KPIs) for UMTS and GSM | 461d? | 2007-06-07 A | 2009-03-12 A | 100% |  | 2007-06-07 | 2009-03-12 | 461d? |  | finish no earlier than 2009-03-12 | S5 | 3688h | 3688h | OAM8 |  | China Mobile | Rel-8 |  | Dionisio |  |  |
| 1675 | 535.3 | **Rel-8 Trace Management** | 1247d? | 2008-03-07 A | 2012-12-07 | 87% | 163.92d? | 2008-03-07 | 2012-12-07 | 1247d? | 463d |  | S5,C1,C3,C4,IETF | 19270.4h | 9432.44h | OAM8-Trace |  |  | Rel-8 |  | Dionisio |  |  |
| 1676 | 535.3.1 | CT1 part of Service Level Tracing in IMS | 196d? | 2008-03-07 A | 2008-12-05 A | 100% |  | 2008-03-07 | 2008-12-05 | 196d? |  | finish no earlier than 2008-12-05 | C1 | 1568h | 1568h | OAM8-Trace |  | Vodafone | Rel-8 |  | Frederic |  |  |
| 1677 | 535.3.2 | (IETF) Service Level Tracing in IMS (draft-dawes-sipping-debug) | 715d? | 2008-03-07 A | 2012-12-07 | 75% | 178.75d? | 2008-03-07 | 2012-12-07 | 715d? | 463d | finish no earlier than 2012-12-07 | C1-IETF | 5720h | 4290h | OAM8-Trace | PCG-27 | Peter Dawes | Rel-8 | CP-52 | Frederic |  |  |
| 1678 | 535.3.3 | (IETF) Service Level Tracing in IMS (draft-dawes-sipping-debug-event) | 98d? | 2008-03-07 A | 2011-12-09 A | 100% |  | 2008-03-07 | 2011-12-09 | 98d? |  | finish no earlier than 2011-12-09 | C1-IETF | 768.04h | 768.04h | OAM8-Trace | PCG-27 | Peter Dawes | Rel-8 | CP-53 |  |  |  |
| 1679 | 535.3.4 | CT4 part of Service Level Tracing in IMS | 175.4d? | 2008-03-07 A | 2008-12-05 A | 100% |  | 2008-03-07 | 2008-12-05 | 175.4d? |  | finish no earlier than 2008-12-05 | C4 | 1403.2h | 1403.2h | OAM8-Trace | PCG-21 | Vodafone | Rel-8 | CP-40 | Frederic |  |  |
| 1680 | 535.3.5 | Deleted - CT3 part of Service Level Tracing in IMS | 175.4d? | 2008-03-07 A | 2008-12-05 A | 100% |  | 2008-03-07 | 2008-12-05 | 175.4d? |  | finish no earlier than 2008-12-05 | C3 | 1403.2h | 1403.2h | OAM8-Trace | PCG-21 | Vodafone | Rel-8 | CP-40 | Jiwan | CP-42 |  |

Notes:
- 1657: TSG#43 completed / Text5: olle.franceschi@ericsson.com, nleung@qualcomm.com
- 1658: SP#43 completed / Text3: 26.114 / Text5: nleung@qualcomm.com & kyunghun.jung@samsung.com
- 1659: CP#43 completed / Text3: 29.163 / Text5: Tingfang Tang (tagna_online@huawei.com)
- 1660: CP#43 completed / Text3: 29.332 / Text5: Tingfang Tang (tagna_online@huawei.com)
- 1661: CP#42 stopped (No CT1-impact). WID updated CP-080422=>CP-080774 / Text5: Tingfang Tang (tagna_online@huawei.com)
- 1662: OAM8 is an umbrella Feature also for OAM&P related TEI8 type of changes that are not part of any other dedicated feature/WI / Text3: TR 30.818
- 1663: -
- 1664: SP#43 completed / Text3: 32.155, 32.153 / Text5: thomas.tovinger@ericsson.com
- 1665: SP#40 completed / Text3: 32.121, 32.122, 32.123 / Text5: SUERBAUM, Clemens
- 1666: SP#40 completed / Text3: 32.632, 32.633, 32.635 / Text5: Li Jian (lijian@chinamobile.com)
- 1667: SP#42 completed / Text3: 32.101/2, 32-series / Text5: tommy.berggren@teliasonera.com
- 1668: SP#43 completed / Text3: 32.111-7, 32.617, 32.417, 32.367, 32.347, 32.111-1, 32.111-2, 32.111-3, 32.111-5, 32.307, 32.317, 32.341, 32.342, 32.343, 32.345, 32.361, 32.362, 32.363, 32.365, 32.411, 32.412, 32.413, 32.415, 32.611, 32.612, 32.613, 32.615, 32.625 / Text5: edwin.tse@ericsson.com
- 1669: SP#46 completed. Create missing XML definitions specs for IRPs (Advanced Alarm Management, Communication Surveillance, Self-Configuration of Network Elements, Software Management) needed for implementation of Rel-8 Notification Log IRP (TS 32.33x) / Text3: new (32.125, 32.355, 32.505, 32.535), 32.150, 32.153, 32.335 / Text5: Shuqiang Huang (huangsq@zte.com.cn)
- 1670: SP#41 Work stopped. Contributions related to E-UTRAN/EPC to be submitted to UID_380036 E-UTRAN NRM IRP/ UID_380037 EPC NRM IRP / Text3: 32.152, 32.62/3/4x, 32.73x / Text5: Yizhi Yao (yzyao@motorola.com)
- 1671: - / Text5: Li Jian (lijian@chinamobile.com)
- 1672: SP#42 completed / Text3: 32.321, 32.322, 32.323, 32.325 / Text5: lilianyuan@chinamobile.com
- 1673: SP#42 completed / Text3: 32.405 / Text5: Li Jian (lijian@chinamobile.com)
- 1674: SP#43 completed / Text3: 32.410 / Text5: Li Jian (lijian@chinamobile.com), Liang Shuangchun (liangshuangchun@cmdi.chinamobile.com)
- 1675: -
- 1676: CP#42 completed / Text3: 24.323, 24.229 / Text5: peter.dawes@vodafone.com
- 1677: Not completed internet-draft / Text3: draft-dawes-dispatch-debug / Text5: peter.dawes@vodafone.com
- 1678: CP#54 Draft removed from 3GPP documentation, covered by draft-dawes-sipping-debug / Text3: draft-dawes-sipping-debug-event / Text5: peter.dawes@vodafone.com
- 1679: CP#42 completed / Text3: 29.228, 29.229 / Text5: peter.dawes@vodafone.com
- 1680: CP#42 stopped (No CT3-impact) / Text5: peter.dawes@vodafone.com

| ID | WBS | Task | Type | Duration | Start | Finish | Complete | Baseline start | Baseline finish | Baseline duration | Constraint | Resources | Work | Actual work | Text1 | Text6 | Text8 | Text4 | Text5 | Text2 | Text7 | Text9 | Text12 | Text11 |
| --- | --- | --- | --- | --- | --- | --- | --- | --- | --- | --- | --- | --- | --- | --- | --- | --- | --- | --- | --- | --- | --- | --- | --- | --- |
| 1681 | 536 | **Rel-8 Charging Management small Enhancements** |  | 716d? | 2006-03-16 A | 2008-12-11 A | 100% | 2006-03-16 | 2008-12-11 | 716d? |  | S5 | 12544h | 12544h | CH8 | Rel-8 | Dionisio |  |  |  |  |  |  |  |
| 1682 | 536.1 | Online charging correlation |  | 457d? | 2006-03-16 A | 2007-12-14 A | 100% | 2006-03-16 | 2007-12-14 | 457d? | start no earlier than 2006-03-16 | S5 | 3656h | 3656h | CH8 | Rel-8 | Dionisio | Orange | Chahine, Rony |  |  |  |  |  |
| 1683 | 536.2 | SMS online charging |  | 137d? | 2007-06-07 A | 2007-12-14 A | 100% | 2007-06-07 | 2007-12-14 | 137d? | finish no earlier than 2007-12-14 | S5 | 1096h | 1096h | CH8 | Rel-8 | Dionisio | Vodafone | Gavin.Wong@vodafone.com |  |  |  |  |  |
| 1684 | 536.3 | Introduce Online Charging from SMS-SC into the SMS Charging Specifications |  | 61d? | 2008-09-18 A | 2008-12-11 A | 100% | 2008-09-18 | 2008-12-11 | 61d? | finish no earlier than 2008-12-11 | S5 | 488h | 488h | CH8 | Rel-8 | Dionisio | Acision | erik.gebler@acision.com | PCG-21 | SP-41 |  |  |  |
| 1685 | 536.4 | Deleted - WLAN Offline Charging |  | 244d? | 2008-01-07 A | 2008-12-11 A | 100% | 2008-01-07 | 2008-12-11 | 244d? | finish no earlier than 2008-12-11 | S5 | 1952h | 1952h | CH8 | Rel-8 | Dionisio | Alcatel-Lucent | Maryse.Gardella@alcatel.fr | PCG-21 | SP-38 | PCG-22 | SP-42 |  |
| 1686 | 537 | **Conferencing enhancements for Mp interface** |  | 266d? | 2007-11-30 A | 2008-12-05 A | 100% | 2007-11-30 | 2008-12-05 | 266d? |  | C4 | 6384h | 6384h | eMp | Rel-8 | Kimmo | Huawei | Chencheng@huawei.com | PCG-21 |  |  |  |  |
| 1687 | 537.1 | Stage 2 for eMp |  | 266d? | 2007-11-30 A | 2008-12-05 A | 100% | 2007-11-30 | 2008-12-05 | 266d? | finish no earlier than 2008-12-11 | C4 | 2128h | 2128h | eMp | Rel-8 | Kimmo | Huawei | Chencheng@huawei.com | PCG-21 | CP-38 |  |  |  |
| 1688 | 537.2 | Stage 3 for eMp |  | 266d? | 2007-11-30 A | 2008-12-05 A | 100% | 2007-11-30 | 2008-12-05 | 266d? | finish no earlier than 2008-12-05 | C4 | 2128h | 2128h | eMp | Rel-8 | Kimmo | Huawei | Chencheng@huawei.com | PCG-21 | CP-38 |  |  |  |
| 1689 | 538 | **Contact Manager for 3GPP UICC applications** |  | 642d? | 2006-06-22 A | 2008-12-05 A | 100% | 2006-06-22 | 2008-12-05 | 642d? |  | C6 | 13352h | 13352h | eUPHBOOK | Rel-8 | Xavier | Gemalto | Jacques.seif@gemalto.com |  |  |  |  |  |
| 1690 | 538.1 | Requirements for Contact Manager |  | 392d? | 2006-06-22 A | 2007-12-21 A | 100% | 2006-06-22 | 2007-12-21 | 392d? | finish no earlier than 2007-12-21 | C6 | 3136h | 3136h | eUPHBOOK-St1 | Rel-8 | Xavier | Gemalto | Jacques.seif@gemalto.com |  |  |  |  |  |
| 1691 | 538.2 | External interface for eUPHBOOK |  | 220d? | 2007-05-07 A | 2008-03-07 A | 100% | 2007-05-07 | 2008-03-07 | 220d? | finish no earlier than 2008-03-07 | C6 | 1760h | 1760h | eUPHBOOK-Ext_Spec | Rel-8 | Xavier | Gemalto | Jacques.seif@gemalto.com |  |  |  |  |  |
| 1692 | 538.3 | Internal interface for eUPHBOOK |  | 415d? | 2007-05-07 A | 2008-12-05 A | 100% | 2007-05-07 | 2008-12-05 | 415d? | finish no earlier than 2008-12-05 | C6 | 3320h | 3320h | eUPHBOOK-Int_Spec | Rel-8 | Xavier | Gemalto | Jacques.seif@gemalto.com |  | CP-37 |  |  |  |
| 1693 | 538.4 | Deleted - Implementation of eUPHBOOK | milestone | 0d? | 2007-06-21 A | 2007-06-21 A | 100% | 2007-06-21 | 2007-06-21 | 0d? | start no earlier than 2007-06-21 | C6 |  |  | eUPHBOOK-St23 | Rel-8 | Xavier | Giesecke & Devrient | Claus Dietze |  |  |  | SP-33 |  |
| 1694 | 539 | **Rel-8 LTE – 3G Long Term Evolution - Evolved Packet System RAN part** |  | 644d? | 2006-09-25 A | 2009-03-12 A | 100% | 2006-09-25 | 2009-03-12 | 644d? |  | RP,S5 | 44896h | 44896h | LTE | Rel-8 |  | NTT DoCoMo | Takehiro Nakamura (nakamurata@nttdocomo.co.jp) |  |  |  |  | RP-080741 |
| 1695 | 539.1 | LTE – Physical Layer |  | 380d? | 2006-09-25 A | 2008-03-07 A | 100% | 2006-09-25 | 2008-03-07 | 380d? | finish no earlier than 2007-09-14 | R1 | 3040h | 3040h | LTE-Phys | Rel-8 | Patrick | NTT DoCoMo | Sadayuki Abeta |  |  |  |  | RP-080741 |
| 1696 | 539.2 | LTE – Radio Interface Layer 2 and 3 Protocol Aspect |  | 575d? | 2006-09-25 A | 2008-12-05 A | 100% | 2006-09-25 | 2008-12-05 | 575d? | finish no earlier than 2008-12-11 | R2 | 4600h | 4600h | LTE-L23 | Rel-8 | Joern | Nokia Siemens Networks | benoist.sebire@nokia.com |  |  |  |  | RP-080741 |
| 1697 | 539.3 | LTE – eUTRAN Interfaces |  | 575d? | 2006-09-25 A | 2008-12-05 A | 100% | 2006-09-25 | 2008-12-05 | 575d? | finish no earlier than 2008-12-11 | R3 | 4600h | 4600h | LTE-interfaces | Rel-8 | Juha | Ericsson | Martin Israelsson |  |  |  |  | RP-080741 |
| 1698 | 539.4 | LTE – Evolved UTRA and UTRAN RF Radio Transmission/Reception, System Performance Requirements and Conformance Testing |  | 575d? | 2006-09-25 A | 2008-12-05 A | 100% | 2006-09-25 | 2008-12-05 | 575d? | finish no earlier than 2008-12-11 | R4 | 4600h | 4600h | LTE-RF | Rel-8 | Issam | Nokia Siemens Networks | Tuomo Saynajakangas |  |  |  |  | RP-080741 |
| 1699 | 539.5 | LTE – FDD repeaters |  | 386d? | 2007-09-14 A | 2009-03-06 A | 100% | 2007-09-14 | 2009-03-06 | 386d? | finish no earlier than 2009-03-06 | R4 | 3088h | 3088h | LTE-Repeaters | Rel-8 | Issam | Powerwave Technologies, Andrew Wireless | ralf.michanikl@andrew.com, Alf.Ahlstrom@pwav.com |  | RP-37 |  |  | RP-090037 |
| 1700 | 539.6 | **E-UTRAN Data Definitions** |  | 389d? | 2007-09-17 A | 2009-03-12 A | 100% | 2007-09-17 | 2009-03-12 | 389d? |  | S5 | 13096h | 13096h | E-UTRAN-OAM | Rel-8 | Dionisio |  |  | PCG-21 | SP-39 |  |  |  |
| 1701 | 539.6.1 | Subscriber and Equipment Trace for E-UTRAN and EPC |  | 389d? | 2007-09-17 A | 2009-03-12 A | 100% | 2007-09-17 | 2009-03-12 | 389d? | finish no earlier than 2009-03-12 | S5 | 3112h | 3112h | E-UTRAN-OAM | Rel-8 | Dionisio | Ericsson | robert.petersen@ericsson.com |  | SP-37 |  |  |  |
| 1702 | 539.6.2 | E-UTRAN Network Resource Model (NRM) Integration Reference Point (IRP) |  | 309d? | 2008-01-07 A | 2009-03-12 A | 100% | 2008-01-07 | 2009-03-12 | 309d? | finish no earlier than 2009-03-12 | S5 | 2472h | 2472h | E-UTRAN-OAM | Rel-8 | Dionisio | Ericsson | ELMDAHL, Per | PCG-21 | SP-38 |  |  |  |
| 1703 | 539.6.3 | Performance measurements for E-UTRAN |  | 275d? | 2008-02-22 A | 2009-03-12 A | 100% | 2008-02-22 | 2009-03-12 | 275d? | finish no earlier than 2009-03-12 | S5 | 2200h | 2200h | E-UTRAN-OAM | Rel-8 | Dionisio | Motorola, Huawei | Yizhi Yao (yzyao@motorola.com) | PCG-21 | SP-39 |  |  |  |
| 1704 | 539.6.4 | Key Performance Indicators (KPIs) for E-UTRAN |  | 275d? | 2008-02-22 A | 2009-03-12 A | 100% | 2008-02-22 | 2009-03-12 | 275d? | finish no earlier than 2009-03-12 | S5 | 2200h | 2200h | E-UTRAN-OAM | Rel-8 | Dionisio | Ericsson | ulf.hubinette@ericsson.com | PCG-21 | SP-39 |  |  |  |

Notes:
- 1681: CH8 is an umbrella Feature also for OAM&P related TEI8 type of changes that are not part of any other dedicated feature/WI / Text3: TR 30.818
- 1682: SP#38 completed / Text3: 32.296
- 1683: SP#38 completed / Text3: 32.240, 32.299, new 32.274
- 1684: SP#42 completed. Linked to SA2 UID 32081 (Support of SMS over IP networks) and CT4 UID 340016 (Routeing of MT-SMS via the HPLMN). / Text3: 32.274, 32.299
- 1685: SP#42 stopped / Text3: 32.252, 32.298, 32.299
- 1686: CP#42 completed
- 1687: CP#42 completed / Text3: 23.333
- 1688: CP#42 completed / Text3: 29.333
- 1689: CP#42 completed. CP#40: WID updated CP-070622=>CP-080382. aka Enhanced USIM phonebook
- 1690: CP#38 completed / Text3: 21.111
- 1691: CP#39 completed / Text3: new 31.220
- 1692: CP#42 completed / Text3: new 31.221
- 1693: SP#33 stopped / Text3: 31.102
- 1694: RP#43 completed. Role model for SAE/LTE system wide project management by SA2 in SP-060166 / Text3: LTE 36.300, 36.938
- 1695: RP#39 completed / Text3: 36.201, 36.211, 36.212, 36.213, 36.214, 25.215, 25.225
- 1696: RP#42 completed / Text3: 36.302, 36.304, 36.306, 36.314, 36.321, 36.322, 36.323, 36.331, 25.302, 25.304, 25.331
- 1697: RP#42 completed / Text3: 36.401, 36.410, 36.411, 36.412, 36.413, 36.414, 36.420, 36.421, 36.422, 36.423, 36.424, 25.413
- 1698: RP#42 completed. RP#47 abandoned draft 36.801, 36.803, 36.804 / Text3: 36.101, 36.104, 36.113, 36.124, 36.133, 36.141, 36.942, 25.123, 25.133
- 1699: RP#43 completed. RP#47 create Rel-9 TR 36.956 (see R4-100386, RP-100320_RAN4 Report) / Text3: 36.106, 36.143, 25.113
- 1700: SP#43 completed
- 1701: SP#43 completed / Text3: 32.421, 2.422, 32.423, 2.441, 32.442, 32.443, 32.445
- 1702: SP#43 completed / Text3: new (32.761, 32.762, 32.763, 32.765)
- 1703: SP#43 completed / Text3: new 32.425
- 1704: SP#43 completed / Text3: new (32.450, 32.451)

| ID | WBS | Task | Duration | Start | Finish | Complete | Baseline start | Baseline finish | Baseline duration | Constraint | Resources | Work | Actual work | Text1 | Text2 | Text4 | Text5 | Text6 | Text7 | Text8 | Text11 | Text12 | Text9 |
| --- | --- | --- | --- | --- | --- | --- | --- | --- | --- | --- | --- | --- | --- | --- | --- | --- | --- | --- | --- | --- | --- | --- | --- |
| 1705 | 539.7 | **Self-Organizing Networks (SON)** | 210d? | 2008-02-22 A | 2008-12-11 A | 100% | 2008-02-22 | 2008-12-11 | 210d? |  | S5 | 6720h | 6720h | LTE_SON-OAM | PCG-21 | Vodafone | GOMPAKIS, Panagiotis | Rel-8 | SP-39 | Dionisio |  |  |  |
| 1706 | 539.7.1 | SON Concepts and requirements | 210d? | 2008-02-22 A | 2008-12-11 A | 100% | 2008-02-22 | 2008-12-11 | 210d? |  | S5 | 1680h | 1680h | LTE_SON-OAM | PCG-21 | Vodafone | GOMPAKIS, Panagiotis | Rel-8 | SP-39 | Dionisio |  |  |  |
| 1707 | 539.7.2 | Self-Establishment of eNBs, including automated Software Management | 210d? | 2008-02-22 A | 2008-12-11 A | 100% | 2008-02-22 | 2008-12-11 | 210d? | start no earlier than 2008-02-22 | S5 | 1680h | 1680h | LTE_SON-OAM | PCG-21 | Nokia Siemens Networks | SUERBAUM, Clemens | Rel-8 | SP-39 | Dionisio |  |  |  |
| 1708 | 539.7.3 | SON Automatic Neighbour Relations (ANR) List Management | 210d? | 2008-02-22 A | 2008-12-11 A | 100% | 2008-02-22 | 2008-12-11 | 210d? | finish no earlier than 2008-12-11 | S5 | 1680h | 1680h | LTE_SON-OAM | PCG-21 | Ericsson | edwin.tse@ericsson.com | Rel-8 | SP-39 | Dionisio |  |  |  |
| 1709 | 540 | **Rel-8 LTE – Terminal Conformance Test Specification** | 657d? | 2007-06-01 A | 2009-12-04 A | 100% | 2007-06-01 | 2009-12-04 | 657d? |  | R5 | 17544h | 17544h | LTE-UEConTest |  |  |  | Rel-8 |  | Ingbert |  |  |  |
| 1710 | 540.1 | 3G LTE – Terminal Protocol Conformance Test Specifications | 657d? | 2007-06-01 A | 2009-12-04 A | 100% | 2007-06-01 | 2009-12-04 | 657d? | finish no earlier than 2009-12-04 | R5 | 5256h | 5256h | LTE-UEConTest_SIG |  | NEC, Motorola | david.lecompte@nectech.fr, Jacob.John@motorola.com | Rel-8 |  | Ingbert | RP-091060 |  |  |
| 1711 | 540.2 | LTE – Terminal Radio Transmission and Reception Conformance Test Specifications | 657d? | 2007-06-01 A | 2009-12-04 A | 100% | 2007-06-01 | 2009-12-04 | 657d? |  | R5 | 5256h | 5256h | LTE-UEConTest_RF |  | Agilent | andrea_leonardi@agilent.com | Rel-8 |  | Ingbert | RP-091059 |  |  |
| 1712 | 540.3 | Deleted - LTE – Terminal Radio Transmission and Reception Conformance Test Specifications | 401d? | 2007-06-01 A | 2008-12-12 A | 100% | 2007-06-01 | 2008-12-12 | 401d? |  | R5 | 3208h | 3208h | LTE-UEConTest_RF |  | Agilent | andrea_leonardi@agilent.com | Rel-8 |  | Ingbert | RP-091059 | RP-41 |  |
| 1713 | 541 | **Rel-8 Improvements of the Radio Interface** | 525d? | 2007-03-05 A | 2009-03-06 A | 100% | 2007-03-05 | 2009-03-06 | 525d? |  | RP | 18152h | 18152h | RInImp8 |  |  |  | Rel-8 |  | Issam |  |  |  |
| 1714 | 541.1 | UMTS 1500 MHz | 140d? | 2007-03-05 A | 2007-09-14 A | 100% | 2007-03-05 | 2007-09-14 | 140d? | finish no earlier than 2007-09-14 | R4 | 1120h | 1120h | RInImp8-UMTS1500 |  | NTT DoCoMo | Takehiro Nakamura (nakamurata@nttdocomo.co.jp) | Rel-8 |  | Issam | RP-070526 |  |  |
| 1715 | 541.2 | UMTS 700 MHz FDD | 325d? | 2007-03-05 A | 2008-05-30 A | 100% | 2007-03-05 | 2008-05-30 | 325d? | finish no earlier than 2008-06-12 | R4 | 2600h | 2600h | RInImp8-UMTS700 |  | Nokia | Tuomo Saynajakangas | Rel-8 |  | Issam | RP-080260 |  |  |
| 1716 | 541.3 | UMTS 1880 MHz TDD | 126d? | 2008-09-12 A | 2009-03-06 A | 100% | 2008-09-12 | 2009-03-06 | 126d? | finish no earlier than 2009-03-09 | R4 | 1008h | 1008h | RInImp9-UMTS1880TDD | PCG-21 | CATT | Yuexia Song (songyuexia@datangmobile.cn) | Rel-8 | RP-41 | Issam | RP-090044 |  |  |
| 1717 | 541.4 | UMTS 2300 MHz TDD LCR | 195d? | 2007-12-17 A | 2008-09-12 A | 100% | 2007-12-17 | 2008-09-12 | 195d? | finish no earlier than 2008-09-12 | R4 | 1560h | 1560h | RInImp8-UMTS2300TDD | PCG-21 | CATT | songyuexia@datangmobile.cn | Rel-8 | RP-38 | Issam | RP-080517 |  |  |
| 1718 | 541.5 | Further Improved Minimum Performance Requirements for HSDPA UE (FDD) - Two-Branch Interference Cancellation | 265d? | 2007-03-05 A | 2008-03-07 A | 100% | 2007-03-05 | 2008-03-07 | 265d? | finish no earlier than 2008-03-12 | R4 | 2120h | 2120h | RInImp8-2BIC |  | AT&T | Marc Grant | Rel-8 |  | Issam | RP-080041 |  |  |
| 1719 | 541.6 | CS Voice Service over HSPA | 167d? | 2007-07-19 A | 2008-03-07 A | 100% | 2007-07-19 | 2008-03-07 | 167d? |  | R2 | 1336h | 1336h | RInImp8-CsHspa |  | Nokia Siemens Networks | woonhee.hwang@nsn.com | Rel-8 | RP-37 | Joern | RP-080042 |  |  |
| 1720 | 541.7 | Performance requirements for 15 code reception with 16QAM/QPSK (FDD) | 126d? | 2007-06-11 A | 2008-03-07 A | 100% | 2007-06-11 | 2008-03-07 | 126d? | finish no earlier than 2008-06-12 | R4 | 1008h | 1008h | RInImp8-Hsdpa15codes |  | Vodafone | tim.frost@vodafone.com | Rel-8 | RP-37 | Issam | RP-080043 |  |  |
| 1721 | 541.8 | Deleted - UMTS 2300 MHz FDD/TDD | 400d? | 2007-03-05 A | 2008-09-12 A | 100% | 2007-03-05 | 2008-09-12 | 400d? | finish no earlier than 2008-12-11 | R4 | 3200h | 3200h | RInImp8-UMTS2300 |  | AT&T | Marc Grant | Rel-8 |  | Issam | RP-080515 | RP-41 | PCG-21 |
| 1722 | 542 | **Rel-8 Improvements of the Radio Interface - UE Conformance Testing** | 396d? | 2007-06-01 A | 2008-12-05 A | 100% | 2007-06-01 | 2008-12-05 | 396d? |  | R5 | 6256h | 6256h | RInImp-UEConTest |  |  |  | Rel-8 |  | Ingbert |  |  |  |
| 1723 | 542.1 | Conformance Test Aspects – CS Voice Service over HSPA | 336d? | 2007-06-01 A | 2008-09-12 A | 100% | 2007-06-01 | 2008-09-12 | 336d? | finish no earlier than 2008-09-12 | R5 | 2688h | 2688h | RInImp8-CsHspa_UEConTest |  | Huawei | baoyi@huawei.com | Rel-8 |  | Ingbert | RP-080542 |  |  |
| 1724 | 542.2 | Conformance Test Aspects – Performance requirements for 15 code reception with 16QAM/QPSK (FDD) | 195d? | 2008-03-07 A | 2008-12-05 A | 100% | 2008-03-07 | 2008-12-05 | 195d? | finish no earlier than 2008-12-05 | R5 | 1560h | 1560h | RInImp8-UEConTest_ Hsdpa15codes | PCG-21 | Ericsson | Mikael.Ziren@Ericsson.com | Rel-8 | RP-40 | Ingbert | RP-080818 |  |  |
| 1725 | 543 | **Rel-8 RAN improvements** | 520d? | 2007-06-04 A | 2009-05-29 A | 100% | 2007-06-04 | 2009-05-29 | 520d? |  | RP | 29776h | 29776h | RANimp |  |  |  | Rel-8 |  |  |  |  |  |
| 1726 | 543.1 | Combination of 64QAM and MIMO for HSDPA (FDD) | 205d? | 2007-06-04 A | 2008-09-12 A | 100% | 2007-06-04 | 2008-09-12 | 205d? | finish no earlier than 2008-09-12 | R1 | 1640h | 1640h | RANimp-64QamMimoHsdpa |  | Ericsson | Johan.Bergman@ericsson.com | Rel-8 |  | Patrick | RP-080518 |  |  |
| 1727 | 543.2 | Improved L2 for uplink | 186d? | 2007-09-14 A | 2008-05-30 A | 100% | 2007-09-14 | 2008-05-30 | 186d? | finish no earlier than 2008-05-30 | R2 | 1488h | 1488h | RANimp-UplinkL2dataRates |  | Ericsson | Janne.Peisa@ericsson.com | Rel-8 | RP-37 | Joern | RP-080265 |  |  |
| 1728 | 543.3 | Enhanced Uplink for CELL_FACH State in FDD | 321d? | 2007-09-14 A | 2008-12-05 A | 100% | 2007-09-14 | 2008-12-05 | 321d? | finish no earlier than 2008-12-12 | R2 | 2568h | 2568h | RANimp-UplinkEnhState |  | Nokia Siemens Networks | markus.wimmer@nsn.com | Rel-8 | RP-37 | Joern | RP-080804 |  |  |
| 1729 | 543.4 | Enhanced UE Discontinuous Reception (DRX) for FDD | 261d? | 2007-09-14 A | 2008-09-12 A | 100% | 2007-09-14 | 2008-09-12 | 261d? | finish no earlier than 2008-09-12 | R2 | 2088h | 2088h | RANimp-DRX |  | Nokia | luis.barreto@nokia.com | Rel-8 | RP-37 | Joern | RP-080520 |  |  |
| 1730 | 543.5 | Enhancements for Serving Radio Network Subsystem (SRNS) Relocation Procedure | 261d? | 2007-09-14 A | 2008-09-12 A | 100% | 2007-09-14 | 2008-09-12 | 261d? | finish no earlier than 2008-09-12 | R3 | 2088h | 2088h | RANimp-SrnsReloc |  | Nokia Siemens Networks | masatoshi.nakamata@nsn.com | Rel-8 | RP-37 | Juha | RP-080521 |  |  |
| 1731 | 543.6 | Enhancements for FDD HSPA Evolution | 321d? | 2007-09-14 A | 2008-12-05 A | 100% | 2007-09-14 | 2008-12-05 | 321d? | finish no earlier than 2008-12-05 | R3,R2 | 2568h | 2568h | RANimp-HSPAEvo |  | Nokia Siemens Networks | masatoshi.nakamata@nsn.com | Rel-8 | RP-37 | Juha | RP-080805 |  |  |
| 1732 | 543.7 | 64QAM for 1.28 Mcps TDD HSDPA | 264d? | 2007-12-04 A | 2008-12-05 A | 100% | 2007-12-04 | 2008-12-05 | 264d? | finish no earlier than 2008-12-05 | R1 | 2112h | 2112h | RANimp-64Qam1.28TDD | PCG-21 | ZTE | zfmail@zte.com.cn | Rel-8 | RP-38 | Patrick | RP-080806 |  |  |
| 1733 | 543.8 | Enhanced CELL_FACH state in 1.28 Mcps TDD | 264d? | 2007-12-04 A | 2008-12-05 A | 100% | 2007-12-04 | 2008-12-05 | 264d? | finish no earlier than 2008-12-12 | R2 | 2112h | 2112h | RANimp-EnhState1.28TDD | PCG-21 | ZTE | zhang.yincheng@zte.com.cn | Rel-8 | RP-38 | Joern | RP-080807 |  |  |
| 1734 | 543.9 | Continuous Connectivity for packet data users for 1.28 Mcps TDD | 321d? | 2008-03-07 A | 2009-05-29 A | 100% | 2008-03-07 | 2009-05-29 | 321d? | finish no earlier than 2009-05-29 | R1 | 2568h | 2568h | RANimp-LCRCPC | PCG-21 | TD Tech | chenying@td-tech.com | Rel-8 | RP-39 | Patrick | RP-090394 |  |  |
| 1735 | 543.10 | HSPA VoIP to WCDMA/GSM CS continuity | 261d? | 2008-03-07 A | 2009-03-06 A | 100% | 2008-03-07 | 2009-03-06 | 261d? | finish no earlier than 2009-03-06 | R2 | 2088h | 2088h | RANimp-HSPAVoIP | PCG-21 | Nokia | Simone.Provvedi@nokia.com | Rel-8 | RP-39 | Joern | RP-090050 |  |  |
| 1736 | 543.11 | HS-DSCH Serving Cell Change Enhancements | 196d? | 2008-03-07 A | 2008-12-05 A | 100% | 2008-03-07 | 2008-12-05 | 196d? | finish no earlier than 2008-12-12 | R2 | 1568h | 1568h | RANimp-HSDSCH | PCG-21 | Ericsson | henrik.enbuske@ericsson.com | Rel-8 | RP-39 | Joern | RP-080811 |  |  |
| 1737 | 543.12 | MIMO for 1.28 Mcps TDD. Linked to Rel-8 Study on Scope of future HSPA Evolution for 1.28 Mcps TDD (UID_370041) TR 25.824 | 201d? | 2007-11-01 A | 2009-03-06 A | 100% | 2007-11-01 | 2009-03-06 | 201d? | finish no earlier than 2009-05-29 | R1,R4 | 1608h | 1608h | RANimp-MIMOLCR | PCG-21 | CATT | wangke@datangmobile.cn | Rel-8 | RP-40 | Patrick | RP-090313 |  |  |
| 1738 | 543.13 | Dual-Cell HSDPA operation on adjacent carriers | 140d? | 2008-05-30 A | 2008-12-11 A | 100% | 2008-05-30 | 2008-12-11 | 140d? | finish no earlier than 2009-05-29 | R1,R4 | 1120h | 1120h | RANimp-DCHSDPA | PCG-21 | Ericsson | johan.bergman@ericsson.com | Rel-8 | RP-40 | Patrick | RP-080814 |  |  |

Notes:
- 1705: SP#42 completed (WT UID_390007 moved to Rel-9)
- 1706: SP#42 completed / Text3: new 32.500
- 1707: SP#42 completed / Text3: new (32.501, 32.502, 32.503, 32.531, 32.532, 32.533)
- 1708: SP#42 completed / Text3: 32.761, 32.762, 32.763, 32.765, new 32.511
- 1709: Testing for Feature UID_20068 (LTE)
- 1710: RP#46 completed / Text3: 36.521-1, 36.521-2, 36.508, 36.509, 36.523-1, 36.523-2, 36.523-3
- 1711: RP#46 completed. RP#50 TR 36.903 v100 for Approval / Text3: 36.521-1, 36.521-2, 36.521-3, new TR 36.903
- 1712: RP#41 stopped / Text3: 36.521-1, 36.521-2, 36.521-3
- 1713: -
- 1714: RP#37 completed / Text3: 25.101, 25.104, 25.133, 25.141, 25.331, 25.942, 25.306, 25.307, 34.121
- 1715: RP#40 completed / Text3: 25.101, 25.104, 25.133, 25.141, 25.331, 25.942, 25.306, 25.307, 34.121
- 1716: RP#43 completed / Text3: 25.102, 25.105, 25.113, 25.123, 25.142, 34.124, 25.307
- 1717: RP#41 completed. RP#47 abandoned draft 25.828 / Text3: 25.102, 25.105, 25.113, 25.123, 25.142, 34.124, 25.306, 25.331, 34.122
- 1718: RP#39 completed / Text3: 25.101
- 1719: RP#39 completed / Text3: 25.323, 25.331, 25.322
- 1720: RP#39 completed / Text3: 25.101
- 1721: RP#41 stopped / Text3: 25.101, 25.104, 25.133, 25.141, 25.331, 25.942, 25.306, 25.307, 34.121
- 1722: 05/08: Linked to Feature UID_20028 (RInImp)
- 1723: RP#41 completed / Text3: 34.108, 34.123-1, 34.123-2, 34.123-3
- 1724: RP#42 completed / Text3: 34.121-1, 34.121-2
- 1725: -
- 1726: RP#41 completed / Text3: 25.308, 25.211, 25.212, 25.213, 25.306, 25.331, 25.433, 25.435, 25.423, 25.425, 25.101, 25.104, 25.141
- 1727: RP#40 completed. Linked to UID_370037 Enhanced Uplink for CELL_FACH State in FDD / Text3: 25.319, 25.301, 25.306, 25.321, 25.331, 25.433, 25.435, 25.423, 25.425, 25.427
- 1728: RP#42 completed. Linked to UID_370036 Improved L2 for uplink / Text3: 25.309, 25.211, 25.214, 25.321, 25.331, 25.423, 25.433
- 1729: RP#41 completed. Continuation of Rel-7 work item "Continuous connectivity for packet data users" UID_20046. / Text3: 25.306, 25.308, 25.321, 25.331, 25.423
- 1730: RP#41 completed. Linked to UID_370040 Enhancements for FDD HSPA Evolution / Text3: 25.306, 25.308, 25.321, 25.331, 25.423, 25.433, 25.214, 25.133
- 1731: RP#42 completed. Triggered by Rel-7 Study on Scope of future FDD HSPA Evolution (UID_20065) TR 25.999 / Text3: 25.401, 25.413, 25.420, 25.423, 25.427, 25.433, 25.446, 25.301, 25.346
- 1732: RP#42 completed. Linked to Rel-8 Study on Scope of future HSPA Evolution for 1.28 Mcps TDD (UID_370041) TR 25.824 / Text3: 25.102, 25.105, 25.123, 25.142, 25.201, 25.221, 25.222, 25.223, 25.224, 25.306, 25.308, 25.321, 25.331, 25.423, 25.433
- 1733: RP#42 completed. Linked to Rel-8 Study on Scope of future HSPA Evolution for 1.28 Mcps TDD (UID_370041) TR 25.824 / Text3: 25.123, 25.221, 25.222, 25.224, 25.301, 25.302, 25.304, 25.306, 25.308, 25.319, 25.321, 25.331, 25.401, 25.423, 25.425, 25.433, 25.435
- 1734: RP#44 completed. Linked to Rel-8 Study on Scope of future HSPA Evolution for 1.28 Mcps TDD (UID_370041) TR 25.824 / Text3: 25.929, 25.308, 25.319
- 1735: RP#43 completed / Text3: 25.331, 25.413
- 1736: RP#42 completed / Text3: 25.101, 25.104, 25.133, 25.212, 25.214, 25.308, 25.321, 25.331, 25.423, 25.433
- 1737: RP#43 completed / Text3: 25.201, 25.221, 25.222, 25.223, 25.224, 25.306, 25.308, 25.321, 25.331, 25.423, 25.433, 25.102, 25.105, 25.142
- 1738: RP#42 completed. Triggered by UID_390032 Study on Dual-Cell HSDPA (withdrawn TR 25.825 v100). / Text3: 25.101, 25.104, 25.133, 25.141, 25.211, 25.212, 25.213, 25.214, 25.215, 25.306, 25.308, 25.321, 25.331, 25.423, 25.433

| ID | WBS | Task | Duration | Start | Finish | Complete | Baseline start | Baseline finish | Baseline duration | Constraint | Resources | Work | Actual work | Text1 | Text6 | Text8 | Text2 | Text4 | Text7 | Text11 |
| --- | --- | --- | --- | --- | --- | --- | --- | --- | --- | --- | --- | --- | --- | --- | --- | --- | --- | --- | --- | --- |
| 1739 | 544 | **Rel-8 RAN improvements - UE Conformance Testing** | 602d? | 2008-05-30 A | 2010-09-17 A | 100% | 2008-05-30 | 2010-09-17 | 602d? |  | R5 | 29391.2h | 29391.2h | RANimp-UEConTest | Rel-8 | Ingbert |  |  |  |  |
| 1740 | 544.1 | Conformance Test Aspects – Combination of 64QAM and MIMO for HSDPA (FDD) | 322d? | 2008-09-12 A | 2009-12-04 A | 100% | 2008-09-12 | 2009-12-04 | 322d? | finish no earlier than 2009-12-04 | R5 | 2576h | 2576h | RANimp-UEConTest_64QamMimoHsdpa | Rel-8 | Ingbert | PCG-21 | Ericsson | RP-41 | RP-091058 |
| 1741 | 544.2 | Conformance Test Aspects – Improved L2 for uplink | 341d? | 2008-05-30 A | 2009-09-18 A | 100% | 2008-05-30 | 2009-09-18 | 341d? | finish no earlier than 2009-09-18 | R5 | 2728h | 2728h | RANimp-UEConTest_UplinkL2dataRates | Rel-8 | Ingbert | PCG-21 | Ericsson | RP-40 | RP-090712 |
| 1742 | 544.3 | Conformance Test Aspects – 1.28 Mcps TDD Improved L2 support for high data rates | 342d? | 2009-05-29 A | 2010-09-17 A | 100% | 2009-05-29 | 2010-09-17 | 342d? | finish no earlier than 2010-09-17 | R5 | 2736h | 2736h | RANimp-UEConTest_ImprovedL2LCRTDD | Rel-8 | Ingbert | PCG-23 | CATT | RP-44 | RP-100737 |
| 1743 | 544.4 | Conformance Test Aspects – 64QAM for 1.28 Mcps TDD HSDPA | 261d? | 2008-05-30 A | 2009-05-29 A | 100% | 2008-05-30 | 2009-05-29 | 261d? | finish no earlier than 2009-05-29 | R5 | 2088h | 2088h | RANimp-UEConTest_64Qam1.28TDD | Rel-8 | Ingbert | PCG-21 | ZTE | RP-40 | RP-090415 |
| 1744 | 544.5 | Conformance Test Aspects – Dual-Cell HSDPA operation on adjacent carriers | 391d? | 2008-12-05 A | 2010-06-04 A | 100% | 2008-12-05 | 2010-06-04 | 391d? | finish no earlier than 2010-06-04 | R5 | 3128h | 3128h | RANimp-UEConTest_DCHSDPA | Rel-8 | Ingbert | PCG-22 | Qualcomm | RP-42 | RP-100479 |
| 1745 | 544.6 | Conformance Test Aspects – Enhanced Uplink for CELL_FACH State in FDD | 326d? | 2009-03-06 A | 2010-06-04 A | 100% | 2009-03-06 | 2010-06-04 | 326d? | finish no earlier than 2010-06-04 | R5 | 2608h | 2608h | RANimp-UEConTest_EnhancedRACHCellFACHState | Rel-8 | Ingbert | PCG-22 | Nokia | RP-43 | RP-100483 |
| 1746 | 544.7 | Conformance Test Aspects – Receiver Type3i | 196d? | 2009-03-06 A | 2009-12-04 A | 100% | 2009-03-06 | 2009-12-04 | 196d? | finish no earlier than 2009-12-04 | R5 | 1568h | 1568h | RANimp-UEConTest_ReceiverType3i | Rel-8 | Ingbert | PCG-22 | Qualcomm | RP-43 | RP-091066 |
| 1747 | 544.8 | Conformance Test Aspects – Enhanced CELL_FACH State in LCR TDD | 341d? | 2009-05-30 A | 2010-09-17 A | 100% | 2009-05-30 | 2010-09-17 | 341d? | finish no earlier than 2010-09-17 | R5 | 2728h | 2728h | RANimp-UEConTest_EnhancedCellFACHStateLCRTDD | Rel-8 | Ingbert | PCG-23 | CATT | RP-44 | RP-100735 |
| 1748 | 544.9 | Conformance Test Aspects – Continuous Connectivity for packet data users for 1.28 Mcps TDD | 261d? | 2009-09-18 A | 2010-09-17 A | 100% | 2009-09-18 | 2010-09-17 | 261d? | finish no earlier than 2010-09-17 | R5 | 2088h | 2088h | RANimp-UEConTest_CPCLCRTDD | Rel-8 | Ingbert | PCG-23 | ZTE | RP-45 | RP-100739 |
| 1749 | 544.10 | Conformance Test Aspects – MIMO for 1.28 Mcps TDD | 186d? | 2009-09-18 A | 2010-06-04 A | 100% | 2009-09-18 | 2010-06-04 | 186d? | finish no earlier than 2010-06-04 | R5 | 1488h | 1488h | RANimp-UEConTest_MIMOLCRTDD | Rel-8 | Ingbert | PCG-23 | ZTE | RP-45 | RP-100660 |
| 1750 | 544.11 | Conformance Test Aspects – HS-DSCH Serving Cell Change Enhancements | 131d? | 2009-09-18 A | 2010-03-19 A | 100% | 2009-09-18 | 2010-03-19 | 131d? | finish no earlier than 2010-03-12 | R5 | 1048h | 1048h | HSDSCH_UEConTest | Rel-8 | Ingbert | PCG-23 | Qualcomm | RP-45 | RP-100077 |
| 1751 | 545 | 3.84 Mcps TDD MBSFN Integrated Mobile Broadcast | 395d? | 2007-06-04 A | 2008-12-05 A | 100% | 2007-06-04 | 2008-12-05 | 395d? |  | R1 | 3160h | 3160h | MBSFN-DOB | Rel-8 | Patrick |  | Ericsson |  | RP-080218 |
| 1752 | 546 | Conformance Test Aspects – 3.84 Mcps TDD MBSFN Integrated Mobile Broadcast | 211d? | 2009-05-30 A | 2010-03-19 A | 100% | 2009-05-30 | 2010-03-19 | 211d? | finish no earlier than 2010-03-19 | R5 | 1688h | 1688h | MBSFN_IMB_UEConTest | Rel-8 | Ingbert | PCG-23 | IPwireless | RP-44 | RP-100070 |
| 1753 | 547 | **GERAN support for GERAN - 3G Long Term Evolution interworking** | 1365d? | 2006-09-08 A | 2011-11-25 A | 100% | 2006-09-08 | 2011-11-25 | 1365d? |  | GP,G1,C1,G3new | 37200h | 37200h | GELTE | Rel-8 | Paolo |  | Nokia, Nokia Siemens Networks |  |  |
| 1754 | 547.1 | G1 part of GERAN support for GERAN - 3G Long Term Evolution interworking | 641d? | 2006-09-08 A | 2009-02-20 A | 100% | 2006-09-08 | 2009-02-20 | 641d? | finish no earlier than 2009-02-20 | G1 | 5128h | 5128h | GELTE | Rel-8 | Paolo |  | Nokia, Nokia Siemens Networks |  |  |
| 1755 | 547.2 | G2 part of GERAN support for GERAN - 3G Long Term Evolution interworking | 641d? | 2006-09-08 A | 2009-02-20 A | 100% | 2006-09-08 | 2009-02-20 | 641d? | finish no earlier than 2009-02-20 | G2 | 5128h | 5128h | GELTE | Rel-8 | Paolo |  | Nokia, Nokia Siemens Networks |  |  |
| 1756 | 547.3 | CT1 part of GERAN support for GERAN - 3G Long Term Evolution interworking | 641d? | 2006-09-08 A | 2009-02-20 A | 100% | 2006-09-08 | 2009-02-20 | 641d? | finish no earlier than 2009-02-20 | C1 | 5128h | 5128h | GELTE | Rel-8 | Paolo |  | Nokia, Nokia Siemens Networks |  |  |
| 1757 | 547.4 | Testing for GERAN support for GERAN - 3G Long Term Evolution interworking | 1363d? | 2006-09-08 A | 2011-11-25 A | 100% | 2006-09-08 | 2011-11-25 | 1363d? | finish no earlier than 2011-11-25 | G3new | 10896h | 10896h | GELTE | Rel-8 | Ingbert |  | Renesas Mobile |  |  |
| 1758 | 548 | U-TDOA Enhancement | 131d? | 2007-05-18 A | 2007-11-16 A | 100% | 2007-05-18 | 2007-11-16 | 131d? | finish no earlier than 2007-05-18 | GP | 1048h | 1048h | GUTEN | Rel-8 | Paolo |  | TruePosition |  |  |
| 1759 | 549 | **GAN Enhancements** | 604.2d? | 2007-05-15 A | 2009-09-04 A | 100% | 2007-05-15 | 2009-09-04 | 604.2d? |  | GP | 9432h | 9432h | GANENH | Rel-8 | Paolo |  | T-Mobile |  |  |
| 1760 | 549.1 | Update to GAN specifications | 126d? | 2007-08-31 A | 2008-02-22 A | 100% | 2007-08-31 | 2008-02-22 | 126d? | finish no earlier than 2008-02-22 | GP | 1008h | 1008h | GANENH-SPEC | Rel-8 | Paolo |  | T-Mobile |  |  |
| 1761 | 549.2 | Update TS 51.010 Mobile Station (MS) Conformance Specification for GAN Enhancements | 526d? | 2007-05-15 A | 2009-09-04 A | 100% | 2007-05-15 | 2009-09-04 | 526d? | finish no earlier than 2009-09-04 | G3new | 4208h | 4208h | GANENH-MStest | Rel-8 | Ingbert |  | T-Mobile |  |  |
| 1762 | 550 | **AoIP (A-interface over IP)** | 2335d? | 2000-01-03 A | 2008-12-11 A | 100% | 2000-01-03 | 2008-12-11 | 2335d? |  | GP,S4,C4,C1,C3 | 42500.1h | 42500.1h | AoIP | Rel-8 | Paolo | PCG-21 | China Mobile, Ericsson |  |  |
| 1763 | 550.1 | GERAN aspects of AoIP | 2321d? | 2000-01-03 A | 2008-11-21 A | 100% | 2000-01-03 | 2008-11-21 | 2321d? | finish no earlier than 2008-11-21 | GP | 18560h | 18560h | AoIP | Rel-8 | Paolo | PCG-21 | China Mobile, Ericsson | SP-40 |  |
| 1764 | 550.2 | Media Requirements for CS over IP based User Plane | 267d? | 2007-12-05 A | 2008-12-11 A | 100% | 2007-12-05 | 2008-12-11 | 267d? | finish no earlier than 2008-12-11 | S4 | 1996.09h | 1996.09h | AoIP-CSoIP | Rel-8 | Paolo | PCG-21 | China Mobile, Ericsson | SP-40 |  |

Notes:
- 1739: Linked to Feature UID_20029 (RANimp)
- 1740: RP#46 completed. Testing for UID_360013 / Text3: 34.108, 34.121-1, 34.121-2, 34.123-1, 34.123-2 / Text5: leif.mattisson@ericsson.com
- 1741: RP#45 completed. Testing for UID_370036 / Text3: 34.108, 34.123-1, 34.123-2, 34.123-3 / Text5: leif.mattisson@ericsson.com
- 1742: RP#49 completed. Testing for Rel-7 UID_340039 Improved L2 support for high data rates and Rel-8 UID_370036 Improved L2 for uplink / Text3: 34.108, 34.123-1, 34.123-2, 34.123-3 / Text5: Xiaozhong Chen (chenxiaozhong@datangmobile.cn)
- 1743: RP#44 completed. Testing for UID_380075 / Text3: 34.108, 34.122, 34.123-1, 34.123-2, 34.123-3 / Text5: ma.zijiang@zte.com.cn
- 1744: RP#48 completed. Testing for UID_400052 / Text3: 34.108, 34.121-1, 34.121-2, 34.123-1, 34.123-2, 34.123-3 / Text5: Shubhang Vora (svora@qualcomm.com)
- 1745: RP#48 completed. Testing for UID_370037 / Text3: 34.108, 34.121-1, 34.121-2, 34.123-1, 34.123-2, 34.123-3 / Text5: jarkko.hellsten@nokia.com
- 1746: RP#46 completed. Testing for Receiver Type3i in 25.101 UE radio Tx and Rx FDD / Text3: 34.108, 34.121-1, 34.121-2 / Text5: Ashok Kumar Narayanaswamy (anarayan@qualcomm.com)
- 1747: RP#49 completed. Testing for UID_380076 / Text3: 34.108, 34.123-1, 34.123-2, 34.123-3 / Text5: Xiaozhong Chen (chenxiaozhong@datangmobile.cn)
- 1748: RP#49 completed. Testing for UID_390028 / Text3: 34.108, 34.123-1, 34.123-2, 34.123-3 / Text5: huang.he4@zte.com.cn
- 1749: PR#48 completed. Testing for UID_400050 / Text3: 34.108, 34.122, 34.123-1, 34.123-2, 34.123-3 / Text5: huang.chun2@zte.com.cn
- 1750: RP#47 completed. Testing for UID_390030 / Text3: 34.108, 34.121-1, 34.121-2, 34.123-1, 34.123-2, 34.123-3 / Text5: Shubhang Vora (svora@qualcomm.com)
- 1751: RP#42 completed. WID updated RP-070493=>RP-081124 (changed WI title "MBSFN Downlink Optimized Broadcast (DOB) 3.84 Mcps TDD" => "3.84Mcps TDD MBSFN Integrated Mobile Broadcast"). / Text3: 25.102, 25.105, 25.123, 25.201, 25.221, 25.222, 25.223, 25.224, 25.304, 25.306, 25.331, 25.346, 25.402, 25.433 / Text5: Lars.Lindbom@ericsson.com
- 1752: RP#47 completed. Testing for Rel-8 MBSFN-DOB UID_360008 / Text3: 34.108, 34.122, 34.123-1, 34.123-2, 34.123-3 / Text5: Phil Young (pyoung@ipwireless.com)
- 1753: GP#41 completed. GP#52 completed MS conformance testing / Text3: 44.018, 44.060, 45.002, 45.008, 45.010, 48.008, 48.018, 51.010 / Text5: sergio.parolari@nsn.com, vlora.rexhepi@nokia.com
- 1754: GP#41 completed / Text3: 43.055, 43.129, 43.246, 45.002, 45.008, 45.010 / Text5: sergio.parolari@nsn.com, vlora.rexhepi@nokia.com
- 1755: GP#41 completed / Text3: 44.018, 44.060, 48.008, 48.018 / Text5: sergio.parolari@nsn.com, vlora.rexhepi@nokia.com
- 1756: - / Text3: 24.008 / Text5: sergio.parolari@nsn.com, vlora.rexhepi@nokia.com
- 1757: GP#52 completed / Text3: 51.010 / Text5: deepa.kamath@renesasmobile.com
- 1758: GP#36 completed U-TDOA (Uplink Time Difference of Arrival) / Text3: 43.059, 45.008, 48.071 / Text5: Terry Brooks (terri.brooks@trueposition.com)
- 1759: GP#37 completed. GP#43 completed Testing / Text5: mohammed.versi@t-mobile.com
- 1760: GP#37 completed / Text3: 43.318, 44.318 / Text5: mohammed.versi@t-mobile.com
- 1761: GP#43 completed / Text3: 51.010 / Text5: mohammed.versi@t-mobile.com
- 1762: GP#40/TSG#42 completed . Triggered by TR 43.903 Study on A-interface over IP (AINTIP) UID_50589. / Text5: wangshuaiyu@chinamobile.com, paul.schliwa-bertling@ericsson.com
- 1763: GP#40 completed. GP#39 updated WID GP-080901=>GP-081362. / Text3: 48.001, 48.002, 48.008, 48.020, 49.008, 48.103 / Text5: wangshuaiyu@chinamobile.com, paul.schliwa-bertling@ericsson.com
- 1764: SP#42 completed / Text3: 26.102, 26.103, 26.202 / Text5: Karl.Hellwig@Ericsson.com

| ID | WBS | Task | Type | Duration | Start | Finish | Complete | Baseline start | Baseline finish | Baseline duration | Constraint | Resources | Work | Actual work | Text1 | Text2 | Text4 | Text6 | Text7 | Text8 | Text3 | Text11 | Text12 | Text9 |
| --- | --- | --- | --- | --- | --- | --- | --- | --- | --- | --- | --- | --- | --- | --- | --- | --- | --- | --- | --- | --- | --- | --- | --- | --- |
| 1765 | 550.3 | **Core Network Impacts for A-Interface User Plane over IP** |  | 136d? | 2008-05-30 A | 2008-12-05 A | 100% | 2008-05-30 | 2008-12-05 | 136d? |  | C4,C1,C3 | 3264h | 3264h | AoIP-CN | PCG-21 | Ericsson | Rel-8 | CP-40 | Kimmo |  |  |  |  |
| 1766 | 550.3.1 | CT4 part of Core Network Impacts for A-Interface User Plane over IP |  | 136d? | 2008-05-30 A | 2008-12-05 A | 100% | 2008-05-30 | 2008-12-05 | 136d? | start no earlier than 2008-05-30 | C4 | 1088h | 1088h | AoIP-CN | PCG-21 | Ericsson | Rel-8 | CP-40 | Kimmo | 23.205, 23.153, 23.231, 29.232 |  |  |  |
| 1767 | 550.3.2 | CT1 part of Core Network Impacts for A-Interface User Plane over IP |  | 68d? | 2008-05-30 A | 2008-12-05 A | 100% | 2008-05-30 | 2008-12-05 | 68d? | finish no earlier than 2008-12-05 | C1 | 544h | 544h | AoIP-CN | PCG-21 | Ericsson | Rel-8 | CP-40 | Frederic | 23.009 |  |  |  |
| 1768 | 550.3.3 | CT3 part of Core Network Impacts for A-Interface User Plane over IP |  | 68d? | 2008-05-30 A | 2008-12-05 A | 100% | 2008-05-30 | 2008-12-05 | 68d? | finish no earlier than 2008-12-05 | C3 | 544h | 544h | AoIP-CN | PCG-21 | Ericsson | Rel-8 | CP-40 | Jiwan | 29.007 |  |  |  |
| 1769 | 551 | New multicarrier BTS class |  | 261d? | 2007-08-31 A | 2008-08-29 A | 100% | 2007-08-31 | 2008-08-29 | 261d? | finish no earlier than 2008-08-29 | G1 | 2088h | 2088h | MCBTS |  | Alcatel-Lucent | Rel-8 |  | Paolo | 45.005, 45.050, 51.021 |  |  |  |
| 1770 | 552 | **Support for Additional Navigation Satellite Systems (ANSS) for LCS** |  | 150d? | 2008-05-16 A | 2008-12-11 A | 100% | 2008-05-16 | 2008-12-11 | 150d? |  | S1,G2,R2 | 3384h | 3384h | ANSS |  | Qualcomm | Rel-8 |  | Paolo |  |  |  |  |
| 1771 | 552.1 | Stage 1 for ANSS for LCS |  | 1d? | 2008-12-11 A | 2008-12-11 A | 100% | 2008-12-11 | 2008-12-11 | 1d? | start no earlier than 2008-12-11 | S1 | 8h | 8h | ANSS | PCG-22 |  | Rel-8 | SP-42 | Alain | 22.071 |  |  |  |
| 1772 | 552.2 | GERAN2 part of Support for Additional Navigation Satellite Systems (ANSS) for LCS |  | 136d? | 2008-05-16 A | 2008-11-21 A | 100% | 2008-05-16 | 2008-11-21 | 136d? | start no earlier than 2008-05-16 | G2 | 1088h | 1088h | ANSS |  | Qualcomm | Rel-8 |  | Paolo | 43.059, 44.031, 49.031, 44.071, 48.031, 51.010 |  |  |  |
| 1773 | 552.3 | RAN2 part of Support for Additional Navigation Satellite Systems (ANSS) for LCS |  | 136d? | 2008-05-30 A | 2008-12-05 A | 100% | 2008-05-30 | 2008-12-05 | 136d? | finish no earlier than 2008-12-08 | R2 | 1088h | 1088h | RANimp-ANSS | PCG-21 | Qualcomm | Rel-8 | RP-40 | Joern | 25.305, 25.306, 25.331, 25.413, 25.423, 25.433, 25.453 | RP-080813 |  |  |
| 1774 | 553 | **Conformance testing for the Latency Reductions feature** |  | 532d? | 2008-02-22 A | 2010-03-05 A | 100% | 2008-02-22 | 2010-03-05 | 532d? |  | G1, G3new | 10592h | 10592h | CTLATRED | PCG-21 | Ericsson | Rel-8 |  | Paolo |  |  |  |  |
| 1775 | 553.1 | MS conformance testing for the Latency Reductions feature |  | 532d? | 2008-02-22 A | 2010-03-05 A | 100% | 2008-02-22 | 2010-03-05 | 532d? | finish no earlier than 2010-03-05 | G3new | 4248h | 4248h | CTLATRED-MStest | PCG-21 | Ericsson | Rel-8 |  | Ingbert | 51.010 |  |  |  |
| 1776 | 553.2 | BTS conformance testing for the Latency Reductions feature |  | 261d? | 2008-02-22 A | 2009-02-20 A | 100% | 2008-02-22 | 2009-02-20 | 261d? | finish no earlier than 2009-02-20 | G1 | 2088h | 2088h | CTLATRED-BTStest | PCG-21 | Ericsson | Rel-8 |  | Paolo | 51.021 |  |  |  |
| 1777 | 554 | MS conformance testing of changes introduced by WI "Support of Packet-switched Handover for GERAN A/Gb mode" |  | 196d? | 2008-02-22 A | 2008-11-21 A | 100% | 2008-02-22 | 2008-11-21 | 196d? | finish no earlier than 2008-11-21 | G3new | 1568h | 1568h | PSHCT-MStest | PCG-21 | Rohde & Schwarz | Rel-8 |  | Ingbert | 51.010 |  |  |  |
| 1778 | 555 | (Small) Technical Enhancements and Improvements for Rel-8 |  | 509d? | 2007-01-01 A | 2008-12-11 A | 100% | 2007-01-01 | 2008-12-11 | 509d? | finish no earlier than 2008-12-11 | All | 4072h | 4072h | TEI8 |  |  | Rel-8 |  | All |  |  |  |  |
| 1779 | 556 | (IETF) (Small) Technical Enhancements and Improvements for Rel-8 |  | 650d? | 2007-01-01 A | 2012-09-07 A | 100% | 2007-01-01 | 2012-09-07 | 650d? | finish no earlier than 2012-09-07 | C1-IETF | 5200h | 5200h | TEI8 | PCG-27 | Christer Holmberg | Rel-8 | CP-52 | Frederic | RFC 6714 (was draft-ietf-simple-msrp-cema) |  |  |  |
| 1780 | 557 | Test - (Small) Technical Enhancements and Improvements for Rel-8 |  | 672d? | 2007-03-07 A | 2010-12-24 A | 100% | 2007-03-07 | 2010-12-24 | 672d? | finish no earlier than 2010-12-24 | R5,G3new | 5376h | 5376h | TEI8_Test | PCG-21 |  | Rel-8 | RP-40 | Ingbert |  |  |  |  |
| 1781 | 558 | **Deleted - All-IP Network** |  | 448d? | 2004-06-28 A | 2006-03-15 A | 100% | 2004-06-28 | 2006-03-15 | 448d? |  | S1 | 7168h | 7168h | AIPN |  | NTT DoCoMo | Rel-8 |  | Alain |  |  | SP-38 |  |
| 1782 | 558.1 | Deleted - Stage 1 |  | 448d? | 2004-06-28 A | 2006-03-15 A | 100% | 2004-06-28 | 2006-03-15 | 448d? | finish no earlier than 2006-03-15 | S1 | 3584h | 3584h | AIPN |  | NTT DoCoMo | Rel-8 |  | Alain | 22.258 |  | SP-38 |  |
| 1783 | 559 | Deleted - was Rel-7 - LCS for 3GPP Interworking WLAN | milestone | 0d? | 2007-09-28 A | 2007-09-28 A | 100% | 2007-09-28 | 2007-09-28 | 0d? | start no earlier than 2007-09-28 | S2 |  |  | LCS4_IWLAN |  | LG Electronics | Rel-8 |  | Maurice | 23.234, 23.271, 23.167 |  | SP-35 |  |
| 1784 | 560 | Deleted - never approved- FBI Phase 2 | milestone | 0d | 2007-09-28 A | 2007-09-28 A | 100% | 2007-09-28 | 2007-09-28 | 0d | start no earlier than 2007-09-28 | S2 |  |  | FBI2 |  | Nokia Siemens Networks | Rel-8 |  | Maurice |  |  | SP-38 |  |
| 1785 | 561 | Deleted -Enhancements to BS30 Bearer service for Videotelephony | milestone | 0d? | 2007-03-15 A | 2007-03-15 A | 100% | 2007-03-15 | 2007-03-15 | 0d? | finish no earlier than 2007-03-15 | S1 |  |  | BS30 |  |  | Rel-8 |  | Alain | 22.002, 22.004, 22.101, 22.105, 24.008 |  | SP-38 |  |
| 1786 | 562 | Deleted - IMS Enhancements Rel-8 |  | 75d? | 2007-09-03 A | 2007-12-14 A | 100% | 2007-09-03 | 2007-12-14 | 75d? |  | S1 | 600h | 600h | IMS8 |  | Telecom Italia | Rel-8 | SP-37 | Alain |  |  | SP-38 |  |
| 1787 | 563 | **Deleted - Contact Manager Conformance Test specifications** |  | 471d? | 2008-06-02 A | 2010-03-19 A | 100% | 2008-06-02 | 2010-03-19 | 471d? |  | C6 | 11304h | 11304h | eUPHBOOK-Test | PCG-21 | Comprion, Gemalto | Rel-8 | CP-40 | Xavier |  |  | CP-47 | PCG-24 |
| 1788 | 563.1 | Deleted - Contact Manager for 3GPP UICC applications test specifications |  | 471d? | 2008-06-02 A | 2010-03-19 A | 100% | 2008-06-02 | 2010-03-19 | 471d? | finish no earlier than 2010-03-19 | C6 | 3768h | 3768h | eUPHBOOK-Test | PCG-21 | Comprion | Rel-8 | CP-40 | Xavier | 31.320 (external interface for communication with the ME) |  | CP-47 | PCG-24 |
| 1789 | 563.2 | Deleted - Contact Manager API for Java™ Card test specification |  | 471d? | 2008-06-02 A | 2010-03-19 A | 100% | 2008-06-02 | 2010-03-19 | 471d? | finish no earlier than 2010-03-19 | C6 | 3768h | 3768h | eUPHBOOK-Test | PCG-21 | Gemalto | Rel-8 | CP-40 | Xavier | 31.321 (internal interface (API)) |  | CP-47 | PCG-24 |
| 1790 | 564 | Deleted - MS conformance testing of Support of Conversational Services in A/Gb mode via the PS domain |  | 401d? | 2008-02-25 A | 2009-09-04 A | 100% | 2008-02-25 | 2009-09-04 | 401d? | finish no earlier than 2009-09-04 | G3new | 3208h | 3208h | SCSAGBCT-MStest | PCG-21 | Nokia | Rel-8 |  | Ingbert | 51.010 |  | GP-43 | PCG-23 |
| 1791 | 565 | Release 8 Studies |  | 1332d? | 2005-10-07 A | 2010-11-12 A | 100% | 2005-10-07 | 2010-11-12 | 1332d? | start no earlier than 2000-01-03 | CP,GP,RP,SP | 10656h | 10656h |  |  |  | Rel-8 |  | All |  |  |  |  |
| 1792 | 566 | Study on Customised Alerting Tone (CAT) Requirements |  | 245d? | 2005-10-07 A | 2006-09-14 A | 100% | 2005-10-07 | 2006-09-14 | 245d? | start no earlier than 2005-10-07 | S1 | 1960h | 1960h | FS_CAT |  | China Mobile | Rel-8 |  | Alain | 22.982 |  |  |  |
| 1793 | 567 | Study on Facilitating Machine to Machine Communication in GSM and UMTS (M2M) |  | 350d? | 2005-11-04 A | 2007-03-08 A | 100% | 2005-11-04 | 2007-03-08 | 350d? | finish no earlier than 2006-06-16 | S1 | 2800h | 2800h | FS_M2M |  | Siemens | Rel-8 |  | Alain | 22.868 |  |  |  |
| 1794 | 568 | Study on Network Composition |  | 526d? | 2005-12-07 A | 2007-12-12 A | 100% | 2005-12-07 | 2007-12-12 | 526d? | finish no earlier than 2006-09-27 | S1 | 4208h | 4208h | FS_NetComp |  | Nokia Siemens Networks | Rel-8 |  | Alain | 22.980 |  |  |  |
| 1795 | 569 | Study on Requirements of IMS Multimedia Conferencing |  | 330d? | 2006-06-08 A | 2007-09-12 A | 100% | 2006-06-08 | 2007-09-12 | 330d? | finish no earlier than 2007-03-21 | S1 | 2640h | 2640h | FS_IMSconf |  | China Mobile | Rel-8 |  | Alain | 22.948 |  |  |  |
| 1796 | 570 | Study on support of a Public Warning System |  | 140d? | 2007-09-03 A | 2008-03-14 A | 100% | 2007-09-03 | 2008-03-14 | 140d? |  | S1 | 1120h | 1120h | FS_PWS |  | T-Mobile | Rel-8 |  | Alain | 22.968 |  |  |  |
| 1797 | 571 | Study on Paging Permission with Access Control |  | 256d? | 2006-09-28 A | 2007-09-20 A | 100% | 2006-09-28 | 2007-09-20 | 256d? | finish no earlier than 2007-09-20 | S1 | 2048h | 2048h | FS_PPAC |  | NTT DoCoMo | Rel-8 |  | Alain | 22.908 |  |  |  |
| 1798 | 572 | Study on Non-3GPP access Network Selection Principles (NSP) |  | 392d? | 2006-12-06 A | 2008-06-05 A | 100% | 2006-12-06 | 2008-06-05 | 392d? | finish no earlier than 2007-11-19 | S1 | 3136h | 3136h | FS_N3GtoNSP |  | Telefónica O2 | Rel-8 |  | Alain | 22.912 |  |  |  |
| 1799 | 573 | Study on Value Added Services for Short Message Service |  | 263d? | 2006-12-06 A | 2007-12-07 A | 100% | 2006-12-06 | 2007-12-07 | 263d? | finish no earlier than 2007-12-07 | S1 | 2104h | 2104h | FS_VAS4SMS |  | China Mobile | Rel-8 |  | Alain | 22.942 |  |  |  |
| 1800 | 574 | Study on Service continuity between mobile and WLAN networks |  | 262d? | 2006-12-06 A | 2007-12-06 A | 100% | 2006-12-06 | 2007-12-06 | 262d? | finish no earlier than 2008-12-25 | S1 | 2096h | 2096h | FS_SMLSWLAN |  | NEC | Rel-8 |  | Alain | 22.937 |  |  |  |
| 1801 | 575 | Study on Services Alignment and Migration |  | 331d? | 2006-12-06 A | 2008-03-12 A | 100% | 2006-12-06 | 2008-03-12 | 331d? | finish no earlier than 2007-09-20 | S1 | 2648h | 2648h | FS_ServAl |  | Telefónica O2 | Rel-8 | SP-37 | Alain | 22.983 |  |  |  |

Notes:
- 1765: CP#42 completed. Updated WID CP-080278=>CP-080722 / Text5: philip.hodges@ericsson.com
- 1766: CP#42 completed. Updated WID CP-080278=>CP-080722 / Text5: philip.hodges@ericsson.com
- 1767: CP#42 completed. Updated WID CP-080278=>CP-080722 / Text5: philip.hodges@ericsson.com
- 1768: CP#42 completed. Updated WID CP-080278=>CP-080722 / Text5: philip.hodges@ericsson.com
- 1769: GP#39 completed / Text5: thomas.bitzer@alcatel-lucent.de
- 1770: GP#40 completed / Text5: Mungal Dhanda
- 1771: SP#42 completed by 22.071 CR0077
- 1772: GP#40 completed / Text5: Mungal Dhanda
- 1773: RP#42 WI closed at 95%. Considers Rel-9 performance requirements / Text5: Etienne Chaponniere (echaponn@qualcomm.com)
- 1774: GP#45 completed / Text5: mats.y.samuelsson@ericsson.com, hakan.e.grunditz@ericsson.com
- 1775: GP#45 completed / Text5: hakan.e.grunditz@ericsson.com
- 1776: GP#41 completed / Text5: mats.y.samuelsson@ericsson.com
- 1777: GP#40 completed / Text5: Franz.Segerer@ROHDE-SCHWARZ.COM
- 1778: SP#42 completed
- 1779: CP#57 completed / Text5: christer.holmberg@ericsson.com
- 1780: -
- 1781: SP#38 stopped. 25/07/08 Moved UID_31059 Study on All-IP Network (FS_AIPN/was AIPFS ) to Rel-7 out of the stopped Rel-8 Feature UID_31067 Deleted - All-IP Network (AIPN) / Text5: c.masyu@nttdocomo.co.jp
- 1782: 22.258 withdrawn, superseded by 22.278 (UID 320022). SP#38 stopped / Text5: c.masyu@nttdocomo.co.jp
- 1783: SP#35 stopped / Text5: dhshim@lge.com
- 1784: SP#38 stopped
- 1785: SP#38 stopped (no support) / Text5: andre.jarvis@three.co.uk
- 1786: SP#38 stopped
- 1787: CP#47 work stopped/abandoned / Text5: Udo Willenbrink, Jacques Seif
- 1788: CP#47 work stopped/abandoned / Text5: Udo Willenbrink (uwillenbrink@comprion.com )
- 1789: CP#47 work stopped/abandoned / Text5: jacques.seif@gemalto.com
- 1790: GP#43 work stopped/abandoned (completion 0%) / Text5: arsi.heino@nokia.com
- 1791: -
- 1792: Spin-off Rel-8 Feature Customized Alerting Tone (CAT) Service UID_340029 / Text5: Qing Huang (huangqing@chinamobile.com)
- 1793: SP#35 completed. Spin-off SA3 Study on Security Aspects of Remote Provisioning and Change of Subscription for M2M (UID_370053). SP#40 Spin-off new Feature UID_410030 (NIMTC) / Text5: Juergen Merkel
- 1794: SP#38 completed / Text5: Joerg Swetina (joerg.swetina@nw.neclab.eu)
- 1795: SP#37 completed. Spin-off New Feature UID_370026 Value-Added Services for Short Message Service (VAS4SMS) / Text5: Qing Huang (huangqing@chinamobile.com)
- 1796: SP#39 completed. Spin-off Rel-9 Feature UID_380057 (PWS) / Text5: mark.younge@t-mobile.com
- 1797: SP#37 completed. Spin-off new Feature UID_370084 (PPACR) / Text5: Katsuhiro NOGUCHI (noguchi@nttdocomo.co.jp)
- 1798: SP#38 completed. Spin-off New Feature UID_380062 (N3GTONSP). SP#40 WID updated SP-060930=>SP-080318. TR re-approved with new # 22.812=>22.912 / Text5: chris.friel@O2.com
- 1799: SP#38 completed. Spin-off New Feature UID_370026 (VAS4SM) / Text5: Qing Huang (huangqing@chinamobile.com)
- 1800: SP#38 completed / Text5: joerg.swetina@neclab.eu
- 1801: SP#39 completed. Spin-off Rel-9 Feature UID_330017 Services Alignment and Migration (ServAl) / Text5: chris.friel@O2.com

| ID | WBS | Task | Duration | Start | Finish | Complete | Baseline start | Baseline finish | Baseline duration | Constraint | Resources | Work | Actual work | Text1 | Text4 | Text5 | Text6 | Text8 | Text3 | Text2 | Text7 | Text11 | Text9 | Text12 |
| --- | --- | --- | --- | --- | --- | --- | --- | --- | --- | --- | --- | --- | --- | --- | --- | --- | --- | --- | --- | --- | --- | --- | --- | --- |
| 1802 | 576 | **Study on 3GPP System Architecture Evolution** | 1115d? | 2004-12-03 A | 2009-03-12 A | 100% | 2004-12-03 | 2009-03-12 | 1115d? |  | S2,S3 | 23456h | 23456h | FS_SAE | Vodafone | Chris Pudney | Rel-8 | Maurice |  |  |  |  |  |  |
| 1803 | 576.1 | Stage 2 Interim conclusion for RAN Work to start | 990d? | 2004-12-03 A | 2008-09-18 A | 100% | 2004-12-03 | 2008-09-18 | 990d? | finish no earlier than 2005-09-23 | S2 | 7920h | 7920h | FS_SAE | Vodafone | Chris Pudney | Rel-8 | Maurice | 23.882 |  |  |  |  |  |
| 1804 | 576.2 | Stage 2 study on 3GPP architectural development | 704d? | 2006-01-09 A | 2008-09-18 A | 100% | 2006-01-09 | 2008-09-18 | 704d? | finish no earlier than 2007-09-28 | S2 | 5632h | 5632h | FS_SAE | Vodafone | Chris Pudney | Rel-8 | Maurice | 23.882 |  |  |  |  |  |
| 1805 | 576.3 | Security study for Inter-access mobility between non-3GPP and 3GPP system | 334d? | 2007-09-03 A | 2009-03-12 A | 100% | 2007-09-03 | 2009-03-12 | 334d? | finish no earlier than 2009-03-12 | S3 | 2672h | 2672h | FS_SAE | Nokia | dajiang.zhang@nokia.com | Rel-8 | Dionisio | 33.821, 33.822 |  |  |  |  |  |
| 1806 | 577 | Study on Stage 2 aspects of IMS Service Brokering | 589d? | 2006-06-19 A | 2008-09-18 A | 100% | 2006-06-19 | 2008-09-18 | 589d? | finish no earlier than 2008-09-18 | S2 | 4712h | 4712h | FS_ISB_ST2 | Telcordia | raquel@research.telcordia.com | Rel-8 | Maurice | 23.810 |  |  |  |  |  |
| 1807 | 578 | Study on IMS utilizing multicast bearer services | 447d? | 2006-03-22 A | 2007-12-06 A | 100% | 2006-03-22 | 2007-12-06 | 447d? | finish no earlier than 2007-12-03 | S2 | 3576h | 3576h | FS_MLTICAST-IMS | Nokia Siemens Networks |  | Rel-8 | Maurice | 23.847 |  |  |  |  |  |
| 1808 | 579 | Study on Multimedia Session Continuity | 291d? | 2007-04-26 A | 2008-06-05 A | 100% | 2007-04-26 | 2008-06-05 | 291d? | finish no earlier than 2008-06-05 | S2 | 2328h | 2328h | FS_MMSC | LG Electronics |  | Rel-8 | Maurice | 23.893 |  |  |  |  |  |
| 1809 | 580 | **Study on centralized IMS service control** | 363d? | 2006-10-23 A | 2008-03-12 A | 100% | 2006-10-23 | 2008-03-12 | 363d? |  | S2,S1 | 7952h | 7952h | FS_ICS | Ericsson | peter.bleckert@ericsson.com | Rel-8 | Alain |  | PCG-21 | SP-38 |  |  |  |
| 1810 | 580.1 | Study on centralized IMS services requirements | 268d? | 2007-03-05 A | 2008-03-12 A | 100% | 2007-03-05 | 2008-03-12 | 268d? | start no earlier than 2007-03-05 | S1 | 2144h | 2144h | FS_ICS-S1 | NEC | joerg.swetina@neclab.eu | Rel-8 | Alain | 22.892 |  | SP-37 |  |  |  |
| 1811 | 580.2 | Study on centralized IMS services control | 363d? | 2006-10-23 A | 2008-03-12 A | 100% | 2006-10-23 | 2008-03-12 | 363d? | finish no earlier than 2008-02-21 | S2 | 2904h | 2904h | FS_IMS_CSC | Alcatel-Lucent | andy.bennett@alcatel-lucent.com | Rel-8 | Maurice | 23.892 |  |  |  |  |  |
| 1812 | 581 | Study on Architecture of IMS based Customized Alerting Tone (CAT) | 208d? | 2007-12-04 A | 2008-09-18 A | 100% | 2007-12-04 | 2008-09-18 | 208d? | finish no earlier than 2008-09-08 | S2 | 1664h | 1664h | FS_CAT-St2 | China Mobile | WANG, Jing (wangjing@chinamobilecom) | Rel-8 | Maurice | 23.872 | PCG-21 | SP-38 |  |  |  |
| 1813 | 582 | Study on Home (e)NodeB Security | 321d? | 2007-12-20 A | 2009-03-12 A | 100% | 2007-12-20 | 2009-03-12 | 321d? | finish no earlier than 2009-03-10 | S3 | 2568h | 2568h | FS_HNB_Sec | Huawei | yangyanmei@huawei.com | Rel-8 | Dionisio | 33.820 | PCG-21 | SP-38 |  |  |  |
| 1814 | 583 | Study on Transferring of emergency call data – in-band modem solution | 265d? | 2006-12-07 A | 2007-12-12 A | 100% | 2006-12-07 | 2007-12-12 | 265d? | finish no earlier than 2008-09-18 | S4 | 2120h | 2120h | eCALLIBMS | Airbiquity | lhong@airbiquity.com | Rel-8 | Paolo | 26.967 |  |  |  |  |  |
| 1815 | 584 | Study on Element Operations Systems Function (EOSF) definition | 266d? | 2007-06-07 A | 2008-06-12 A | 100% | 2007-06-07 | 2008-06-12 | 266d? | finish no earlier than 2008-12-11 | S5 | 2128h | 2128h | OAM7-NIM- EOSF | China Mobile | Li Jian (lijian@chinamobile.com) | Rel-8 | Dionisio | 32.819 |  |  |  |  |  |
| 1816 | 585 | Study on SA5 MTOSI XML Harmonization | 351d? | 2006-05-10 A | 2007-09-12 A | 100% | 2006-05-10 | 2007-09-12 | 351d? | finish no earlier than 2007-12-14 | S5 | 2808h | 2808h | OAM8-NIM-XML | Nortel | jduguay@nortel.com | Rel-8 | Dionisio | 32.818 |  |  |  |  |  |
| 1817 | 586 | Study on Common Profile Storage (CPS) Framework of User Data for network services and management | 244d? | 2006-07-03 A | 2007-06-07 A | 100% | 2006-07-03 | 2007-06-07 | 244d? | finish no earlier than 2007-06-07 | S5 | 1952h | 1952h | OAM7-CPS | T-Mobile | istvan.aba@t-mobile.at | Rel-8 | Dionisio | 32.808 |  |  |  |  |  |
| 1818 | 587 | Study on Management for LTE and SAE | 526d? | 2006-12-07 A | 2008-12-11 A | 100% | 2006-12-07 | 2008-12-11 | 526d? | finish no earlier than 2008-12-11 | S5 | 4208h | 4208h | FS_OAM_LTE_SAE | Ericsson | robert.petersen@ericsson.com | Rel-8 | Dionisio | 32.816 |  |  |  |  |  |
| 1819 | 588 | Study on Charging Aspects of 3GPP System Evolution | 179d? | 2007-04-02 A | 2007-12-06 A | 100% | 2007-04-02 | 2007-12-06 | 179d? | finish no earlier than 2007-12-06 | S5 | 1432h | 1432h | FS_SAEcharg | Nokia Siemens Networks | Gerald.Goermer@nsn.com | Rel-8 | Dionisio | 32.820 |  |  |  |  |  |
| 1820 | 589 | Study on AS-MRFC media server control protocol | 583d? | 2006-03-22 A | 2008-06-13 A | 100% | 2006-03-22 | 2008-06-13 | 583d? | finish no earlier than 2008-06-13 | C1 | 4664h | 4664h | MRFC | Hewlett-Packard | mark.syrett@hp.com | Rel-8 | Frederic | 24.880 |  |  |  |  |  |
| 1821 | 590 | Study on IMS Restoration Procedures | 310d? | 2007-03-26 A | 2008-05-30 A | 100% | 2007-03-26 | 2008-05-30 | 310d? | finish no earlier than 2008-05-30 | C4 | 2480h | 2480h | FS_IMS_RP | Ericsson | german.blanco@ericsson.com | Rel-8 | Kimmo | 23.820 |  |  |  |  |  |
| 1822 | 591 | Study on IMS Application Server Service Data Descriptions for AS interoperability | 261d? | 2007-09-14 A | 2008-09-12 A | 100% | 2007-09-14 | 2008-09-12 | 261d? | finish no earlier than 2008-09-12 | C4 | 2088h | 2088h | FS_IMS_ASIO | Alcatel-Lucent | Jean-Jacques Trottin | Rel-8 | Kimmo | 29.864 |  |  |  |  |  |
| 1823 | 592 | Study on Customized Alerting Tone (CAT) solution for voice and video call in CS domain | 261d? | 2007-09-14 A | 2008-09-12 A | 100% | 2007-09-14 | 2008-09-12 | 261d? |  | C4 | 626.4h | 626.4h | FS_CAT_VVC_CS | China Mobile | zhanghao@chinamobile.com | Rel-8 | Kimmo | 29.882 |  |  |  |  |  |
| 1824 | 593 | Study on InterWorking Function between MAP based and Diameter based interfaces | 266d? | 2007-11-30 A | 2008-12-05 A | 100% | 2007-11-30 | 2008-12-05 | 266d? | finish no earlier than 2008-12-05 | C4 | 2128h | 2128h | FS_MAP2Diam | Huawei | liming49985@huawei.com | Rel-8 | Kimmo | 29.805 | PCG-21 | CP-38 |  |  |  |
| 1825 | 594 | Study on Scope of future HSPA Evolution for 1.28 Mcps TDD | 186d? | 2007-09-14 A | 2008-05-30 A | 100% | 2007-09-14 | 2008-05-30 | 186d? | finish no earlier than 2008-05-30 | R1 | 1488h | 1488h | FS_RAN-LCRTDDHSPAEvo | RITT | Xu Fei | Rel-8 | Patrick | 25.824 |  | RP-37 | RP-080290 |  |  |
| 1826 | 595 | Study on Synchronized E-DCH for UTRA FDD | 126d? | 2007-09-14 A | 2008-03-07 A | 100% | 2007-09-14 | 2008-03-07 | 126d? | finish no earlier than 2008-03-14 | R1 | 1008h | 1008h | FS_RAN-UplinkSync | Nokia Siemens Networks | Karri.Ranta-aho@nsn.com | Rel-8 | Patrick | 25.823 |  | RP-37 | RP-080068 |  |  |
| 1827 | 596 | Study on Improved network controlled mobility between LTE and 3GPP2/mobile WiMAX radio technologies | 131d? | 2007-06-04 A | 2007-12-03 A | 100% | 2007-06-04 | 2007-12-03 | 131d? | finish no earlier than 2007-12-03 | R4 | 1048h | 1048h | FS_RAN-LTEmob | Motorola | hao.bi@Motorola.com | Rel-8 | Issam | 36.938 |  |  | RP-070827 |  |  |
| 1828 | 597 | Study on 3G Home NodeB/eNodeB | 325d? | 2007-03-05 A | 2008-05-30 A | 100% | 2007-03-05 | 2008-05-30 | 325d? | finish no earlier than 2008-05-30 | R4 | 2600h | 2600h | FS_RAN-HNBeNB | Motorola | howard.thomas@motorola.com | Rel-8 | Issam | 25.820 |  |  | RP-080289 |  |  |
| 1829 | 598 | Study on A-interface over IP | 126d? | 2007-08-31 A | 2008-02-22 A | 100% | 2007-08-31 | 2008-02-22 | 126d? | finish no earlier than 2008-02-22 | GP | 1008h | 1008h | AINTIP | China Mobile, Ericsson | paul.schliwa-bertling@ericsson.com | Rel-8 | Paolo | 43.903 |  |  |  |  |  |
| 1830 | 599 | Study on Multi-User Reusing-One-Slot | 782d? | 2007-11-16 A | 2010-11-12 A | 100% | 2007-11-16 | 2010-11-12 | 782d? | finish no earlier than 2010-11-12 | GP | 6248h | 6248h | MUROS | Nokia Siemens Networks | juergen.hofmann@nsn.com | Rel-8 | Paolo | 45.914 |  |  |  |  |  |
| 1831 | 600 | Study on Optimized Transmit Pulse Shape for Downlink EGPRS2-B | 657d? | 2007-11-16 A | 2010-05-21 A | 100% | 2007-11-16 | 2010-05-21 | 657d? | finish no earlier than 2010-05-27 | G1 | 5248.44h | 5248.44h | WIDER | Research In Motion, Nokia Siemens Networks | jdwyer@RIM.COM and eddie.riddington@nsn.com | Rel-8 | Paolo | 45.913 |  |  |  |  |  |
| 1832 | 601 | Deleted - Study on Mobility between 3GPP-WLAN Interworking and 3GPP Systems | 393d? | 2007-03-20 A | 2008-09-18 A | 100% | 2007-03-20 | 2008-09-18 | 393d? | finish no earlier than 2008-09-18 | S2 | 3144h | 3144h | FS_SM3GWLAN | Orange |  | Rel-8 | Maurice | withdrawn 23.827 |  |  |  | PCG-21 | SP-41 |
| 1833 | 602 | Deleted - equals 340035 -FS on Service continuity between mobile and WLAN networks | 75d? | 2007-09-03 A | 2007-12-14 A | 100% | 2007-09-03 | 2007-12-14 | 75d? | finish no earlier than 2007-12-14 | S1 | 600h | 600h | FSSCMobToW | BT | mike.meyerstein@bt.com | Rel-8 | Alain | 22.937 |  | SP-37 |  | PCG-21 | SP-39 |
| 1834 | 603 | Deleted - Study on Evaluation of LCS Control Plane Solution for EPS | 100d? | 2008-01-14 A | 2008-05-30 A | 100% | 2008-01-14 | 2008-05-30 | 100d? | finish no earlier than 2009-03-20 | S2 | 800h | 800h | FS_LCS_EPS | SiRF |  | Rel-8 | Maurice | 23.891 |  | SP-38 |  | PCG-21 | SP-40 |
| 1835 | 604 | Deleted - Study on HS-PDSCH serving cell change enhancements | 60d? | 2007-12-17 A | 2008-03-07 A | 100% | 2007-12-17 | 2008-03-07 | 60d? | finish no earlier than 2008-06-12 | R4 | 480h | 480h | FS_RAN-HSPDSCH | Qualcomm |  | Rel-8 | Issam | none | PCG-21 | RP-38 | RP-080070 | PCG-21 | RP-39 |
| 1836 | 605 | Deleted - Study on Dual-Cell HSDPA operation | 261d? | 2007-08-15 A | 2009-03-06 A | 100% | 2007-08-15 | 2009-03-06 | 261d? | finish no earlier than 2009-03-06 | R1 | 2088h | 2088h | FS_RAN-DCHS | Qualcomm | Josef Blanz | Rel-8 | Patrick | withdrawn 25.825 v100 | PCG-21 | RP-39 | RP-090066 | PCG-22 | RP-43 |
| 1837 | 606 | Release 7 Features | 679d? | 2005-05-02 A | 2007-12-06 A | 100% | 2005-05-02 | 2007-12-06 | 679d? | start no earlier than 2000-01-01 | CP,GP,RP,SP | 5432h | 5432h |  |  |  | Rel-7 | All |  |  |  |  |  |  |

Notes:
- 1802: SP#43 completed
- 1803: SP#41 completed
- 1804: SP#41 completed
- 1805: SP#43 completed
- 1806: SP#41 completed. No spin-off activity proposed. [Note: IMS Service Brokering enhancements UID_31088 moved back from R8 to R7 to give a home to 22228CR0036_(Rel-7)_S1-051232. Hence, Rel-7 ISB has Stage 1 only (and is misaligned with Rel-7 Stages 2/3.]
- 1807: SP#38 completed
- 1808: SP#40 completed
- 1809: SP#39 completed
- 1810: SP#39 completed
- 1811: SP#39 completed
- 1812: SP#41 completed as Rel-8
- 1813: SP#43 completed. Linked to RAN4 Study on 3G Home NodeB/eNodeB (UID_350039) and to SA5 Study on Self-Organizing Networks (SON) related OAM interfaces for Home NodeB (UID_360007)
- 1814: SP#38 completed. Spin-off WID UID_34042 (eCall_Phase2)
- 1815: SP#40 completed. WID updated SP-050608=>SP-070307
- 1816: SP#37 completed. WID updated SP-050295=>SP-070305
- 1817: SP#36 completed. Spin-off New Feature UID_400034 User Data Convergence (UDC)
- 1818: SP#42 completed
- 1819: SP#38 completed
- 1820: CP#40 completed. Spin-off New Feature UID_380035 (MRFC_TS)
- 1821: CP#40 completed. Spin-off WID UID_400012 (IMS_RP)
- 1822: CP#41 completed. Linked to SA5 Study on Common Profile Storage framework UID_320006. Spin-off WID UID_410003 (IMS_ASIO)
- 1823: CP#41 completed. Spin-off WID under Feature CAT UID_340029
- 1824: CP#42 completed. Spin-off implementation Building Block UID_410007 (MAP2Diam) under the SAES Feature UID_320005
- 1825: RP#40 completed
- 1826: RP#39 completed
- 1827: RP#38 completed
- 1828: RP#40 completed
- 1829: GP#37 completed. Spin-off implementation Feature AoIP (A-interface over IP) UID_50591
- 1830: GP#48 completed as Rel-8. Spin-off implementation WI UID_420002 VAMOS (Voice services over Adaptive Multi-user channels on One Slot)
- 1831: GP#46 completed
- 1832: SP#41 stopped. Draft TR 23.827 content implemented in TS 23.327.
- 1833: SP#39 stopped
- 1834: SP#40 spin-off Feature UID_400038 (LCS_CPS_EPS). SP#40 FS stopped
- 1835: RP#39 stopped (no TR produced). Spin-off HS-DSCH Serving Cell Change Enhancements (UID_39003)
- 1836: RP#43 stopped (draft TR 25.825 v100 withdrawn). Conclusions in RP-090318 (RAN1 findings of the UTRA Multi-Carrier Evolution study). RP#42 New WI approved on Dual-Cell HSDPA operation on adjacent carriers (UID_400052)
- 1837: -

| ID | WBS | Task | Type | Duration | Start | Finish | Complete | Baseline start | Baseline finish | Baseline duration | Constraint | Resources | Work | Actual work | Text1 | Text4 | Text5 | Text6 | Text8 | Text12 | Text11 | Text7 | Text2 |
| --- | --- | --- | --- | --- | --- | --- | --- | --- | --- | --- | --- | --- | --- | --- | --- | --- | --- | --- | --- | --- | --- | --- | --- |
| 1838 | 607 | **Identification of Communication Services in IMS** |  | 620d? | 2005-05-02 A | 2007-09-14 A | 100% | 2005-05-02 | 2007-09-14 | 620d? |  | S2,S1,C1,S5 | 13016h | 13016h | ServID | Ericsson | stephen.terrill@ericsson.com | Rel-7 | Maurice |  |  |  |  |
| 1839 | 607.1 | TR on ServID |  | 232d? | 2005-05-02 A | 2006-03-21 A | 100% | 2005-05-02 | 2006-03-21 | 232d? | finish no earlier than 2006-03-20 | S2 | 1856h | 1856h | ServID | Ericsson | stephen.terrill@ericsson.com | Rel-7 | Maurice |  |  |  |  |
| 1840 | 607.2 | Stage 1,2 of ServID |  | 144d? | 2005-11-11 A | 2006-05-31 A | 100% | 2005-11-11 | 2006-05-31 | 144d? | start no earlier than 2005-11-11 | S1,S2 | 1152h | 1152h | ServID | Ericsson | stephen.terrill@ericsson.com | Rel-7 | Maurice |  |  |  |  |
| 1841 | 607.3 | Stage 3 of ServID |  | 250d? | 2006-03-31 A | 2007-03-15 A | 100% | 2006-03-31 | 2007-03-15 | 250d? | finish no earlier than 2007-03-15 | C1 | 2000h | 2000h | ServID | Ericsson | christer.holmberg@ericsson.com | Rel-7 | Frederic |  |  |  |  |
| 1842 | 607.4 | Charging of ServID |  | 381d? | 2006-03-31 A | 2007-09-14 A | 100% | 2006-03-31 | 2007-09-14 | 381d? | finish no earlier than 2007-09-14 | S5 | 3048h | 3048h | ServID | Orange | alain.bibas@orange-ft.com | Rel-7 | Dionisio |  |  |  |  |
| 1843 | 608 | **Supporting Globally Routable User Agent URIs in IMS** |  | 415d? | 2005-11-14 A | 2007-06-15 A | 100% | 2005-11-14 | 2007-06-15 | 415d? |  | S2,S1,C1 | 7760h | 7760h | GRUU | Research In Motion | Adrian Buckley (abuckley@rim.com) | Rel-7 | Maurice |  |  |  |  |
| 1844 | 608.1 | Deleted - TR on GRUU |  | 219d? | 2005-11-14 A | 2006-09-14 A | 100% | 2005-11-14 | 2006-09-14 | 219d? | finish no earlier than 2006-09-14 | S2 | 1752h | 1752h | GRUU | Research In Motion | Adrian Buckley (abuckley@rim.com) | Rel-7 | Maurice | SP-32 |  |  |  |
| 1845 | 608.2 | Stage 1,2 of GRUU |  | 65d? | 2006-07-03 A | 2006-09-29 A | 100% | 2006-07-03 | 2006-09-29 | 65d? | start no earlier than 2006-07-03 | S1,S2 | 520h | 520h | GRUU | Research In Motion | Adrian Buckley (abuckley@rim.com) | Rel-7 | Maurice |  |  |  |  |
| 1846 | 608.3 | Stage 3 of GRUU |  | 271d? | 2006-06-02 A | 2007-06-15 A | 100% | 2006-06-02 | 2007-06-15 | 271d? | finish no earlier than 2007-06-15 | C1 | 2168h | 2168h | GRUU | CableLabs | Bernie McKibben (b.mckibben@cablelabs.com) | Rel-7 | Frederic |  |  |  |  |
| 1847 | 609 | **Multimedia Telephony Service for IMS** |  | 357d? | 2006-02-01 A | 2007-06-15 A | 100% | 2006-02-01 | 2007-06-15 | 357d? |  | S1,C1,S4 | 8976h | 8976h | MTSI | Ericsson | peter.bleckert@ericsson.com | Rel-7 | Alain |  |  |  |  |
| 1848 | 609.1 | Stage 1 of MTSI |  | 173d? | 2006-02-01 A | 2006-09-29 A | 100% | 2006-02-01 | 2006-09-29 | 173d? | start no earlier than 2006-02-01 | S1 | 1384h | 1384h | MTSI-REQ | Ericsson | peter.bleckert@ericsson.com | Rel-7 | Alain |  |  |  |  |
| 1849 | 609.2 | Stage 3 of MTSI |  | 330d? | 2006-03-10 A | 2007-06-14 A | 100% | 2006-03-10 | 2007-06-14 | 330d? | finish no earlier than 2007-06-15 | C1 | 2640h | 2640h | MTSI | Ericsson | christer.holmberg@ericsson.com | Rel-7 | Frederic |  |  |  |  |
| 1850 | 609.3 | Media handling and interaction in MTSI |  | 262d? | 2006-03-15 A | 2007-03-15 A | 100% | 2006-03-15 | 2007-03-15 | 262d? | finish no earlier than 2007-03-15 | S4 | 2096h | 2096h | MTSI-MHI | Ericsson | olle.franceschi@ericsson.com | Rel-7 | Paolo |  |  |  |  |
| 1851 | 609.4 | Deleted - duplicates UID7039 - IMS Multimedia Telephony Service | milestone | 0d? | 2007-06-15 A | 2007-06-15 A | 100% | 2007-06-15 | 2007-06-15 | 0d? | start no earlier than 2007-06-15 | S1 |  |  | MMTEL | Ericsson | peter.bleckert@ericsson.com | Rel-7 | Alain | SP-32 |  |  |  |
| 1852 | 610 | Multimedia Telephony Service for IMS (MTSI) - UE Conformance Testing |  | 387d | 2007-09-19 A | 2009-03-12 A | 100% | 2007-09-19 | 2009-03-12 | 387d | finish no earlier than 2009-03-13 | R5 | 1664h | 1664h | MTSI-UEConTest | Ericsson, Motorola | Leif.Mattisson@ericsson.com, Jacob.John@motorola.com | Rel-7 | Ingbert |  | RP-090056 |  |  |
| 1853 | 611 | TISPAN requirements for Multimedia Telephony with PSTN/ISDN simulation services |  | 58d? | 2007-09-18 A | 2007-12-06 A | 100% | 2007-09-18 | 2007-12-06 | 58d? | start no earlier than 2007-09-18 | S1 | 464h | 464h | TMMTEL7 |  |  | Rel-7 | Alain |  |  | SP-37 |  |
| 1854 | 612 | **Maintenance of TISPAN release 1 common IMS** |  | 180d? | 2007-07-02 A | 2008-03-07 A | 100% | 2007-07-02 | 2008-03-07 | 180d? |  | S2 | 3520h | 3520h | MCIMSTR1 | Ericsson | Raymond Forbes | Rel-7 | Maurice |  |  | SP-38 | PCG-21 |
| 1855 | 612.1 | SA1 aspects of MCIMSTR1 |  | 58d? | 2007-09-18 A | 2007-12-06 A | 100% | 2007-09-18 | 2007-12-06 | 58d? | finish no earlier than 2007-12-06 | S1 | 464h | 464h | MCIMSTR1-S1 | Telecom Italia | Marco.DeLuca1@telecomitalia.it | Rel-7 | Alain |  |  | SP-38 | PCG-21 |
| 1856 | 612.2 | SA2 aspects of MCIMSTR1 |  | 58d? | 2007-09-18 A | 2007-12-06 A | 100% | 2007-09-18 | 2007-12-06 | 58d? | finish no earlier than 2007-12-06 | S2 | 464h | 464h | MCIMSTR1-S2 | Ericsson | Raymond Forbes | Rel-7 | Maurice |  |  | SP-38 | PCG-21 |
| 1857 | 612.3 | SA1,SA2 part of Maintenance of TISPAN release 1 common IMS |  | 114d? | 2007-07-02 A | 2007-12-06 A | 100% | 2007-07-02 | 2007-12-06 | 114d? | finish no earlier than 2007-12-06 | S2,S1 | 912h | 912h | IMS_Comm_Mtce7 | BT, Ericsson | Dick Knight, Raymond Forbes | Rel-7 | Maurice |  |  | SP-38 | PCG-21 |
| 1858 | 612.4 | Maintenance of TISPAN R1 |  | 86d? | 2007-11-09 A | 2008-03-07 A | 100% | 2007-11-09 | 2008-03-07 | 86d? | start no earlier than 2007-11-09 | C1,C3,C4 | 688h | 688h | MAINT_R1 | Alcatel-Lucent | Keith Drage (drage@alcatel-lucent.com) | Rel-7 | Frederic |  |  | CP-38 | PCG-21 |
| 1859 | 613 | **PS domain and IMS impacts for supporting IMS Emergency calls** |  | 2934d? | 2000-09-18 A | 2011-12-09 A | 100% | 2000-09-18 | 2011-12-09 | 2934d? |  | S2,S1,C1,C4,IETF | 66749.8h | 66749.8h | EMC1 | Siemens | Rainer Liebhart | Rel-7 | Maurice |  |  |  |  |
| 1860 | 10.1.1 | Service Requirements for IP-based emergency calls |  | 985d | 2000-09-18 A | 2004-06-25 A | 100% | 2000-09-18 | 2004-06-25 | 985d | finish no earlier than 2004-06-25 | S1 | 7880h | 7880h | EMC1 | Siemens | Rainer Liebhart | Rel-7 | Alain |  |  |  |  |
| 1861 | 613.2 | Study on Stage 2 for IMS-level solution |  | 668d? | 2003-02-26 A | 2005-09-16 A | 100% | 2003-02-26 | 2005-09-16 | 668d? | finish no earlier than 2005-09-16 | S2 | 5344h | 5344h | EMC1 | Siemens | Rainer Liebhart | Rel-7 | Maurice |  |  |  |  |
| 1862 | 613.3 | Study on Stage 2 for GPRS-level solution |  | 301d? | 2004-10-14 A | 2005-12-08 A | 100% | 2004-10-14 | 2005-12-08 | 301d? | finish no earlier than 2005-12-08 | S2 | 2408h | 2408h | EMC1 | Siemens | Rainer Liebhart | Rel-7 | Maurice |  |  |  |  |
| 1863 | 613.4 | Stage 2 Specification Phase - IMS-level |  | 200d? | 2005-09-05 A | 2006-06-09 A | 100% | 2005-09-05 | 2006-06-09 | 200d? | finish no earlier than 2006-06-09 | S2 | 1600h | 1600h | EMC1 | Siemens | Rainer Liebhart | Rel-7 | Maurice |  |  |  |  |
| 1864 | 613.5 | Deleted - Stage 2 Specification Phase - GPRS-level | milestone | 0d? | 2007-03-02 A | 2007-03-02 A | 100% | 2007-03-02 | 2007-03-02 | 0d? | start no earlier than 2007-03-02 | S2 |  |  | EMC1 | Siemens | Rainer Liebhart | Rel-7 | Maurice | SP-32 |  |  |  |

Notes:
- 1838: WID approved SP#28. WID updated SP#32
- 1839: - / Text3: 23.816
- 1840: - / Text3: 22.228, 23.228, 23.203
- 1841: CP#32 approved WID / Text3: 23.218, 24.229
- 1842: - / Text3: 32.260, 32.298, 32.299
- 1843: SP#29 approved WID
- 1844: Abandoned
- 1845: SP#29 approved WID / Text3: 22.228, 23.228, 23.218, 24.229
- 1846: CP#32 approved WID / Text3: 24.229
- 1847: -
- 1848: - / Text3: 22.173
- 1849: - / Text3: 24.173
- 1850: - / Text3: 26.114
- 1851: - / Text3: 22.173
- 1852: RP#43 completed. Linked UID_7038 (MTSI) / Text3: 34.123-1, 34.123-2, 34.123-3, 34.229-1, 34.229-2
- 1853: - / Text3: 22.273 (EI 181 002 maintenance)
- 1854: - / Text3: http://www.3gpp.org/specs/TISPAN-IMS-ansfer.htm
- 1855: - / Text3: 22.173, 22.273
- 1856: - / Text3: 23.406, 23.417, 23.508,23.509, 23.511
- 1857: SP#38 completed / Text3: 22.173, 22.273, 22.401, 23.406, 23.417, 23.508, 23.509, 23.511
- 1858: CP#39 completed / Text3: 24.404, 24.405, 24.406, 24.407, 24.408, 24.410, 24.411, 24.416, 29.421, 24.423, 24.428, 24.429, 29.433, 24.441, 24.403, 29.427, 24.430, 29.412
- 1859: -
- 1860: - / Text3: 22.101
- 1861: - / Text3: 23.867
- 1862: - / Text3: 23.867
- 1863: - / Text3: 23.167, 23.228, 23.060, 23.002, 23.271
- 1864: -

| ID | WBS | Task | Type | Duration | Start | Finish | Complete | Baseline start | Baseline finish | Baseline duration | Constraint | Resources | Work | Actual work | Text1 | Text4 | Text5 | Text6 | Text8 | Text3 | Text2 | Text7 | Text12 | Text10 | Text11 |
| --- | --- | --- | --- | --- | --- | --- | --- | --- | --- | --- | --- | --- | --- | --- | --- | --- | --- | --- | --- | --- | --- | --- | --- | --- | --- |
| 1865 | 10.1 | **Emergency Call Enhancements for IP& PS Based Calls – stage 3** |  | 1549d? | 2006-01-09 A | 2011-12-09 A | 100% | 2006-01-09 | 2011-12-09 | 1549d? |  | C1,C4,IETF | 26045.8h | 26045.8h | EMC1 | Ericsson | alf.heidermark@ericsson.com | Rel-7 | Frederic |  |  |  |  |  |  |
| 1866 | 10.1.2 | CT1 IMS aspects to support IMS Emergency sessions |  | 350.82d | 2006-01-09 A | 2007-06-15 A | 100% | 2006-01-09 | 2007-06-15 | 350.82d | finish no earlier than 2007-06-15 | C1 | 2806.57h | 2806.57h | EMC1 | Ericsson | alf.heidermark@ericsson.com | Rel-7 | Frederic | 24.229 |  |  |  |  |  |
| 1867 | 613.6.2 | (IETF) CT1 IMS aspects to support IMS Emergency sessions |  | 452d? | 2006-01-09 A | 2011-12-09 A | 100% | 2006-01-09 | 2011-12-09 | 452d? | finish no earlier than 2011-12-09 | C1-IETF | 3608h | 3608h | EMC1 | Keith Drage |  | Rel-7 | Frederic | RFC 6442 (was draft-ietf-sipcore-location-conveyance) | PCG-27 | CP-52 |  |  |  |
| 1868 | 10.1.2 | Deleted - CT3 IMS aspects to support IMS Emergency sessions |  | 95d | 2006-05-08 A | 2006-09-15 A | 100% | 2006-05-08 | 2006-09-15 | 95d | finish no earlier than 2006-09-15 | C3 | 760h | 760h | EMC1 | Ericsson | alf.heidermark@ericsson.com | Rel-7 | Jiwan | 29.163 |  |  | CP-33 |  |  |
| 1869 | 10.1.5 | Deleted - CT3 PS domain aspects to support IMS Emergency sessions |  | 95d | 2006-05-08 A | 2006-09-15 A | 100% | 2006-05-08 | 2006-09-15 | 95d | start no earlier than 2006-05-08 | C3 | 760h | 760h | EMC1 | Ericsson | alf.heidermark@ericsson.com | Rel-7 | Jiwan | 29.061 |  |  | CP-33 |  |  |
| 1870 | 10.1.5 | CT1 PS domain aspects to support IMS Emergency sessions |  | 349.9d | 2006-01-09 A | 2007-06-15 A | 100% | 2006-01-09 | 2007-06-15 | 349.9d | finish no earlier than 2007-06-15 | C1 | 2799.2h | 2799.2h | EMC1 | Ericsson | alf.heidermark@ericsson.com | Rel-7 | Frederic | 24.008, 24.234 |  |  |  |  |  |
| 1871 | 10.1.5 | CT4 PS domain aspects to support IMS Emergency sessions |  | 365d | 2006-01-09 A | 2007-06-01 A | 100% | 2006-01-09 | 2007-06-01 | 365d | finish no earlier than 2007-06-01 | C4 | 2920h | 2920h | EMC1-GPRSc4 | Ericsson | alf.heidermark@ericsson.com | Rel-7 | Kimmo | 29.060 |  |  |  |  |  |
| 1872 | 614 | IMS Support of Conferencing |  | 355d? | 2005-11-04 A | 2007-03-15 A | 100% | 2005-11-04 | 2007-03-15 | 355d? | finish no earlier than 2007-03-15 | C1 | 2840h | 2840h | IMSconf | Alcatel-Lucent | Keith Drage (drage@alcatel-lucent.com) | Rel-7 | Frederic | 24.147, 24.229 |  |  |  |  |  |
| 1873 | 615 | Performance Characterization of VoIMS over HSDPA\EUL channels |  | 713d? | 2005-03-15 A | 2007-12-06 A | 100% | 2005-03-15 | 2007-12-06 | 713d? | finish no earlier than 2007-12-06 | S4 | 5704h | 5704h | VoIMS-PCVoIMS | Alcatel-Lucent | mcgowan@alcatel-lucent.com | Rel-7 | Paolo | 26.935 |  |  |  |  |  |
| 1874 | 616 | **WLAN-UMTS Interworking Phase 2** |  | 371d? | 2004-01-05 A | 2005-06-07 A | 100% | 2004-01-05 | 2005-06-07 | 371d? |  | S1,S2 | 3888h | 3888h | WLAN2 | Telenor | frederic.paint@telenor.com | Rel-7 | Alain | 33.234 (SP-36 SA3 CRs approved) |  |  |  |  |  |
| 1875 | 616.1 | Stage 1 on Session Continuity |  | 115d? | 2004-01-05 A | 2004-06-11 A | 100% | 2004-01-05 | 2004-06-11 | 115d? | start no earlier than 2004-01-05 | S1 | 920h | 920h | WLAN-SC |  |  | Rel-7 | Alain | 22.234 |  |  |  | SP-24 |  |
| 1876 | 616.2 | Stage 2 on Session Continuity: covered by SAE | milestone | 0d? | 2005-06-07 A | 2005-06-07 A | 100% | 2005-06-07 | 2005-06-07 | 0d? | finish no earlier than 2005-06-07 | S2 |  |  | WLAN-SC |  |  | Rel-7 | Maurice |  |  |  |  |  |  |
| 1877 | 617 | **WLAN Interworking – Private Network access from WLAN 3GPP IP Access** |  | 252d? | 2005-10-10 A | 2006-09-26 A | 100% | 2005-10-10 | 2006-09-26 | 252d? |  | S2,C1,C3,C4 | 8936h | 8936h | WLANPNA | NEC | Toshiyuki Tamura (tamurato@aj.jp.nec.com) | Rel-7 | Maurice |  |  |  |  |  |  |
| 1878 | 617.1 | WLAN-PNA - Stage 2 |  | 185d? | 2005-10-10 A | 2006-06-23 A | 100% | 2005-10-10 | 2006-06-23 | 185d? | start no earlier than 2005-10-10 | S2 | 1480h | 1480h | WLANPNA-st2 | NEC | Toshiyuki Tamura (tamurato@aj.jp.nec.com) | Rel-7 | Maurice | 23.234, 33.234 |  |  |  |  |  |
| 1879 | 617.2 | **WLAN-PNA - Stage 3** |  | 170d? | 2006-02-01 A | 2006-09-26 A | 100% | 2006-02-01 | 2006-09-26 | 170d? |  | C1,C3,C4 | 5440h | 5440h | WLANPNA-st3 | NEC |  | Rel-7 | Frederic |  |  |  |  |  |  |
| 1880 | 617.2.1 | CT1 aspets for WLAN-PNA |  | 170d? | 2006-02-01 A | 2006-09-26 A | 100% | 2006-02-01 | 2006-09-26 | 170d? | start no earlier than 2006-02-01 | C1 | 1360h | 1360h | WLANPNA-st3 | NEC |  | Rel-7 | Frederic | 24.234 |  |  |  |  |  |
| 1881 | 617.2.2 | CT3 aspets for WLAN-PNA |  | 170d? | 2006-02-01 A | 2006-09-26 A | 100% | 2006-02-01 | 2006-09-26 | 170d? | start no earlier than 2006-02-01 | C3 | 1360h | 1360h | WLANPNA-st3 | NEC |  | Rel-7 | Jiwan | 29.161 |  |  |  |  |  |
| 1882 | 617.2.3 | Deleted - CT4 aspets for WLAN-PNA |  | 170d? | 2006-02-01 A | 2006-09-26 A | 100% | 2006-02-01 | 2006-09-26 | 170d? | start no earlier than 2006-02-01 | C4 | 1360h | 1360h | WLANPNA-st3 | NEC |  | Rel-7 | Kimmo | 29.234 |  |  | CP-32 |  |  |
| 1883 | 618 | **Enhancements to support QoS provisioning over 3GPP/WLAN Interworking** |  | 520d? | 2005-03-14 A | 2007-03-09 A | 100% | 2005-03-14 | 2007-03-09 | 520d? |  | S2,C4,C1 | 8360h | 8360h | WLANQOS | Samsung |  | Rel-7 | Maurice |  |  |  |  |  |  |
| 1884 | 618.1 | Deleted - TR on support of QoS on WLAN |  | 232d? | 2005-03-14 A | 2006-01-31 A | 100% | 2005-03-14 | 2006-01-31 | 232d? | start no earlier than 2005-03-14 | S2 | 1856h | 1856h | WLANQOS | Samsung |  | Rel-7 | Maurice | 23.836 |  |  | SP-32 |  |  |
| 1885 | 618.2 | Stage 2 on support of QoS over 3GPP/WLAN interworking |  | 108d? | 2006-02-01 A | 2006-06-30 A | 100% | 2006-02-01 | 2006-06-30 | 108d? | start no earlier than 2006-02-01 | S2 | 864h | 864h | WLANQOS | Samsung |  | Rel-7 | Maurice | 23.234 |  |  |  |  |  |
| 1886 | 618.3 | Stage 3 CT4 on support of QoS over 3GPP/WLAN Interworking |  | 121d? | 2006-09-22 A | 2007-03-09 A | 100% | 2006-09-22 | 2007-03-09 | 121d? | finish no earlier than 2007-03-09 | C4 | 968h | 968h | WLANQOS | Huawei | zhang.peng@huawei.com | Rel-7 | Kimmo | 29.234, 23.008 |  |  |  |  |  |
| 1887 | 618.4 | Stage 3 CT1 on support of QoS over 3GPP/WLAN Interworking |  | 64d? | 2006-09-04 A | 2006-11-30 A | 100% | 2006-09-04 | 2006-11-30 | 64d? | finish no earlier than 2006-11-30 | C1 | 512h | 512h | WLANQOS | Huawei | zhang.peng@huawei.com | Rel-7 | Frederic | 24.234 |  |  |  |  |  |
| 1888 | 619 | **Location Services enhancements** |  | 906d? | 2004-06-28 A | 2007-12-17 A | 100% | 2004-06-28 | 2007-12-17 | 906d? |  | S1,S2,GP,C4,R2 | 46933.6h | 46933.6h | LCS3 |  |  | Rel-7 | Alain |  |  |  |  |  |  |
| 1889 | 619.1 | Stage 2 for LCS3 (including IMS emergency location aspects) |  | 446d? | 2004-12-31 A | 2006-09-15 A | 100% | 2004-12-31 | 2006-09-15 | 446d? | finish no earlier than 2006-09-15 | S2 | 3568h | 3568h | LCS3 | SiRF | brodilitz@sirf.com | Rel-7 | Maurice | 23.271 |  |  |  |  |  |
| 1890 | 619.2 | LCS Enhancements related to Location-Based Services |  | 695d? | 2005-01-03 A | 2007-08-31 A | 100% | 2005-01-03 | 2007-08-31 | 695d? | finish no earlier than 2007-08-31 | GP | 5560h | 5560h | LCS3-LBS | SiRF | kjudge@sirf.com | Rel-7 | Paolo | 43.059, 44.031, 48.008, 49.031 |  |  |  |  |  |
| 1891 | 619.3 | CT4 aspects for LCS UEPos-LBS |  | 240d? | 2006-01-02 A | 2006-12-01 A | 100% | 2006-01-02 | 2006-12-01 | 240d? | finish no earlier than 2006-12-01 | C4 | 1920h | 1920h | LCS3-UEPos-LBS | SiRF | brodilitz@sirf.com | Rel-7 | Kimmo | 24.030, 24.080, 29.002 |  |  |  |  |  |
| 1892 | 619.4 | UE positioning - Velocity |  | 394d? | 2005-03-15 A | 2006-09-15 A | 100% | 2005-03-15 | 2006-09-15 | 394d? | finish no earlier than 2006-09-15 | R2 | 3152h | 3152h | LCS3-UEPos-Velocity | SiRF | BRodilitz@SiRF.com | Rel-7 | Joern | 25.305, 25.331, 25.410, 25.413, 25.453 |  |  |  |  | RP-060459 |
| 1893 | 619.5 | Inclusion of Uplink TDOA UE positioning method in the UTRAN specifications |  | 849d? | 2004-09-15 A | 2007-12-17 A | 100% | 2004-09-15 | 2007-12-17 | 849d? | finish no earlier than 2007-12-17 | R2 | 6792h | 6792h | LCS3-UEPos-UTDOA | TruePosition | Robert Gross (rgross@polariswireless.com) | Rel-7 | Joern | 25.305, 25.453, new TS 25.111 |  |  |  |  | RP-070797 |

Notes:
- 1865: -
- 1866: -
- 1867: CP#54 completed
- 1868: Cancelled for Rel-7 and there is no corresponding Rel-8 WI
- 1869: Cancelled for Rel-7 and there is no corresponding Rel-8 WI
- 1870: -
- 1871: -
- 1872: CP#35 revised WID
- 1873: -
- 1874: Created at SP#27 because of WLAN items belonging to Rel-7
- 1875: -
- 1876: -
- 1877: -
- 1878: Approved at SP#29
- 1879: Approved at CP#29
- 1880: Approved at CP#29
- 1881: Approved at CP#29
- 1882: CT4#31; no impacts identified, therefore completed. CP-32 stopped
- 1883: Moved from FS section Feb 06. SP-30 updated WID
- 1884: SP#32 stopped
- 1885: SP#30 updated WID
- 1886: CP#33 approved WID
- 1887: CP#33 approved WID
- 1888: -
- 1889: SP#27 approved WID
- 1890: -
- 1891: -
- 1892: -
- 1893: -

| ID | WBS | Task | Type | Duration | Start | Finish | Complete | Baseline start | Baseline finish | Baseline duration | Constraint | Resources | Work | Actual work | Text1 | Text4 | Text5 | Text6 | Text8 | Text12 | Text11 | Text2 | Text7 |
| --- | --- | --- | --- | --- | --- | --- | --- | --- | --- | --- | --- | --- | --- | --- | --- | --- | --- | --- | --- | --- | --- | --- | --- |
| 1894 | 619.6 | **LCS for 3GPP Interworking WLAN** |  | 700d? | 2004-06-28 A | 2007-03-02 A | 100% | 2004-06-28 | 2007-03-02 | 700d? |  | S1,S2 | 11901.6h | 11901.6h | LCS3-IWLAN | Telcordia | Mike Loushine | Rel-7 | Alain |  |  |  |  |
| 1895 | 619.6.1 | FS on 3GPP system to WLAN Interworking with LCS |  | 512.7d? | 2004-06-28 A | 2006-06-30 A | 100% | 2004-06-28 | 2006-06-30 | 512.7d? | finish no earlier than 2005-09-29 | S1 | 4101.6h | 4101.6h | LCS3-IWLAN-FSs1 | Telcordia | Mike Loushine | Rel-7 | Alain |  |  |  |  |
| 1896 | 619.6.2 | Deleted - Study of work on an LCS architecture for I-WLAN. |  | 180d? | 2006-06-26 A | 2007-03-02 A | 100% | 2006-06-26 | 2007-03-02 | 180d? | finish no earlier than 2007-03-02 | S2 | 1440h | 1440h | LCS3-IWLAN-FSs2 | LG Electronics | dhshim@lge.com ; phede@lge.com | Rel-7 | Maurice | SP-35 |  |  |  |
| 1897 | 619.6.3 | Stage 2 for LCS architecture for I-WLAN |  | 95d? | 2006-10-23 A | 2007-03-02 A | 100% | 2006-10-23 | 2007-03-02 | 95d? | finish no earlier than 2007-03-02 | S2 | 760h | 760h | LCS3-IWLAN | LG Electronics | dhshim@lge.com ; phede@lge.com | Rel-7 | Maurice |  |  |  |  |
| 1898 | 619.7 | Deleted - UE positioning Rel-7 |  | 849d? | 2004-09-15 A | 2007-12-17 A | 100% | 2004-09-15 | 2007-12-17 | 849d? |  | RP | 6792h | 6792h | LCS3-UEpos |  |  | Rel-7 | Joern | RP-38 |  |  |  |
| 1899 | 619.8 | Deleted - RAN2 aspects for LBS | milestone | 0d? | 2005-06-15 A | 2005-06-15 A | 100% | 2005-06-15 | 2005-06-15 | 0d? | start no earlier than 2005-06-15 | R2 |  |  | LCS3-UEPos-LBS | SiRF | BRodilitz@SiRF.com | Rel-7 | Joern | RP-31 |  |  |  |
| 1900 | 620 | **MBMS Enhancements** |  | 625d? | 2005-07-11 A | 2007-11-30 A | 100% | 2005-07-11 | 2007-11-30 | 625d? |  | S1,R1,C3 | 10844.6h | 10844.6h | MBMSE | China Mobile | liuhongyfw@chinamobile.com | Rel-7 | Alain |  |  |  |  |
| 1901 | 620.1 | Stage 1 of MBMSE |  | 109d? | 2005-07-11 A | 2005-12-08 A | 100% | 2005-07-11 | 2005-12-08 | 109d? | finish no earlier than 2005-12-08 | S1 | 872h | 872h | MBMSE | China Mobile | liuhongyfw@chinamobile.com | Rel-7 | Alain |  |  |  |  |
| 1902 | 620.2 | MBMS FDD Physical layer Enhancements |  | 117.29d? | 2006-12-15 A | 2007-06-04 A | 100% | 2006-12-15 | 2007-06-04 | 117.29d? | finish no earlier than 2007-06-04 | R1 | 938.32h | 938.32h | MBMSE-RANPhysFDD | Ericsson | Lars.Lindbom@ericsson.com | Rel-7 | Patrick |  | RP-070290 |  |  |
| 1903 | 620.3 | MBMS TDD Physical layer Enhancements |  | 117.29d? | 2006-12-15 A | 2007-06-04 A | 100% | 2006-12-15 | 2007-06-04 | 117.29d? | finish no earlier than 2007-06-04 | R1 | 938.32h | 938.32h | MBMSE-RANPhysTDD | IPWireless | Nicholas Anderson | Rel-7 | Patrick |  | RP-070291 |  |  |
| 1904 | 620.4 | MBMS Low Chip Rate TDD Physical Layer Enhancement |  | 127d? | 2007-03-16 A | 2007-09-10 A | 100% | 2007-03-16 | 2007-09-10 | 127d? | finish no earlier than 2007-09-10 | R1 | 1016h | 1016h | MBMSE-RANPhysLCRTDD | RITT | Lin Hui | Rel-7 | Patrick |  | RP-070292 |  |  |
| 1905 | 620.5 | MBMS Mz interface |  | 260d? | 2006-12-04 A | 2007-11-30 A | 100% | 2006-12-04 | 2007-11-30 | 260d? | finish no earlier than 2007-05-11 | C3 | 2080h | 2080h | MBMSMz | Huawei | Deng Tingting (ttdeng@huawei.com) | Rel-7 | Jiwan |  |  |  |  |
| 1906 | 621 | **MBMS - UE Conformance Testing** |  | 657d? | 2007-06-01 A | 2009-12-04 A | 100% | 2007-06-01 | 2009-12-04 | 657d? |  | R5 | 13848h | 13848h | MBMSE_UEConTest |  |  | Rel-7 | Ingbert |  |  | PCG-21 | SP-40 |
| 1907 | 621.1 | Conformance Test Aspects – MBMS TDD Physical layer Enhancements – MBSFN for HCR and VHCR TDD |  | 336d? | 2007-06-01 A | 2008-09-12 A | 100% | 2007-06-01 | 2008-09-12 | 336d? | start no earlier than 2007-06-01 | R5 | 2688h | 2688h | MBMSE-RANPhysTDD_UEConTest | IPWireless | tspeight@ipwireless.com | Rel-7 | Ingbert |  | RP-080541 |  |  |
| 1908 | 621.2 | Conformance Test Aspects – MBMS LCR TDD Physical Layer Enhancement |  | 342d? | 2008-05-30 A | 2009-09-18 A | 100% | 2008-05-30 | 2009-09-18 | 342d? | finish no earlier than 2009-09-18 | R5 | 2728h | 2728h | MBMSE-RANPhysLCRTDD_UEConTest | CATT | chenxiaozhong@datangmobile.cn | Rel-7 | Ingbert |  | RP-090715 | PCG-21 | RP-40 |
| 1909 | 621.3 | Conformance Test Aspects – MBSFN for FDD |  | 397d? | 2008-05-30 A | 2009-12-04 A | 100% | 2008-05-30 | 2009-12-04 | 397d? | finish no earlier than 2009-12-04 | R5 | 3176h | 3176h | MBMSE-UEConTest_RANPhysFDD | Huawei | Xiang Li (trica_li@huawei.com) | Rel-7 | Ingbert |  | RP-091214 | PCG-21 | RP-40 |
| 1910 | 622 | MBMS User Service Extensions |  | 392d? | 2005-12-07 A | 2007-06-07 A | 100% | 2005-12-07 | 2007-06-07 | 392d? | finish no earlier than 2007-06-07 | S4 | 3136h | 3136h | MBMSUSE | Ericsson | Thorsten.Lohmar@ericsson.com | Rel-7 | Paolo |  |  |  |  |
| 1911 | 623 | **Advanced Global Navigation Satellite System (AGNSS) concept** |  | 830d? | 2004-06-28 A | 2007-08-31 A | 100% | 2004-06-28 | 2007-08-31 | 830d? |  | S1,S2,GP,R2 | 16201.6h | 16201.6h | LCS3-AGNSS | Alcatel | Michel.monnerat@thalesaleniaspace.com | Rel-7 | Alain |  |  |  |  |
| 1912 | 623.1 | Stage 1/2 for Towards AGNSS Concept |  | 1d? | 2007-02-16 A | 2007-02-16 A | 100% | 2007-02-16 | 2007-02-16 | 1d? | start no earlier than 2007-02-16 | S1,S2 | 8h | 8h | AGNSS | Alcatel | richard.couty@space.alcatel.fr | Rel-7 |  |  |  |  |  |
| 1913 | 623.2 | Towards AGNSS Concept |  | 811.2d? | 2004-06-28 A | 2007-08-31 A | 100% | 2004-06-28 | 2007-08-31 | 811.2d? | finish no earlier than 2007-08-31 | GP | 6489.6h | 6489.6h | AGNSS-GP | Alcatel | richard.couty@space.alcatel.fr | Rel-7 | Paolo |  |  |  |  |
| 1914 | 623.3 | Global Navigation Satellite System (GNSS) in UTRAN |  | 383d? | 2005-12-15 A | 2007-06-04 A | 100% | 2005-12-15 | 2007-06-04 | 383d? | finish no earlier than 2007-06-04 | R2 | 3064h | 3064h | LCS3-GNSS-UTRAN | France Telecom | alain.abinakhoul@francetelecom.com | Rel-7 | Joern |  | RP-070482 |  |  |
| 1915 | 624 | A-GPS Minimum Performance |  | 351d? | 2006-04-28 A | 2007-08-31 A | 100% | 2006-04-28 | 2007-08-31 | 351d? | finish no earlier than 2007-08-31 | G1,G3 | 2808h | 2808h | GAGR | Spirent | richard.catmur@spirentcom.com | Rel-7 | Paolo |  |  |  |  |
| 1916 | 625 | **USSD message delivery and transfer to USIM** |  | 376d? | 2004-03-05 A | 2005-08-12 A | 100% | 2004-03-05 | 2005-08-12 | 376d? |  | S1,C6 | 2762.4h | 2762.4h | USSD-USIM | Axalto | Christophe Dubois (cdubois@axalto.com) | Rel-7 | Alain |  |  |  |  |
| 1917 | 625.1 | Stage 1 for USSD message delivery and transfer to USIM |  | 152d? | 2004-03-18 A | 2004-10-15 A | 100% | 2004-03-18 | 2004-10-15 | 152d? | start no earlier than 2004-03-18 | S1 | 1216h | 1216h | USSD-USIM | Axalto | Christophe Dubois (cdubois@axalto.com) | Rel-7 | Alain |  |  |  |  |
| 1918 | 625.2 | Alignment with requirements regarding USSD usage |  | 193.3d? | 2004-03-05 A | 2005-08-12 A | 100% | 2004-03-05 | 2005-08-12 | 193.3d? | finish no earlier than 2005-08-12 | C6 | 1546.4h | 1546.4h | USSD-USIM | Axalto | Christophe Dubois (cdubois@axalto.com) | Rel-7 | Xavier |  |  |  |  |

Notes:
- 1894: -
- 1895: - / Text3: new TR 22.935
- 1896: SP#41 TR withdrawn. All work transferred to specs / Text3: 23.837
- 1897: - / Text3: 23.234, 23.271, 23.167
- 1898: -
- 1899: - / Text3: 25.305, 25.331, 25.410, 25.413, 25.453
- 1900: -
- 1901: - / Text3: 22.146, 22.246, 22.228
- 1902: - / Text3: 25.211, 25.212, 25.213, 25.101, 25.104, 25.331, 25.433, 25.346, 25.306
- 1903: - / Text3: 25.346, 25.221, 25.222, 25.223, 25.224, 25.306, 25.331, 25.402, 25.433, 25.102, 25.105, 25.123
- 1904: - / Text3: 25.346, 25.221, 25.222, 25.223, 25.224, 25.306, 25.331, 25.402, 25.433, 25.102, 25.105, 25.123
- 1905: - / Text3: 29.061
- 1906: Linked to Rel-7 Feature UID_31084 (MBMSE)
- 1907: RP#41 completed / Text3: 34.108, 34.122, 34.123-1/2/3
- 1908: RP#45 completed / Text3: 34.108, 34.123-1
- 1909: RP#46 completed / Text3: 34.108, 34.109, 34.121-1, 34.121-2, 34.123-1, 34.123-2, 34.123-3
- 1910: - / Text3: 26.346, 26.946
- 1911: -
- 1912: - / Text3: 22.071, 23.271
- 1913: GP#36 completed / Text3: 43.030, 43.059, 44.031, 44.035, 44.071, 48.008, 48.018, 48.031, 49.031
- 1914: - / Text3: 25.305, 25.331, 25.306, 25.413, 25.423, 25.433, 25.453, 25.302, 25.215, 25.401, 25.402, 25.450, 25.452
- 1915: - / Text3: 45.005, 51.010
- 1916: -
- 1917: - / Text3: 22.090
- 1918: - / Text3: 31.111, 31.115, 31.130

| ID | WBS | Task | Type | Duration | Start | Finish | Complete | Baseline start | Baseline finish | Baseline duration | Constraint | Resources | Work | Actual work | Text1 | Text4 | Text5 | Text6 | Text8 | Text3 | Text12 |
| --- | --- | --- | --- | --- | --- | --- | --- | --- | --- | --- | --- | --- | --- | --- | --- | --- | --- | --- | --- | --- | --- |
| 1919 | 626 | **Combinational Services** |  | 296d? | 2005-01-17 A | 2006-03-06 A | 100% | 2005-01-17 | 2006-03-06 | 296d? |  | S1,S2,C1,S4 | 5176h | 5176h | CSICS | TeliaSonera | Robert.Frank@teliasonera.com | Rel-7 | Alain |  |  |
| 1920 | 626.1 | Stage 1 for CSICS |  | 104d? | 2005-01-17 A | 2005-06-09 A | 100% | 2005-01-17 | 2005-06-09 | 104d? | start no earlier than 2005-01-17 | S1 | 832h | 832h | CSICS | TeliaSonera | Robert.Frank@teliasonera.com | Rel-7 | Alain | 22.279 |  |
| 1921 | 626.2 | Stage 2 for CSICS |  | 130d? | 2005-01-17 A | 2005-07-15 A | 100% | 2005-01-17 | 2005-07-15 | 130d? | start no earlier than 2005-01-17 | S2 | 1040h | 1040h | CSICS | TeliaSonera | Robert.Frank@teliasonera.com | Rel-7 | Maurice | 23.279 |  |
| 1922 | 626.3 | Stage 3 for CSICS CN aspects |  | 221d? | 2005-05-02 A | 2006-03-06 A | 100% | 2005-05-02 | 2006-03-06 | 221d? | finish no earlier than 2006-03-06 | C1 | 1768h | 1768h | CSICS | Vodafone | peter.dawes@vodafone.com | Rel-7 | Frederic | 24.879, 24.279, 24.229, 24.008 |  |
| 1923 | 626.4 | Stage 3 for codec aspects |  | 192d? | 2005-03-15 A | 2005-12-07 A | 100% | 2005-03-15 | 2005-12-07 | 192d? | finish no earlier than 2005-12-07 | S4 | 1536h | 1536h | CSICS-Codec | Ericsson | Per.Frojdh@ericsson.com | Rel-7 | Paolo | 26.141, 26.235 |  |
| 1924 | 627 | **CAMEL Trunk Triggers** |  | 251d? | 2004-12-17 A | 2005-12-05 A | 100% | 2004-12-17 | 2005-12-05 | 251d? |  | S1,C4 | 6024h | 6024h | TTCAMEL | Nortel | Amar Deol (deola@nortelnetworks.com) | Rel-7 | Alain |  |  |
| 1925 | 627.1 | Stage 1 for CAMEL Trunk Triggers |  | 251d? | 2004-12-17 A | 2005-12-05 A | 100% | 2004-12-17 | 2005-12-05 | 251d? |  | S1 | 2008h | 2008h | TTCAMEL | Nortel | Amar Deol (deola@nortelnetworks.com) | Rel-7 | Alain | 22.078 |  |
| 1926 | 627.2 | CAMEL Trunk Originated Trigger Detection Points |  | 251d? | 2004-12-17 A | 2005-12-05 A | 100% | 2004-12-17 | 2005-12-05 | 251d? | start no earlier than 2004-12-17 | C4 | 2008h | 2008h | CamelR7 | Nortel | David Hutton (dhutton@nortel.com) | Rel-7 | Kimmo |  |  |
| 1927 | 628 | **IMS Service Brokering enhancements** |  | 69d? | 2005-12-07 A | 2006-03-13 A | 100% | 2005-12-07 | 2006-03-13 | 69d? |  | S1 | 1104h | 1104h | ISB | Telcordia | jbakker@telcordia.com | Rel-7 | Alain | 22.228 |  |
| 1928 | 628.1 | Stage 1 for ISB |  | 69d? | 2005-12-07 A | 2006-03-13 A | 100% | 2005-12-07 | 2006-03-13 | 69d? | finish no earlier than 2006-03-13 | S1 | 552h | 552h | ISB-s1 | Telcordia | jbakker@telcordia.com | Rel-7 | Alain | 22.228 |  |
| 1929 | 629 | **Enhancements of VGCS for public authority officials** |  | 731d? | 2004-08-27 A | 2007-06-15 A | 100% | 2004-08-27 | 2007-06-15 | 731d? |  | S1,C1,C4,G2 | 25920h | 25920h | EVGCS |  |  | Rel-7 | Alain | 43.068, 44.068, 24.008, 29.002 |  |
| 1930 | 629.1 | Stage 1 for Enhancements of VGCS for public authority officials | milestone | 0d? | 2004-08-27 A | 2004-08-27 A | 100% | 2004-08-27 | 2004-08-27 | 0d? | finish no earlier than 2004-08-27 | S1 |  |  | EVGCS | Siemens | Joerg Swetina (joerg.swetina@nw.neclab.eu) | Rel-7 | Alain | 42.068, 43.068 |  |
| 1931 | 629.2 | **Architecture and protocol aspects** |  | 731d? | 2004-08-27 A | 2007-06-15 A | 100% | 2004-08-27 | 2007-06-15 | 731d? |  | C1,C4 | 14904h | 14904h | EVGCS | Siemens | robert.zaus@nsn.com | Rel-7 | Frederic | 43.068, 44.068 |  |
| 1932 | 629.2.1 | CT1 aspects of EVGCS |  | 731d? | 2004-08-27 A | 2007-06-15 A | 100% | 2004-08-27 | 2007-06-15 | 731d? | finish no earlier than 2006-09-15 | C1 | 5848h | 5848h | EVGCS | Siemens | robert.zaus@nsn.com | Rel-7 | Frederic | 43.068, 44.068, 24.008 |  |
| 1933 | 629.2.2 | CT4 aspects of EVGCS |  | 401d? | 2004-08-27 A | 2006-03-10 A | 100% | 2004-08-27 | 2006-03-10 | 401d? | finish no earlier than 2006-03-10 | C4 | 3208h | 3208h | EVGCS | Siemens | robert.zaus@nsn.com | Rel-7 | Kimmo | 29.002 |  |
| 1934 | 629.3 | GERAN2 aspects of EVGCS |  | 646d? | 2004-08-27 A | 2007-02-16 A | 100% | 2004-08-27 | 2007-02-16 | 646d? | finish no earlier than 2007-02-16 | G2 | 5168h | 5168h | EVGCS | Siemens | kenneth.isaacs@roke.co.uk | Rel-7 | Gert |  |  |
| 1935 | 630 | **Improvements of VGCS for parallel use of services** |  | 523d? | 2005-03-15 A | 2007-03-15 A | 100% | 2005-03-15 | 2007-03-15 | 523d? |  | S1 | 12230.2h | 12230.2h | IVGCS |  |  | Rel-7 | Alain |  |  |
| 1936 | 630.1 | Service Requirements for VGCS improvements |  | 62d? | 2005-03-15 A | 2005-06-08 A | 100% | 2005-03-15 | 2005-06-08 | 62d? | finish no earlier than 2005-06-08 | S1 | 496h | 496h | IVGCS | T-Mobile | kurt.bischinger@t-mobile.at | Rel-7 | Alain | 42.068 |  |
| 1937 | 630.2 | Stage 2 modifications for VGCS improvements |  | 335d? | 2005-12-01 A | 2007-03-14 A | 100% | 2005-12-01 | 2007-03-14 | 335d? | start no earlier than 2005-12-01 | C1 | 2680h | 2680h | IVGCS | T-Mobile | kurt.bischinger@t-mobile.at | Rel-7 | Frederic | 43.068 |  |
| 1938 | 630.3 | **Protocol aspects** |  | 336d? | 2005-12-01 A | 2007-03-15 A | 100% | 2005-12-01 | 2007-03-15 | 336d? |  | C1 | 5376h | 5376h | IVGCS | T-Mobile | Dieter Jacobsohn | Rel-7 | Frederic | 44.068 |  |
| 1939 | 630.3.1 | CT1 aspects of IVGCS |  | 336d? | 2005-12-01 A | 2007-03-15 A | 100% | 2005-12-01 | 2007-03-15 | 336d? | finish no earlier than 2007-03-15 | C1 | 2688h | 2688h | IVGCS | T-Mobile |  | Rel-7 | Frederic | 43.068, 44.068 |  |
| 1940 | 630.3.2 | Deleted - CT4 aspects of IVGCS | milestone | 0d? | 2007-03-09 A | 2007-03-09 A | 100% | 2007-03-09 | 2007-03-09 | 0d? | finish no earlier than 2007-03-09 | C4 |  |  | IVGCS-St3-c4 | T-mobile |  | Rel-7 | Kimmo | 29.002 | CP-35 |
| 1941 | 631 | **Open Service Access (OSA) Rel-7** |  | 584d? | 2005-03-15 A | 2007-06-08 A | 100% | 2005-03-15 | 2007-06-08 | 584d? |  | S1,C5 | 17920h | 17920h | OSA7 | AePONA | eamonn.murray@aepona.com | Rel-7 | Alain |  |  |
| 1942 | 631.1 | Service Requirements for OSA Service Broker |  | 62d? | 2005-03-15 A | 2005-06-08 A | 100% | 2005-03-15 | 2005-06-08 | 62d? | finish no earlier than 2005-06-08 | S1 | 496h | 496h | OSA7-SB | AePONA | eamonn.murray@aepona.com | Rel-7 | Alain | 22.127 |  |
| 1943 | 631.2 | Stage 2 OSA API Service Brokering |  | 156d? | 2006-04-28 A | 2006-12-01 A | 100% | 2006-04-28 | 2006-12-01 | 156d? |  | C5 | 1248h | 1248h | OSA7-SB | AePONA | damian.oneill@aepona.com | Rel-7 | Kimmo | 23.198 |  |
| 1944 | 631.3 | Stage 3 OSA API Service Brokering |  | 156d? | 2006-04-28 A | 2006-12-01 A | 100% | 2006-04-28 | 2006-12-01 | 156d? | finish no earlier than 2006-12-01 | C5 | 1248h | 1248h | OSA7-SB | AePONA | damian.oneill@aepona.com | Rel-7 | Kimmo | 29.198-16 |  |

Notes:
- 1919: -
- 1920: -
- 1921: -
- 1922: -
- 1923: -
- 1924: -
- 1925: -
- 1926: -
- 1927: No CR submitted in rel-8 (according to CR database).
- 1928: No Rel-8 changes
- 1929: Moved from Rel-6 UID_50563 Enhancements of VGCS in public networks for communication of public authority officials
- 1930: Voice Group Call Service
- 1931: -
- 1932: -
- 1933: -
- 1934: -
- 1935: Voice Group Call Service
- 1936: -
- 1937: -
- 1938: Previous name (before CT32) was Architecture and protocol aspects
- 1939: -
- 1940: CT4#33 stage 2 solution is still open. ...
- 1941: -
- 1942: -
- 1943: -
- 1944: -

| ID | WBS | Task | Type | Duration | Start | Finish | Complete | Baseline start | Baseline finish | Baseline duration | Constraint | Resources | Work | Actual work | Text1 | Text3 | Text4 | Text5 | Text6 | Text8 | Text12 | Text11 |
| --- | --- | --- | --- | --- | --- | --- | --- | --- | --- | --- | --- | --- | --- | --- | --- | --- | --- | --- | --- | --- | --- | --- |
| 1945 | 631.4 | **Rel-7 OSA Stage 2/3 enhancements** |  | 291d? | 2006-04-28 A | 2007-06-08 A | 100% | 2006-04-28 | 2007-06-08 | 291d? |  | C5 | 10256h | 10256h | OSA7 | 29.198/9, 23.198 | AePONA | damian.oneill@aepona.com | Rel-7 | Kimmo |  |  |
| 1946 | 631.4.1 | Parlay X Message Broadcast Web Service |  | 156d? | 2006-04-28 A | 2006-12-01 A | 100% | 2006-04-28 | 2006-12-01 | 156d? | finish no earlier than 2006-12-01 | C5 | 1248h | 1248h | OSA7 | 29.199-15, 23.198 | ETRI |  | Rel-7 | Kimmo |  |  |
| 1947 | 631.4.2 | Parlay X Geocoding Web Service |  | 156d? | 2006-04-28 A | 2006-12-01 A | 100% | 2006-04-28 | 2006-12-01 | 156d? | finish no earlier than 2006-12-01 | C5 | 1248h | 1248h | OSA7 | 29.199-16, 23.198 | ETRI |  | Rel-7 | Kimmo |  |  |
| 1948 | 631.4.3 | Parlay X Application driven QoS Web Service |  | 226d? | 2006-04-28 A | 2007-03-09 A | 100% | 2006-04-28 | 2007-03-09 | 226d? | finish no earlier than 2007-03-09 | C5 | 1808h | 1808h | OSA7 | 29.199-17, 23.198 | BT |  | Rel-7 | Kimmo |  |  |
| 1949 | 631.4.4 | Parlay-X Device Capabilities and Configuration |  | 162d? | 2006-10-26 A | 2007-06-08 A | 100% | 2006-10-26 | 2007-06-08 | 162d? | finish no earlier than 2007-06-09 | C5 | 1296h | 1296h | OSA7 | 29.199-18, 23.198 | Telenor |  | Rel-7 | Kimmo |  |  |
| 1950 | 631.4.5 | Parlay-X Multimedia Streaming Session Management Web Service |  | 97d? | 2006-10-26 A | 2007-03-09 A | 100% | 2006-10-26 | 2007-03-09 | 97d? | start no earlier than 2006-10-26 | C5 | 776h | 776h | OSA7 | 29.199-19, 23.198 | Telenor |  | Rel-7 | Kimmo |  |  |
| 1951 | 631.4.6 | Parlay-X Multimedia Multicast Control Web Service |  | 97d? | 2006-10-26 A | 2007-03-09 A | 100% | 2006-10-26 | 2007-03-09 | 97d? | start no earlier than 2006-10-26 | C5 | 776h | 776h | OSA7 | 29.199-20, 23.198 | ETRI |  | Rel-7 | Kimmo |  |  |
| 1952 | 631.4.7 | OSA API Conference Call Control SCF |  | 97d? | 2006-10-26 A | 2007-03-09 A | 100% | 2006-10-26 | 2007-03-09 | 97d? | start no earlier than 2006-10-26 | C5 | 776h | 776h | OSA7 | 29.198-04-5, 23.198 | Ericsson |  | Rel-7 | Kimmo |  |  |
| 1953 | 632 | **Selective Disabling of UE Capabilities** |  | 624.36d? | 2005-01-24 A | 2007-06-15 A | 100% | 2005-01-24 | 2007-06-15 | 624.36d? |  | S1,S2,C1 | 12351.7h | 12351.7h | SDoUE |  | Motorola |  | Rel-7 | Alain |  |  |
| 1954 | 632.1 | Stage 1 of SDoUE |  | 393.6d? | 2005-01-24 A | 2006-12-08 A | 100% | 2005-01-24 | 2006-12-08 | 393.6d? | finish no earlier than 2006-12-08 | S1 | 3148.8h | 3148.8h | SDoUE-CR | 22.011 | Motorola |  | Rel-7 | Alain |  |  |
| 1955 | 632.2 | Deleted - TR on different possible architectures |  | 195d? | 2005-03-21 A | 2005-12-16 A | 100% | 2005-03-21 | 2005-12-16 | 195d? | finish no earlier than 2005-12-16 | S2 | 1560h | 1560h | SDoUE-FS | 23.805 abandonned at SP-30; descendant C1 24.305 | Vodafone | Gavin.Wong@vodafone.com | Rel-7 | Maurice | SP-30 |  |
| 1956 | 632.3 | Stage 3 of SDoUE |  | 331d? | 2006-03-10 A | 2007-06-15 A | 100% | 2006-03-10 | 2007-06-15 | 331d? | finish no earlier than 2007-06-15 | C1 | 2648h | 2648h | SDoUE | 24.305 | Ericsson | christian.herrero@ericsson.com | Rel-7 | Frederic |  |  |
| 1957 | 633 | **Network selection enhancements (NSP)** |  | 328d? | 2006-03-15 A | 2007-06-15 A | 100% | 2006-03-15 | 2007-06-15 | 328d? |  | S1 | 6320h | 6320h | NSP-CR | 22.101, 22.011, 23.122, 24.008, 25.304, 31.102, 45.008 | O2 | chris.friel@O2.com | Rel-7 | Alain |  |  |
| 1958 | 633.1 | Stage 1 of NSP |  | 191d? | 2006-03-15 A | 2006-12-06 A | 100% | 2006-03-15 | 2006-12-06 | 191d? | start no earlier than 2006-03-15 | S1 | 1528h | 1528h | NSP-TS | 22.101, 22.011, 23.122, 24.008, 25.304, 31.102, 45.008 | O2 | chris.friel@O2.com | Rel-7 | Alain |  |  |
| 1959 | 633.2 | Procedural aspects of NSP |  | 271d? | 2006-06-02 A | 2007-06-15 A | 100% | 2006-06-02 | 2007-06-15 | 271d? | finish no earlier than 2007-06-15 | C1 | 2168h | 2168h | NSP-CR | 23.122, 24.008, 31.102 | Motorola | Andrew Howell | Rel-7 | Frederic |  |  |
| 1960 | 634 | Network selection enhancements (NSP) - UE Conformance Testing |  | 396d? | 2007-06-01 A | 2008-12-05 A | 100% | 2007-06-01 | 2008-12-05 | 396d? | finish no earlier than 2008-12-05 | R5 | 3168h | 3168h | NSP-CR_UEConTest | 34.108, 34.123-1, 34.123-2, 34.123-3 | Nokia | jarkko.hellsten@nokia.com | Rel-7 | Ingbert |  | RP-080819 |
| 1961 | 635 | **Access Class Barring and Overload Protection** |  | 650d? | 2004-03-15 A | 2006-09-08 A | 100% | 2004-03-15 | 2006-09-08 | 650d? |  | S2,C1 | 3568h | 3568h | ACBOP | 23.898 | Vodafone | Chris Pudney | Rel-7 | Maurice |  |  |
| 1962 | 635.1 | TR on Stage 2 |  | 274d? | 2004-03-15 A | 2005-03-31 A | 100% | 2004-03-15 | 2005-03-31 | 274d? | finish no earlier than 2005-03-31 | S2 | 2192h | 2192h | ACBOP | 23.898 | NTT DoCoMo | Jean-Jacques Davidian (davidian@docomo.fr) | Rel-7 | Maurice |  |  |
| 1963 | 635.2 | Stage 3 CN aspects of ACBOP |  | 172d? | 2005-06-06 A | 2006-01-31 A | 100% | 2005-06-06 | 2006-01-31 | 172d? | start no earlier than 2005-06-06 | C1 | 1376h | 1376h | ACBOP | 24.008 |  |  | Rel-7 | Frederic |  |  |
| 1964 | 635.3 | Deleted - Potential impact on Iu interface Overload functionality | milestone | 0d? | 2004-03-15 A | 2004-03-15 A | 100% | 2004-03-15 | 2004-03-15 | 0d? | finish no earlier than 2004-03-15 | RP |  |  | ACBOP | 25.413 |  |  | Rel-7 | Issam | RP-25 |  |
| 1965 | 635.4 | Deleted - Extra ACBOP information in RAN | milestone | 0d? | 2004-03-15 A | 2004-03-15 A | 100% | 2004-03-15 | 2004-03-15 | 0d? | finish no earlier than 2004-03-15 | RP |  |  | ACBOP | 25.331 |  |  | Rel-7 | Issam | RP-25 |  |
| 1966 | 635.5 | Deleted - Extra ACBOP information in GERAN | milestone | 0d? | 2006-09-08 A | 2006-09-08 A | 100% | 2006-09-08 | 2006-09-08 | 0d? | start no earlier than 2006-09-08 | GP |  |  | ACBOP | 44.018 |  |  | Rel-7 | Paolo | RP-33 |  |
| 1967 | 636 | **System enhancements for Fixed Broadband access to IMS** |  | 2117d? | 2003-11-05 A | 2011-12-09 A | 100% | 2003-11-05 | 2011-12-09 | 2117d? |  | S2,S3,S5,C1,C3,C4,IETF | 75372.8h | 75372.8h | FBI |  |  |  | Rel-7 | Maurice |  |  |
| 1968 | 636.1 | **TISPAN Rel 1 related aspects** |  | 2117d? | 2003-11-05 A | 2011-12-09 A | 100% | 2003-11-05 | 2011-12-09 | 2117d? |  | S2,S3,C1,C3,C4,IETF | 57724.8h | 57724.8h | FBI-TIS1 |  |  |  | Rel-7 | Maurice |  |  |
| 1969 | 636.1.1 | Stage 2 of FBI for TISPAN R1 |  | 365d? | 2004-10-14 A | 2006-03-08 A | 100% | 2004-10-14 | 2006-03-08 | 365d? | start no earlier than 2004-10-14 | S2 | 2920h | 2920h | FBI-TIS1 |  |  |  | Rel-7 | Maurice |  |  |

Notes:
- 1945: CP#34 updated WID CP-060607=>CP-070200
- 1946: -
- 1947: -
- 1948: -
- 1949: -
- 1950: -
- 1951: -
- 1952: -
- 1953: Moved from FS section Feb 06
- 1954: Moved from FS section Feb 06
- 1955: Moved from FS section Feb 06. Abandoned at SP-30
- 1956: -
- 1957: -
- 1958: -
- 1959: -
- 1960: RP#42 completed. Testing for Feature UID_7041 (NSP-CR)
- 1961: -
- 1962: -
- 1963: -
- 1964: -
- 1965: -
- 1966: -
- 1967: -
- 1968: -
- 1969: -

| ID | WBS | Task | Duration | Start | Finish | Complete | Baseline start | Baseline finish | Baseline duration | Constraint | Resources | Work | Actual work | Text1 | Text4 | Text5 | Text6 | Text8 | Text2 | Text7 | Text12 |
| --- | --- | --- | --- | --- | --- | --- | --- | --- | --- | --- | --- | --- | --- | --- | --- | --- | --- | --- | --- | --- | --- |
| 1970 | 636.1.2 | **Protocol impact of FBI for TISPAN R1** | 2117d? | 2003-11-05 A | 2011-12-09 A | 100% | 2003-11-05 | 2011-12-09 | 2117d? |  | S3,C1,C3,C4,IETF | 41300.8h | 41300.8h | FBI-TIS1 | Siemens | peter.leis@nsn.com | Rel-7 | Frederic |  |  |  |
| 1971 | 636.1.2.1 | (IETF) CT aspects of FBI for TISPAN R1 | 1936.6d? | 2003-11-05 A | 2011-12-09 A | 100% | 2003-11-05 | 2011-12-09 | 1936.6d? | start no earlier than 2003-11-05 | C1-IETF, C3-IETF | 15492.8h | 15492.8h | FBI-TIS1 | Roland Jesske |  | Rel-7 | Frederic | PCG-27 | CP-52 |  |
| 1972 | 636.1.2.2 | CT1 aspects of FBI for TISPAN R1 | 802d? | 2003-11-05 A | 2006-11-30 A | 100% | 2003-11-05 | 2006-11-30 | 802d? | finish no earlier than 2006-11-30 | C1 | 6416h | 6416h | FBI-TIS1 | Siemens | peter.leis@nsn.com | Rel-7 | Frederic |  |  |  |
| 1973 | 636.1.2.3 | CT3 aspects of FBI for TISPAN R1 | 808d? | 2003-11-05 A | 2006-12-08 A | 100% | 2003-11-05 | 2006-12-08 | 808d? | finish no earlier than 2006-12-08 | C3 | 6464h | 6464h | FBI-TIS1 | Siemens | peter.leis@nsn.com | Rel-7 | Jiwan |  |  |  |
| 1974 | 636.1.2.4 | CT4 aspects of FBI for TISPAN R1 | 301d? | 2006-01-13 A | 2007-03-09 A | 100% | 2006-01-13 | 2007-03-09 | 301d? | finish no earlier than 2007-03-09 | C4 | 2408h | 2408h | FBI-TIS1-st3-c4 | Siemens | peter.leis@nsn.com | Rel-7 | Kimmo |  |  |  |
| 1975 | 636.1.3 | Security Enhancements for FBI | 118d? | 2005-06-28 A | 2005-12-08 A | 100% | 2005-06-28 | 2005-12-08 | 118d? | start no earlier than 2005-06-28 | S3 | 944h | 944h | FBI-ISE | Ericsson | Bengt.Sahlin@ericsson.com | Rel-7 | Dionisio |  |  |  |
| 1976 | 636.2 | **PacketCable Related aspects** | 291d? | 2006-02-01 A | 2007-03-14 A | 100% | 2006-02-01 | 2007-03-14 | 291d? |  | S2,S5,C1 | 5088h | 5088h | FBI-PCBL | CableLabs | Bernie McKibben (b.mckibben@cablelabs.com) | Rel-7 | Maurice |  |  |  |
| 1977 | 636.2.1 | Stage 1,2 of FBI for PacketCable | 228d? | 2006-02-01 A | 2006-12-15 A | 100% | 2006-02-01 | 2006-12-15 | 228d? | finish no earlier than 2006-12-15 | S2 | 1824h | 1824h | FBI-PCBL | CableLabs | Bernie McKibben (b.mckibben@cablelabs.com) | Rel-7 | Maurice |  |  |  |
| 1978 | 636.2.2 | Protocol impact of FBI for PacketCable | 228d? | 2006-05-01 A | 2007-03-14 A | 100% | 2006-05-01 | 2007-03-14 | 228d? | finish no earlier than 2007-03-15 | C1 | 1824h | 1824h | FBI-PCBL |  |  | Rel-7 | Frederic |  |  |  |
| 1979 | 636.2.3 | SA5 Charging aspects of FBI for PacketCable | 180d? | 2006-03-31 A | 2006-12-07 A | 100% | 2006-03-31 | 2006-12-07 | 180d? | finish no earlier than 2006-12-07 | S5 | 1440h | 1440h | FBI-PCBL-CH | CableLabs | Bernie McKibben (b.mckibben@cablelabs.com) | Rel-7 | Dionisio |  |  |  |
| 1980 | 637 | **Support of SMS over generic 3GPP IP access** | 696d? | 2004-10-14 A | 2007-06-14 A | 100% | 2004-10-14 | 2007-06-14 | 696d? |  | S2,C4,C1 | 12408h | 12408h | SMSIP | Huawei | zhangwenlin@huawei.com | Rel-7 | Maurice |  |  |  |
| 1981 | 637.1 | FS on SMSIP | 173d? | 2004-10-14 A | 2005-06-13 A | 100% | 2004-10-14 | 2005-06-13 | 173d? | start no earlier than 2004-10-14 | S2 | 1384h | 1384h | SMSIP | Huawei | zhangwenlin@huawei.com | Rel-7 | Maurice |  |  |  |
| 1982 | 637.2 | Stage 2 for SMSIP | 333d? | 2005-06-08 A | 2006-09-15 A | 100% | 2005-06-08 | 2006-09-15 | 333d? | finish no earlier than 2006-09-15 | S2 | 2664h | 2664h | SMSIP | Huawei | zhangwenlin@huawei.com | Rel-7 | Maurice |  |  |  |
| 1983 | 637.3 | **Stage 3 for SMSIP** | 527d? | 2005-06-08 A | 2007-06-14 A | 100% | 2005-06-08 | 2007-06-14 | 527d? |  | C4,C1 | 8360h | 8360h | SMSIP-St3 | Nokia | jari.jansson@nokia.com | Rel-7 | Kimmo |  |  |  |
| 1984 | 637.3.1 | CT1 aspects for SMSIP | 527d? | 2005-06-08 A | 2007-06-14 A | 100% | 2005-06-08 | 2007-06-14 | 527d? | finish no earlier than 2007-06-15 | C1 | 4216h | 4216h | SMSIP | Nokia | jari.jansson@nokia.com | Rel-7 | Frederic |  |  |  |
| 1985 | 637.3.2 | CT4 aspects for SMSIP | 518d? | 2005-06-08 A | 2007-06-01 A | 100% | 2005-06-08 | 2007-06-01 | 518d? | finish no earlier than 2007-06-01 | C4 | 4144h | 4144h | SMSIP-St3-c4 | Nokia | jari.jansson@nokia.com | Rel-7 | Kimmo |  |  |  |
| 1986 | 638 | **Evolution of Policy Control and Charging** | 817d? | 2004-10-14 A | 2007-11-30 A | 100% | 2004-10-14 | 2007-11-30 | 817d? |  | S2,S5,C3,C1 | 30336h | 30336h | PCC | Nokia | balazs.bertenyi@nsn.com | Rel-7 | Maurice |  |  |  |
| 1987 | 638.1 | Deleted - TR for PCC | 315d? | 2004-10-14 A | 2005-12-29 A | 100% | 2004-10-14 | 2005-12-29 | 315d? | finish no earlier than 2005-12-28 | S2 | 2520h | 2520h | PCC | Nokia | balazs.bertenyi@nsn.com | Rel-7 | Maurice |  |  | SP-33 |
| 1988 | 638.2 | Stage 2 for PCC | 315d? | 2005-07-04 A | 2006-09-15 A | 100% | 2005-07-04 | 2006-09-15 | 315d? | finish no earlier than 2006-09-15 | S2 | 2520h | 2520h | PCC | Nokia | balazs.bertenyi@nsn.com | Rel-7 | Maurice |  |  |  |
| 1989 | 638.3 | Evolution of policy control and flow based bearer level charging | 109d? | 2006-08-01 A | 2006-12-29 A | 100% | 2006-08-01 | 2006-12-29 | 109d? | start no earlier than 2006-08-01 | S2 | 872h | 872h | PCC | Nokia | balazs.bertenyi@nsn.com | Rel-7 | Maurice |  |  |  |
| 1990 | 638.4 | SA5 Charging aspects of PCC | 316d? | 2006-03-31 A | 2007-06-15 A | 100% | 2006-03-31 | 2007-06-15 | 316d? | finish no earlier than 2007-06-15 | S5 | 2528h | 2528h | PCC-CH | Orange | alain.bibas@orange-ft.com | Rel-7 | Dionisio |  |  |  |
| 1991 | 638.5 | Gx reference point for Policy and Charging Control | 521d? | 2005-12-02 A | 2007-11-30 A | 100% | 2005-12-02 | 2007-11-30 | 521d? | finish no earlier than 2007-09-14 | C3 | 4168h | 4168h | PCC-Gx | Siemens | Thomas.Belling@nsn.com | Rel-7 | Jiwan |  |  |  |
| 1992 | 638.6 | **Rx reference point for PCC CT3 aspects** | 521d? | 2005-12-02 A | 2007-11-30 A | 100% | 2005-12-02 | 2007-11-30 | 521d? |  | C3,C1 | 11192h | 11192h | PCC-Rx | Ericsson | j.javier.pastor@ericsson.com | Rel-7 | Jiwan |  |  |  |
| 1993 | 638.6.1 | PCC-Rx CT3 aspects | 521d? | 2005-12-02 A | 2007-11-30 A | 100% | 2005-12-02 | 2007-11-30 | 521d? | finish no earlier than 2007-09-14 | C3 | 4168h | 4168h | PCC-Rx-c3 | Ericsson | j.javier.pastor@ericsson.com | Rel-7 | Jiwan |  |  |  |
| 1994 | 638.6.2 | PCC-Rx CT1 aspects | 357d? | 2005-12-02 A | 2007-06-15 A | 100% | 2005-12-02 | 2007-06-15 | 357d? | finish no earlier than 2007-06-15 | C1 | 2856h | 2856h | PCC-Rx-Gx-c1 | Ericsson | j.javier.pastor@ericsson.com | Rel-7 | Frederic |  |  |  |

Notes:
- 1970: -
- 1971: CP#54 completed / Text3: RFC 6432 (was draft-jesske-dispatch-update3326-reason-responses)
- 1972: - / Text3: 24.819, 24.229
- 1973: - / Text3: 29.163, 29.209
- 1974: CT4#32: a set of CRs on FBI for cable labs / Text3: 29.229
- 1975: Duplicated entry ("ACCSEC2", "Access Security Enhancements", SP-040865) deleted by A.Sultan / Text3: 33.203
- 1976: -
- 1977: - / Text3: 22.228, 23.228
- 1978: -
- 1979: 03/2006 SP#31 WID approved / Text3: 32.240, 32.260, 32.298, 32.299
- 1980: SP#33 updated WID (removed MMS)
- 1981: SP#33 updated WID / Text3: 23.804
- 1982: SP#33 updated WID / Text3: 23.204
- 1983: CP#34 updated WID
- 1984: CP#34 updated WID / Text3: 23.040, 24.229
- 1985: CP#34 updated WID / Text3: 23.008, 29.002
- 1986: SP-29 approved WID. SP-31 updated WID adding SA5 charging. 23.125 will be discontinued from Rel-7.
- 1987: SP-30: S2 has no intention for TR completion / Text3: 23.803
- 1988: SP-29 approved WID. SP-31 updated WID. 23.125 will be discontinued from Rel-7. / Text3: 23.203
- 1989: SP-29 approved WID. SP-31 updated WID. 23.125 will be discontinued from Rel-7. / Text3: 23.207, 23.002, 23.228
- 1990: SP-31 updated WID with SA5 charging. / Text3: 32.250, 32.251, 32.298, 32.299
- 1991: - / Text3: 29.212 (not progressed to Rel-7: 29.210, 29.207, 29.208)
- 1992: WID approved at CP#30, Revised at CP#31, Revised at CP#33
- 1993: - / Text3: 29.213, 29.214 (not progressed to Rel-7: 29.209, 29.211)
- 1994: - / Text3: 24.229

| ID | WBS | Task | Type | Duration | Start | Finish | Complete | Baseline start | Baseline finish | Baseline duration | Constraint | Resources | Work | Actual work | Text1 | Text4 | Text5 | Text6 | Text8 | Text3 | Text12 |
| --- | --- | --- | --- | --- | --- | --- | --- | --- | --- | --- | --- | --- | --- | --- | --- | --- | --- | --- | --- | --- | --- |
| 1995 | 639 | **Voice Call Continuity between CS and IMS (incl. I-WLAN)** |  | 641d? | 2004-12-31 A | 2007-06-15 A | 100% | 2004-12-31 | 2007-06-15 | 641d? |  | S2,S1,S5,C1,C4 | 12224h | 12224h | VCC | Alcatel-Lucent | Keith Drage (drage@alcatel-lucent.com) | Rel-7 | Maurice |  |  |
| 1996 | 639.1 | TR for Voice Call Continuity between CS and IMS (incl. I-WLAN) |  | 245d? | 2004-12-31 A | 2005-12-08 A | 100% | 2004-12-31 | 2005-12-08 | 245d? | finish no earlier than 2005-12-08 | S2 | 1960h | 1960h | VCC | Alcatel-Lucent | andy.bennett@alcatel-lucent.com | Rel-7 | Maurice | 23.806 |  |
| 1997 | 639.2 | Stage 1 for Voice Call Continuity between CS and IMS (incl. I-WLAN) |  | 140d? | 2005-03-17 A | 2005-09-28 A | 100% | 2005-03-17 | 2005-09-28 | 140d? | finish no earlier than 2005-09-28 | S1 | 1120h | 1120h | VCC | Alcatel-Lucent | andy.bennett@alcatel-lucent.com | Rel-7 | Alain | 22.101 |  |
| 1998 | 639.3 | Stage 2 for Voice Call Continuity between CS and IMS (incl. I-WLAN) |  | 264d? | 2005-09-06 A | 2006-09-08 A | 100% | 2005-09-06 | 2006-09-08 | 264d? | finish no earlier than 2006-09-08 | S2 | 2112h | 2112h | VCC | Alcatel-Lucent | andy.bennett@alcatel-lucent.com | Rel-7 | Maurice | 23.206 |  |
| 1999 | 639.4 | SA5 Charging for Voice Call Continuity between CS and IMS (incl. I-WLAN) |  | 325d? | 2006-03-17 A | 2007-06-14 A | 100% | 2006-03-17 | 2007-06-14 | 325d? | finish no earlier than 2007-06-14 | S5 | 2600h | 2600h | VCC-CH | Orange | alain.bibas@orange-ft.com | Rel-7 | Dionisio | 32.250, 32.260 |  |
| 2000 | 639.5 | **Stage 3 for Voice Call Continuity between CS and IMS (incl. I-WLAN)** |  | 358d? | 2006-02-01 A | 2007-06-15 A | 100% | 2006-02-01 | 2007-06-15 | 358d? |  | C1,C4 | 4432h | 4432h | VCC | Alcatel-Lucent | Keith Drage (drage@alcatel-lucent.com) | Rel-7 | Frederic |  |  |
| 2001 | 639.5.1 | CT1 aspects of Stage 3 for Voice Call Continuity between CS and IMS (incl. I-WLAN) |  | 358d? | 2006-02-01 A | 2007-06-15 A | 100% | 2006-02-01 | 2007-06-15 | 358d? | finish no earlier than 2007-06-15 | C1 | 2864h | 2864h | VCC | Alcatel-Lucent | Keith Drage (drage@alcatel-lucent.com) | Rel-7 | Frederic | 24.206, 24.216 |  |
| 2002 | 639.5.2 | CT4 aspects of Stage 3 for Voice Call Continuity between CS and IMS (incl. I-WLAN) |  | 196d? | 2006-06-09 A | 2007-03-09 A | 100% | 2006-06-09 | 2007-03-09 | 196d? | start no earlier than 2006-06-09 | C4 | 1568h | 1568h | VCC-St3-c4 | Alcatel-Lucent | Keith Drage (drage@alcatel-lucent.com) | Rel-7 | Kimmo | 23.003 |  |
| 2003 | 639.5.3 | Deleted - CT3 aspects of Stage 3 for Voice Call Continuity between CS and IMS (incl. I-WLAN) | milestone | 0d? | 2006-11-02 A | 2006-11-02 A | 100% | 2006-11-02 | 2006-11-02 | 0d? | finish no earlier than 2006-11-02 | C3 |  |  | VCC | Alcatel-Lucent | Keith Drage (drage@alcatel-lucent.com) | Rel-7 | Jiwan | 29.163 | CP-33 |
| 2004 | 640 | **One Tunnel solution for optimization of Packet Data Traffic** |  | 418d? | 2006-03-27 A | 2007-10-31 A | 100% | 2006-03-27 | 2007-10-31 | 418d? |  | S2 | 7048h | 7048h | OPTUNEL | Nokia | antti.j.pasanen@nokia.com | Rel-7 | Maurice |  |  |
| 2005 | 640.1 | Deleted - Study on Stage 2 for One Tunnel solution |  | 125d? | 2006-03-27 A | 2006-09-15 A | 100% | 2006-03-27 | 2006-09-15 | 125d? | finish no earlier than 2005-09-12 | S2 | 1000h | 1000h | OPTUNEL-Study | Nokia | antti.j.pasanen@nokia.com | Rel-7 | Maurice | 23.809 | SP-34 |
| 2006 | 640.2 | One Tunnel Deployment Guideline |  | 268d? | 2006-10-23 A | 2007-10-31 A | 100% | 2006-10-23 | 2007-10-31 | 268d? | finish no earlier than 2007-10-31 | S2 | 2144h | 2144h | OPTUNEL-Guide | Huawei | lan.liu@huawei.com | Rel-7 | Maurice | 23.919 |  |
| 2007 | 640.3 | Stage 2 specification for One Tunnel solution |  | 70d? | 2006-09-11 A | 2006-12-15 A | 100% | 2006-09-11 | 2006-12-15 | 70d? | finish no earlier than 2006-12-15 | S2 | 560h | 560h | OPTUNEL-Stage2 | Nokia | antti.j.pasanen@nokia.com | Rel-7 | Maurice | 23.060 |  |
| 2008 | 641 | **CSI Terminating Session handling** |  | 267d? | 2006-06-08 A | 2007-06-15 A | 100% | 2006-06-08 | 2007-06-15 | 267d? |  | S2,C1 | 4728h | 4728h | CSItermS | Samsung | Osok Song | Rel-7 | Maurice |  |  |
| 2009 | 641.1 | Stage 2 of CStermS |  | 192d? | 2006-06-08 A | 2007-03-02 A | 100% | 2006-06-08 | 2007-03-02 | 192d? | start no earlier than 2006-06-08 | S2 | 1536h | 1536h | CSItermS | Samsung | Osok Song | Rel-7 | Maurice | 23.279 |  |
| 2010 | 641.2 | Stage 3 of CStermS |  | 132d? | 2006-12-14 A | 2007-06-15 A | 100% | 2006-12-14 | 2007-06-15 | 132d? | finish no earlier than 2007-06-15 | C1 | 1056h | 1056h | CSItermS | Samsung | chenho.chin@samsung.com | Rel-7 | Frederic | 24.229, 24.279 |  |
| 2011 | 641.3 | Deleted - duplicated with UID 340015 -Stage 3 CSI Terminating Session handling | milestone | 0d? | 2007-03-09 A | 2007-03-09 A | 100% | 2007-03-09 | 2007-03-09 | 0d? | start no earlier than 2007-03-09 | C1 |  |  | CSItermS | Samsung | chenho.chin@samsung.com | Rel-7 | Frederic | 24.229, 24.179, 24.279 | CP-34 |
| 2012 | 642 | Liberty Alliance and 3GPP Security Interworking |  | 451d? | 2005-03-10 A | 2006-11-30 A | 100% | 2005-03-10 | 2006-11-30 | 451d? | finish no earlier than 2006-11-30 | S3 | 3608h | 3608h | LibSec | Nokia | Silke.Holtmanns@nokia.com | Rel-7 | Dionisio | 33.980 |  |
| 2013 | 643 | Trust Requirements for Open Platforms in 3GPP |  | 499d? | 2005-01-03 A | 2006-11-30 A | 100% | 2005-01-03 | 2006-11-30 | 499d? | finish no earlier than 2006-11-30 | S3 | 3992h | 3992h | TrustOP | Nokia | Silke.Holtmanns@nokia.com | Rel-7 | Dionisio | 33.905 |  |
| 2014 | 644 | Development of UEA2 and UIA2 |  | 268d? | 2004-12-01 A | 2005-12-09 A | 100% | 2004-12-01 | 2005-12-09 | 268d? | finish no earlier than 2005-12-09 | S3 | 2144h | 2144h | AlgUEA2 | TeliaSonera | per.christoffersson@teliasonera.com | Rel-7 | Dionisio | 35.919, 35.215, 35.216, 35.217, 35.218 |  |
| 2015 | 645 | Lawful Interception in the 3GPP Rel-7 architecture |  | 118d? | 2005-06-28 A | 2005-12-08 A | 100% | 2005-06-28 | 2005-12-08 | 118d? | start no earlier than 2005-06-28 | S3 | 944h | 944h | LI-7A | BMWI | berthold.wilhelm@regtp.de | Rel-7 | Dionisio | 33.106, 33.107, 33.108 |  |
| 2016 | 646 | Key establishment between a UICC and a terminal |  | 201.45d? | 2005-12-07 A | 2006-09-28 A | 100% | 2005-12-07 | 2006-09-28 | 201.45d? | finish no earlier than 2006-09-28 | S3 | 1611.6h | 1611.6h | KeyEstUTerm | Gemalto | mireille.pauliac@gemplus.com | Rel-7 | Dionisio | 33.110 |  |
| 2017 | 647 | NDS Authentication Framework Extension for Transport Layer Security |  | 50d? | 2006-09-28 A | 2006-12-06 A | 100% | 2006-09-28 | 2006-12-06 | 50d? | finish no earlier than 2006-09-28 | S3 | 400h | 400h | NDSAFTLS | Nokia | tiina.s.koskinen@nokia.com | Rel-7 | Dionisio | 33.310 |  |
| 2018 | 648 | **Security enhancements** |  | 319d? | 2005-09-12 A | 2006-11-30 A | 100% | 2005-09-12 | 2006-11-30 | 319d? |  | S3,C1,C4 | 4856h | 4856h | SEC7 |  |  | Rel-7 | Dionisio |  |  |
| 2019 | 648.1 | HTTPS connection between a UICC and a NAF |  | 1d? | 2005-09-12 A | 2005-09-12 A | 100% | 2005-09-12 | 2005-09-12 | 1d? | start no earlier than 2005-09-12 | S3,C1 | 8h | 8h | SEC7-HSUN | Gemalto | JSeif@axalto.com, mireille.pauliac@gemplus.com | Rel-7 | Dionisio | 33.918, 33.222, 24.109 |  |
| 2020 | 648.2 | 2G GBA: 2G SIM usage in 3GPP GAA framework |  | 61d? | 2005-09-12 A | 2005-12-05 A | 100% | 2005-09-12 | 2005-12-05 | 61d? | finish no earlier than 2005-12-05 | S3 | 488h | 488h | SEC7-2GGBA | Nokia | Silke.Holtmanns@nokia.com | Rel-7 | Dionisio | 33.920, 33.220 |  |
| 2021 | 648.3 | Generic Authentication Architecture usage extensions and optimizations |  | 319d? | 2005-09-12 A | 2006-11-30 A | 100% | 2005-09-12 | 2006-11-30 | 319d? | finish no earlier than 2006-11-30 | S3 | 2552h | 2552h | SEC7-GAA2 | Nokia | Silke.Holtmanns@nokia.com | Rel-7 | Dionisio | 33.220, 29.109, 24.109, (33.223 goes to R8) |  |

Notes:
- 1995: WID approved SP#27; updated SP#28; updated SP#32
- 1996: -
- 1997: -
- 1998: -
- 1999: 03/2006 SP#31 WID approved
- 2000: -
- 2001: -
- 2002: -
- 2003: -
- 2004: -
- 2005: TR for Info SP-33. SP-34: S2 Report intention to discontinue TR
- 2006: -
- 2007: -
- 2008: Triggered by the abandoned Study UID_32117
- 2009: -
- 2010: CP-34 approved WID. CP-35 updated WID
- 2011: CP-34 approved WID
- 2012: WID approved SP#27.
- 2013: WID approved SP#26.
- 2014: WID approved SP#26, Dependant on Funding Availability.
- 2015: -
- 2016: -
- 2017: TLS profile is moved to Rel-8
- 2018: -
- 2019: -
- 2020: -
- 2021: 33.223 goes to R8

| ID | WBS | Task | Duration | Start | Finish | Complete | Baseline start | Baseline finish | Baseline duration | Constraint | Resources | Work | Actual work | Text1 | Text4 | Text5 | Text6 | Text8 | Text3 | Text12 | Text2 | Text7 |
| --- | --- | --- | --- | --- | --- | --- | --- | --- | --- | --- | --- | --- | --- | --- | --- | --- | --- | --- | --- | --- | --- | --- |
| 2022 | 648.4 | **SS7 TCAP security Gateway** | 241d? | 2005-09-12 A | 2006-08-14 A | 100% | 2005-09-12 | 2006-08-14 | 241d? |  | S3,C4 | 1808h | 1808h | SEC7-NDS-TCAPsec | Siemens | marc.blommaert.ext@nsn.com | Rel-7 | Dionisio |  |  |  |  |
| 2023 | 648.4.1 | SA3 aspects of SEC7-NDS-TCAPsec | 130d? | 2005-09-12 A | 2006-03-10 A | 100% | 2005-09-12 | 2006-03-10 | 130d? | finish no earlier than 2006-03-10 | S3 | 1040h | 1040h | SEC7-NDS-TCAPsec-SA3 | Siemens | marc.blommaert.ext@nsn.com | Rel-7 | Dionisio | 33.204 |  |  |  |
| 2024 | 648.4.2 | TCAPsec Gateway | 96d? | 2006-04-03 A | 2006-08-14 A | 100% | 2006-04-03 | 2006-08-14 | 96d? | start no earlier than 2006-04-01 | C4 | 768h | 768h | SEC7-TCAP | Siemens | Ulrich.wiehe@gksag.de | Rel-7 | Kimmo | 29.204, 29.002 |  |  |  |
| 2025 | 649 | IMS Stage 3 IETF Protocol Alignment | 589d? | 2004-12-10 A | 2007-03-14 A | 100% | 2004-12-10 | 2007-03-14 | 589d? | finish no earlier than 2007-03-15 | C1 | 4712h | 4712h | IMSProtoc |  |  | Rel-7 | Frederic | 24.930 |  |  |  |
| 2026 | 650 | **Interoperability between VGCS/VBS and A/Gb flexibility** | 253d? | 2006-03-22 A | 2007-03-09 A | 100% | 2006-03-22 | 2007-03-09 | 253d? |  | C1,C4 | 3296h | 3296h | VGCSFlex | Siemens | robert.zaus@nsn.com | Rel-7 | Frederic |  |  |  |  |
| 2027 | 650.1 | CT1 aspects of VGCSFlex | 159d? | 2006-03-22 A | 2006-10-30 A | 100% | 2006-03-22 | 2006-10-30 | 159d? | finish no earlier than 2006-10-30 | C1 | 1272h | 1272h | VGCSFlex | Siemens | robert.zaus@nsn.com | Rel-7 | Frederic | 43.068, 43.069 |  |  |  |
| 2028 | 650.2 | CT4 aspects of VGCSFlex | 253d? | 2006-03-22 A | 2007-03-09 A | 100% | 2006-03-22 | 2007-03-09 | 253d? | finish no earlier than 2007-03-09 | C4 | 2024h | 2024h | VGCSFlex-c4 | Siemens | robert.zaus@nsn.com | Rel-7 | Kimmo | 29.002 |  |  |  |
| 2029 | 651 | DIAMETER on the GGSN Gi interface | 586d? | 2004-09-10 A | 2006-12-08 A | 100% | 2004-09-10 | 2006-12-08 | 586d? | finish no earlier than 2006-12-08 | C3 | 4688h | 4688h | DIAMGi | Vodafone | Nico.Gabriele@vodafone.com | Rel-7 | Jiwan | 29.061 |  |  |  |
| 2030 | 652 | DIAMETER on the PDG Wi interface | 586d? | 2004-09-10 A | 2006-12-08 A | 100% | 2004-09-10 | 2006-12-08 | 586d? | finish no earlier than 2006-12-08 | C3 | 4688h | 4688h | DIAMWi | Vodafone | Nico.Gabriele@vodafone.com | Rel-7 | Jiwan | 29.161 |  |  |  |
| 2031 | 653 | Interworking between the 3GPP CS domain with BICC or ISUP as signalling protocol and external SIP-I networks | 478d? | 2006-09-22 A | 2008-07-22 A | 100% | 2006-09-22 | 2008-07-22 | 478d? | finish no earlier than 2007-09-14 | C3 | 3824h | 3824h | ExtSIPI | Siemens | Thomas.Belling@nsn.com | Rel-7 | Jiwan | 29.164 |  |  |  |
| 2032 | 654 | PDU multiplexing at Nb Interface with IP transport | 427d? | 2006-12-04 A | 2008-07-22 A | 100% | 2006-12-04 | 2008-07-22 | 427d? | start no earlier than 2006-12-04 | C3 | 3416h | 3416h | NbIPMux | Alcatel-Lucent | Jean.Rzeznik@alcatel-lucent.fr | Rel-7 | Jiwan | 29.414 |  |  |  |
| 2033 | 655 | **Mp (MRFC - MRFP) interface** | 345d? | 2006-02-13 A | 2007-06-08 A | 100% | 2006-02-13 | 2007-06-08 | 345d? |  | C4,C1 | 4384h | 4384h | Mp | Ericsson | philip.hodges@ericsson.com | Rel-7 | Kimmo |  |  |  |  |
| 2034 | 655.1 | CT1 aspects of Mp | 1d | 2006-02-13 A | 2006-02-13 A | 100% | 2006-02-13 | 2006-02-13 | 1d | finish no earlier than 2006-02-13 | C1 | 8h | 8h | Mp | Ericsson | philip.hodges@ericsson.com | Rel-7 | Frederic | 24.229 |  |  |  |
| 2035 | 655.2 | Deleted - CT3 aspects of Mp | 1d | 2006-09-22 A | 2006-09-22 A | 100% | 2006-09-22 | 2006-09-22 | 1d | start no earlier than 2006-09-22 | C3 | 8h | 8h | Mp | Ericsson | philip.hodges@ericsson.com | Rel-7 | Jiwan | 29.162 | CP-33 |  |  |
| 2036 | 655.3 | Procedures description | 201d? | 2006-06-02 A | 2007-03-09 A | 100% | 2006-06-02 | 2007-03-09 | 201d? | finish no earlier than 2007-03-09 | C4 | 1608h | 1608h | Mp-PROCc4 | Huawei | Chencheng@huawei.com | Rel-7 | Kimmo | 23.333 |  |  |  |
| 2037 | 655.4 | Stage 3 for Mp (MRFC - MRFP) interface | 345d | 2006-02-13 A | 2007-06-08 A | 100% | 2006-02-13 | 2007-06-08 | 345d | finish no earlier than 2007-06-08 | C4 | 2760h | 2760h | Mp-St3c4 | Ericsson | philip.hodges@ericsson.com | Rel-7 | Kimmo | 29.333 |  |  |  |
| 2038 | 656 | Routeing of MT-SMS via the HPLMN | 71d? | 2006-12-01 A | 2007-03-09 A | 100% | 2006-12-01 | 2007-03-09 | 71d? | finish no earlier than 2007-03-09 | C4,C1 | 568h | 568h | SMSviaH | Vodafone | Nick.Russell@vodafone.com | Rel-7 | Kimmo | 23.040, 29.002 |  |  |  |
| 2039 | 657 | Mobile Termination whilst the MS is moving to another MSC | 60d? | 2007-03-09 A | 2007-05-31 A | 100% | 2007-03-09 | 2007-05-31 | 60d? | start no earlier than 2007-03-09 | C4 | 480h | 480h | MTmovMS | Alcatel-Lucent | bruno.landais@alcatel-lucent.fr | Rel-7 | Kimmo | 23.008, 23.012, 23.018, 23.078, 23.079, 29.002 |  |  |  |
| 2040 | 658 | ISIM API for Java Card | 620d? | 2005-03-14 A | 2007-07-27 A | 100% | 2005-03-14 | 2007-07-27 | 620d? | finish no earlier than 2007-07-27 | C6 | 4960h | 4960h | APIJAVA | Sun | Sebastian Hans | Rel-7 | Xavier | 31.103, 102 241 |  |  |  |
| 2041 | 659 | Rel-7 (U)SIM API Testing (TS 31.213) | 211d? | 2009-05-30 A | 2010-03-19 A | 100% | 2009-05-30 | 2010-03-19 | 211d? | finish no earlier than 2010-03-12 | C6 | 1688h | 1688h | USIM_API_Test | Sagem Orga | gerrit.hartbrod@sagem-orga.com | Rel-7 | Xavier | 31.213 |  | PCG-23 | CP-44 |
| 2042 | 660 | High speed interface between the UICC and the ME | 311d? | 2006-09-22 A | 2007-11-30 A | 100% | 2006-09-22 | 2007-11-30 | 311d? | finish no earlier than 2007-11-30 | C6 | 2488h | 2488h | HSI | Gemalto | jacques.seif@GEMALTO.COM | Rel-7 | Xavier | 31.101 |  |  |  |
| 2043 | 661 | Video Codec Performance Requirements | 634d? | 2005-01-03 A | 2007-06-07 A | 100% | 2005-01-03 | 2007-06-07 | 634d? | finish no earlier than 2007-06-07 | S4 | 5072h | 5072h | VICPer | Siemens | juergen.pandel@siemens.com | Rel-7 | Paolo | 26.234, 26.235, 26.346, 26.140, 26.902 |  |  |  |
| 2044 | 662 | Dynamic and Interactive Multimedia Scenes | 583d? | 2005-03-15 A | 2007-06-07 A | 100% | 2005-03-15 | 2007-06-07 | 583d? | finish no earlier than 2007-06-07 | S4 | 4664h | 4664h | DIMS | Streamezzo | gaelle.martin-cocher@streamezzo.com | Rel-7 | Paolo | 26.140, 26.142, 26.234, 26.244, 23.346 |  |  |  |
| 2045 | 663 | 3G-324M Video Telephony Call Setup Times Improvements | 341d? | 2005-06-08 A | 2006-09-27 A | 100% | 2005-06-08 | 2006-09-27 | 341d? | finish no earlier than 2006-09-27 | S4 | 2728h | 2728h | VTCSTI | Vodafone | edward.hall@vodafone.co.uk | Rel-7 | Paolo | 26.911 |  |  |  |

Notes:
- 2022: -
- 2023: -
- 2024: -
- 2025: TR 24.930: Signalling flows for the session setup in the IM CN subsystem based on Session Initiation Protocol (SIP)
- 2026: Voice Group Call Service
- 2027: -
- 2028: -
- 2029: -
- 2030: -
- 2031: -
- 2032: -
- 2033: -
- 2034: -
- 2035: CP#34: CT3 not involved in Mp interface definition
- 2036: -
- 2037: -
- 2038: WID approved in CP#34
- 2039: -
- 2040: -
- 2041: CP#47 completed. Update of Rel-6 (U)SIM API for Java Card Testing UID_43007 under Rel-6 UICC/USIM enhancements and interworking UID_1800
- 2042: Following ETSI publication of TS 102 600, expected to be completed at CT6 meeting 45
- 2043: -
- 2044: -
- 2045: -

| ID | WBS | Task | Type | Duration | Start | Finish | Complete | Baseline start | Baseline finish | Baseline duration | Constraint | Resources | Work | Actual work | Text1 | Text4 | Text5 | Text6 | Text8 | Text12 |
| --- | --- | --- | --- | --- | --- | --- | --- | --- | --- | --- | --- | --- | --- | --- | --- | --- | --- | --- | --- | --- |
| 2046 | 664 | **Optimizations for Multimedia Telephony over IMS** |  | 0d? | 2005-09-28 A | 2005-09-28 A | 100% | 2005-09-28 | 2005-09-28 | 0d? |  | S4 |  |  | OMTIMS | Ericsson | olle.franceschi@ericsson.com | Rel-7 | Paolo |  |
| 2047 | 664.1 | Deleted - Characterisation of Adaptive Jitter Management Performance for VoIP Services | milestone | 0d? | 2005-09-28 A | 2005-09-28 A | 100% | 2005-09-28 | 2005-09-28 | 0d? | start no earlier than 2007-03-15 | S4 |  |  | OMTIMS-CAJMP | Lucent | dhuo@lucent.com | Rel-7 | Paolo | SP-35 |
| 2048 | 665 | End-to-End Multimedia Services Performance Metrics |  | 382d? | 2005-09-28 A | 2007-03-15 A | 100% | 2005-09-28 | 2007-03-15 | 382d? | finish no earlier than 2007-03-15 | S4 | 3056h | 3056h | E2EMSPM | China Mobile | zhangyanyf@chinamobile.com | Rel-7 | Paolo |  |
| 2049 | 666 | Packet Switched Streaming Enhancements |  | 261d? | 2006-06-08 A | 2007-06-07 A | 100% | 2006-06-08 | 2007-06-07 | 261d? | finish no earlier than 2007-06-07 | S4 | 2088h | 2088h | PSSe | Ericsson | olle.franceschi@ericsson.com | Rel-7 | Paolo |  |
| 2050 | 667 | **Rel-7 Operations, Administration, Maintenance and Provisioning (OAM&P)** |  | 472.86d? | 2005-09-02 A | 2007-06-26 A | 100% | 2005-09-02 | 2007-06-26 | 472.86d? |  | S5 | 82725.8h | 82725.8h | OAM7 | Huawei | Christian.Toche@huawei.com | Rel-7 | Dionisio |  |
| 2051 | 667.1 | **Rel-7 Network Infrastructure Management** |  | 465d? | 2005-09-02 A | 2007-06-14 A | 100% | 2005-09-02 | 2007-06-14 | 465d? |  | S5 | 41800h | 41800h | OAM7-NIM |  |  | Rel-7 | Dionisio |  |
| 2052 | 667.1.1 | Enhance NRM to accommodate NGN (IMS as basis of the Next Generation Network) |  | 465d? | 2005-09-02 A | 2007-06-14 A | 100% | 2005-09-02 | 2007-06-14 | 465d? | finish no earlier than 2007-06-14 | S5 | 3720h | 3720h | OAM7-NIM | Motorola |  | Rel-7 | Dionisio |  |
| 2053 | 667.1.2 | Co-operative Element Management interface (CO-OP) (Study + Implementation) |  | 400d? | 2005-09-02 A | 2007-03-15 A | 100% | 2005-09-02 | 2007-03-15 | 400d? | finish no earlier than 2007-03-15 | S5 | 3200h | 3200h | OAM7-NIM | Motorola |  | Rel-7 | Dionisio |  |
| 2054 | 667.1.3 | Network Management (NM) Itf-N performance criteria |  | 465d? | 2005-09-02 A | 2007-06-14 A | 100% | 2005-09-02 | 2007-06-14 | 465d? | finish no earlier than 2007-06-14 | S5 | 3720h | 3720h | OAM7-NIM | China Mobile |  | Rel-7 | Dionisio |  |
| 2055 | 667.1.4 | Delta synchronization between IRP Manager and IRP Agent (Study + Implementation) |  | 465d? | 2005-09-02 A | 2007-06-14 A | 100% | 2005-09-02 | 2007-06-14 | 465d? | finish no earlier than 2007-06-14 | S5 | 3720h | 3720h | OAM7-NIM | Siemens |  | Rel-7 | Dionisio |  |
| 2056 | 667.1.5 | Subscription Management (SuM) IRP Solution Sets |  | 330d? | 2005-09-02 A | 2006-12-07 A | 100% | 2005-09-02 | 2006-12-07 | 330d? | finish no earlier than 2006-12-07 | S5 | 2640h | 2640h | OAM7-NIM | Ericsson |  | Rel-7 | Dionisio |  |
| 2057 | 667.1.6 | Integration Reference Point (IRP) Security Management |  | 400d? | 2005-09-02 A | 2007-03-15 A | 100% | 2005-09-02 | 2007-03-15 | 400d? | finish no earlier than 2007-03-15 | S5 | 3200h | 3200h | OAM7-NIM | Huawei | Christian.Toche@huawei.com | Rel-7 | Dionisio |  |
| 2058 | 667.1.7 | Partial suspension of Itf-N during maintenance/testing (Study + Implementation) |  | 465d? | 2005-09-02 A | 2007-06-14 A | 100% | 2005-09-02 | 2007-06-14 | 465d? | finish no earlier than 2007-06-14 | S5 | 3720h | 3720h | OAM7-NIM | Siemens |  | Rel-7 | Dionisio |  |
| 2059 | 667.1.8 | Deleted - Management of Legacy Equipment |  | 336d? | 2005-09-02 A | 2006-12-15 A | 100% | 2005-09-02 | 2006-12-15 | 336d? | finish no earlier than 2006-12-15 | S5 | 2688h | 2688h | OAM7-NIM | Siemens |  | Rel-7 | Dionisio | SP-35 |
| 2060 | 667.1.9 | Deleted - Rules for Vendor Specific Extensions |  | 400d? | 2005-09-02 A | 2007-03-15 A | 100% | 2005-09-02 | 2007-03-15 | 400d? | finish no earlier than 2007-03-15 | S5 | 3200h | 3200h | OAM7-NIM | Siemens |  | Rel-7 | Dionisio | SP-35 |
| 2061 | 667.1.10 | Backward and Forward Compatibility of IRP systems |  | 465d? | 2005-09-02 A | 2007-06-14 A | 100% | 2005-09-02 | 2007-06-14 | 465d? | finish no earlier than 2007-06-14 | S5 | 3720h | 3720h | OAM7-NIM | Ericsson |  | Rel-7 | Dionisio |  |
| 2062 | 667.1.11 | Repeater Network Resource Model (NRM) definition |  | 214d? | 2006-02-13 A | 2006-12-07 A | 100% | 2006-02-13 | 2006-12-07 | 214d? | finish no earlier than 2006-12-07 | S5 | 1712h | 1712h | OAM7-NIM | China Mobile |  | Rel-7 | Dionisio |  |
| 2063 | 667.1.12 | UTRAN radio channel power monitoring |  | 284d? | 2006-02-13 A | 2007-03-15 A | 100% | 2006-02-13 | 2007-03-15 | 284d? | finish no earlier than 2007-03-15 | S5 | 2272h | 2272h | OAM7-NIM | China Mobile |  | Rel-7 | Dionisio |  |
| 2064 | 667.1.13 | Notification XML Schema |  | 71d? | 2006-12-07 A | 2007-03-15 A | 100% | 2006-12-07 | 2007-03-15 | 71d? | finish no earlier than 2007-03-15 | S5 | 568h | 568h | OAM7-NIM | Huawei | Christian.Toche@huawei.com | Rel-7 | Dionisio |  |
| 2065 | 667.2 | **Rel-7 Performance Management** |  | 465d? | 2005-09-02 A | 2007-06-14 A | 100% | 2005-09-02 | 2007-06-14 | 465d? |  | S5 | 22992h | 22992h | OAM7-PM |  |  | Rel-7 | Dionisio |  |
| 2066 | 667.2.1 | Performance measurements definition for CN CS |  | 400d? | 2005-09-02 A | 2007-03-15 A | 100% | 2005-09-02 | 2007-03-15 | 400d? | finish no earlier than 2007-03-15 | S5 | 3200h | 3200h | OAM7-PM | China Mobile |  | Rel-7 | Dionisio |  |
| 2067 | 667.2.2 | Enhancement UTRAN performance measurements definition |  | 465d? | 2005-09-02 A | 2007-06-14 A | 100% | 2005-09-02 | 2007-06-14 | 465d? | finish no earlier than 2007-06-14 | S5 | 3720h | 3720h | OAM7-PM | China Mobile |  | Rel-7 | Dionisio |  |
| 2068 | 667.2.3 | Add TDD specific counters in Performance measurement |  | 330d? | 2005-09-02 A | 2006-12-07 A | 100% | 2005-09-02 | 2006-12-07 | 330d? | finish no earlier than 2006-12-15 | S5 | 2640h | 2640h | OAM7-PM | CATT |  | Rel-7 | Dionisio |  |
| 2069 | 667.2.4 | ATM bearer network Performance measurements |  | 400d? | 2005-09-02 A | 2007-03-15 A | 100% | 2005-09-02 | 2007-03-15 | 400d? | finish no earlier than 2007-03-15 | S5 | 3200h | 3200h | OAM7-PM | ZTE |  | Rel-7 | Dionisio |  |
| 2070 | 667.2.5 | Performance measurements definition for IMS |  | 465d? | 2005-09-02 A | 2007-06-14 A | 100% | 2005-09-02 | 2007-06-14 | 465d? | finish no earlier than 2007-06-14 | S5 | 3720h | 3720h | OAM7-PM | China Mobile |  | Rel-7 | Dionisio |  |
| 2071 | 667.2.6 | HSDPA performance measurements |  | 349d? | 2006-02-13 A | 2007-06-14 A | 100% | 2006-02-13 | 2007-06-14 | 349d? | finish no earlier than 2007-06-14 | S5 | 2792h | 2792h | OAM7-PM | China Mobile |  | Rel-7 | Dionisio |  |

Notes:
- 2046: - / Text3: 26.235, 26.236
- 2047: SP-35 stopped
- 2048: - / Text3: 26.944
- 2049: - / Text3: 26.234, 26.244
- 2050: OAM7 is an umbrella Feature also for OAM&P related TEI7 type of changes that are not part of any other dedicated feature/WI / Text3: TR 30.817
- 2051: -
- 2052: - / Text3: 32.731/2/3/5, 32.631/2/3/5
- 2053: - / Text3: 32.806, 32.814, 32.101
- 2054: - / Text3: 32.811
- 2055: - / Text3: 32.391/2/3/5
- 2056: - / Text3: 32.307/317/607/667/665, 32.101, 32.175
- 2057: - / Text3: 32.372/3/5, 32.111,32.30x,32.32x,32.33x,32.34x,32.35x,32.36x,32.41x,32.60x,32.61x,32.66x
- 2058: - / Text3: 32.381/2/3/5
- 2059: Request to TSG#35 to STOP the WI / Text3: new 32.xxx
- 2060: Request to TSG#35 to STOP the WI / Text3: 32.62n; For n = 1 to 5
- 2061: - / Text3: 32.154
- 2062: - / Text3: 32.721/2/3/5
- 2063: - / Text3: 32.405, 32.64n; For n = 1 to 5
- 2064: 12/2006 SP#34 WID approved / Text3: New 32.325/345/365/415, CR to 32.335/615/665
- 2065: -
- 2066: - / Text3: 32.407, 32.408
- 2067: - / Text3: 32.405
- 2068: - / Text3: 32.405
- 2069: - / Text3: No impact on 32.404, 32.405, 32.406, 32.407
- 2070: - / Text3: 32.404,32.409,32.437, 32.632/3/4/5
- 2071: - / Text3: 32.405

| ID | WBS | Task | Type | Duration | Start | Finish | Complete | Baseline start | Baseline finish | Baseline duration | Constraint | Resources | Work | Actual work | Text1 | Text4 | Text6 | Text8 | Text12 | Text5 | Text11 |
| --- | --- | --- | --- | --- | --- | --- | --- | --- | --- | --- | --- | --- | --- | --- | --- | --- | --- | --- | --- | --- | --- |
| 2072 | 44.5 | **Rel-7 Trace Management** |  | 472.86d? | 2005-09-02 A | 2007-06-26 A | 100% | 2005-09-02 | 2007-06-26 | 472.86d? |  | S5 | 14150.9h | 14150.9h | OAM7-Trace | Vodafone | Rel-7 | Dionisio |  |  |  |
| 2073 | 667.3.1 | End-to-end Service Level tracing for IMS |  | 350d? | 2005-11-11 A | 2007-03-15 A | 100% | 2005-11-11 | 2007-03-15 | 350d? | finish no earlier than 2007-03-15 | S5 | 2800h | 2800h | OAM7-Trace | Vodafone | Rel-7 | Dionisio | SP-31 |  |  |
| 2074 | 667.3.2 | Trace record content for UTRAN TDD |  | 330d? | 2005-09-02 A | 2006-12-07 A | 100% | 2005-09-02 | 2006-12-07 | 330d? | finish no earlier than 2006-12-07 | S5 | 2640h | 2640h | OAM7-Trace | Nokia | Rel-7 | Dionisio |  |  |  |
| 2075 | 667.3.3 | IRP for Subscriber and Equipment Trace Management |  | 465d? | 2005-09-02 A | 2007-06-14 A | 100% | 2005-09-02 | 2007-06-14 | 465d? | finish no earlier than 2007-06-14 | S5 | 3720h | 3720h | OAM7-Trace | Nokia | Rel-7 | Dionisio |  |  |  |
| 2076 | 667.3.4 | Deleted - SIP enhancements for trace | milestone | 0d? | 2007-06-15 A | 2007-06-26 A | 100% | 2007-06-15 | 2007-06-26 | 0d? | start no earlier than 2007-06-15 | C1 |  |  | OAM7-Trace |  | Rel-7 | Frederic | CP-32 |  |  |
| 2077 | 667.3.5 | Deleted - duplicated with UID 35063 - IRP for Subscriber and Equipment Trace Management |  | 336d? | 2005-09-02 A | 2006-12-15 A | 100% | 2005-09-02 | 2006-12-15 | 336d? | finish no earlier than 2006-12-15 | S5 | 2688h | 2688h | OAM7-Trace | Nokia | Rel-7 | Dionisio | SP-33 |  |  |
| 2078 | 668 | **Rel-7 Charging Management small Enhancements** |  | 279d? | 2006-05-22 A | 2007-06-14 A | 100% | 2006-05-22 | 2007-06-14 | 279d? |  | S5 | 5952h | 5952h | CH7 | Orange | Rel-7 | Dionisio |  | alain.bibas@orange-ft.com |  |
| 2079 | 668.1 | Alternate Charged Party (ACP) for IMS |  | 279d? | 2006-05-22 A | 2007-06-14 A | 100% | 2006-05-22 | 2007-06-14 | 279d? | finish no earlier than 2007-06-14 | S5 | 2232h | 2232h | CH7-IMS-ACP | Lucent | Rel-7 | Dionisio |  | njmazzarella@alcatel-lucent.com |  |
| 2080 | 668.2 | Align 3GPP Charging with OMA PoC Enabler Release 2.0 |  | 186d? | 2006-09-28 A | 2007-06-14 A | 100% | 2006-09-28 | 2007-06-14 | 186d? | finish no earlier than 2007-06-14 | S5 | 1488h | 1488h | CH7-PoC | Siemens | Rel-7 | Dionisio |  | Gerald.Goermer@nsn.com |  |
| 2081 | 8.5 | **Multiple-Input Multiple-Output (MIMO) antennas** |  | 1301d? | 2003-03-14 A | 2008-03-07 A | 100% | 2003-03-14 | 2008-03-07 | 1301d? |  | R1,R5 | 45440h | 45440h | MIMO | Alcatel-Lucent | Rel-7 | Patrick |  | hchuang@Alcatel-Lucent.com | RP-070037, RP-070531 |
| 2082 | 669.1 | MIMO - Physical layer |  | 915d? | 2003-09-12 A | 2007-03-15 A | 100% | 2003-09-12 | 2007-03-15 | 915d? | finish no earlier than 2007-03-15 | R1 | 7320h | 7320h | MIMO-Phys | Alcatel-Lucent | Rel-7 | Patrick |  | hchuang@Alcatel-Lucent.com | RP-070037 |
| 2083 | 669.2 | MIMO - Layer 2,3 aspects |  | 915d? | 2003-09-12 A | 2007-03-15 A | 100% | 2003-09-12 | 2007-03-15 | 915d? | finish no earlier than 2007-03-15 | R2 | 7320h | 7320h | MIMO-L23 | Alcatel-Lucent | Rel-7 | Joern |  | hchuang@Alcatel-Lucent.com | RP-070037 |
| 2084 | 669.3 | MIMO - Iub/Iur Protocol Aspects |  | 1045d? | 2003-03-14 A | 2007-03-15 A | 100% | 2003-03-14 | 2007-03-15 | 1045d? | finish no earlier than 2007-03-15 | R3 | 8360h | 8360h | MIMO-IurIub | Alcatel-Lucent | Rel-7 | Juha |  | hchuang@Alcatel-Lucent.com | RP-070037 |
| 2085 | 669.4 | MIMO - RF Radio Transmission/Reception, System Performance Requirements and Conformance Testing |  | 982d? | 2003-12-12 A | 2007-09-17 A | 100% | 2003-12-12 | 2007-09-17 | 982d? | finish no earlier than 2007-09-17 | R4 | 7856h | 7856h | MIMO-RF | Alcatel-Lucent | Rel-7 | Issam |  | ngm@Alcatel-Lucent.com | RP-070531 |
| 2086 | 669.5 | **UE Conformance Testing for Multiple Input Multiple Output antennas (MIMO)** |  | 261d? | 2007-03-09 A | 2008-03-07 A | 100% | 2007-03-09 | 2008-03-07 | 261d? |  | R5 | 4176h | 4176h | MIMO-UEConTest | Qualcomm | Rel-7 | Ingbert |  | svora@qualcomm.com |  |
| 2087 | 669.5.1 | Conformance Test Aspects – Multiple Input Multiple Output Antennas (MIMO) for FDD |  | 261d? | 2007-03-09 A | 2008-03-07 A | 100% | 2007-03-09 | 2008-03-07 | 261d? | finish no earlier than 2008-03-07 | R5 | 2088h | 2088h | MIMO-UEConTest_FDD | Qualcomm | Rel-7 | Ingbert |  | svora@qualcomm.com |  |
| 2088 | 670 | **Rel-7 Improvements of the Radio Interface** |  | 709d? | 2004-09-15 A | 2007-06-04 A | 100% | 2004-09-15 | 2007-06-04 | 709d? |  | RP,GP | 24024h | 24024h | RInImp |  | Rel-7 | Issam |  |  |  |
| 2089 | 670.1 | Extended UMTS 1.7/2.1 GHz |  | 198d? | 2006-03-15 A | 2006-12-15 A | 100% | 2006-03-15 | 2006-12-15 | 198d? | finish no earlier than 2006-12-15 | R4 | 1584h | 1584h | RInImp-UMTS1721Ext | Ericsson | Rel-7 | Issam |  | johan.skold@ericsson.com | RP-060681 |
| 2090 | 670.2 | UMTS 2.6 GHz 7.68 Mcps TDD |  | 67d? | 2006-06-15 A | 2006-09-15 A | 100% | 2006-06-15 | 2006-09-15 | 67d? | finish no earlier than 2006-09-15 | R4 | 536h | 536h | RInImp-UMTS26VHCRTDD | IPWireless | Rel-7 | Issam |  | Shin Horng Wong (shwong@ipwireless.com) | RP-060451 |
| 2091 | 670.3 | UMTS 2.6 GHz |  | 195d? | 2004-09-15 A | 2005-06-14 A | 100% | 2004-09-15 | 2005-06-14 | 195d? | finish no earlier than 2005-06-14 | R4 | 1560h | 1560h | RInImp-UMTS2600 | Nokia | Rel-7 | Issam |  | jussi.numminen@nokia.com | RP-050184 |
| 2092 | 670.4 | UMTS 2.6 GHz TDD |  | 261d? | 2004-12-15 A | 2005-12-14 A | 100% | 2004-12-15 | 2005-12-14 | 261d? | finish no earlier than 2005-12-15 | R4 | 2088h | 2088h | RInImp-UMTS2600TDD | IPWireless | Rel-7 | Issam |  | Shin Horng Wong (shwong@ipwireless.com) | RP-050661 |
| 2093 | 670.5 | UMTS 900 MHz |  | 261d? | 2004-12-15 A | 2005-12-14 A | 100% | 2004-12-15 | 2005-12-14 | 261d? | finish no earlier than 2005-12-15 | R4 | 2088h | 2088h | RInImp-UMTS900 | Nortel | Rel-7 | Issam |  | Yannick Li (yli@nortelnetworks.com) | RP-050662 |
| 2094 | 670.6 | UMTS 1700 MHz |  | 197d? | 2005-03-15 A | 2005-12-14 A | 100% | 2005-03-15 | 2005-12-14 | 197d? | finish no earlier than 2005-12-15 | R4 | 1576h | 1576h | RInImp-UMTS1700 | NTT DoCoMo | Rel-7 | Issam |  | Takehiro Nakamura (nakamurata@nttdocomo.co.jp) | RP-050824 |
| 2095 | 670.7 | UE Antenna Performance Evaluation Method and Requirements |  | 644d? | 2004-12-15 A | 2007-06-04 A | 100% | 2004-12-15 | 2007-06-04 | 644d? | finish no earlier than 2007-06-04 | R4,GP | 5152h | 5152h | RInImp-UEAnt | TeliaSonera | Rel-7 | Issam |  | Christian.Bergljung@TeliaSonera.com | RP-070281 |
| 2096 | 670.8 | Improved Performance Requirements for HSDPA UE based on Rx Diversity (type 1) & LMMSE equalizer (type 2) | milestone | 0d? | 2005-03-15 A | 2005-03-15 A | 100% | 2005-03-15 | 2005-03-15 | 0d? | finish no earlier than 2005-03-15 | R4 |  |  | RInImp-HSPerf-Type3 | Cingular | Rel-7 | Issam |  | Marc Grant | RP-060015 |

Notes:
- 2072: -
- 2073: 07/2005: OMA (Stage 1), Stage 2/3 SA5, CT1/3/4 / Text3: CR 32.101, 32.421/2/3.
- 2074: - / Text3: CR 32.421/2/3.
- 2075: - / Text3: 32.441/2/3/5, CRs 32.632/3/5
- 2076: combined with UID 11067
- 2077: - / Text3: 32.421,32.422,32.423. 3 new 32.4x1,2,3
- 2078: CH7 is an umbrella Feature also for OAM&P related TEI7 type of changes that are not part of any other dedicated feature/WI / Text3: TR 30.817
- 2079: - / Text3: 32.240, 32.260, 32.298, 32.299
- 2080: 09/2006 SP#33 WID approved / Text3: 32.240, 32.272, 32.299, 32.298
- 2081: Completed Sep 2007; SR in RP-070037and RP-070531 / Text3: 25.876, 25.996
- 2082: Completed Sep 2007; SR in RP-070037 / Text3: 25.211, 25.212, 25.213, 25.214, 25.215, 25.221
- 2083: Completed Sep 2007; SR in RP-070037 / Text3: 25.876
- 2084: Completed Sep 2007; SR in RP-070037
- 2085: Completed Sep 2007; SR in RP-070531
- 2086: BB place holder for a number of RAN5 Tasks
- 2087: - / Text3: TS 34.108, TS 34.109, TS 34.121-1, TS 34.121-2, TS 34.123-1, TS 34.123-2, TS 34.123-3
- 2088: Generic feature
- 2089: RP#34 completed. Introduction of Band X (Extended UMTS 1.7/2.1 GHz) in 25.307 / Text3: 25.806, 25.101, 25.104, 25.133, 24.141, 25.331, 25.306, 25.307, 25.423, 25.461, 25.463, 34.121
- 2090: RP#33 completed / Text3: 25.102, 25.105, 25.123, 25.113, 25.142, 34.124
- 2091: RP#28 completed / Text3: 25.101, 25.104, 25.133, 25.141, 25.331, 25.942, 25.306, 25.307, 34.121
- 2092: RP#30 completed / Text3: 25.102, 25.105, 25.113, 25.123, 25.142, 25.331, 25.942, 25.306, 25.307, 34.122, 34.124
- 2093: RP#30 completed / Text3: 25.101, 25.104, 25.113, 25.133, 25.141, 25.331, 25.942, 25.306, 25.307, 34.121
- 2094: RP#30 completed / Text3: 25.101, 25.104, 25.113, 25.133, 25.141, 25.306, 25.307, 25.331, 34.121
- 2095: RP#36 completed / Text3: 25.101, new TR (25.914, 25.963)
- 2096: RP#27 completed / Text3: 25.101

| ID | WBS | Task | Type | Duration | Start | Finish | Complete | Baseline start | Baseline finish | Baseline duration | Constraint | Deadline | Resources | Work | Actual work | Text1 | Text4 | Text5 | Text6 | Text8 | Text11 | Text12 | Text9 | Text10 |
| --- | --- | --- | --- | --- | --- | --- | --- | --- | --- | --- | --- | --- | --- | --- | --- | --- | --- | --- | --- | --- | --- | --- | --- | --- |
| 2097 | 670.9 | **Additional minimum UE performance requirement for non-HSDPA channels based on type 1 enhanced receiver (Rx Diversity)** |  | 327d? | 2005-09-15 A | 2006-12-15 A | 100% | 2005-09-15 | 2006-12-15 | 327d? |  |  | R4 | 7344h | 7344h | RInImp-RxDiv | Qualcomm | Serge Willenegger (sergew@qualcomm.com) | Rel-7 | Issam |  |  |  |  |
| 2098 | 670.9.1 | Additional minimum UE performance requirement for DL physical channels in support of DCH/HS-DSCH operation based on type 1 enhanced receiver (RX-Diversity) |  | 195d? | 2005-09-15 A | 2006-06-14 A | 100% | 2005-09-15 | 2006-06-14 | 195d? | finish no earlier than 2006-06-15 |  | R4 | 1560h | 1560h | RInImp-RxDiv-DCH | Cingular | Marc Grant | Rel-7 | Issam | RP-060235 |  |  |  |
| 2099 | 670.9.2 | Additional minimum UE performance requirement for downlink physical channels in support of MTCH and MCCH operation based on type 1 enhanced receiver (Rx-Diversity) |  | 198d? | 2006-03-15 A | 2006-12-15 A | 100% | 2006-03-15 | 2006-12-15 | 198d? | finish no earlier than 2006-12-15 |  | R4 | 1584h | 1584h | RInImp-RxDiv-MBMS | Qualcomm | Serge Willenegger (sergew@qualcomm.com) | Rel-7 | Issam | RP-060678 |  |  |  |
| 2100 | 670.9.3 | Additional minimum UE performance requirement for downlink physical channels in support of E-DCH operation based on type 1 enhanced receiver (Rx-Diversity) |  | 198d? | 2006-03-15 A | 2006-12-15 A | 100% | 2006-03-15 | 2006-12-15 | 198d? | finish no earlier than 2006-12-15 |  | R4 | 1584h | 1584h | RInImp-RxDiv-EDCH | Qualcomm | Serge Willenegger (sergew@qualcomm.com) | Rel-7 | Issam | RP-060679 |  |  |  |
| 2101 | 670.10 | Deleted Improved support of gaming over HSDPA/EDCH |  | 262d? | 2005-12-15 A | 2006-12-15 A | 100% | 2005-12-15 | 2006-12-15 | 262d? | finish no earlier than 2006-12-15 |  | R2 | 2096h | 2096h | RInImp-Gaming | Cingular | Don Zelmer (dz1069@att.com) | Rel-7 | Joern | RP-060680 | RP-34 |  |  |
| 2102 | 670.11 | Deleted (not approved at PCG) - UMTS 2.6 GHz FDD DL External | milestone | 0d? | 2005-09-15 A | 2005-09-15 A | 100% | 2005-09-15 | 2005-09-15 | 0d? | finish no earlier than 2005-09-15 |  | R4 |  |  | RInImp-UMTS2600Ext | T-mobile | han.van.bussel@t-mobile.de | Rel-7 | Issam |  | RP-31 | PCG-16 |  |
| 2103 | 671 | **Rel-7 Improvements of the Radio Interface - UE Conformance Testing** |  | 741d? | 2005-11-11 A | 2008-09-12 A | 100% | 2005-11-11 | 2008-09-12 | 741d? |  |  | R5 | 17568h | 17568h | RInImp-UEConTest |  |  | Rel-7 | Ingbert |  |  |  |  |
| 2104 | 16.5.1 | UE Conformance Test for UMTS 2600 MHz |  | 146d | 2005-11-11 A | 2006-06-02 A | 100% | 2005-11-11 | 2006-06-02 | 146d | finish no earlier than 2006-06-02 | 2006-06-02 | R5 | 1168h | 1168h | RInImp-UMTS2600_Test | Nokia | Aleksi.Heino@nokia.com | Rel-7 | Ingbert |  |  |  | Fri 7/11/05 |
| 2105 | 16.5.1 | UE Conformance Test for UMTS 900 MHz (band VIII) |  | 146d | 2005-11-11 A | 2006-06-02 A | 100% | 2005-11-11 | 2006-06-02 | 146d | finish no earlier than 2006-06-02 | 2006-06-02 | R5 | 1168h | 1168h | RInImp-UMTS900_Test | Qualcomm | hanye@qualcomm.com | Rel-7 | Ingbert |  |  |  | Fri 11/03/05 |
| 2106 | 671.3 | Conformance Test Aspects – Improved Performance of HSDPA Receiver type 3 |  | 191d? | 2006-03-10 A | 2006-12-01 A | 100% | 2006-03-10 | 2006-12-01 | 191d? | finish no earlier than 2006-12-01 |  | R5 | 1528h | 1528h | RInImp-HSPerf-Type3_Test | Motorola | carolyn.taylor@motorola.com | Rel-7 | Ingbert |  |  |  |  |
| 2107 | 671.4 | UE antenna Over The Air (OTA) conformance testing |  | 518d? | 2006-09-20 A | 2008-09-12 A | 100% | 2006-09-20 | 2008-09-12 | 518d? | finish no earlier than 2008-09-12 |  | R5 | 4144h | 4144h | RInImp-UEAnt_Test | Nokia | Aleksi.Heino@nokia.com | Rel-7 | Ingbert | RP-080535 |  |  |  |
| 2108 | 671.5 | UE conformance testing for FDD Inter-Band Operation |  | 131d? | 2006-06-02 A | 2006-12-01 A | 100% | 2006-06-02 | 2006-12-01 | 131d? | finish no earlier than 2006-12-01 |  | R5 | 1048h | 1048h | RInImp-InterBand_Test | NEC, Motorola | Jacob.John@motorola.com | Rel-7 | Ingbert |  |  |  |  |
| 2109 | 671.6 | Conformance Test Aspects – Extended UMTS 1.7/2.1 GHz |  | 131d? | 2006-12-01 A | 2007-06-01 A | 100% | 2006-12-01 | 2007-06-01 | 131d? | finish no earlier than 2007-06-01 |  | R5 | 1048h | 1048h | RInImp-UEConTest_UMTS1721Ext | Motorola | carolyn.taylor@motorola.com | Rel-7 | Ingbert | RP-070312 |  |  |  |
| 2110 | 671.7 | Conformance Test Aspects – Minimum UE performance requirement for downlink physical channels in support of E-DCH operation based on type 1 enhanced receiver (Rx-Diversity) |  | 136d? | 2007-06-01 A | 2007-12-07 A | 100% | 2007-06-01 | 2007-12-07 | 136d? | finish no earlier than 2007-12-07 |  | R5 | 1088h | 1088h | RInImp-UEConTest_RxDivEDCH | Motorola | carolyn.taylor@motorola.com | Rel-7 | Ingbert | RP-070810 |  |  |  |
| 2111 | 671.8 | Conformance Test Aspects – Minimum UE performance requirement for downlink physical channels in support of MTCGH and MCCH operation based on type 1 enhanced receiver (Rx-Diversity) |  | 201d? | 2007-06-01 A | 2008-03-07 A | 100% | 2007-06-01 | 2008-03-07 | 201d? | finish no earlier than 2008-03-07 |  | R5 | 1608h | 1608h | RInImp-UEConTest_RxDivMBMS | Ericsson | leif.mattisson@ericsson.com | Rel-7 | Ingbert | RP-080056 |  |  |  |
| 2112 | 672 | **Rel-7 RAN improvements** |  | 653d? | 2004-12-15 A | 2007-06-15 A | 100% | 2004-12-15 | 2007-06-15 | 653d? |  |  | RP,S5 | 24728h | 24728h | RANimp |  |  | Rel-7 |  |  |  |  |  |
| 2113 | 672.1 | Optimization of channelisation code utilisation for 1.28 Mcps TDD |  | 523d? | 2004-12-15 A | 2006-12-15 A | 100% | 2004-12-15 | 2006-12-15 | 523d? | finish no earlier than 2006-12-15 |  | R1 | 4184h | 4184h | RANimp-RABSE-CodOptLCRTDD | UTStarcom | Ka Leong Lo (kaleong.lo@UTSTAR.COM) | Rel-7 | Patrick | RP-060682 |  |  |  |
| 2114 | 672.2 | Delay optimization for procedures applicable to CS and PS Connections |  | 394d? | 2005-03-15 A | 2006-09-15 A | 100% | 2005-03-15 | 2006-09-15 | 394d? | finish no earlier than 2006-09-15 |  | R2 | 3152h | 3152h | RANimp-DelayOpt | Nokia | juho.pirskanen@nokia.com | Rel-7 | Joern | RP-060453 |  |  |  |
| 2115 | 672.3 | Improved support of IMS Realtime Services using HSDPA/HSUPA |  | 197d? | 2005-03-15 A | 2005-12-14 A | 100% | 2005-03-15 | 2005-12-14 | 197d? | start no earlier than 2005-03-15 |  | R2 | 1576h | 1576h | RANimp-IMSRealTime | Cingular | Don Zelmer (dz1069@att.com) | Rel-7 | Joern | RP-050667 |  |  |  |
| 2116 | 672.4 | UE Performance Requirements for MBMS (TDD) |  | 328d? | 2005-03-15 A | 2006-06-15 A | 100% | 2005-03-15 | 2006-06-15 | 328d? | finish no earlier than 2006-06-15 |  | R4 | 2624h | 2624h | MBMS-RAN-RF-TDD | IPwireless | shwong@ipwireless.com | Rel-7 | Issam | RP-060477 |  |  |  |
| 2117 | 672.5 | Continuous connectivity for packet data users |  | 524d? | 2005-03-14 A | 2007-03-15 A | 100% | 2005-03-14 | 2007-03-15 | 524d? | finish no earlier than 2007-03-15 |  | R1 | 4192h | 4192h | RANimp-CPC | Siemens | Joern.Krause@siemens.com | Rel-7 | Patrick | RP-070033 |  |  |  |
| 2118 | 672.6 | Extended WCDMA Cell Range |  | 198d? | 2006-03-15 A | 2006-12-15 A | 100% | 2006-03-15 | 2006-12-15 | 198d? | finish no earlier than 2006-12-15 |  | R3 | 1584h | 1584h | RANimp-ExtCell | Ericsson | Muhammad Kazmi | Rel-7 | Juha | RP-060685 |  |  |  |
| 2119 | 672.7 | 7.68 Mcps TDD Enhanced Uplink |  | 198d? | 2006-03-15 A | 2006-12-15 A | 100% | 2006-03-15 | 2006-12-15 | 198d? | finish no earlier than 2006-12-15 |  | R1 | 1584h | 1584h | RANimp-VHCRTDD-EDCH | IPwireless | nanderson@ipwireless.com | Rel-7 | Patrick | RP-060684 |  |  |  |
| 2120 | 672.8 | Enhanced CELL_FACH State in FDD |  | 181d? | 2006-09-25 A | 2007-06-04 A | 100% | 2006-09-25 | 2007-06-04 | 181d? | finish no earlier than 2007-06-04 |  | R2 | 1448h | 1448h | RANimp-EnhState | Nokia | juho.pirskanen@nokia.com | Rel-7 | Joern | RP-070286 |  |  |  |
| 2121 | 672.9 | 64QAM for HSDPA (FDD) |  | 110d? | 2006-12-15 A | 2007-06-04 A | 100% | 2006-12-15 | 2007-06-04 | 110d? | finish no earlier than 2007-06-04 |  | R1 | 880h | 880h | RANimp-64QamDownlink | Ericsson | Johan.Bergman@ericsson.com | Rel-7 | Patrick | RP-070287 |  |  |  |
| 2122 | 672.10 | Improved L2 support for high data rates |  | 122d? | 2006-12-15 A | 2007-06-04 A | 100% | 2006-12-15 | 2007-06-04 | 122d? | finish no earlier than 2007-06-04 |  | R2 | 976h | 976h | RANimp-L2DataRates | Ericsson | Janne.Peisa@ericsson.com | Rel-7 | Joern | RP-070289 |  |  |  |
| 2123 | 672.11 | Introduction of 16QAM in HSUPA (FDD) |  | 110d? | 2006-12-15 A | 2007-06-04 A | 100% | 2006-12-15 | 2007-06-04 | 110d? | finish no earlier than 2007-06-04 |  | R1 | 880h | 880h | RANimp-16QamUplink | Nokia | Karri.Ranta-aho@nsn.com | Rel-7 | Patrick | RP-070288 |  |  |  |

Notes:
- 2097: - / Text3: 25.101
- 2098: RP#32 completed / Text3: 25.101
- 2099: RP#34 completed / Text3: 25.101
- 2100: RP#34 completed / Text3: 25.101
- 2101: RP#34 stopped. SR in RP-060680
- 2102: This item was conditionnaly approved pending decision of PCG#16 who decided not to approve it / Text3: 25.101, 25.104, 25.133, 25.141, 25.331, 25.942, 25.306, 25.307, 34.121
- 2103: Linked to Feature UID_20028 (RInImp)
- 2104: RP#32 completed / Text3: 34.108, 34.121
- 2105: RP#32 completed / Text3: 34.108, 34.121
- 2106: RP#34 completed / Text3: 34.121, 34.108
- 2107: RP#41 completed (GERAN aspects might need to be included later) / Text3: 34.114
- 2108: RP#34 completed / Text3: 34.108, 34.123-1, 34.123-2, 34.123-3
- 2109: RP#36 completed / Text3: 34.108, 34.121-1, 34.121-2
- 2110: RP#38 completed
- 2111: RP#39 completed / Text3: 34.121-1, 34.121-2
- 2112: Generic feature
- 2113: RP#34 completed
- 2114: RP#33 completed / Text3: 25.815, 25.321, 25.322, 25.331
- 2115: RP#30 completed
- 2116: RP#32 completed / Text3: 25.102, 25.123
- 2117: RP#35 completed / Text3: 25.903, 25.201, 25.211, 25.212, 25.214, 25.308, 25.321, 25.331, 25.423, 25.433, 25.101, 25.133
- 2118: RP#34 completed / Text3: 25.133, 25.423, 25.425, 25.433, 25.435, 25.453, 25.331
- 2119: RP#34 completed / Text3: 25.201, 25.202, 25.221, 25.222, 25.223, 25.224, 25.225, 25.331, 23.321, 25.306, 25.302, 25.401, 25.420, 25.423, 25.427, 25.433, 25.102, 25.105, 25.142
- 2120: RP#36 completed / Text3: 25.308, 25.304, 25.306, 25.321, 25.331, 25.433, 25.435, 25.423, 25.425,
- 2121: RP#36 completed / Text3: 25.308, 25.211, 25.212, 25.213, 25.306, 25.331, 25.433, 25.435, 25.423, 25.425, 25.101, 25.104, 25.141
- 2122: RP#36 completed / Text3: 25.301, 25.308,25.306, 25.321, 25.322, 25.331, 25.433, 25.435, 25.423, 25.425, 25.999
- 2123: RP#36 completed / Text3: 25.319, 25.101, 25.104, 25.133, 25.141, 25.211, 25.212, 25.213, 25.214, 25.306, 25.321, 25.331, 25.423, 25.433

| ID | WBS | Task | Duration | Start | Finish | Complete | Baseline start | Baseline finish | Baseline duration | Constraint | Resources | Work | Actual work | Text1 | Text4 | Text5 | Text6 | Text8 | Text11 | Text2 | Text7 |
| --- | --- | --- | --- | --- | --- | --- | --- | --- | --- | --- | --- | --- | --- | --- | --- | --- | --- | --- | --- | --- | --- |
| 2124 | 672.12 | **Interface to control Tower Mounted Amplifiers (TMAs)** | 271d? | 2006-06-02 A | 2007-06-15 A | 100% | 2006-06-02 | 2007-06-15 | 271d? |  | R3,S5 | 1648h | 1648h | RANImp-TMA | Vodafone | alexej.kulakov@vodafone.com | Rel-7 | Juha | RP-070140 |  |  |
| 2125 | 672.12.1 | RAN3 part of Interface to control Tower Mounted Amplifiers (TMAs) | 206d? | 2006-06-02 A | 2007-03-16 A | 100% | 2006-06-02 | 2007-03-16 | 206d? |  | R3 | 840h | 840h | RANImp-TMA | Vodafone | alexej.kulakov@vodafone.com | Rel-7 | Juha | RP-070140 |  |  |
| 2126 | 672.12.2 | OAM aspects to Interface to control TMAs | 101d? | 2007-01-26 A | 2007-06-15 A | 100% | 2007-01-26 | 2007-06-15 | 101d? | finish no earlier than 2007-06-15 | S5 | 808h | 808h | RANImp-TMA-OAM | Vodafone | Adrian.Neal@vodafone.com | Rel-7 | Dionisio |  |  |  |
| 2127 | 673 | **Rel-7 RAN improvements - UE Conformance Testing** | 784d? | 2006-09-20 A | 2009-09-18 A | 100% | 2006-09-20 | 2009-09-18 | 784d? |  | R5 | 25472h | 25472h | RANimp-UEConTest |  |  | Rel-7 | Ingbert |  |  |  |
| 2128 | 673.1 | Conformance Test Aspects - 3.84 Mcps and 7.68 Mcps TDD Enhanced Uplink | 518d? | 2006-09-20 A | 2008-09-12 A | 100% | 2006-09-20 | 2008-09-12 | 518d? | finish no earlier than 2008-09-12 | R5 | 4144h | 4144h | RANimp-UEConTest_EDCHTDH | IPWireless | tspeight@ipwireless.com | Rel-7 | Ingbert | RP-080536 |  |  |
| 2129 | 673.2 | Conformance Test Aspects – 64QAM for HSDPA (FDD) | 257d? | 2007-03-09 A | 2008-03-03 A | 100% | 2007-03-09 | 2008-03-03 | 257d? | finish no earlier than 2008-03-03 | R5 | 2056h | 2056h | RANimp-UEConTest_64QamDownlink | Ericsson | leif.mattisson@ericsson.com | Rel-7 | Ingbert | RP-080059 |  |  |
| 2130 | 673.3 | Conformance Test Aspects – 16QAM for HSUPA (FDD) | 321d? | 2007-03-09 A | 2008-05-30 A | 100% | 2007-03-09 | 2008-05-30 | 321d? | finish no earlier than 2008-05-30 | R5 | 2568h | 2568h | RANimp-UEConTest_16QamUplink | Motorola | carolyn.taylor@motorola.com | Rel-7 | Ingbert | RP-080281 |  |  |
| 2131 | 673.4 | Conformance Test Aspects – Improved L2 support for high data rates | 321d? | 2007-03-09 A | 2008-05-30 A | 100% | 2007-03-09 | 2008-05-30 | 321d? | finish no earlier than 2008-05-30 | R5 | 2568h | 2568h | RANimp-UEConTest_L2DataRates | Ericsson | leif.mattisson@ericsson.com | Rel-7 | Ingbert | RP-080256 |  |  |
| 2132 | 673.5 | Conformance Test Aspects – Continuous connectivity for packet data users | 321d? | 2007-03-09 A | 2008-05-30 A | 100% | 2007-03-09 | 2008-05-30 | 321d? | finish no earlier than 2008-05-30 | R5 | 2568h | 2568h | RANimp-UEConTest_CPC | Nokia | jarkko.hellsten@nokia.com | Rel-7 | Ingbert | RP-080282 |  |  |
| 2133 | 673.6 | Conformance Test Aspects – Enhanced CELL_FACH state in FDD | 662d? | 2007-03-09 A | 2009-09-18 A | 100% | 2007-03-09 | 2009-09-18 | 662d? | finish no earlier than 2009-09-18 | R5 | 5296h | 5296h | RANimp-UEConTest_EnhancedCellFACHState | Nokia | jarkko.hellsten@nokia.com | Rel-7 | Ingbert | RP-090711 |  |  |
| 2134 | 674 | **7.68 Mcps TDD option** | 783d? | 2004-09-15 A | 2007-09-14 A | 100% | 2004-09-15 | 2007-09-14 | 783d? |  | R1,R2,R3,R4,R5 | 24496h | 24496h | VHCRTDD | IPwireless | Martin Beale (mbeale@ipwireless.com) | Rel-7 |  | RP-060684 |  |  |
| 2135 | 674.1 | VHCRTDD: Stage 2 | 391d? | 2004-09-15 A | 2006-03-15 A | 100% | 2004-09-15 | 2006-03-15 | 391d? | finish no earlier than 2006-03-15 | R1 | 3128h | 3128h | VHCRTDD-Stage2 | IPwireless | Martin Beale (mbeale@ipwireless.com) | Rel-7 | Patrick | RP-060684 |  |  |
| 2136 | 674.2 | VHCRTDD: Physical Layer | 391d? | 2004-09-15 A | 2006-03-15 A | 100% | 2004-09-15 | 2006-03-15 | 391d? | finish no earlier than 2006-03-15 | R1 | 3128h | 3128h | VHCRTDD-Phys | IPwireless | Martin Beale (mbeale@ipwireless.com) | Rel-7 | Patrick | RP-060684 |  |  |
| 2137 | 674.3 | VHCRTDD: Layer 2 and layer 3 protocol aspects | 391d? | 2004-09-15 A | 2006-03-15 A | 100% | 2004-09-15 | 2006-03-15 | 391d? | finish no earlier than 2006-03-15 | R2 | 3128h | 3128h | VHCRTDD-L23 | IPwireless | drichards@ipwireless.com | Rel-7 | Joern | RP-060684 |  |  |
| 2138 | 674.4 | VHCRTDD: UTRAN Iub/Iur Protocol Aspects | 391d? | 2004-09-15 A | 2006-03-15 A | 100% | 2004-09-15 | 2006-03-15 | 391d? | finish no earlier than 2006-03-15 | R3 | 3128h | 3128h | VHCRTDD-IurIub | IPwireless | Peter Legg (plegg@ipwireless.com) | Rel-7 | Juha | RP-060684 |  |  |
| 2139 | 674.5 | VHCRTDD: RF Radio Transmission/ Reception, System Performance Requirements and Conformance Testing | 457d? | 2004-09-15 A | 2006-06-15 A | 100% | 2004-09-15 | 2006-06-15 | 457d? | finish no earlier than 2006-06-15 | R4 | 3656h | 3656h | VHCRTDD-RF | IPwireless | Shin Horng Wong (shwong@ipwireless.com) | Rel-7 | Issam | RP-060684 |  |  |
| 2140 | 674.6 | Conformance Test Aspects - 7.68 Mcps TDD | 258d? | 2006-09-20 A | 2007-09-14 A | 100% | 2006-09-20 | 2007-09-14 | 258d? | finish no earlier than 2007-09-10 | R5 | 2064h | 2064h | VHCRTDD-UEConTest | IPWireless | tspeight@ipwireless.com | Rel-7 | Ingbert | RP-070307 |  |  |
| 2141 | 675 | **3.84 Mcps TDD Enhanced Uplink** | 394d? | 2005-03-15 A | 2006-09-15 A | 100% | 2005-03-15 | 2006-09-15 | 394d? |  | RP | 18384h | 18384h | EDCHTDD | IPwireless | nanderson@ipwireless.com | Rel-7 |  | RP-060462 |  |  |
| 2142 | 675.1 | EDCHTDD: Stage 2 | 328d? | 2005-03-15 A | 2006-06-15 A | 100% | 2005-03-15 | 2006-06-15 | 328d? | finish no earlier than 2006-06-15 | R2 | 2624h | 2624h | EDCHTDD-Stage2 | IPwireless | nanderson@ipwireless.com | Rel-7 | Joern | RP-060462 |  |  |
| 2143 | 675.2 | EDCHTDD: Physical Layer | 394d? | 2005-03-15 A | 2006-09-15 A | 100% | 2005-03-15 | 2006-09-15 | 394d? | finish no earlier than 2006-09-15 | R1 | 3152h | 3152h | EDCHTDD-Phys | IPwireless | nanderson@ipwireless.com | Rel-7 | Patrick | RP-060462 |  |  |
| 2144 | 675.3 | EDCHTDD: Layer 2 and 3 Protocol Aspects | 394d? | 2005-03-15 A | 2006-09-15 A | 100% | 2005-03-15 | 2006-09-15 | 394d? | finish no earlier than 2006-09-15 | R2 | 3152h | 3152h | EDCHTDD-L23 | IPwireless | drichards@ipwireless.com | Rel-7 | Joern | RP-060462 |  |  |
| 2145 | 675.4 | EDCHTDD: UTRAN Iub/Iur Protocol Aspects | 394d? | 2005-03-15 A | 2006-09-15 A | 100% | 2005-03-15 | 2006-09-15 | 394d? | finish no earlier than 2006-09-15 | R3 | 3152h | 3152h | EDCHTDD-IurIub | Interdigital | jim.miller@interdigital.com | Rel-7 | Juha | RP-060462 |  |  |
| 2146 | 675.5 | EDCHTDD: RF Radio Transmission/ Reception, System Performance Requirements and Conformance Testing | 394d? | 2005-03-15 A | 2006-09-15 A | 100% | 2005-03-15 | 2006-09-15 | 394d? | finish no earlier than 2006-09-15 | R4 | 3152h | 3152h | EDCHTDD-RF | IPwireless | Shin Horng Wong (shwong@ipwireless.com) | Rel-7 | Issam | RP-060462 |  |  |
| 2147 | 676 | **1.28 Mcps TDD Enhanced Uplink** | 653d? | 2006-03-15 A | 2008-09-12 A | 100% | 2006-03-15 | 2008-09-12 | 653d? |  | R1,R2,R3,R4,R5 | 14760h | 14760h | LCRTDD-EDCH | CATT | Haijing Hu | Rel-7 |  | RP-070296 |  |  |
| 2148 | 676.1 | 1.28 Mcps TDD Enhanced Uplink: Physical Layer | 262d? | 2006-03-15 A | 2007-03-15 A | 100% | 2006-03-15 | 2007-03-15 | 262d? | finish no earlier than 2007-03-15 | R1 | 2096h | 2096h | LCRTDD-EDCH-Phys | CATT | Ke Wang | Rel-7 | Patrick | RP-070038 |  |  |
| 2149 | 676.2 | 1.28 Mcps TDD Enhanced Uplink: Layer 2 and 3 Protocol Aspects | 262d? | 2006-03-15 A | 2007-03-15 A | 100% | 2006-03-15 | 2007-03-15 | 262d? | finish no earlier than 2007-03-15 | R2 | 2096h | 2096h | LCRTDD-EDCH-L23 | CATT | Haiyang Quan | Rel-7 | Joern | RP-070038 |  |  |
| 2150 | 676.3 | 1.28 Mcps TDD Enhanced Uplink: UTRAN Iub/Iur Protocol Aspects | 262d? | 2006-03-15 A | 2007-03-15 A | 100% | 2006-03-15 | 2007-03-15 | 262d? | finish no earlier than 2007-03-15 | R3 | 2096h | 2096h | LCRTDD-EDCH-IubIur | CATT | Yincheng Zhang | Rel-7 | Juha | RP-070038 |  |  |
| 2151 | 676.4 | 1.28 Mcps TDD Enhanced Uplink: RF Radio Transmission/ Reception, System Performance Requirements and Conformance Testing | 328d? | 2006-03-15 A | 2007-06-15 A | 100% | 2006-03-15 | 2007-06-15 | 328d? | finish no earlier than 2007-06-15 | R4 | 2624h | 2624h | LCRTDD-EDCH-RF | CATT | Yuexia Song | Rel-7 | Issam | RP-070296 |  |  |
| 2152 | 676.5 | 1.28 Mcps TDD Enhanced Uplink - UE Conformance Testing | 257d? | 2007-09-20 A | 2008-09-12 A | 100% | 2007-09-20 | 2008-09-12 | 257d? | finish no earlier than 2008-09-11 | R5 | 624h | 624h | LCRTDD-EDCH-UEConTest | CATT | chenxiaozhong@datangmobile.cn | Rel-7 | Ingbert | RP-080539 |  |  |
| 2153 | 677 | Conformance Test Aspects – Multiple Band and Multiple Frequency operation for LCR TDD | 263d? | 2010-09-17 A | 2011-09-16 A | 100% | 2010-09-17 | 2011-09-16 | 263d? | finish no earlier than 2011-12-09 | R5 | 2091.37h | 2091.37h | LCRTDD_MB_MF_UEConTest | CATR | Ms Jun Chen (chenjun@catr.cn) | Rel-7 | Ingbert | RP-110968 | PCG-25 | RP-49 |
| 2154 | 678 | MS Antenna Performance Evaluation Method and Requirements | 731d? | 2005-01-28 A | 2007-11-16 A | 100% | 2005-01-28 | 2007-11-16 | 731d? | finish no earlier than 2007-11-16 | GP | 5848h | 5848h | APEMR | TeliaSonera | Ulf.Tegth@teliasonera.com | Rel-7 | Paolo |  |  |  |

Notes:
- 2124: RP#35 completed
- 2125: RP#35 completed
- 2126: SP#36 completed / Text3: 32.642, 32.643, 32.645 – Align with RAN 25.466
- 2127: Linked to Feature UID_20029 (RANimp)
- 2128: RP#41 completed / Text3: 34.108, 34.122, 34.123-1, 34.123-2, 34.123-3
- 2129: RP#39 completed / Text3: 34.108, 34.121-1, 34.121-2, 34.123-1, 34.123-2, 34.123-3
- 2130: RP#40 completed / Text3: 34.108, 34.121-1, 34.121-2, 34.123-1, 34.123-2, 34.123-3
- 2131: RP#40 completed / Text3: 34.108, 34.123-1, 34.123-2, 34.123-3
- 2132: RP#40 completed / Text3: 34.108, 34.121-1, 34.121-2, 34.123-1, 34.123-2, 34.123-3
- 2133: RP#45 completed / Text3: 34.108, 34.123-1, 34.123-2, 34.123-3
- 2134: RP#31 completed
- 2135: RP#31 completed / Text3: 25.202
- 2136: RP#31 completed / Text3: 25.221, 25.222, 25.223, 25.224,25.225
- 2137: RP#31 completed / Text3: 25.301, 25.302, 25.305, 25.306, 25.321, 25.331
- 2138: RP#31 completed / Text3: 25.401, 25.420, 25.423, 25.425, 25.427, 25.430, 25.433, 25.435
- 2139: RP#32 completed / Text3: 25.102, 25.105, 25.123, 25.133, 25.142
- 2140: RP#37 completed / Text3: 34.108, 34.122, 34.123-1, 34.123-2, 34.123-3
- 2141: RP#33 completed
- 2142: RP#33 completed
- 2143: RP#33 completed / Text3: 25.201, 25.221,25.222, 25.223, 25.224, 25.225
- 2144: RP#33 completed / Text3: 25.301, 25.302, 25.306, 25.321, 25.331
- 2145: RP#33 completed / Text3: 25.401, 25.420, 25.423, 25.427, 25.430, 25.433, 25.435
- 2146: RP#33 completed / Text3: 25.102, 25.105, 25.123, 25.142
- 2147: RP#35 completed
- 2148: RP#35 completed / Text3: 25.201, 25.221, 25.222, 25.223, 25.224, 25.225
- 2149: RP#35 completed / Text3: 25.301, 25.302, 25.306, 25.321, 25.331
- 2150: RP#35 completed / Text3: 25.401, 25.420, 25.423, 25.425, 25.427, 25.430, 25.433, 25.435
- 2151: RP#36 completed / Text3: 25.102, 25.105, 25.123, 25.142
- 2152: RP#41 completed / Text3: 34.108, 34.122, 34.123-1/2/3
- 2153: RP#53 completed. Core specification was introduced via Rel-7 CR under TEI7 (RP#37 RP-070650) and via 2 Rel-8 work items: RInImp9-UMTS1880TDD and RInImp8-UMTS2300TDD. / Text3: UTRA 34.108, 34.123-1, 34.123-2, 34.123-3
- 2154: GP#36 completed for R7 / Text3: 25.914, 25.144, 45.005

| ID | WBS | Task | Type | Duration | Start | Finish | Complete | Baseline start | Baseline finish | Baseline duration | Constraint | Resources | Work | Actual work | Text1 | Text4 | Text5 | Text6 | Text8 | Text12 |
| --- | --- | --- | --- | --- | --- | --- | --- | --- | --- | --- | --- | --- | --- | --- | --- | --- | --- | --- | --- | --- |
| 2155 | 679 | **Lower 700 MHz Inclusion in the GERAN Specifications** |  | 390d? | 2005-01-03 A | 2006-06-30 A | 100% | 2005-01-03 | 2006-06-30 | 390d? |  | GP | 7632h | 7632h | GSM710 | UTC | dcotton@mtview.union-tel.com | Rel-7 | Paolo |  |
| 2156 | 679.1 | Inclusion of the 698 – 746 MHz band into GERAN core specifications |  | 129d? | 2005-01-03 A | 2005-06-30 A | 100% | 2005-01-03 | 2005-06-30 | 129d? | finish no earlier than 2005-06-30 | G1 | 1032h | 1032h | GSM710-core |  |  | Rel-7 | Paolo |  |
| 2157 | 679.2 | G1 aspects of GSM710 |  | 217.5d? | 2005-08-31 A | 2006-06-30 A | 100% | 2005-08-31 | 2006-06-30 | 217.5d? | finish no earlier than 2006-06-30 | G1 | 1740h | 1740h | GSM-710-test |  |  | Rel-7 | Paolo |  |
| 2158 | 679.3 | G3 aspects of GSM710 |  | 217.5d? | 2005-08-31 A | 2006-06-30 A | 100% | 2005-08-31 | 2006-06-30 | 217.5d? | finish no earlier than 2006-06-30 | G3new | 1740h | 1740h | GSM-710-test |  |  | Rel-7 | Ingbert |  |
| 2159 | 680 | **Support of Conversational Services in A/Gb mode via the PS domain** |  | 626d? | 2005-04-08 A | 2007-08-31 A | 100% | 2005-04-08 | 2007-08-31 | 626d? |  | GP | 15442.8h | 15442.8h | SCSAGB | Ericsson | gunnar.hedby@ericsson.com | Rel-7 | Paolo |  |
| 2160 | 680.1 | Minimise the transfer delay between the SGSN and the MS |  | 604.95d? | 2005-04-08 A | 2007-08-31 A | 100% | 2005-04-08 | 2007-08-31 | 604.95d? | finish no earlier than 2007-08-31 | GP | 4839.6h | 4839.6h | SCSAGB-MTD | Ericsson | gunnar.hedby@ericsson.com | Rel-7 | Paolo |  |
| 2161 | 680.2 | Definition of radio resource management functionality for Support of Conversational Services in A/Gb mode via the PS domain |  | 626d? | 2005-04-08 A | 2007-08-31 A | 100% | 2005-04-08 | 2007-08-31 | 626d? | finish no earlier than 2007-08-31 | G1 | 5008h | 5008h | SCSAGB-RRM | Ericsson | gunnar.hedby@ericsson.com | Rel-7 | Paolo |  |
| 2162 | 680.3 | Support of Conversational Services in A/Gb mode via the PS domain – RLC Non-Persistent mode |  | 101d? | 2006-06-30 A | 2006-11-17 A | 100% | 2006-06-30 | 2006-11-17 | 101d? | finish no earlier than 2006-11-17 | G2 | 808h | 808h | SCSAGB-RLCNP | Ericsson | gunnar.hedby@ericsson.com | Rel-7 | Gert |  |
| 2163 | 680.4 | Deleted- Radio Channel Support | milestone | 0d? | 2006-07-17 A | 2006-07-17 A | 100% | 2006-07-17 | 2006-07-17 | 0d? | start no earlier than 2006-07-17 | G2 |  |  | SCSAGB-RCHS | Ericsson | gunnar.hedby@ericsson.com | Rel-7 | Gert | SP-32 |
| 2164 | 680.5 | Deleted- Modifications to FLO | milestone | 0d? | 2006-07-17 A | 2006-07-17 A | 100% | 2006-07-17 | 2006-07-17 | 0d? | start no earlier than 2006-07-17 | G2 |  |  | SCSAGB-FLO | Ericsson | gunnar.hedby@ericsson.com | Rel-7 | Gert | SP-32 |
| 2165 | 681 | **Addition of new frequency band to GSM (T-GSM810)** |  | 626d? | 2005-04-08 A | 2007-08-31 A | 100% | 2005-04-08 | 2007-08-31 | 626d? |  | GP | 12112h | 12112h | TGSM810 | Huawei | chende@huawei.com | Rel-7 | Paolo |  |
| 2166 | 681.1 | Changes to core specification |  | 106d? | 2005-04-08 A | 2005-09-02 A | 100% | 2005-04-08 | 2005-09-02 | 106d? | finish no earlier than 2005-09-02 | GP | 848h | 848h | TGSM810-Core | Huawei | chende@huawei.com | Rel-7 | Paolo |  |
| 2167 | 681.2 | Changes to MS testing specification |  | 626d? | 2005-04-08 A | 2007-08-31 A | 100% | 2005-04-08 | 2007-08-31 | 626d? | finish no earlier than 2007-08-31 | G3new | 5008h | 5008h | TGSM810-MStest | Huawei | chende@huawei.com | Rel-7 | Ingbert |  |
| 2168 | 681.3 | Changes to BTS testing specification |  | 156d? | 2005-04-08 A | 2005-11-11 A | 100% | 2005-04-08 | 2005-11-11 | 156d? | finish no earlier than 2005-11-11 | G1 | 1248h | 1248h | TGSM810-BTStest | Huawei | chende@huawei.com | Rel-7 | Paolo |  |
| 2169 | 682 | **Handover of dedicated and shared resources while in Dual Transfer Mode** |  | 421d? | 2005-04-08 A | 2006-11-17 A | 100% | 2005-04-08 | 2006-11-17 | 421d? |  | GP | 12672h | 12672h | HODSRDTM | Nokia | rami.vaittinen@nokia.com | Rel-7 | Paolo |  |
| 2170 | 682.1 | GERAN2 part of Handover of dedicated and shared resources while in Dual Transfer Mode |  | 321d? | 2005-04-08 A | 2006-06-30 A | 100% | 2005-04-08 | 2006-06-30 | 321d? | finish no earlier than 2006-06-30 | G2 | 2568h | 2568h | HODSRDTM-G2 | Nokia | rami.vaittinen@nokia.com | Rel-7 | Gert |  |
| 2171 | 682.2 | Deleted - MS Conformance Testing |  | 421d? | 2005-04-08 A | 2006-11-17 A | 100% | 2005-04-08 | 2006-11-17 | 421d? | finish no earlier than 2006-11-17 | G3new | 3368h | 3368h | HODSRDTM-MStest | Nokia | rami.vaittinen@nokia.com | Rel-7 | Ingbert | GP-32 |
| 2172 | 682.3 | Deleted - BTS conformance testing |  | 421d? | 2005-04-08 A | 2006-11-17 A | 100% | 2005-04-08 | 2006-11-17 | 421d? | finish no earlier than 2006-11-17 | G1 | 3368h | 3368h | HODSRDTM-BTStest | Nokia | rami.vaittinen@nokia.com | Rel-7 | Paolo | GP-32 |
| 2173 | 683 | **Mobile Station Receive Diversity (DARP Phase II)** |  | 526d? | 2005-11-11 A | 2007-11-16 A | 100% | 2005-11-11 | 2007-11-16 | 526d? |  | GP | 16360h | 16360h | MSRD2 | Nokia | kent.pedersen@nokia.com | Rel-7 | Paolo |  |
| 2174 | 683.1 | Performance Requirements for Mobile Station Receive Diversity, DARP Phase II |  | 331d? | 2005-11-11 A | 2007-02-16 A | 100% | 2005-11-11 | 2007-02-16 | 331d? | finish no earlier than 2007-02-16 | GP | 2648h | 2648h | MSRD2-PerfReq | Nokia | kent.pedersen@nokia.com | Rel-7 | Paolo |  |
| 2175 | 683.2 | Capability signalling of Mobile Station Receive Diversity, DARP Phase II |  | 331d? | 2005-11-11 A | 2007-02-16 A | 100% | 2005-11-11 | 2007-02-16 | 331d? | finish no earlier than 2007-02-16 | GP | 2648h | 2648h | MSRD2-CapSig | Nokia | kent.pedersen@nokia.com | Rel-7 | Paolo |  |
| 2176 | 683.3 | Test Scenarios for Mobile Station Receive Diversity, DARP Phase II |  | 331d? | 2005-11-11 A | 2007-02-16 A | 100% | 2005-11-11 | 2007-02-16 | 331d? | finish no earlier than 2007-02-16 | GP | 2648h | 2648h | MSRD2-TestSc | Nokia | kent.pedersen@nokia.com | Rel-7 | Paolo |  |
| 2177 | 683.4 | MS conformance test of DARP Phase II (MSRD) |  | 526d? | 2005-11-11 A | 2007-11-16 A | 100% | 2005-11-11 | 2007-11-16 | 526d? | finish no earlier than 2007-11-16 | GP | 4208h | 4208h | MSRD2-Msconf | Nokia | kent.pedersen@nokia.com | Rel-7 | Ingbert |  |
| 2178 | 684 | **Downlink Dual Carrier** |  | 947d? | 2006-01-20 A | 2009-09-04 A | 100% | 2006-01-20 | 2009-09-04 | 947d? |  | GP | 15446.6h | 15446.6h | GDCDL | Nokia Siemens Networks | leonardo.provvedi@roke.co.uk | Rel-7 | Paolo |  |
| 2179 | 684.1 | Downlink Dual Carrier Stage 2 |  | 116d? | 2006-01-20 A | 2006-06-30 A | 100% | 2006-01-20 | 2006-06-30 | 116d? | finish no earlier than 2006-06-30 | G1 | 928h | 928h | GDCDL-Stage2 | Nokia Siemens Networks | leonardo.provvedi@roke.co.uk | Rel-7 | Paolo |  |
| 2180 | 684.2 | Downlink Dual Carrier Stage 3 |  | 421d? | 2006-01-20 A | 2007-08-31 A | 100% | 2006-01-20 | 2007-08-31 | 421d? | finish no earlier than 2007-08-31 | G1 | 3368h | 3368h | GDCDL-Stage2 | Nokia Siemens Networks | leonardo.provvedi@roke.co.uk | Rel-7 | Paolo |  |
| 2181 | 684.3 | Downlink Dual Carrier – MS Conformance Test |  | 446.82d? | 2006-01-20 A | 2009-09-04 A | 100% | 2006-01-20 | 2009-09-04 | 446.82d? | finish no earlier than 2009-09-04 | G3new | 3574.6h | 3574.6h | GDCDL-MStest | Nokia Siemens Networks | leonardo.provvedi@roke.co.uk | Rel-7 | Ingbert |  |
| 2182 | 685 | Support of SIGTRAN in GERAN |  | 116d? | 2006-01-20 A | 2006-06-30 A | 100% | 2006-01-20 | 2006-06-30 | 116d? | finish no earlier than 2006-06-30 | GP | 928h | 928h | GSIGT | Ericsson | peter.ostrup@ericsson.com | Rel-7 | Ingbert |  |

Notes:
- 2155: - / Text3: 24.008, 43.022, 44.018, 44.118, 45, 001, 45.005, 51.010, 51.021
- 2156: Completed / Text3: 24.008, 43.022, 44.018, 44.118, 45, 001, 45.005,
- 2157: - / Text3: 51.021
- 2158: - / Text3: 51.010
- 2159: Originally started Nov. 2003 as GP-030443
- 2160: -
- 2161: -
- 2162: - / Text3: 43.955, 43.064, 44.060, 45.001, 45.002, 45.003, 45.005, 45.010, 51.010, 51.021
- 2163: -
- 2164: -
- 2165: - / Text3: 45.005, 45.050, 24.008, 45.008, 45.001, 43.022, 43.030, 44.018, 44.060, 51.010-1, 51.021
- 2166: - / Text3: 45.005, 45.050, 24.008, 45.008, 45.001, 43.022, 43.030, 44.018, 44.060
- 2167: - / Text3: 51010-1
- 2168: - / Text3: 51021
- 2169: GP#30 completed. Started at GP#24
- 2170: GP#30 completed / Text3: 43.055, 44.018, 44.060
- 2171: Stopped, no work done. 12/2008 Marked as stopped ("deleted") / Text3: 51-010
- 2172: Stopped, no work done. 12/2008 Marked as stopped ("deleted") / Text3: 51.026
- 2173: GP#36 completed
- 2174: GP#33 completed / Text3: 45.005
- 2175: GP#33 completed / Text3: 24.008
- 2176: GP#33 completed / Text3: 45.005
- 2177: GP#36 completed / Text3: 51.010
- 2178: GP#35 completed
- 2179: GP#30 completed / Text3: 43.055, 43.064
- 2180: GP#35 completed / Text3: 24.008, 44.018, 44.060, 45.001, 45.002, 45.005, 45.008
- 2181: GP#43 completed / Text3: 51.010
- 2182: GP#30 completed / Text3: 48.001, 48.006, 43.059, 49.031

| ID | WBS | Task | Type | Duration | Start | Finish | Complete | Baseline start | Baseline finish | Baseline duration | Constraint | Resources | Work | Actual work | Text1 | Text4 | Text5 | Text6 | Text8 | Text12 |
| --- | --- | --- | --- | --- | --- | --- | --- | --- | --- | --- | --- | --- | --- | --- | --- | --- | --- | --- | --- | --- |
| 2183 | 686 | **Latency Reductions** |  | 306d? | 2006-06-30 A | 2007-08-31 A | 100% | 2006-06-30 | 2007-08-31 | 306d? |  | GP | 7344h | 7344h | LATRED | Ericsson | Hakan.Persson@Ericsson.com | Rel-7 | Paolo |  |
| 2184 | 686.1 | Improved Ack/Nack reporting |  | 306d? | 2006-06-30 A | 2007-08-31 A | 100% | 2006-06-30 | 2007-08-31 | 306d? | finish no earlier than 2007-08-31 | G2 | 2448h | 2448h | LATRED-ACKNAR | Ericsson | Hakan.Persson@Ericsson.com | Rel-7 | Gert |  |
| 2185 | 686.2 | Reduced TTI |  | 306d? | 2006-06-30 A | 2007-08-31 A | 100% | 2006-06-30 | 2007-08-31 | 306d? | finish no earlier than 2007-08-31 | G2 | 2448h | 2448h | LATRED-REDTTI | Ericsson | Hakan.Persson@Ericsson.com | Rel-7 | Gert |  |
| 2186 | 687 | PS Handover between GERAN/UTRAN mode and GAN Mode |  | 166d? | 2006-06-30 A | 2007-02-16 A | 100% | 2006-06-30 | 2007-02-16 | 166d? | finish no earlier than 2007-02-16 | G2 | 1328h | 1328h | GUGAN | Ericsson | John.Diachina@Ericsson.com | Rel-7 | Gert |  |
| 2187 | 688 | **Higher Uplink performance for GERAN Evolution** |  | 1227d? | 2006-09-08 A | 2011-05-20 A | 100% | 2006-09-08 | 2011-05-20 | 1227d? |  | GP | 37184h | 37184h | HUGE | Nokia Siemens Networks, Ericsson | eddie.riddington@nokia.com, stefan.g.eriksson@ericsson.com | Rel-7 | Paolo |  |
| 2188 | 688.1 | Stage 2 for HUGE |  | 261d? | 2006-09-08 A | 2007-09-07 A | 100% | 2006-09-08 | 2007-09-07 | 261d? | finish no earlier than 2007-09-07 | G1 | 2088h | 2088h | HUGE-Stage2 | Nokia Siemens Networks, Ericsson | eddie.riddington@nokia.com, stefan.g.eriksson@ericsson.com | Rel-7 | Paolo |  |
| 2189 | 688.2 | Layer 1 Support for HUGE |  | 381d? | 2006-09-08 A | 2008-02-22 A | 100% | 2006-09-08 | 2008-02-22 | 381d? | finish no earlier than 2008-02-22 | G1 | 3048h | 3048h | HUGE-Layer1 | Nokia Siemens Networks, Ericsson | eddie.riddington@nokia.com, stefan.g.eriksson@ericsson.com | Rel-7 | Paolo |  |
| 2190 | 688.3 | Layer 2/3 Support for HUGE |  | 256d? | 2006-09-08 A | 2007-08-31 A | 100% | 2006-09-08 | 2007-08-31 | 256d? | finish no earlier than 2007-08-31 | G2 | 2048h | 2048h | HUGE-Layer23 | Nokia Siemens Networks, Ericsson | eddie.riddington@nokia.com, stefan.g.eriksson@ericsson.com | Rel-7 | Gert |  |
| 2191 | 688.4 | Performance requirements for HUGE |  | 516d? | 2006-09-08 A | 2008-08-29 A | 100% | 2006-09-08 | 2008-08-29 | 516d? | finish no earlier than 2008-08-29 | G1 | 4128h | 4128h | HUGE-Perfreq | Nokia Siemens Networks, Ericsson | eddie.riddington@nokia.com, stefan.g.eriksson@ericsson.com | Rel-7 | Paolo |  |
| 2192 | 688.5 | BTS Conformance Test for HUGE |  | 782d? | 2006-09-08 A | 2009-09-04 A | 100% | 2006-09-08 | 2009-09-04 | 782d? | finish no earlier than 2009-09-04 | G1 | 6248h | 6248h | HUGE-BTStest | Nokia Siemens Networks, Ericsson | eddie.riddington@nokia.com, stefan.g.eriksson@ericsson.com | Rel-7 | Paolo |  |
| 2193 | 688.6 | MS Conformance Test for HUGE |  | 1226d? | 2006-09-08 A | 2011-05-20 A | 100% | 2006-09-08 | 2011-05-20 | 1226d? | finish no earlier than 2011-05-20 | G3new | 9808h | 9808h | HUGE-Mstest | Nokia Siemens Networks, Ericsson | eddie.riddington@nokia.com, stefan.g.eriksson@ericsson.com | Rel-7 | Ingbert |  |
| 2194 | 689 | **REduced symbol Duration, Higher Order modulation and Turbo coding (RED HOT) for downlink** |  | 1177d? | 2006-11-17 A | 2011-05-20 A | 100% | 2006-11-17 | 2011-05-20 | 1177d? |  | GP | 28808h | 28808h | REDHOT | Ericsson, Nokia Siemens Networks, Marvell | stefan.g.eriksson@ericsson.com | Rel-7 | Paolo |  |
| 2195 | 689.1 | Stage 2 for REDHOT |  | 206d? | 2006-11-17 A | 2007-08-31 A | 100% | 2006-11-17 | 2007-08-31 | 206d? | finish no earlier than 2007-08-31 | G1 | 1648h | 1648h | REDHOT-Stage2 | Ericsson, Nokia Siemens Networks, Marvell | stefan.g.eriksson@ericsson.com | Rel-7 | Paolo |  |
| 2196 | 689.2 | Stage 3 for REDHOT |  | 391d? | 2006-11-17 A | 2008-05-16 A | 100% | 2006-11-17 | 2008-05-16 | 391d? | finish no earlier than 2008-05-16 | G1 | 3128h | 3128h | REDHOT-Stage3 | Ericsson, Nokia Siemens Networks, Marvell | stefan.g.eriksson@ericsson.com | Rel-7 | Paolo |  |
| 2197 | 689.3 | BTS Conformance Tests for REDHOT |  | 651d? | 2006-11-17 A | 2009-05-15 A | 100% | 2006-11-17 | 2009-05-15 | 651d? | finish no earlier than 2009-05-15 | G1 | 5208h | 5208h | REDHOT-BTStest | Ericsson, Nokia Siemens Networks, Marvell | stefan.g.eriksson@ericsson.com | Rel-7 | Paolo |  |
| 2198 | 689.4 | MS Conformance Tests for REDHOT |  | 1176d? | 2006-11-17 A | 2011-05-20 A | 100% | 2006-11-17 | 2011-05-20 | 1176d? | finish no earlier than 2011-05-20 | G3new | 9408h | 9408h | REDHOT-Mstest | Ericsson, Nokia Siemens Networks, Marvell | stefan.g.eriksson@ericsson.com | Rel-7 | Ingbert |  |
| 2199 | 690 | (Small) Technical Enhancements and Improvements for Rel-7 | milestone | 0d? | 2007-03-26 A | 2007-03-26 A | 100% | 2007-03-26 | 2007-03-26 | 0d? | start no earlier than 2007-03-26 | All |  |  | TEI7 |  |  | Rel-7 | All |  |
| 2200 | 691 | Test - (Small) Technical Enhancements and Improvements for Rel-7 |  | 389d? | 2006-06-02 A | 2007-11-28 A | 100% | 2006-06-02 | 2007-11-28 | 389d? | finish no earlier than 2010-06-04 | R5 | 3112h | 3112h | TEI7_Test |  |  | Rel-7 | Ingbert |  |
| 2201 | 692 | **Deleted - PS domain and IMS support for IMS Emergency sessions** |  | 63.69d? | 2006-06-23 A | 2006-09-21 A | 100% | 2006-06-23 | 2006-09-21 | 63.69d? |  | S2 |  |  | IMS-EMER | Nokia | curt.c.wong@nokia.com | Rel-7 | Maurice | SP-30 |
| 2202 | 692.1 | Deleted - IMS aspects to support IMS Emergency sessions | milestone | 0d? | 2006-06-23 A | 2006-09-21 A | 100% | 2006-06-23 | 2006-09-21 | 0d? | start no earlier than 2006-06-23 | S2 |  |  | IMS-EMER | Nokia | curt.c.wong@nokia.com | Rel-7 | Maurice | SP-30 |
| 2203 | 692.2 | Deleted - PS domain aspects to support IMS Emergency sessions | milestone | 0d? | 2006-06-23 A | 2006-09-21 A | 100% | 2006-06-23 | 2006-09-21 | 0d? | start no earlier than 2006-06-23 | S2 |  |  | IMS-EMER | Nokia | curt.c.wong@nokia.com | Rel-7 | Maurice | SP-30 |
| 2204 | 16.7 | **Deleted - IMS Local services** |  | 0d? | 2006-01-06 A | 2006-01-06 A | 100% | 2006-01-06 | 2006-01-06 | 0d? |  | S2 |  |  | IMSLocal |  |  | Rel-7 | Maurice | SP-28 |
| 2205 | 16.7.1 | Deleted - Stage 2 | milestone | 0d | 2006-01-06 A | 2006-01-06 A | 100% | 2006-01-06 | 2006-01-06 | 0d | start no earlier than 2006-01-06 | S2 |  |  | IMSLocal |  |  | Rel-7 | Maurice | SP-26 |
| 2206 | 693.2 | Deleted - Stage 3 for IMS Local services | milestone | 0d? | 2006-01-06 A | 2006-01-06 A | 100% | 2006-01-06 | 2006-01-06 | 0d? | finish no earlier than 2006-01-06 | C1 |  |  | IMSLocal | Lucent | Keith Drage (drage@alcatel-lucent.com) | Rel-7 | Frederic | SP-25 |
| 2207 | 694 | Deleted - IMS Phase 3 | milestone | 0d? | 2006-01-06 A | 2006-01-06 A | 100% | 2006-01-06 | 2006-01-06 | 0d? | start no earlier than 2006-01-06 | S2 |  |  |  |  |  | Rel-7 | Maurice | SP-25 |
| 2208 | 695 | Deleted - Improvements of Radio Interface | milestone | 0d? | 2004-09-15 A | 2004-09-15 A | 100% | 2004-09-15 | 2004-09-15 | 0d? | start no earlier than 2004-09-15 | RP |  |  | RInImp |  |  | Rel-7 | Issam | SP-24 |
| 2209 | 696 | Deleted: Generic User Profile Phase 2 | milestone | 0d | 2005-08-08 A | 2006-06-30 A | 100% | 2005-08-08 | 2006-06-30 | 0d |  | C4 |  |  |  |  |  | Rel-7 | Kimmo | SP-27 |
| 2210 | 30.4 | Deleted - Stage 3 - Common objects | milestone | 0d | 2005-08-08 A | 2006-06-30 A | 100% | 2005-08-08 | 2006-06-30 | 0d | finish no earlier than 2006-06-30 | C4 |  |  |  |  |  | Rel-7 | Kimmo | SP-27 |
| 2211 | 698 | Release 7 Studies |  | 841d? | 2004-06-28 A | 2007-09-17 A | 100% | 2004-06-28 | 2007-09-17 | 841d? |  | CP,GP,RP,SP | 6728h | 6728h |  |  |  | Rel-7 | All |  |
| 2212 | 699 | Study on Multimedia Telephony Capabilities for IMS |  | 276d? | 2005-07-11 A | 2006-07-31 A | 100% | 2005-07-11 | 2006-07-31 | 276d? |  | S1 | 2145.6h | 2145.6h | MITE | Ericsson | peter.bleckert@ericsson.com | Rel-7 | Alain |  |
| 2213 | 700 | Study on Behaviour of Multi system UEs |  | 384d? | 2004-06-28 A | 2005-12-15 A | 100% | 2004-06-28 | 2005-12-15 | 384d? | start no earlier than 2004-06-28 | S1 | 3072h | 3072h | BMSU | Qualcomm | dwilliams@qualcomm.com | Rel-7 | Alain |  |
| 2214 | 701 | Study on Combining CS calls and IMS sessions |  | 189d? | 2004-06-28 A | 2005-03-17 A | 100% | 2004-06-28 | 2005-03-17 | 189d? | start no earlier than 2004-06-28 | S1 | 1512h | 1512h | IRTSD-CS_IMS | TeliaSonera | robert.frank@teliasonera.com | Rel-7 | Alain |  |
| 2215 | 702 | Study on All-IP Network |  | 188d? | 2004-06-28 A | 2005-03-16 A | 100% | 2004-06-28 | 2005-03-16 | 188d? | start no earlier than 2004-06-28 | S1 | 1504h | 1504h | FS_AIPN | NTT DoCoMo | Shin-ichi Isobe (isobes@nttdocomo.co.jp) | Rel-7 | Alain |  |
| 2216 | 703 | Study on Videotelephony teleservice |  | 231d? | 2005-03-01 A | 2006-01-17 A | 100% | 2005-03-01 | 2006-01-17 | 231d? |  | S1 | 1848h | 1848h | VidTel | T-Mobile | michael.kurz@t-mobile.at | Rel-7 | Alain |  |
| 2217 | 704 | Study on Network Selection Principles |  | 193d? | 2005-03-15 A | 2005-12-08 A | 100% | 2005-03-15 | 2005-12-08 | 193d? |  | S1 | 1544h | 1544h | NetSel | O2 | chris.friel@O2.com | Rel-7 | Alain |  |
| 2218 | 705 | Study on Multimedia Priority Service |  | 851d? | 2003-03-28 A | 2006-06-30 A | 100% | 2003-03-28 | 2006-06-30 | 851d? | finish no earlier than 2005-12-16 | S1 | 6808h | 6808h | PRIOR-MM | Telcordia | James Garrahan (jgarraha@telcordia.com) | Rel-7 | Alain |  |
| 2219 | 706 | Study on Transferring of emergency Call data |  | 190d? | 2005-07-11 A | 2006-03-31 A | 100% | 2005-07-11 | 2006-03-31 | 190d? | finish no earlier than 2005-12-08 | S1 | 1520h | 1520h | eCALL | Motorola | jian.j.wu@motorola.com | Rel-7 | Alain |  |
| 2220 | 707 | Study on Enhancement of E2E QoS |  | 281.4d? | 2004-06-28 A | 2005-09-15 A | 100% | 2004-06-28 | 2005-09-15 | 281.4d? | finish no earlier than 2005-12-01 | S2 | 2251.2h | 2251.2h | QoS7 | Huawei | Robert Jaksa | Rel-7 | Maurice |  |
| 2221 | 708 | Study on SOAP/HTTP IRP Solution Sets |  | 330d? | 2005-09-02 A | 2006-12-07 A | 100% | 2005-09-02 | 2006-12-07 | 330d? | finish no earlier than 2006-12-07 | S5 | 2640h | 2640h | OAM7-NIM-XML | Nortel | Suzèle Lariven (lariven@nortel.com) | Rel-7 | Dionisio |  |
| 2222 | 709 | Study on Itf-N Implementation Conformance Statement (ICS) template |  | 400d? | 2005-09-02 A | 2007-03-15 A | 100% | 2005-09-02 | 2007-03-15 | 400d? | finish no earlier than 2007-03-15 | S5 | 3200h | 3200h | OAM7-NIM-ICS | China Mobile | Li Yewen (liyewen@chinamobile.com) | Rel-7 | Dionisio |  |
| 2223 | 710 | Study on IRP Information Model |  | 400d? | 2005-09-02 A | 2007-03-15 A | 100% | 2005-09-02 | 2007-03-15 | 400d? | finish no earlier than 2007-03-15 | S5 | 3200h | 3200h | OAM7-NIM-IM | Motorola | trevor.pirt@motorola.com | Rel-7 | Dionisio |  |
| 2224 | 711 | Study on Bandwidth Saving at Nb Interface with IP transport |  | 261d? | 2006-03-10 A | 2007-03-09 A | 100% | 2006-03-10 | 2007-03-09 | 261d? | finish no earlier than 2007-03-09 | C3 | 2088h | 2088h | BSNbIP | Siemens | Thomas.Belling@siemens.com | Rel-7 | Jiwan |  |
| 2225 | 712 | Study on Routeing of MT-SMS via the HPLMN |  | 301d? | 2005-10-07 A | 2006-12-01 A | 100% | 2005-10-07 | 2006-12-01 | 301d? | finish no earlier than 2006-12-01 | C4 | 2408h | 2408h | SMS7 | Vodafone | Nick.Russell@vodafone.com | Rel-7 | Kimmo |  |
| 2226 | 713 | Study on the TCAPsec Gateway concept |  | 96d? | 2005-10-28 A | 2006-03-10 A | 100% | 2005-10-28 | 2006-03-10 | 96d? | finish no earlier than 2006-03-10 | C4 | 768h | 768h | SEC7-TCAP | Siemens | Ulrich.wiehe@gksag.de | Rel-7 | Kimmo |  |
| 2227 | 714 | Study on using M2PA in 3GPP network |  | 318d? | 2006-03-22 A | 2007-06-08 A | 100% | 2006-03-22 | 2007-06-08 | 318d? | finish no earlier than 2007-06-08 | C4 | 2544h | 2544h | FS-M2PA | China Mobile | zhaoyuyi@chinamobile.com | Rel-7 | Kimmo |  |

Notes:
- 2183: GP#35 completed / Text3: 45.001, 45.002, 45.003, 45.005, 45.010, 43.055, 43.064, 44.060, 51.010-1, 51.021
- 2184: GP#35 completed / Text3: 45.001, 45.002, 45.003, 45.005, 45.010, 43.055, 43.064, 44.060, 51.010-1, 51.021
- 2185: GP#35 completed / Text3: 45.001, 45.002, 45.003, 45.005, 45.010, 43.055, 43.064, 44.060, 51.010-1, 51.021
- 2186: GP#33 completed / Text3: 43.318, 44.318, 43.129, 25.306, 24.008, 44.060, 25.331, 51.010
- 2187: GP#39 completed
- 2188: GP#35 completed / Text3: 43.055, 43.064
- 2189: GP#37 completed / Text3: 45.001, 45.002, 45.003, 45.004, 45.008
- 2190: GP#35 completed / Text3: 24.008, 44.018, 44.060
- 2191: GP#39 completed / Text3: 45.005
- 2192: GP#43 completed / Text3: 51.021
- 2193: GP#50 completed / Text3: 51.010
- 2194: GP#38 completed
- 2195: GP#35 completed / Text3: 43.055, 43.064
- 2196: GP#38 completed / Text3: 24.008, 44.018, 44.060, 45.001, 45.002, 45.003, 45.004, 45.005, 45.008
- 2197: GP#42 completed / Text3: 51.021
- 2198: GP#50 completed / Text3: 51.010
- 2199: -
- 2200: -
- 2201: Approved at SP#29 / Text3: 23.867, 23.abc, 23.060, 23.002, 23.271
- 2202: Approved at SP#29 / Text3: 23.867, 23.abc, 23.060, 23.002, 23.271
- 2203: Approved at SP#29 / Text3: 23.867, 23.abc, 23.060, 23.002, 23.271
- 2204: - / Text3: 23.228
- 2205: DAB - Not yet required in SA2 as it exists in previous releases
- 2206: -
- 2207: -
- 2208: Stage 2 description of Interim conclusion
- 2209: Created at TSG#27 by A. Sultan because of the move to Rel-7 of "Common Objects".
- 2210: No progress in CN4#26. This have to be moved to Rel-7. It was deleted from WID / Text3: 24.241
- 2211: -
- 2212: Spin-off Feature UID_7038 (MTSI) / Text3: 22.973
- 2213: - / Text3: 22.936
- 2214: - / Text3: 22.979
- 2215: 07/08 Moved to Rel-7 as Study out of stopped Rel-8 Feature UID_31067 All-IP Network (AIPN) / Text3: 22.978
- 2216: - / Text3: 22.903
- 2217: Spin-off Feature Network selection enhancements (NSP-CR) UID_7041 / Text3: 22.811
- 2218: Spin-off Feature PRIOR UID_340044 / Text3: 22.953
- 2219: - / Text3: 22.967
- 2220: - / Text3: 23.802
- 2221: SP#34 completed / Text3: 32.809
- 2222: SP#35 completed / Text3: 32.812
- 2223: SP#35 completed / Text3: 32.810
- 2224: Moved to FS at CT32 (in line with slides) / Text3: 29.814
- 2225: Previously known as "Study of a SMS Centre for MT SMS" / Text3: 23.840
- 2226: TR 29.800 content moved to TS 29.204 under implementation WI UID_310005 TCAPsec Gateway / Text3: 29.800
- 2227: - / Text3: 29.801

| ID | WBS | Task | Type | Duration | Start | Finish | Complete | Baseline start | Baseline finish | Baseline duration | Constraint | Resources | Work | Actual work | Text1 | Text3 | Text4 | Text5 | Text6 | Text8 | Text11 | Text12 |
| --- | --- | --- | --- | --- | --- | --- | --- | --- | --- | --- | --- | --- | --- | --- | --- | --- | --- | --- | --- | --- | --- | --- |
| 2228 | 715 | **Study on Support of (G)MSC-S - (G)MSC-S Nc Interface based on the SIP-I protocol** |  | 350d? | 2006-05-15 A | 2007-09-14 A | 100% | 2006-05-15 | 2007-09-14 | 350d? |  | C4,C3 | 5000h | 5000h | NcSIP | 29.802 | Vodafone | david.hutton@vodafone.com | Rel-7 | Kimmo |  |  |
| 2229 | 715.1 | CT4 aspects of NcSIP |  | 275d? | 2006-05-15 A | 2007-06-01 A | 100% | 2006-05-15 | 2007-06-01 | 275d? | finish no earlier than 2007-06-01 | C4 | 2200h | 2200h | NcSIP | 29.802 | Vodafone | david.hutton@vodafone.com | Rel-7 | Kimmo |  |  |
| 2230 | 715.2 | CT3 aspects of NcSIP |  | 350d? | 2006-05-15 A | 2007-09-14 A | 100% | 2006-05-15 | 2007-09-14 | 350d? | finish no earlier than 2007-09-14 | C3 | 2800h | 2800h | NcSIP | 29.802 | Ericsson | ragnar.huslende@ericsson.com | Rel-7 | Jiwan |  |  |
| 2231 | 716 | Study on Evolved UTRA and UTRAN |  | 458d? | 2004-12-15 A | 2006-09-15 A | 100% | 2004-12-15 | 2006-09-15 | 458d? | finish no earlier than 2006-09-15 | RP | 3664h | 3664h | RANFS-Evo | 25.912 | NTT DoCoMo | nakamurata@NTTDOCOMO.CO.JP | Rel-7 | Issam | RP-060472 |  |
| 2232 | 717 | Study on Performance Evaluation of the UE behaviour in high speed trains with speeds up to 350 kmph |  | 328d? | 2005-03-15 A | 2006-06-15 A | 100% | 2005-03-15 | 2006-06-15 | 328d? | finish no earlier than 2006-06-15 | R4 | 2624h | 2624h | RANFS-HSTrains | none | Vodafone | Mike.vogel@vodafone.com,tim.frost@vodafone.com | Rel-7 | Issam | RP-060412 |  |
| 2233 | 718 | Study on UTRA Tower Mounted Amplifier (FDD) |  | 195d? | 2005-06-15 A | 2006-03-14 A | 100% | 2005-06-15 | 2006-03-14 | 195d? | finish no earlier than 2006-03-15 | R4 | 1560h | 1560h | RANFS-TMA | 25.818 | Ericsson | Klas.Sjerling@ericsson.com | Rel-7 | Issam | RP-060035 |  |
| 2234 | 719 | Study on Continuous connectivity for packet data users |  | 132d? | 2005-03-15 A | 2005-09-14 A | 100% | 2005-03-15 | 2005-09-14 | 132d? | finish no earlier than 2005-09-15 | R1 | 1056h | 1056h | RANFS-cont-packet | none | Siemens | joerg.gustrau@siemens.com | Rel-7 | Patrick | RP-050427 |  |
| 2235 | 720 | Study on Improvement of the Multimedia Broadcast Multicast Service (MBMS) in UTRAN |  | 262d? | 2005-12-15 A | 2006-12-15 A | 100% | 2005-12-15 | 2006-12-15 | 262d? | finish no earlier than 2006-12-15 | R2 | 2096h | 2096h | RANFS-MBMSImp | 25.905 | LG Electronics | leego@lge.com | Rel-7 | Joern | RP-060692 |  |
| 2236 | 721 | Study on Performance Improvements in Small Cells using HSDPA/EDCH |  | 131d? | 2005-12-15 A | 2006-06-15 A | 100% | 2005-12-15 | 2006-06-15 | 131d? | finish no earlier than 2006-06-15 | R4 | 1048h | 1048h | SMALLCELLS | none | Cingular | Marc Grant | Rel-7 | Issam | RP-060263 |  |
| 2237 | 722 | Study on Further Improved Performance Requirements for UMTS/HSDPA UE (FDD) |  | 383d? | 2005-12-15 A | 2007-06-04 A | 100% | 2005-12-15 | 2007-06-04 | 383d? | finish no earlier than 2007-06-04 | R4 | 3064h | 3064h | RANFS-IC | 25.963 | Cingular | Marc Grant | Rel-7 | Issam | RP-070499 |  |
| 2238 | 723 | Study on Scope of future FDD HSPA Evolution |  | 394d? | 2006-03-15 A | 2007-09-17 A | 100% | 2006-03-15 | 2007-09-17 | 394d? | finish no earlier than 2007-09-17 | RP | 3152h | 3152h | RANFS-HSPAEvo | 25.999 | Cingular | Don Zelmer (dz1069@att.com) | Rel-7 | Issam | RP-070533 |  |
| 2239 | 724 | Study on Dynamically reconfiguring a FDD UE receiver to reduce power consumption when desired Quality of Service is met | milestone | 0d? | 2007-06-22 A | 2007-06-22 A | 100% | 2007-06-22 | 2007-06-22 | 0d? |  | R4 |  |  | FSUEPow | 25.906 | Nokia | Chris.callender@nokia.com, tiina.s.koskinen@nokia.com | Rel-7 | Issam | RP-070534 |  |
| 2240 | 725 | Study on Future GERAN Evolution |  | 486d? | 2005-04-08 A | 2007-02-16 A | 100% | 2005-04-08 | 2007-02-16 | 486d? | finish no earlier than 2007-02-16 | GP | 3888h | 3888h | FGE | 45.912 | Nokia | eddie.riddington@nokia.com | Rel-7 | Paolo |  |  |
| 2241 | 726 | Study on GAN Enhancements | milestone | 0d? | 2007-08-31 A | 2007-08-31 A | 100% | 2007-08-31 | 2007-08-31 | 0d? | start no earlier than 2007-08-31 | GP |  |  | EGAN | 43.902 | T-Mobile | janne.linkola@t-mobile.com | Rel-7 | Paolo |  |  |
| 2242 | 727 | Deleted - Study on IMS with real time services deployment |  | 316d? | 2004-06-28 A | 2005-09-12 A | 100% | 2004-06-28 | 2005-09-12 | 316d? |  | S1 | 2528h | 2528h | IRTSD |  |  |  | Rel-7 | Alain |  | SP-30 |
| 2243 | 728 | Deleted - Covered by SI - Personal Network (PN) and Personal Area Network (PAN) | milestone | 0d? | 2005-12-08 A | 2005-12-20 A | 100% | 2005-12-08 | 2005-12-20 | 0d? | start no earlier than 2005-12-08 | S1 |  |  | PNPAN |  | Vodafone | armin.toepfer@vodafone.com | Rel-7 | Alain |  | SP-30 |
| 2244 | 729 | Deleted - Study on Personal Network and Personal Area Network | milestone | 0d? | 2006-10-20 A | 2006-10-20 A | 100% | 2006-10-20 | 2006-10-20 | 0d? | finish no earlier than 2006-10-20 | S1 |  |  | PNPAN |  |  |  | Rel-7 | Alain |  | SP-31 |
| 2245 | 730 | Deleted - Covered by SI - Multimedia Telephony Capabilities for IMS | milestone | 0d? | 2005-12-08 A | 2005-12-20 A | 100% | 2005-12-08 | 2005-12-20 | 0d? | start no earlier than 2005-12-08 | S1 |  |  | MITE |  | Ericsson | peter.bleckert@ericsson.com | Rel-7 | Alain |  | SP-30 |
| 2246 | 731 | Deleted - Covered by SI - Transferring of emergency Call data | milestone | 0d? | 2005-12-08 A | 2005-12-08 A | 100% | 2005-12-08 | 2005-12-08 | 0d? | start no earlier than 2005-12-08 | S1 |  |  | eCALL |  | Motorola | steven.vardy@motorola.com | Rel-7 | Alain |  | SP-30 |
| 2247 | 732 | Deleted - Covered by SI - MBMS Enhancements | milestone | 0d? | 2005-12-08 A | 2005-12-08 A | 100% | 2005-12-08 | 2005-12-08 | 0d? | start no earlier than 2005-12-08 | S1 |  |  | MBMSE |  | China Mobile | liuhongyfw@chinamobile.com | Rel-7 | Alain |  | SP-30 |
| 2248 | 733 | Deleted - Study on Customised Alerting Tone (CAT) Requirements (was duplicated) | milestone | 0d? | 2006-06-30 A | 2006-06-30 A | 100% | 2006-06-30 | 2006-06-30 | 0d? | start no earlier than 2006-06-30 | S1 |  |  | CAT |  |  |  | Rel-7 | Alain |  | SP-31 |
| 2249 | 734 | Deleted - Study on LCS architecture for I-WLAN (covered by 32108) | milestone | 0d? | 2006-12-08 A | 2006-12-08 A | 100% | 2006-12-08 | 2006-12-08 | 0d? | start no earlier than 2006-12-08 | S2 |  |  | IMS-SE |  | LG Electronics | Donghee Shim dhshim@lge.com ; phede@lge.com | Rel-7 | Maurice |  | SP-33 |
| 2250 | 735 | Deleted - IMS security extensions (covered by UID33027) | milestone | 0d? | 2005-12-08 A | 2005-12-08 A | 100% | 2005-12-08 | 2005-12-08 | 0d? | start no earlier than 2005-12-08 | S3 |  |  | IMS-SE |  | Ericsson | Bengt.Sahlin@ericsson.com | Rel-7 | Dionisio |  | SP-30 |
| 2251 | 736 | **Deleted - Study on applicability of GALILEO for LCS** |  | 0d? | 2005-06-30 A | 2005-06-30 A | 100% | 2005-06-30 | 2005-06-30 | 0d? |  | S2 |  |  | Galileo |  |  |  | Rel-7 | Maurice |  | SP-25 |
| 2252 | 736.1 | Deleted - TR on Stage 2 | milestone | 0d? | 2005-06-30 A | 2005-06-30 A | 100% | 2005-06-30 | 2005-06-30 | 0d? | finish no earlier than 2005-06-30 | S2 |  |  | Galileo |  |  |  | Rel-7 | Maurice |  | SP-25 |
| 2253 | 736.2 | Deleted - GERAN review of the TR | milestone | 0d? | 2005-06-30 A | 2005-06-30 A | 100% | 2005-06-30 | 2005-06-30 | 0d? | start no earlier than 2005-06-30 | GP |  |  | Galileo |  |  |  | Rel-7 | Paolo |  | SP-26 |
| 2254 | 737 | Deleted - Study on Stage 2 (IMS services using CS bearers) |  | 316d? | 2004-06-28 A | 2005-09-12 A | 100% | 2004-06-28 | 2005-09-12 | 316d? | finish no earlier than 2005-09-12 | S2 | 2528h | 2528h | IRTSD-IMSCS | 23.899 | Nortel | Mark Watson | Rel-7 | Maurice |  | SP-30 |

Notes:
- 2228: -
- 2229: -
- 2230: -
- 2231: RP#33 (Sep 2006) completed. SR in RP-060472
- 2232: RP#32 (Jun 2006) completed. SR in RP-060412
- 2233: RP#31 (Mar 2006) completed. SR in RP-060035
- 2234: RP#29 (Sep 2006) completed. SR in RP-050427
- 2235: RP#34 completed
- 2236: RP#32 (Jun 2006) closed (no progress). SR in RP-060263
- 2237: RP#36 (May 2007) completed. SR in RP-070499
- 2238: RP#37 (Sep 2007) completed. SR in RP-070533
- 2239: RP#37 (Sep 2007) completed. SR in RP-070534
- 2240: GP#33 completed
- 2241: GP#35 completed
- 2242: -
- 2243: -
- 2244: Moved from FS section Feb 06
- 2245: -
- 2246: -
- 2247: -
- 2248: Awaiting MCC SA3 input
- 2249: -
- 2250: -
- 2251: -
- 2252: -
- 2253: -
- 2254: SP-30: S2 has no intention for TR completion

| ID | WBS | Task | Type | Duration | Start | Finish | Complete | Baseline start | Baseline finish | Baseline duration | Constraint | Resources | Work | Actual work | Text1 | Text6 | Text8 | Text12 | Text3 | Text4 | Text5 | Text7 | Text10 |
| --- | --- | --- | --- | --- | --- | --- | --- | --- | --- | --- | --- | --- | --- | --- | --- | --- | --- | --- | --- | --- | --- | --- | --- |
| 2255 | 738 | **Deleted - VoIMS bearer related enhancements** |  | 0d? | 2006-07-21 A | 2006-07-21 A | 100% | 2006-07-21 | 2006-07-21 | 0d? |  | S2 |  |  | VoIMS | Rel-7 | Maurice | SP-32 |  |  |  |  |  |
| 2256 | 738.1 | Deleted - Study on enhancement of radio performance for VoIMS | milestone | 0d? | 2006-07-21 A | 2006-07-21 A | 100% | 2006-07-21 | 2006-07-21 | 0d? | start no earlier than 2006-07-21 | S2 |  |  | VoIMS | Rel-7 | Maurice | SP-32 | 23.807 | Nortel | Laurence Lautier (lautierl@nortel.com) |  |  |
| 2257 | 739 | Deleted - Study on IMS enhancements and optimizations for real time communication. |  | 430d? | 2005-10-10 A | 2007-06-01 A | 100% | 2005-10-10 | 2007-06-01 | 430d? | finish no earlier than 2007-06-01 | S2 | 3440h | 3440h | IMS-RT | Rel-7 | Maurice | SP-35 | 23.818 | Ericsson | stephen.terrill@ericsson.com |  |  |
| 2258 | 740 | Deleted - Study on Terminating Session handling |  | 255d? | 2006-01-09 A | 2006-12-29 A | 100% | 2006-01-09 | 2006-12-29 | 255d? | finish no earlier than 2006-12-29 | S2 | 2040h | 2040h | CSIterm | Rel-7 | Maurice | SP-32 | 23.819 | Samsung |  |  |  |
| 2259 | 741 | Deleted - Study on Transferring of emergency call data – in-band modem solution (moved to Rel-8) | milestone | 0d? | 2007-06-22 A | 2007-06-22 A | 100% | 2007-06-22 | 2007-06-22 | 0d? | start no earlier than 2007-06-22 | S4 |  |  | eCALLIBMS | Rel-7 | Paolo | SP-38 | 26.967 | Airbiquity | lhong@airbiquity.com |  |  |
| 2260 | 742 | Deleted - Study on IRP usage scenarios |  | 330d? | 2005-09-02 A | 2006-12-07 A | 100% | 2005-09-02 | 2006-12-07 | 330d? | finish no earlier than 2006-12-07 | S5 | 2640h | 2640h | OAM-Study | Rel-7 | Dionisio | SP-32 | 32.8xy | Lucent |  |  |  |
| 2261 | 743 | Deleted - Study on Interference Cancellation for UTRA FDD UE (covered by UID 20053) |  | 1d? | 2007-03-28 A | 2007-03-28 A | 100% | 2007-03-28 | 2007-03-28 | 1d? | start no earlier than 2007-03-28 | R4 | 8h | 8h | RANFS-InterfCanc | Rel-7 | Issam | SP-38 |  |  |  |  |  |
| 2262 | 744 | Deleted - Study on enhanced support of Video Telephony | milestone | 0d? | 2006-06-30 A | 2006-06-30 A | 100% | 2006-06-30 | 2006-06-30 | 0d? | start no earlier than 2006-06-30 | GP |  |  | VIDGER | Rel-7 | Paolo | SP-32 |  | Ericsson | stefan.g.eriksson@ericsson.com |  |  |
| 2263 | 745 | Release 6 Features |  | 915d? | 2002-06-28 A | 2005-12-30 A | 100% | 2002-06-28 | 2005-12-30 | 915d? |  | NP,GP, RP,SP,TP | 7320h | 7320h |  | Rel-6 | All |  |  |  |  |  |  |
| 2264 | 8 | **Rel-6 Improvements of Radio Interface** |  | 1645d? | 2000-08-14 A | 2006-12-01 A | 100% | 2000-08-14 | 2006-12-01 | 1645d? |  | R2,R4,R5 | 55624h | 55624h | RInImp | Rel-6 |  |  |  |  |  |  |  |
| 2265 | 746.1 | Improved support of IMS Realtime Services using HSDPA/EDCH |  | 197d? | 2005-03-15 A | 2005-12-14 A | 100% | 2005-03-15 | 2005-12-14 | 197d? | finish no earlier than 2005-12-14 | R2 | 1576h | 1576h | RInImp-IMSRealTime | Rel-6 | Joern |  |  | Cingular | Don Zelmer (dz1069@att.com) |  |  |
| 2266 | 746.2 | Improving Receiver Performance Requirements for the FDD UE |  | 401d | 2002-03-08 A | 2003-09-19 A | 100% | 2002-03-08 | 2003-09-19 | 401d | start no earlier than 2002-03-08 | R4 | 3208h | 3208h | RInImp-UERecPerf | Rel-6 | Issam |  | 25.101 | Intel | shimon.moshavi@INTEL.COM |  |  |
| 2267 | 8.2 | **Base station classification for FDD** |  | 603d | 2000-08-14 A | 2002-12-04 A | 100% | 2000-08-14 | 2002-12-04 | 603d |  | R4 | 9648h | 9648h | RInImp-BSClass | Rel-6 | Issam |  |  |  |  |  |  |
| 2268 | 8.2.1 | FDD Base station classification |  | 603d | 2000-08-14 A | 2002-12-04 A | 100% | 2000-08-14 | 2002-12-04 | 603d | finish no earlier than 2002-12-04 | R4 | 4824h | 4824h | RInImp-BSClass-FDD | Rel-6 | Issam |  | 25.104, 25.141 | Nokia | antti.toskala@nokia.com |  |  |
| 2269 | 746.4 | UMTS-850 |  | 266d | 2002-12-06 A | 2003-12-12 A | 100% | 2002-12-06 | 2003-12-12 | 266d | finish no earlier than 2003-12-15 | R4 | 2128h | 2128h | RInImp-UMTS850 | Rel-6 | Issam |  | 25.101, 25.104, 25.133, 25.141, 25.307, 25.331, 25.942 | Cingular | Don Zelmer (dz1069@att.com) |  |  |
| 2270 | 746.5 | DS-CDMA introduction in the 800 MHz band |  | 196d | 2003-03-14 A | 2003-12-12 A | 100% | 2003-03-14 | 2003-12-12 | 196d | finish no earlier than 2003-12-15 | R4 | 1568h | 1568h | RInImp-UMTS800 | Rel-6 | Issam |  | 25.101, 25.104, 25.133, 25.141, 25.307, 25.331 | NTT DoCoMo | Takehiro Nakamura (nakamurata@nttdocomo.co.jp) |  |  |
| 2271 | 746.6 | UMTS 1.7/2.1 GHz | milestone | 0d? | 2003-03-14 A | 2003-03-14 A | 100% | 2003-03-14 | 2003-03-14 | 0d? |  | R4 |  |  | RInImp-UMTS1721 | Rel-6 | Issam |  | 25.101, 25.104, 25.133, 25.141, 25.307, 25.331 | Nokia | jussi.numminen@NOKIA.COM |  |  |
| 2272 | 746.7 | Conformance Test Aspects – UMTS 1.7/2.1 GHz Band |  | 191d? | 2006-03-10 A | 2006-12-01 A | 100% | 2006-03-10 | 2006-12-01 | 191d? | finish no earlier than 2006-12-01 | R5 | 1528h | 1528h | RInImp-UMTS1721_Test | Rel-6 | Ingbert |  | TS34.121, TS34.108 | Motorola | carolyn.taylor@motorola.com |  |  |
| 2273 | 746.8 | **Improved Receiver Performance Requirements for HSDPA** |  | 711d | 2003-09-19 A | 2006-06-09 A | 100% | 2003-09-19 | 2006-06-09 | 711d |  | R4,R5 | 22808h | 22808h | RInImp-HSPerf | Rel-6 | Issam |  |  | Nokia | jussi.numminen@NOKIA.COM |  |  |
| 2274 | 746.8.1 | Improved Minimum Performance Requirements for HSDPA UE categories 7 and 8 |  | 453d | 2004-09-15 A | 2006-06-09 A | 100% | 2004-09-15 | 2006-06-09 | 453d |  | R4 | 3624h | 3624h | RInImp-HSPerf-10code | Rel-6 | Issam |  | 25.101 | Nokia | jussi.numminen@nokia.com |  |  |
| 2275 | 746.8.2 | Testing of Improved Minimum Performance for HSDPA |  | 650d | 2003-09-19 A | 2006-03-16 A | 100% | 2003-09-19 | 2006-03-16 | 650d | finish no earlier than 2006-03-16 | R5 | 5200h | 5200h | RInImp-HSPerf-10Code_Test | Rel-6 | Ingbert |  | 34.108, 34.121, 34.122, 34.123-1, 34.123-2, 34.123-3 | Motorola | carolyn.taylor@motorola.com | TSG | 19/9/2003 |
| 2276 | 746.8.3 | Performance Requirements of Receive Diversity for HSDPA |  | 387d | 2003-12-15 A | 2005-06-07 A | 100% | 2003-12-15 | 2005-06-07 | 387d |  | R4 | 3096h | 3096h | RInImp-HSPerf-RxDiv | Rel-6 | Issam |  | 25.101 | NTT DoCoMo | Takehiro Nakamura (nakamurata@nttdocomo.co.jp) |  |  |
| 2277 | 746.8.4 | Testing of Performance of Receiver diversity for HSDPA |  | 650d | 2003-09-19 A | 2006-03-16 A | 100% | 2003-09-19 | 2006-03-16 | 650d | finish no earlier than 2006-03-16 | R5 | 5200h | 5200h | RInImp-HSPerf-RxDiv_Test | Rel-6 | Ingbert |  | 34.108, 34.121, 34.122, 34.123-1, 34.123-2, 34.123-3 | Motorola | carolyn.taylor@motorola.com | TSG | 19/9/2003 |
| 2278 | 747 | **Rel-6 RAN Feasibility Studies** |  | 1196d? | 2000-08-14 A | 2005-03-14 A | 100% | 2000-08-14 | 2005-03-14 | 1196d? |  | RP | 43048h | 43048h |  | Rel-6 |  |  |  |  |  |  |  |
| 2279 | 747.1 | FS of the improved access to UE measurement data for CRNC to support TDD RRM |  | 270d? | 2002-12-06 A | 2003-12-18 A | 100% | 2002-12-06 | 2003-12-18 | 270d? | finish no earlier than 2003-09-19 | R3 | 2160h | 2160h | RANimp-RRMopt-FSUEMsD | Rel-6 | Juha |  | 25.801, 25.423 | Interdigital | jim.miller@interdigital.com |  | SP-24 |
| 2280 | 747.2 | FS on Radio link performance enhancements |  | 1067d | 2000-08-14 A | 2004-09-14 A | 100% | 2000-08-14 | 2004-09-14 | 1067d | finish no earlier than 2004-09-14 | R1 | 8536h | 8536h | RInImp-Rlperf | Rel-6 | Patrick |  | 25.899 | Nokia | antti.toskala@nokia.com |  |  |
| 2281 | 747.3 | FS on Improvement of inter-frequency and inter-system measurements for 1.28 Mcps TDD |  | 461d | 2001-12-14 A | 2003-09-19 A | 100% | 2001-12-14 | 2003-09-19 | 461d | start no earlier than 2001-12-14 | R1 | 3688h | 3688h | RInImp-IfIsMLCR | Rel-6 | Patrick |  | 25.888 | Samsung | Li Xiao Qiang (xqli@samsung.co.kr) |  |  |
| 2282 | 747.4 | FS for the analysis of OFDM for UTRAN enhancement |  | 526d | 2002-06-10 A | 2004-06-14 A | 100% | 2002-06-10 | 2004-06-14 | 526d | start no earlier than 2002-06-10 | R1 | 4208h | 4208h | RInImp-FSOFDM | Rel-6 | Patrick |  | 25.892 | Nortel | Sarah Boumendil |  |  |
| 2283 | 747.5 | FS on Uplink Enhancements for Dedicated Transport Channels |  | 396d | 2002-09-06 A | 2004-03-12 A | 100% | 2002-09-06 | 2004-03-12 | 396d | finish no earlier than 2004-03-12 | R1 | 3168h | 3168h | RInImp-FSUpDTrCh | Rel-6 | Patrick |  | 25.896 | Nokia | Karri.Ranta-aho@nsn.com |  |  |
| 2284 | 747.6 | FS on Analysis on Higher Chip Rates for UTRA TDD evolutions |  | 528d | 2002-09-06 A | 2004-09-14 A | 100% | 2002-09-06 | 2004-09-14 | 528d | finish no earlier than 2004-09-14 | R1 | 4224h | 4224h | RInImp-FSVHCRTDD | Rel-6 | Patrick |  | 25.895 | IPWireless | mbeale@ipwireless.com |  |  |
| 2285 | 747.7 | FS on Low Output Powers for general purpose FDD BSs |  | 128d | 2003-06-13 A | 2004-03-12 A | 100% | 2003-06-13 | 2004-03-12 | 128d | finish no earlier than 2004-03-12 | R3 | 1024h | 1024h | RInImp-FSLoPw | Rel-6 | Juha |  | 25.807 | Telefónica | Ana Burgos (burgos_a@tsm.es) |  |  |
| 2286 | 747.8 | FS on Uplink enhancements for UTRA TDD |  | 462d | 2003-06-06 A | 2005-03-14 A | 100% | 2003-06-06 | 2005-03-14 | 462d | finish no earlier than 2005-03-14 | R1 | 3696h | 3696h | RInImp-FSUpEnhTDD | Rel-6 | Patrick |  | 25.804 | Interdigital | Marian.Rudolf@InterDigital.com |  |  |
| 2287 | 8.8 | FS on UE antenna efficiency test methods performance requirements (2) |  | 131d | 2002-03-08 A | 2002-09-06 A | 100% | 2002-03-08 | 2002-09-06 | 131d | finish no earlier than 2002-09-06 | R4 | 1048h | 1048h | RInImp-UEAnTM2 | Rel-6 | Issam |  |  | Allgon | Alf Ahlström (alf.ahlstrom@pwav.com) |  |  |
| 2288 | 9.4 | Deleted - FS on the evolution of the UTRAN architecture |  | 592d | 2002-09-09 A | 2004-12-14 A | 100% | 2002-09-09 | 2004-12-14 | 592d | finish no earlier than 2004-12-15 | R3 | 4736h | 4736h | RANimp-FSEvo | Rel-6 | Juha | RP-26 |  | Nokia | woonhee.hwang@nsn.com, Antti.Toskala@nokia.com |  |  |

Notes:
- 2255: Created by MCC to group all VoIMS related items, after consultation of chairs
- 2256: WID approved SP#28. SA2#52 stopped
- 2257: abandoned at 65%
- 2258: SP#32 Jun 2006 Study abandoned => spin-off Implementation work UID_320029
- 2259: SP-38 stopped
- 2260: -
- 2261: Deleted. Same as FS on Further Improved Performance Requirements for UMTS/HSDPA UE (FDD)
- 2262: FS CLOSED at G#28 (no input)
- 2263: -
- 2264: -
- 2265: -
- 2266: -
- 2267: -
- 2268: -
- 2269: Introduction of UMTS850 (Band V) in 25.307
- 2270: Introduction of UMTS800 in 25.307
- 2271: Introduction of UMTS1700/2100 (Band IV)
- 2272: -
- 2273: -
- 2274: Approved at RP#25 as RP-040375
- 2275: -
- 2276: -
- 2277: -
- 2278: -
- 2279: -
- 2280: Study finished at RP#25
- 2281: -
- 2282: -
- 2283: -
- 2284: Study finished at RP#25
- 2285: -
- 2286: -
- 2287: The RInImp-UEAnTM FS was re-opened at TSG RP#15 upon request from WG4
- 2288: Study Closed, work will continue within the FS on evolved UTRA and UTRAN

| ID | WBS | Task | Type | Duration | Start | Finish | Complete | Baseline start | Baseline finish | Baseline duration | Constraint | Deadline | Resources | Work | Actual work | Text1 | Text4 | Text5 | Text6 | Text3 | Text8 | Text7 | Text9 | Text10 | Text12 |
| --- | --- | --- | --- | --- | --- | --- | --- | --- | --- | --- | --- | --- | --- | --- | --- | --- | --- | --- | --- | --- | --- | --- | --- | --- | --- |
| 2289 | 748 | **FDD Enhanced Uplink** |  | 915d | 2004-03-15 A | 2007-09-14 A | 100% | 2004-03-15 | 2007-09-14 | 915d |  |  | R2,R1,R3,R4,R5 | 20520h | 20520h | EDCH | Ericsson | Joakim Bergström | Rel-6 |  |  |  |  |  |  |
| 2290 | 748.1 | FDD Enhanced Uplink - Stage 2 |  | 197d | 2004-03-15 A | 2004-12-14 A | 100% | 2004-03-15 | 2004-12-14 | 197d | finish no earlier than 2004-12-14 |  | R2 | 1576h | 1576h | EDCH-Stage2 |  |  | Rel-6 | 25.309 | Joern |  |  |  |  |
| 2291 | 748.2 | FDD Enhanced Uplink - Physical Layer |  | 261d | 2004-03-15 A | 2005-03-14 A | 100% | 2004-03-15 | 2005-03-14 | 261d | finish no earlier than 2005-03-14 |  | R1 | 2088h | 2088h | EDCH-Phys | Nokia | Karri.Ranta-aho@nsn.com | Rel-6 | 25.211, 25.212, 25.213, 25.214, 25.215 | Patrick |  |  |  |  |
| 2292 | 748.3 | FDD Enhanced Uplink - Layer 2 and 3 Protocol Aspects |  | 261d | 2004-03-15 A | 2005-03-14 A | 100% | 2004-03-15 | 2005-03-14 | 261d | finish no earlier than 2005-03-14 |  | R2 | 2088h | 2088h | EDCH-L23 | Ericsson | Joakim Bergström | Rel-6 | 25.301, 25.302, 25.306, 25.321, 25.331 | Joern |  |  |  |  |
| 2293 | 748.4 | FDD Enhanced Uplink - UTRAN Iub/Iur Protocol Aspects |  | 261d | 2004-03-15 A | 2005-03-14 A | 100% | 2004-03-15 | 2005-03-14 | 261d | finish no earlier than 2005-03-14 |  | R3 | 2088h | 2088h | EDCH-IurIub | Nortel | Saso Stojanovski | Rel-6 | 25.401, 25.420, 25.423, 25.430, 25.433 | Juha |  |  |  |  |
| 2294 | 748.5 | FDD Enhanced Uplink - RF Radio Transmission/ Reception, System Performance Requirements and Conformance Testing |  | 74d | 2004-03-15 A | 2004-06-24 A | 100% | 2004-03-15 | 2004-06-24 | 74d |  |  | R4 | 592h | 592h | EDCH-RF | Ericsson | thomas.unshelm@ericsson.com | Rel-6 | 25.101, 25.104, 25.133, 25.141 | Issam |  |  |  |  |
| 2295 | 748.6 | Conformance Test Aspects – FDD Enhanced Uplink |  | 596d | 2005-06-03 A | 2007-09-14 A | 100% | 2005-06-03 | 2007-09-14 | 596d | finish no earlier than 2007-09-14 | 2006-06-02 | R5 | 4768h | 4768h | EDCH_Test | Ericsson | Leif.Mattisson@ericsson.com | Rel-6 | 34.108, 34.109, 34.121, 34.123-1, 34.123-2, 34.123-3 | Ingbert | TSG | BB | Fri 03/06/05 |  |
| 2296 | 749 | **Rel-6 RAN improvements** |  | 656d? | 2002-09-09 A | 2005-03-14 A | 100% | 2002-09-09 | 2005-03-14 | 656d? |  |  | RP,S5 | 19904h | 19904h | RANimp |  |  | Rel-6 |  |  |  |  |  |  |
| 2297 | 9.2 | **RAB support enhancement** |  | 522d? | 2003-03-14 A | 2005-03-14 A | 100% | 2003-03-14 | 2005-03-14 | 522d? |  |  | R2 | 9360h | 9360h | RANimp-RABSE | Nokia | Jussi Kähtävä (juha.mikola@nokia.com) | Rel-6 | 25.862 | Joern |  |  |  |  |
| 2298 | 749.1.1 | Optimization of downlink channelisation code utilisation |  | 262d | 2004-03-12 A | 2005-03-14 A | 100% | 2004-03-12 | 2005-03-14 | 262d | finish no earlier than 2005-03-14 |  | R1 | 2096h | 2096h | RANimp-RABSE-CodeOptFDD | Nortel | Sarah Boumendil | Rel-6 |  | Patrick |  |  |  |  |
| 2299 | 749.1.2 | optimization of channelisation code utilisation for 3.84 Mcps TDD |  | 261d | 2004-03-15 A | 2005-03-14 A | 100% | 2004-03-15 | 2005-03-14 | 261d | finish no earlier than 2005-03-15 |  | R1 | 2088h | 2088h | RANimp-RABSE-CodOptTDD | IPWireless | Nicholas Anderson | Rel-6 |  | Patrick |  |  |  |  |
| 2300 | 749.1.3 | HS-DPCCH ACK/NACK Enhancement |  | 65d? | 2004-09-15 A | 2004-12-14 A | 100% | 2004-09-15 | 2004-12-14 | 65d? | finish no earlier than 2004-12-15 |  | R1 | 520h | 520h | RANimp-RABSE-ACKNACK | Nokia | Jussi Kähtävä (juha.mikola@nokia.com) | Rel-6 | 25.212, 25.214, 24.331, 25.433 | Patrick |  |  |  |  |
| 2301 | 749.1.4 | Deleted - Iu enhancements for IMS support in RAN |  | 320d? | 2003-03-14 A | 2004-06-03 A | 100% | 2003-03-14 | 2004-06-03 | 320d? | start no earlier than 2003-03-14 |  | R3 | 2560h | 2560h | RANimp-RABSE-IuEnhIMS | Nortel | Philippe.Godin@nortelnetworks.com | Rel-6 |  | Juha |  |  |  | RP-24 |
| 2302 | 749.1.5 | Deleted - Improvement of RRM across RNS and RNS/BSS | milestone | 0d? | 2003-12-05 A | 2003-12-05 A | 100% | 2003-12-05 | 2003-12-05 | 0d? | finish no earlier than 2003-12-05 |  | R3 |  |  | RANimp-RRM1 | Nokia | antti.toskala@nokia.com | Rel-6 |  | Juha |  |  |  | RP-23 |
| 2303 | 9.1 | Beamforming Enhancements |  | 66d | 2003-09-19 A | 2003-12-19 A | 100% | 2003-09-19 | 2003-12-19 | 66d | finish no earlier than 2004-03-12 |  | R1 | 528h | 528h | RANimp-BFE | Nokia | Jussi Kähtävä (juha.mikola@nokia.com) | Rel-6 | 24.215, 25.423, 25.425, 25.433, 25.435 | Patrick |  |  |  |  |
| 2304 | 749.3 | **Rel-6 RRM optimization for Iur and Iub** |  | 126d | 2003-09-19 A | 2004-03-12 A | 100% | 2003-09-19 | 2004-03-12 | 126d |  |  | R3 | 2016h | 2016h | RANimp-RRMopt | Ericsson | Gert-Jan.van.Lieshout@eln.ericsson.se | Rel-6 |  | Juha |  |  |  |  |
| 2305 | 749.3.1 | Improved access to UE measurement data for CRNC to support TDD RRM |  | 126d | 2003-09-19 A | 2004-03-12 A | 100% | 2003-09-19 | 2004-03-12 | 126d | finish no earlier than 2004-03-15 |  | R3 | 1008h | 1008h | RANimp-RRMopt-UEMsD | Interdigital | jim.miller@interdigital.com | Rel-6 | 25.423 | Juha |  |  |  | RP-22 |
| 2306 | 749.4 | **Remote Control of Electrical Tilting Antennas** |  | 395d? | 2003-03-14 A | 2004-09-16 A | 100% | 2003-03-14 | 2004-09-16 | 395d? |  |  | R3,S5 | 4304h | 4304h | RANimp-TiltAnt | Vodafone | Andreas.Hauser@vodafone.com | Rel-6 |  | Juha |  |  |  |  |
| 2307 | 749.4.1 | Tilting Antenna - RAN aspects |  | 393d? | 2003-03-14 A | 2004-09-14 A | 100% | 2003-03-14 | 2004-09-14 | 393d? | finish no earlier than 2004-09-14 |  | R3 | 3144h | 3144h | RANimp-TiltAnt | Vodafone | Andreas.Hauser@vodafone.com | Rel-6 | 25.460, 25.461, 25.462, 25.463 | Juha |  |  |  |  |
| 2308 | 749.4.2 | OAM&P impacts |  | 145d | 2004-02-27 A | 2004-09-16 A | 100% | 2004-02-27 | 2004-09-16 | 145d | finish no earlier than 2004-09-16 |  | S5 | 1160h | 1160h | RANimp-TiltAnt-OAM | Vodafone | Adrian.Neal@vodafone.com | Rel-6 | 32.804, 32.64x | Dionisio |  |  | SP-24 |  |
| 2309 | 749.5 | Network Assisted Cell Change (NACC) from UTRAN to GERAN - network-side aspects |  | 462d? | 2002-09-09 A | 2004-06-15 A | 100% | 2002-09-09 | 2004-06-15 | 462d? | finish no earlier than 2004-06-15 |  | R3 | 3696h | 3696h | RANimp-NACC | Vodafone | Brendan.McWilliams@gb.vodafone.co.uk | Rel-6 |  | Juha |  |  |  |  |
| 2310 | 12 | **Location Services enhancements 2** |  | 1024d? | 2001-01-15 A | 2004-12-16 A | 100% | 2001-01-15 | 2004-12-16 | 1024d? |  |  | S2,S5,N4,R2,R4,R5,OMA | 78152h | 78152h | LCS2 | Nokia | Jan Kåll | Rel-6 |  | Maurice |  |  |  |  |
| 2311 | 12.1 | **Improvement on Le interface** |  | 653d? | 2002-06-17 A | 2004-12-15 A | 100% | 2002-06-17 | 2004-12-15 | 653d? |  |  | S2,OMA | 9872h | 9872h | LCS2 | Nokia | Jan Kåll | Rel-6 |  | Maurice |  |  |  |  |
| 2312 | 750.1.1 | Stage 2 for Improvement on Le interface |  | 331d? | 2002-06-17 A | 2003-09-22 A | 100% | 2002-06-17 | 2003-09-22 | 331d? | start no earlier than 2002-06-17 |  | S2 | 2648h | 2648h | LCS2 | Nokia | Jan Kåll | Rel-6 | 23.002,23.271 | Maurice |  |  |  |  |
| 2313 | 750.1.2 | Stage 3 - impacts MLP (Mobile Location Protocol) |  | 250d? | 2004-01-01 A | 2004-12-15 A | 100% | 2004-01-01 | 2004-12-15 | 250d? | finish no earlier than 2004-12-15 |  | OMA | 2000h | 2000h | LCS2 | OMA | OMA-LIAISON@mail.openmobilealliance.org | Rel-6 |  |  |  |  |  |  |

Notes:
- 2289: -
- 2290: -
- 2291: -
- 2292: -
- 2293: -
- 2294: -
- 2295: -
- 2296: Generic feature
- 2297: building block without particular end date
- 2298: -
- 2299: WIDS modified in RP#26, RP-040551
- 2300: Approved at RP#25 as RP-040390
- 2301: Closed RP#24 due to the lack of progress
- 2302: abandoned RP-23
- 2303: -
- 2304: -
- 2305: -
- 2306: -
- 2307: Finished at RP#25
- 2308: SP#25 09/2004 completed
- 2309: -
- 2310: -
- 2311: -
- 2312: -
- 2313: -

| ID | WBS | Task | Type | Duration | Start | Finish | Complete | Baseline start | Baseline finish | Baseline duration | Constraint | Resources | Work | Actual work | Text1 | Text4 | Text5 | Text6 | Text8 | Text12 |
| --- | --- | --- | --- | --- | --- | --- | --- | --- | --- | --- | --- | --- | --- | --- | --- | --- | --- | --- | --- | --- |
| 2314 | 12.2 | **Enhanced support for anonymity and user privacy** |  | 638d? | 2002-07-08 A | 2004-12-15 A | 100% | 2002-07-08 | 2004-12-15 | 638d? |  | S2,OMA | 9144h | 9144h | LCS2 | Nokia | Jan Kåll | Rel-6 | Maurice |  |
| 2315 | 750.2.1 | Stage 2 for Enhanced support for anonymity and user privacy |  | 255d? | 2002-07-08 A | 2003-06-27 A | 100% | 2002-07-08 | 2003-06-27 | 255d? | finish no earlier than 2003-06-27 | S2 | 2040h | 2040h | LCS2 | Nokia | Jan Kåll | Rel-6 | Maurice |  |
| 2316 | 750.2.2 | Stage 3 - impacts MLP and RLP |  | 250d? | 2004-01-01 A | 2004-12-15 A | 100% | 2004-01-01 | 2004-12-15 | 250d? | finish no earlier than 2004-12-15 | OMA | 2000h | 2000h | LCS2 | OMA | OMA-LIAISON@mail.openmobilealliance.org | Rel-6 |  |  |
| 2317 | 12.3 | **Enhanced inter-GMLC interface** |  | 648d? | 2002-06-24 A | 2004-12-15 A | 100% | 2002-06-24 | 2004-12-15 | 648d? |  | S2,OMA | 9704h | 9704h | LCS2 | Nokia | Jan Kåll | Rel-6 | Maurice |  |
| 2318 | 750.3.1 | Stage 2 for Enhanced inter-GMLC interface |  | 315d? | 2002-06-24 A | 2003-09-05 A | 100% | 2002-06-24 | 2003-09-05 | 315d? | finish no earlier than 2003-09-05 | S2 | 2520h | 2520h | LCS2 | Nokia | Jan Kåll | Rel-6 | Maurice |  |
| 2319 | 750.3.2 | Stage 3 - definition of RLP and PCP |  | 250d? | 2004-01-01 A | 2004-12-15 A | 100% | 2004-01-01 | 2004-12-15 | 250d? | finish no earlier than 2004-12-15 | OMA | 2000h | 2000h | LCS2 | OMA | OMA-LIAISON@mail.openmobilealliance.org | Rel-6 |  |  |
| 2320 | 12.4 | **Location Services support for IMS public identities** |  | 473d? | 2003-02-24 A | 2004-12-15 A | 100% | 2003-02-24 | 2004-12-15 | 473d? |  | S2,OMA | 7704h | 7704h | LCS2 | Nokia | Jan Kåll | Rel-6 | Maurice |  |
| 2321 | 750.4.1 | Stage 2 for Location Services support for IMS public identities |  | 240d? | 2003-02-24 A | 2004-01-23 A | 100% | 2003-02-24 | 2004-01-23 | 240d? | finish no earlier than 2004-01-23 | S2 | 1920h | 1920h | LCS2 | Nokia | Jan Kåll | Rel-6 | Maurice |  |
| 2322 | 750.4.2 | OMA Stage 3 for Location Services support for IMS public identities - impacts MLP, RLP and PCP |  | 250d? | 2004-01-01 A | 2004-12-15 A | 100% | 2004-01-01 | 2004-12-15 | 250d? | finish no earlier than 2004-12-15 | OMA | 2000h | 2000h | LCS2 | OMA | OMA-LIAISON@mail.openmobilealliance.org | Rel-6 |  |  |
| 2323 | 12.5 | **New area event for location service triggering reports** |  | 663d? | 2002-06-03 A | 2004-12-15 A | 100% | 2002-06-03 | 2004-12-15 | 663d? |  | S2,N4,OMA | 11416h | 11416h | LCS2 | Nokia | Jan Kåll | Rel-6 | Maurice |  |
| 2324 | 750.5.1 | Stage 2 for New area event for location service triggering reports |  | 280d? | 2002-06-03 A | 2003-06-27 A | 100% | 2002-06-03 | 2003-06-27 | 280d? | finish no earlier than 2003-06-27 | S2 | 2240h | 2240h | LCS2 | Nokia | Jan Kåll | Rel-6 | Maurice |  |
| 2325 | 750.5.2 | Stage 3 for UE-CN signalling |  | 234d? | 2003-10-09 A | 2004-08-31 A | 100% | 2003-10-09 | 2004-08-31 | 234d? | start no earlier than 2003-10-09 | N4 | 1872h | 1872h | LCS2 | Nokia |  | Rel-6 | Kimmo |  |
| 2326 | 750.5.3 | Stage 3 for New area event for location service triggering reports - impacts MLP, RLP and PCP |  | 250d? | 2004-01-01 A | 2004-12-15 A | 100% | 2004-01-01 | 2004-12-15 | 250d? | finish no earlier than 2004-12-15 | OMA | 2000h | 2000h | LCS2 | OMA | OMA-LIAISON@mail.openmobilealliance.org | Rel-6 |  |  |
| 2327 | 12.7 | **UE positioning for Location Services enhancements 2** |  | 957d? | 2001-01-15 A | 2004-09-14 A | 100% | 2001-01-15 | 2004-09-14 | 957d? |  | R2,R4,R5 | 18480h | 18480h | LCS2-UEpos |  |  | Rel-6 | Issam |  |
| 2328 | 12.8 | Open SMLC-SRNC Interface within the UTRAN to support UTRAN Rel-4 positioning methods |  | 700d? | 2001-01-15 A | 2003-09-19 A | 100% | 2001-01-15 | 2003-09-19 | 700d? | finish no earlier than 2003-09-19 | R2 | 5600h | 5600h | LCS-Rel4Pos | Siemens | Meik.Kottkamp@siemens.com | Rel-6 | Joern |  |
| 2329 | 750.6.2 | A-GPS minimum performance specification |  | 333d? | 2003-06-06 A | 2004-09-14 A | 100% | 2003-06-06 | 2004-09-14 | 333d? | finish no earlier than 2004-09-14 | R4,R5 | 2664h | 2664h | LCS-UEPos-AGPSPerf | AT&T Wireless | donglin.shen@attws.com | Rel-6 | Issam |  |
| 2330 | 12.7.2 | Deleted - FS on Enhancements to OTDOA Positioning using advanced blanking methods |  | 320d | 2002-07-01 A | 2003-09-19 A | 100% | 2002-07-01 | 2003-09-19 | 320d | finish no earlier than 2003-09-19 | R2 | 2560h | 2560h | LCS2-UEpos-FSBlank | Cambridge Positioning Systems | david.bartlett@cursor-system.com | Rel-6 | Joern | RP-38 |
| 2331 | 750.6.4 | Deleted - UE positioning enhancements - other methods | milestone | 0d? | 2003-09-26 A | 2003-09-26 A | 100% | 2003-09-26 | 2003-09-26 | 0d? | finish no earlier than 2003-09-26 | R2 |  |  | LCS2-UEpos-enh | Siemens | Meik.Kottkamp@siemens.com | Rel-6 | Joern | RP-24 |
| 2332 | 750.7 | LCS charging |  | 455d? | 2003-03-21 A | 2004-12-16 A | 100% | 2003-03-21 | 2004-12-16 | 455d? | start no earlier than 2003-03-21 | S5 | 3640h | 3640h | LCS2-CH | France Telecom | alain.bibas@orange-ft.com | Rel-6 | Dionisio |  |
| 2333 | 14 | **Rel-6 Security enhancements** |  | 1018d? | 2001-01-03 A | 2004-11-26 A | 100% | 2001-01-03 | 2004-11-26 | 1018d? |  | S3 | 28824h | 28824h | SEC1 | Vodafone | Peter.Howard@vodafone.com | Rel-6 | Dionisio |  |
| 2334 | 14.1 | **Enhanced HE control of security (including positive authentication reporting)** |  | 712d | 2001-01-03 A | 2003-09-25 A | 100% | 2001-01-03 | 2003-09-25 | 712d |  | S3 | 14064h | 14064h | SEC1 | Vodafone | Peter.Howard@vodafone.com | Rel-6 | Dionisio |  |
| 2335 | 14.1.1 | Deleted - SEC1 Stage 2 (Enhanced HE control of security) |  | 378d | 2001-01-03 A | 2002-06-14 A | 100% | 2001-01-03 | 2002-06-14 | 378d | finish no earlier than 2002-06-14 | S3 | 3024h | 3024h | SEC1 |  |  | Rel-6 | Dionisio | SP-16 |
| 2336 | 14.1.3 | **Rel-6 Network Domain Security** |  | 334d | 2002-06-17 A | 2003-09-25 A | 100% | 2002-06-17 | 2003-09-25 | 334d |  | S3 | 5344h | 5344h | SEC1-NDS | Telenor | Geir-myrdahl.koien@telenor.com | Rel-6 | Dionisio |  |
| 2337 | 14.1.3.1 | Rel-6 IP network layer security (NDS/IP) |  | 334d | 2002-06-17 A | 2003-09-25 A | 100% | 2002-06-17 | 2003-09-25 | 334d | finish no earlier than 2003-09-25 | S3 | 2672h | 2672h | SEC1-NDS-IP |  |  | Rel-6 | Dionisio |  |
| 2338 | 751.2 | Network Domain Security; Authentication Framework (NDS/AF) |  | 521d? | 2002-02-15 A | 2004-02-13 A | 100% | 2002-02-15 | 2004-02-13 | 521d? | finish no earlier than 2004-02-13 | S3 | 4168h | 4168h | SEC1-NDS-AF | Nokia | tommi.viitanen@nokia.com | Rel-6 | Dionisio |  |
| 2339 | 751.3 | Key Management of group keys for Voice Group Call Services |  | 306d | 2003-09-26 A | 2004-11-26 A | 100% | 2003-09-26 | 2004-11-26 | 306d | finish no earlier than 2004-11-26 | S3 | 2448h | 2448h | SECGKYV | Vodafone | benno.tietz@vodafone.com | Rel-6 | Dionisio |  |
| 2340 | 752 | Network Domain Security; MAP application layer security (NDS/MAPsec) |  | 127d? | 2004-07-06 A | 2004-12-29 A | 100% | 2004-07-06 | 2004-12-29 | 127d? | finish no earlier than 2003-12-26 | S3 | 1016h | 1016h | MAPSEC | Vodafone | Peter.Howard@vodafone.com | Rel-6 | Dionisio |  |

Notes:
- 2314: -
- 2315: - / Text3: 23.002,23.271
- 2316: -
- 2317: -
- 2318: - / Text3: 23.002,23.271
- 2319: -
- 2320: -
- 2321: - / Text3: 23.002,23.271
- 2322: -
- 2323: -
- 2324: - / Text3: 23.002,23.271
- 2325: Current stage 3 fullfills stage 2
- 2326: -
- 2327: -
- 2328: - / Text3: 25.305, 25.401, 25.450, 25.452, 25.453
- 2329: RP#25 completed (FDD) / Text3: new 25.171, 34.171 (testing)
- 2330: RP#38 Work stopped / Text3: new TR 25.894
- 2331: RP#24 Work stopped
- 2332: SP#26 completed / Text3: new TS 32.271
- 2333: SP#9 approved WID
- 2334: SP#9 approved WID S3-000490 (Enhanced home control of security by HE) / Text3: 33.102
- 2335: Marked as stopped 12/2008
- 2336: SP#9 approved WID S3-000606 (Network Domain Security) / Text3: 33.102, 33.103, 33.105
- 2337: SP#9 approved WID S3-000626 (Access security for IP-based services) / Text3: 33.210
- 2338: SP#19 approved WID / Text3: 33.810
- 2339: - / Text3: 42.068, 43.068, 44.068, 42.069, 43.069, 44.069, 31.102, 24.008, 48.008, 42.009, 43.020
- 2340: SP#19 approved WID. Marked as closed 12/2008 (was marked 20% complete) / Text3: 33.200

| ID | WBS | Task | Type | Duration | Start | Finish | Complete | Baseline start | Baseline finish | Baseline duration | Constraint | Resources | Work | Actual work | Text1 | Text6 | Text8 | Text3 | Text4 | Text5 | Text12 |
| --- | --- | --- | --- | --- | --- | --- | --- | --- | --- | --- | --- | --- | --- | --- | --- | --- | --- | --- | --- | --- | --- |
| 2341 | 16 | **IMS Phase 2** |  | 1840d? | 2000-08-28 A | 2007-09-14 A | 100% | 2000-08-28 | 2007-09-14 | 1840d? |  | S1,S2,S3,S5,NP,R5 | 136976h | 136976h | IMS2 | Rel-6 | Alain |  |  |  |  |
| 2342 | 753.1 | Enhancements to the Cx and Sh interfaces |  | 323d? | 2003-06-06 A | 2004-08-31 A | 100% | 2003-06-06 | 2004-08-31 | 323d? | finish no earlier than 2004-08-31 | N4 | 2584h | 2584h | IMS2-CCR | Rel-6 | Kimmo |  |  |  |  |
| 2343 | 753.2 | Conformance Test Aspects – IMS Call Control Rel-6 enhancements |  | 396d? | 2006-03-10 A | 2007-09-14 A | 100% | 2006-03-10 | 2007-09-14 | 396d? | finish no earlier than 2007-09-14 | R5 | 3168h | 3168h | IMS2_CCR_Test | Rel-6 | Ingbert | 34.229-1, 34.229-2, 34.229-3, 34.108 | Ericsson | Jacob.John@motorola.com, Leif.Mattisson@ericsson.com |  |
| 2344 | 16.12 | **IMS Group Management** |  | 715d? | 2002-03-14 A | 2004-12-08 A | 100% | 2002-03-14 | 2004-12-08 | 715d? |  | S1 | 12680h | 12680h | IMSGM | Rel-6 | Alain |  | Nokia | juha.kalliokulju@nokia.com |  |
| 2345 | 16.12.1 | Stage 1 - TS on IMS group management |  | 193d | 2002-03-14 A | 2002-12-09 A | 100% | 2002-03-14 | 2002-12-09 | 193d | finish no earlier than 2002-12-09 | S1 | 1544h | 1544h | IMSGM | Rel-6 | Alain |  | Nokia | juha.kalliokulju@nokia.com |  |
| 2346 | 753.3.2 | Stage 2 for IMS Group Management |  | 158d? | 2003-05-26 A | 2003-12-31 A | 100% | 2003-05-26 | 2003-12-31 | 158d? | finish no earlier than 2003-12-31 | S2 | 1264h | 1264h | IMSGM | Rel-6 | Maurice | 23.228 |  |  |  |
| 2347 | 753.3.3 | Stage 3 for IMS Group management (e.g. chat) |  | 519d? | 2002-12-13 A | 2004-12-08 A | 100% | 2002-12-13 | 2004-12-08 | 519d? | finish no earlier than 2004-12-08 | N1 | 4152h | 4152h | IMSGM | Rel-6 | Frederic |  | Lucent | Keith Drage (drage@alcatel-lucent.com) |  |
| 2348 | 753.4 | **IMS Conferencing** |  | 548d? | 2002-11-04 A | 2004-12-08 A | 100% | 2002-11-04 | 2004-12-08 | 548d? |  | N1 | 10960h | 10960h |  | Rel-6 | Frederic |  |  |  |  |
| 2349 | 753.4.1 | Stage 2 for IMS Conferencing |  | 303d? | 2002-11-04 A | 2003-12-31 A | 100% | 2002-11-04 | 2003-12-31 | 303d? | finish no earlier than 2003-12-31 | S2 | 2424h | 2424h |  | Rel-6 | Maurice | 23.228 |  |  |  |
| 2350 | 753.4.2 | Stage 3 for IMS Conferencing |  | 519d? | 2002-12-13 A | 2004-12-08 A | 100% | 2002-12-13 | 2004-12-08 | 519d? | finish no earlier than 2004-12-08 | N1 | 4152h | 4152h |  | Rel-6 | Frederic |  | Lucent | Keith Drage (drage@alcatel-lucent.com) |  |
| 2351 | 16.11 | **IMS Messaging** |  | 992d? | 2002-03-14 A | 2005-12-30 A | 100% | 2002-03-14 | 2005-12-30 | 992d? |  | S1 | 23912h | 23912h | IMSM | Rel-6 | Alain |  | Nokia | juha.kalliokulju@nokia.com |  |
| 2352 | 16.11.1 | TR on support of messaging in the IMS |  | 193d | 2002-03-14 A | 2002-12-09 A | 100% | 2002-03-14 | 2002-12-09 | 193d | finish no earlier than 2002-12-09 | S1 | 1544h | 1544h | IMSM-TR | Rel-6 | Alain | new 22.940 | Nokia | juha.kalliokulju@nokia.com |  |
| 2353 | 753.5.2 | Stage 1 22.340 |  | 23d? | 2002-11-11 A | 2002-12-11 A | 100% | 2002-11-11 | 2002-12-11 | 23d? | finish no earlier than 2002-12-11 | S1 | 184h | 184h | IMSM-TS | Rel-6 | Alain | 22.340 | Nokia | juha.kalliokulju@nokia.com |  |
| 2354 | 753.5.3 | CRs to 22.140 & 22.228 |  | 263d? | 2002-03-14 A | 2003-03-17 A | 100% | 2002-03-14 | 2003-03-17 | 263d? | finish no earlier than 2003-03-17 | S1 | 2104h | 2104h | IMSM-CR | Rel-6 | Alain | 22.140,22.228 | Nokia | juha.kalliokulju@nokia.com |  |
| 2355 | 16.11.3 | Stage 2 for IMS Messaging |  | 477d | 2002-11-04 A | 2004-08-31 A | 100% | 2002-11-04 | 2004-08-31 | 477d | finish no earlier than 2004-08-31 | S2 | 3816h | 3816h | IMSM | Rel-6 | Maurice | 23.228 |  |  |  |
| 2356 | 753.5.5 | Stage 3 for IMS Messaging |  | 519d? | 2002-12-13 A | 2004-12-08 A | 100% | 2002-12-13 | 2004-12-08 | 519d? | finish no earlier than 2004-12-08 | N1 | 4152h | 4152h | IMSM | Rel-6 | Frederic |  | Lucent | Keith Drage (drage@alcatel-lucent.com) |  |
| 2357 | 753.5.6 | SIP/SIMPLE Instant messaging |  | 522d? | 2004-01-01 A | 2005-12-30 A | 100% | 2004-01-01 | 2005-12-30 | 522d? | finish no earlier than 2005-06-30 | OMA | 4176h | 4176h |  | Rel-6 |  |  |  | OMA-LIAISON@mail.openmobilealliance.org |  |
| 2358 | 753.6 | **Additional SIP Capabilities support not covered by Rel-5** |  | 680d? | 2002-11-11 A | 2005-06-17 A | 100% | 2002-11-11 | 2005-06-17 | 680d? |  | N1 | 13392h | 13392h |  | Rel-6 | Frederic |  |  |  |  |
| 2359 | 753.6.1 | Stage 2 for add SIP cap (e.g. forking) |  | 335d? | 2002-11-11 A | 2004-02-20 A | 100% | 2002-11-11 | 2004-02-20 | 335d? | finish no earlier than 2004-02-20 | S2 | 2680h | 2680h |  | Rel-6 | Maurice | 23.228 |  |  |  |
| 2360 | 753.6.2 | Stage 3 for Additional SIP Capabilities |  | 454d? | 2002-12-13 A | 2004-09-08 A | 100% | 2002-12-13 | 2004-09-08 | 454d? | finish no earlier than 2004-09-08 | N1 | 3632h | 3632h |  | Rel-6 | Frederic |  | Lucent | Keith Drage (drage@alcatel-lucent.com) |  |
| 2361 | 753.6.3 | Procedured associated with IMS-ALG |  | 205d? | 2004-09-06 A | 2005-06-17 A | 100% | 2004-09-06 | 2005-06-17 | 205d? | start no earlier than 2004-09-06 | N1 | 1640h | 1640h |  | Rel-6 | Frederic |  |  |  |  |
| 2362 | 753.7 | Review additional SIP Capabilities against IMS |  | 454d? | 2002-12-13 A | 2004-09-08 A | 100% | 2002-12-13 | 2004-09-08 | 454d? | finish no earlier than 2004-09-08 | N1 | 3632h | 3632h |  | Rel-6 | Frederic |  | Lucent | Keith Drage (drage@alcatel-lucent.com) |  |
| 2363 | 16.5 | **Interworking between IMS and IP networks** |  | 1118d? | 2000-08-28 A | 2004-12-08 A | 100% | 2000-08-28 | 2004-12-08 | 1118d? |  | N3 | 31712h | 31712h | IMS-CCR-IWIP | Rel-6 | Gwiho | 23.821, 29.061, 29.162 | BT | nigel.holland@bt.com |  |
| 2364 | 16.5.1 | Interworking for 3GPP_SIP and IETF_SIP |  | 730d | 2000-08-28 A | 2003-06-13 A | 100% | 2000-08-28 | 2003-06-13 | 730d | finish no earlier than 2003-06-13 | N3 | 5840h | 5840h | IMS-CCR-IWIP | Rel-6 | Gwiho | New 29.962 | Siemens | Thomas.Belling@nsn.com |  |
| 2365 | 16.5.2 | Interworking for IPv6 to IPv4 |  | 1118d | 2000-08-28 A | 2004-12-08 A | 100% | 2000-08-28 | 2004-12-08 | 1118d | finish no earlier than 2004-12-08 | N3 | 8944h | 8944h |  | Rel-6 | Gwiho | 29.163 |  |  |  |
| 2366 | 753.8.3 | Interworking for IPv6 to IPv4 (SIP / SDP aspects) |  | 87d? | 2004-05-11 A | 2004-09-08 A | 100% | 2004-05-11 | 2004-09-08 | 87d? | finish no earlier than 2004-09-08 | N1 | 696h | 696h |  | Rel-6 | Frederic |  |  |  |  |
| 2367 | 16.8.1 | stage 3 of interworking with non-IMS IP networks |  | 911d | 2001-03-14 A | 2004-09-08 A | 100% | 2001-03-14 | 2004-09-08 | 911d | finish no earlier than 2004-09-08 | N1 | 7288h | 7288h |  | Rel-6 | Frederic |  |  |  |  |
| 2368 | 16.6.1 | Interworking between IMS and CS networks |  | 929d? | 2000-08-28 A | 2004-03-18 A | 100% | 2000-08-28 | 2004-03-18 | 929d? | finish no earlier than 2004-03-18 | N3 | 7432h | 7432h | IMS-CCR-IWCS | Rel-6 | Gwiho | 29.163, 29.061, 24.228, and new CN4 specification | Vodafone | Brendan.McWilliams@gb.vodafone.co.uk |  |
| 2369 | 16.10 | Mn interface (IM-MGW to MGCF) enhancements (CN4 Part) |  | 418d | 2001-08-07 A | 2004-09-01 A | 100% | 2001-08-07 | 2004-09-01 | 418d | finish no earlier than 2004-09-01 | N4 | 3344h | 3344h | IMS-CCR-Mn | Rel-6 | Kimmo |  |  |  |  |
| 2370 | 753.11 | Study of subscriber and operators relationship in IMS and related ISIM requirements for Rel 6” |  | 20d? | 2002-11-15 A | 2002-12-12 A | 100% | 2002-11-15 | 2002-12-12 | 20d? | finish no earlier than 2002-12-12 | S1 | 160h | 160h |  | Rel-6 | Alain |  | Nokia | juha.kalliokulju@nokia.com |  |
| 2371 | 753.12 | Lawful Interception in Rel-6 architecture |  | 269d? | 2002-12-09 A | 2003-12-18 A | 100% | 2002-12-09 | 2003-12-18 | 269d? | finish no earlier than 2003-12-18 | S3 | 2152h | 2152h | SEC1-LI | Rel-6 | Dionisio | 33.106, 33.107, 33.108 | Reg TP, Nortel | berthold.wilhelm@regtp.de, Ron Ryan |  |
| 2372 | 753.13 | IMS Subscription and access scenarios |  | 130d? | 2002-12-16 A | 2003-06-13 A | 100% | 2002-12-16 | 2003-06-13 | 130d? | start no earlier than 2002-12-16 | S1 | 1040h | 1040h |  | Rel-6 | Alain | 22.800 | TeliaSonera | FRANK, Robert |  |
| 2373 | 753.14 | IMS charging |  | 455d? | 2003-03-21 A | 2004-12-16 A | 100% | 2003-03-21 | 2004-12-16 | 455d? | finish no earlier than 2004-12-16 | S5 | 3640h | 3640h | IMS2-CH | Rel-6 | Dionisio | 32.260 | Ericsson | Patrik TEPPO |  |
| 2374 | 753.15 | IMS Management objects |  | 306d? | 2004-09-03 A | 2005-11-04 A | 100% | 2004-09-03 | 2005-11-04 | 306d? | finish no earlier than 2005-03-04 | N1 | 2448h | 2448h |  | Rel-6 | Frederic | 24.167 |  |  |  |
| 2375 | 753.16 | Deleted - Stage 2 of IMS Phase 2 | milestone | 0d? | 2003-09-19 A | 2003-09-19 A | 100% | 2003-09-19 | 2003-09-19 | 0d? | finish no earlier than 2003-09-19 | S2 |  |  | IMS2 | Rel-6 | Maurice |  |  |  | SP-21 |

Notes:
- 2341: -
- 2342: Shared public user identities need to be solved. If email approval CR is accepted. Work 100% done....
- 2343: -
- 2344: -
- 2345: -
- 2346: -
- 2347: Depends on CN decision on CPCP in Rel-6. Complete, if unresolved IETF dependencies are dropped (-> LS to CN plenary)
- 2348: -
- 2349: -
- 2350: Depends on CN decision on IETF dependencies in Rel-6. Higher figure if CPCP is dropped (-> LS to CN plenary)
- 2351: -
- 2352: -
- 2353: -
- 2354: -
- 2355: -
- 2356: -
- 2357: Updated according to SP-040232
- 2358: -
- 2359: -
- 2360: -
- 2361: -
- 2362: -
- 2363: [DAB 14.02.02] - end date pushed back to March 2003
- 2364: [DAB - 20.08.03] - CN Part of TR Complete @ CN#20
- 2365: -
- 2366: -
- 2367: -
- 2368: [DAB - 25.05.04] - CN3 consider this work to be complete
- 2369: TISPAN issue is open
- 2370: -
- 2371: -
- 2372: -
- 2373: SP#26 12/2004 completed
- 2374: -
- 2375: -

| ID | WBS | Task | Type | Duration | Start | Finish | Complete | Baseline start | Baseline finish | Baseline duration | Constraint | Resources | Work | Actual work | Text1 | Text4 | Text5 | Text6 | Text8 | Text3 | Text10 | Text12 |
| --- | --- | --- | --- | --- | --- | --- | --- | --- | --- | --- | --- | --- | --- | --- | --- | --- | --- | --- | --- | --- | --- | --- |
| 2376 | 754 | **3GPP Enablers for services like Push to Talk over Cellular (PoC)** |  | 459d? | 2003-09-08 A | 2005-06-09 A | 100% | 2003-09-08 | 2005-06-09 | 459d? |  | S2,S4,S5 | 10696h | 10696h | PoC | Ericsson | Shabnam Sultana | Rel-6 | Maurice |  |  |  |
| 2377 | 754.1 | Feasibility Study on 3GPP Enablers for services like Push to Talk over Cellular (PoC) |  | 322d? | 2003-09-08 A | 2004-11-30 A | 100% | 2003-09-08 | 2004-11-30 | 322d? | finish no earlier than 2004-11-30 | S2 | 2576h | 2576h | PoC | Ericsson | Shabnam Sultana | Rel-6 | Maurice | 23.979 | SP-24 |  |
| 2378 | 754.2 | Dependencies on OMA PoC |  | 303d? | 2004-01-01 A | 2005-02-28 A | 100% | 2004-01-01 | 2005-02-28 | 303d? | finish no earlier than 2004-12-30 | OMA | 2424h | 2424h | PoC |  | OMA-LIAISON@mail.openmobilealliance.org | Rel-6 |  |  | SP-24 |  |
| 2379 | 754.3 | Selection of one or more PoC codec(s) for PoC |  | 69d? | 2004-09-13 A | 2004-12-16 A | 100% | 2004-09-13 | 2004-12-16 | 69d? | start no earlier than 2004-09-13 | S4 | 552h | 552h | PoC |  |  | Rel-6 | Paolo | 26.235, 26.236 | SP-25 |  |
| 2380 | 754.4 | PoC charging |  | 184d? | 2004-09-27 A | 2005-06-09 A | 100% | 2004-09-27 | 2005-06-09 | 184d? | finish no earlier than 2005-06-09 | S5 | 1472h | 1472h | PoC-CH | Siemens | Gerald.Goermer@nsn.com | Rel-6 | Dionisio | 32.272 |  |  |
| 2381 | 755 | Study on Interworking aspects and migration scenarios for IPv4 based IMS Implementations |  | 210d? | 2003-09-08 A | 2004-06-25 A | 100% | 2003-09-08 | 2004-06-25 | 210d? | finish no earlier than 2004-06-25 | S2 | 1680h | 1680h | IPv4IMS | Siemens | Alexander Milinski | Rel-6 | Maurice | 23.981 |  |  |
| 2382 | 16.3 | **Interoperability and Commonality between IMS using different IP-connectivity Networks** |  | 325d? | 2002-09-16 A | 2003-12-12 A | 100% | 2002-09-16 | 2003-12-12 | 325d? |  | S2 | 9176h | 9176h | IMSCOOP |  |  | Rel-6 | Maurice | 23.864 |  |  |
| 2383 | 16.3.1 | Stage 2 for Interoperability |  | 272d | 2002-09-16 A | 2003-09-30 A | 100% | 2002-09-16 | 2003-09-30 | 272d | finish no earlier than 2003-09-30 | S2 | 2176h | 2176h | IMSCOOP | Nokia | balazs.bertenyi@nsn.com | Rel-6 | Maurice | 23.864 |  |  |
| 2384 | 756.2 | Stage 2 for commonality |  | 265d? | 2002-09-16 A | 2003-09-19 A | 100% | 2002-09-16 | 2003-09-19 | 265d? | start no earlier than 2002-09-16 | S2 | 2120h | 2120h | IMSCOOP | Nokia | balazs.bertenyi@nsn.com | Rel-6 | Maurice | 23.864 |  |  |
| 2385 | 16.3.2 | Stage 3 for Interoperability and Commonality between IMS using different IP-connectivity Networks |  | 305d | 2002-10-14 A | 2003-12-12 A | 100% | 2002-10-14 | 2003-12-12 | 305d | finish no earlier than 2003-12-12 | N1 | 2440h | 2440h | IMSCOOP | Lucent | Keith Drage (drage@alcatel-lucent.com) | Rel-6 | Frederic |  |  |  |
| 2386 | 17 | **Support of Push Services** |  | 823d | 2001-01-03 A | 2004-02-27 A | 100% | 2001-01-03 | 2004-02-27 | 823d |  | S1 | 11390.6h | 11390.6h | PUSH | NTT Comware | Yoshinori Kitada | Rel-6 | Alain | 23.976 |  |  |
| 2387 | 17.1 | Stage 1 for Support of Push Services |  | 378d | 2001-01-03 A | 2002-06-14 A | 100% | 2001-01-03 | 2002-06-14 | 378d | finish no earlier than 2002-06-14 | S1 | 3024h | 3024h | PUSH |  |  | Rel-6 | Alain |  |  |  |
| 2388 | 17.3 | TR 23.976 on Push Architecture |  | 340d | 2002-11-11 A | 2004-02-27 A | 100% | 2002-11-11 | 2004-02-27 | 340d | finish no earlier than 2004-02-27 | S2 | 2720h | 2720h | PUSH | Research In Motion | Nick Alfano | Rel-6 | Maurice | 23.976 |  |  |
| 2389 | 18 | **Rel-6 Multimedia Messaging (MMS) enhancements** |  | 865d? | 2002-08-15 A | 2005-12-07 A | 100% | 2002-08-15 | 2005-12-07 | 865d? |  | T2,S1,S4,S5,OMA | 31936h | 31936h | MMS6 | Siemens | Josef.Laumen@SAL.SIEMENS.DE | Rel-6 | Kimmo |  |  |  |
| 2390 | 18.1 | **Definition of service requirements for MMS6** |  | 286d? | 2002-11-15 A | 2003-12-19 A | 100% | 2002-11-15 | 2003-12-19 | 286d? |  | S1 | 4576h | 4576h | MMS6-SR |  |  | Rel-6 | Alain | 22.140 |  |  |
| 2391 | 758.1.1 | Definition of service requirements charging |  | 286d? | 2002-11-15 A | 2003-12-19 A | 100% | 2002-11-15 | 2003-12-19 | 286d? | finish no earlier than 2003-12-20 | S1 | 2288h | 2288h | MMS6-SR | Siemens | Josef.Laumen@SAL.SIEMENS.DE | Rel-6 | Alain | 22.140 |  |  |
| 2392 | 18.2 | Technical realization of MMS6 |  | 591d | 2002-09-06 A | 2004-12-10 A | 100% | 2002-09-06 | 2004-12-10 | 591d | finish no earlier than 2004-12-10 | T2 | 4728h | 4728h | MMS6 | Siemens | Josef.Laumen@SAL.SIEMENS.DE | Rel-6 | Kimmo | 23.140 |  |  |
| 2393 | 18.3 | OMA dependencies |  | 446d | 2003-08-15 A | 2005-04-29 A | 100% | 2003-08-15 | 2005-04-29 | 446d | finish no earlier than 2004-12-10 | OMA | 3568h | 3568h | MMS6 |  |  | Rel-6 | Kimmo | OMA specs |  |  |
| 2394 | 18.4 | MMS formats and codecs for MMS6 |  | 865d | 2002-08-15 A | 2005-12-07 A | 100% | 2002-08-15 | 2005-12-07 | 865d | finish no earlier than 2005-12-07 | S4 | 6920h | 6920h | MMS6-Codec | Nokia | roberto.castagno@nokia.com | Rel-6 | Paolo | 26.140, 26.936 |  |  |
| 2395 | 758.5 | Handling of private addressing schemes in MMS |  | 263d | 2003-12-10 A | 2004-12-10 A | 100% | 2003-12-10 | 2004-12-10 | 263d | finish no earlier than 2004-12-10 | T2 | 2104h | 2104h | MMS6 | T-Mobile | Steffen.Habermann@T-MOBILE.DE | Rel-6 | Kimmo | 23.140 |  |  |
| 2396 | 758.6 | MMS charging |  | 390d? | 2003-03-21 A | 2004-09-16 A | 100% | 2003-03-21 | 2004-09-16 | 390d? | start no earlier than 2003-03-21 | S5 | 3120h | 3120h | MMS6-CH |  |  | Rel-6 | Dionisio | 32.270 |  |  |
| 2397 | 758.7 | Deleted - FS Multiple MMS Relay/Server Architecture | milestone | 0d | 2004-12-10 A | 2004-12-10 A | 100% | 2004-12-10 | 2004-12-10 | 0d | finish no earlier than 2004-12-10 | T2 |  |  | MMS6 | Telefónica Móviles | Juan Gorospe (gorospe_j@tsm.es) | Rel-6 | Kimmo | probably Annex to 23.140 |  | TP-26 |
| 2398 | 19 | **Rel-6 MExE enhancements** |  | 326d | 2002-03-08 A | 2003-06-06 A | 100% | 2002-03-08 | 2003-06-06 | 326d |  | T2 | 7328h | 7328h | MEXE6 |  |  | Rel-6 | Kimmo |  |  |  |
| 2399 | 19.1 | MExE Rel-6 Improvements and Investigations |  | 264d | 2002-03-08 A | 2003-03-12 A | 100% | 2002-03-08 | 2003-03-12 | 264d | finish no earlier than 2003-03-12 | T2 | 2112h | 2112h | MEXE6-ENHANC | TTPCom | Lars Brenk ( (lsb_ttpcom@HOTMAIL.COM) | Rel-6 | Kimmo |  |  |  |
| 2400 | 19.2 | MExE Run-Time Independent Framework Feasibility Study |  | 326d | 2002-03-08 A | 2003-06-06 A | 100% | 2002-03-08 | 2003-06-06 | 326d | finish no earlier than 2003-06-06 | T2 | 2608h | 2608h | MEXE6-RTIF | Nokia Siemens Networks | balazs.bertenyi@nokia.com | Rel-6 | Kimmo | 22.857 |  |  |
| 2401 | 21 | Subscription Management |  | 650d | 2002-09-20 A | 2005-03-17 A | 100% | 2002-09-20 | 2005-03-17 | 650d | finish no earlier than 2005-03-17 | S5 | 5200h | 5200h | SuM | T-Mobile | istvan.aba@t-mobile.at | Rel-6 | Dionisio | 32.140/1, 32.171/2/5, 32.803 |  |  |

Notes:
- 2376: -
- 2377: -
- 2378: Updated according to SP-040232
- 2379: Completed
- 2380: SP#28 06/2005 completed
- 2381: -
- 2382: -
- 2383: No contributions assumed that no more will be done in 3GPP hence work may need to be done in 3GPP2
- 2384: -
- 2385: -
- 2386: Changed from FS to actual support of Push
- 2387: -
- 2388: -
- 2389: -
- 2390: -
- 2391: -
- 2392: -
- 2393: -
- 2394: -
- 2395: -
- 2396: SP#25 09/2004 completed
- 2397: originally it was intended to create a FS TR but most likely the work will become an Annex of 23.140
- 2398: -
- 2399: -
- 2400: -
- 2401: SP#27 03/2005 completed

| ID | WBS | Task | Duration | Start | Finish | Complete | Baseline start | Baseline finish | Baseline duration | Constraint | Resources | Work | Actual work | Text1 | Text4 | Text5 | Text6 | Text8 |
| --- | --- | --- | --- | --- | --- | --- | --- | --- | --- | --- | --- | --- | --- | --- | --- | --- | --- | --- |
| 2402 | 22 | **Presence Capability** | 1233d? | 2001-03-19 A | 2005-12-07 A | 100% | 2001-03-19 | 2005-12-07 | 1233d? |  | S1,S2,S3,S4,N1,N3,N4,OMA | 37112h | 37112h | PRESNC | Motorola | Mark Cataldo | Rel-6 | Alain |
| 2403 | 22.1 | Stage 1 for Presence Capability | 610d | 2001-03-19 A | 2003-07-18 A | 100% | 2001-03-19 | 2003-07-18 | 610d | finish no earlier than 2003-07-18 | S1 | 4880h | 4880h | PRESNC | Motorola | Mark Cataldo | Rel-6 | Alain |
| 2404 | 22.2 | Stage 2 for Presence Capability | 268d | 2001-09-12 A | 2002-09-20 A | 100% | 2001-09-12 | 2002-09-20 | 268d | finish no earlier than 2002-09-20 | S2 | 2144h | 2144h | PRESNC | Nokia | balazs.bertenyi@nsn.com | Rel-6 | Maurice |
| 2405 | 22.3 | Stage 3 for Presence Capability | 703d | 2002-04-01 A | 2004-12-08 A | 100% | 2002-04-01 | 2004-12-08 | 703d | finish no earlier than 2004-12-08 | N1,N4 | 5624h | 5624h | PRESNC | Lucent | Keith Drage (drage@alcatel-lucent.com) | Rel-6 | Frederic |
| 2406 | 761.4 | Stage 3 (CN3 Part Pk interface) | 770d? | 2002-04-01 A | 2005-03-11 A | 100% | 2002-04-01 | 2005-03-11 | 770d? | finish no earlier than 2005-03-11 | N3 | 6160h | 6160h | PRESNC | Lucent | Keith Drage (drage@alcatel-lucent.com) | Rel-6 | Gwiho |
| 2407 | 761.5 | Media Codecs and Formats for IMS Messaging and Presence | 650d? | 2003-06-12 A | 2005-12-07 A | 100% | 2003-06-12 | 2005-12-07 | 650d? | finish no earlier than 2005-12-07 | S4 | 5200h | 5200h | PRESNC-COFIMP | Nokia | harri.honko@nokia.com | Rel-6 | Paolo |
| 2408 | 22.4 | Security aspects of Presence Capability | 79d | 2002-08-26 A | 2002-12-12 A | 100% | 2002-08-26 | 2002-12-12 | 79d | finish no earlier than 2002-12-12 | S3 | 632h | 632h | PRESNC | Ericsson | krister.boman@erv.ericsson.se | Rel-6 | Dionisio |
| 2409 | 761.7 | SIMPLE Presence | 326d? | 2004-01-01 A | 2005-03-31 A | 100% | 2004-01-01 | 2005-03-31 | 326d? | finish no earlier than 2004-12-30 | OMA | 2608h | 2608h | PRESNC |  | OMA-LIAISON@mail.openmobilealliance.org | Rel-6 |  |
| 2410 | 25 | **Enhanced A/Gb feasibility study** | 51d? | 2002-08-30 A | 2002-11-08 A | 100% | 2002-08-30 | 2002-11-08 | 51d? |  | GP | 3264h | 3264h | AGbEnFS | Vodafone | jose-luis.carrizo@vodafone.co.uk | Rel-6 | Paolo |
| 2411 | 25.1 | **Feasibility study on A/Gb enhancements** | 51d? | 2002-08-30 A | 2002-11-08 A | 100% | 2002-08-30 | 2002-11-08 | 51d? |  | G2 | 2856h | 2856h | AGbEnFS-FS | Vodafone | jose-luis.carrizo@vodafone.co.uk | Rel-6 | Gert |
| 2412 | 25.1.1 | Requirements for the support of conversational services | 51d | 2002-08-30 A | 2002-11-08 A | 100% | 2002-08-30 | 2002-11-08 | 51d | finish no earlier than 2002-11-08 | GP | 408h | 408h | AGbEnFS-FS |  |  | Rel-6 | Paolo |
| 2413 | 762.1.2 | Identification of the different building blocks for the provision of conversational services on the existing A/Gb protocol stack | 51d? | 2002-08-30 A | 2002-11-08 A | 100% | 2002-08-30 | 2002-11-08 | 51d? | finish no earlier than 2002-11-08 | GP | 408h | 408h | AGbEnFS-FS |  |  | Rel-6 | Paolo |
| 2414 | 762.1.3 | Outline of impact and feasibility of these building blocks and their different solutions | 51d? | 2002-08-30 A | 2002-11-08 A | 100% | 2002-08-30 | 2002-11-08 | 51d? | finish no earlier than 2002-11-08 | GP | 408h | 408h | AGbEnFS-FS |  |  | Rel-6 | Paolo |
| 2415 | 25.1.4 | Impact on 3GPP architecture and requirement to co-ordinatge with other TSGs (CN, SA) | 51d | 2002-08-30 A | 2002-11-08 A | 100% | 2002-08-30 | 2002-11-08 | 51d | finish no earlier than 2002-11-08 | GP | 408h | 408h | AGbEnFS-FS |  |  | Rel-6 | Paolo |
| 2416 | 25.1.5 | Standardisation effort | 51d | 2002-08-30 A | 2002-11-08 A | 100% | 2002-08-30 | 2002-11-08 | 51d | finish no earlier than 2002-11-08 | GP | 408h | 408h | AGbEnFS-FS |  |  | Rel-6 | Paolo |
| 2417 | 25.1.6 | Dependency to other features of Enhanced A/Gb feasibility study | 51d | 2002-08-30 A | 2002-11-08 A | 100% | 2002-08-30 | 2002-11-08 | 51d | finish no earlier than 2002-11-08 | GP | 408h | 408h | AGbEnFS-FS |  |  | Rel-6 | Paolo |
| 2418 | 26 | **Flexible Layer One for GERAN** | 1171d | 2000-01-03 A | 2004-06-25 A | 100% | 2000-01-03 | 2004-06-25 | 1171d |  | GP,S3 | 71551h | 71551h | FLOGER | Nokia | benoist.sebire@nokia.com | Rel-6 | Paolo |
| 2419 | 26.1 | **Realisation of a Flexible Layer One** | 1126d | 2000-01-03 A | 2004-04-23 A | 100% | 2000-01-03 | 2004-04-23 | 1126d |  | GP | 42816h | 42816h | FLOGER-Real | Nokia | benoist.sebire@nokia.com | Rel-6 | Paolo |
| 2420 | 26.1.1 | Technical Report on Realisation of a Flexible Layer One | 471d | 2002-04-19 A | 2004-02-06 A | 100% | 2002-04-19 | 2004-02-06 | 471d | finish no earlier than 2004-02-06 | GP | 3768h | 3768h | FLOGER-Real | Nokia | benoist.sebire@nokia.com | Rel-6 | Paolo |
| 2421 | 26.1.2 | Architecture in 45.001 and 43.051 | 526d | 2002-04-19 A | 2004-04-23 A | 100% | 2002-04-19 | 2004-04-23 | 526d | finish no earlier than 2004-04-23 | G1 | 4208h | 4208h | FLOGER-Real | Nokia | benoist.sebire@nokia.com | Rel-6 | Paolo |
| 2422 | 26.1.3 | Multiplexing in 45.002 | 526d | 2002-04-19 A | 2004-04-23 A | 100% | 2002-04-19 | 2004-04-23 | 526d | finish no earlier than 2004-04-23 | G1 | 4208h | 4208h | FLOGER-Real | Nokia | benoist.sebire@nokia.com | Rel-6 | Paolo |
| 2423 | 26.1.4 | Channel Coding in 45.003 for Realisation of a Flexible Layer One | 526d | 2002-04-19 A | 2004-04-23 A | 100% | 2002-04-19 | 2004-04-23 | 526d | finish no earlier than 2004-04-23 | G1 | 4208h | 4208h | FLOGER-Real | Nokia | benoist.sebire@nokia.com | Rel-6 | Paolo |
| 2424 | 26.1.5 | Performance Requirements in 45.005 for Realisation of a Flexible Layer One | 1126d | 2000-01-03 A | 2004-04-23 A | 100% | 2000-01-03 | 2004-04-23 | 1126d | finish no earlier than 2004-04-23 | G1 | 9000h | 9000h | FLOGER-Real | Nokia | benoist.sebire@nokia.com | Rel-6 | Paolo |
| 2425 | 26.1.6 | Radio subsystem link control in 45.008 for Realisation of a Flexible Layer One | 526d | 2002-04-19 A | 2004-04-23 A | 100% | 2002-04-19 | 2004-04-23 | 526d | finish no earlier than 2004-04-23 | G1 | 4208h | 4208h | FLOGER-Real | Nokia | benoist.sebire@nokia.com | Rel-6 | Paolo |
| 2426 | 26.1.7 | Requirements in 44.004 | 526d | 2002-04-19 A | 2004-04-23 A | 100% | 2002-04-19 | 2004-04-23 | 526d | finish no earlier than 2004-04-23 | G2 | 4208h | 4208h | FLOGER-Real | Nokia | benoist.sebire@nokia.com | Rel-6 | Gert |

Notes:
- 2402: merged "Presence Service Enhancements" (UID31028, PRES1) to this feature as no answer was provided on why Presence and Presence Encmts had same target completion date
- 2403: TP#16 moved Stage 1 to Rel-6 TS 22.141 (existed already in Rel-5) / Text3: 22.141
- 2404: - / Text3: 23.002, 24.229, new 23.141
- 2405: Dependency to 2 IETF drafts, no known work at the moment / Text3: new N1 (24.141, 24.841), N4 (29.002, 29.228, 29.230, 29.328)
- 2406: - / Text3: 29.061, 29.161
- 2407: - / Text3: 26.141, 26.936
- 2408: SP#17 approved WID S3-020429
- 2409: SP#24 OMA LS_in update in SP-040232 OMA dependencies on 3GPP deliverables
- 2410: - / Text3: None
- 2411: - / Text3: None
- 2412: - / Text3: None
- 2413: - / Text3: None
- 2414: - / Text3: None
- 2415: - / Text3: None
- 2416: - / Text3: None
- 2417: - / Text3: None
- 2418: -
- 2419: -
- 2420: -
- 2421: -
- 2422: -
- 2423: -
- 2424: -
- 2425: -
- 2426: -

| ID | WBS | Task | Type | Duration | Start | Finish | Complete | Baseline start | Baseline finish | Baseline duration | Constraint | Resources | Work | Actual work | Text1 | Text4 | Text5 | Text6 | Text8 | Text3 | Text12 |
| --- | --- | --- | --- | --- | --- | --- | --- | --- | --- | --- | --- | --- | --- | --- | --- | --- | --- | --- | --- | --- | --- |
| 2427 | 26.2 | **Signalling and protocol support for a Flexible Layer One** |  | 571d | 2002-04-19 A | 2004-06-25 A | 100% | 2002-04-19 | 2004-06-25 | 571d |  | G2 | 13704h | 13704h | FLOGER-SigPro | Nokia | benoist.sebire@nokia.com | Rel-6 | Gert |  |  |
| 2428 | 26.2.1 | Modifications to RLC/MAC in 44.060 and 44.160 |  | 571d | 2002-04-19 A | 2004-06-25 A | 100% | 2002-04-19 | 2004-06-25 | 571d | finish no earlier than 2004-06-25 | G2 | 4568h | 4568h | FLOGER-SigPro | Nokia | benoist.sebire@nokia.com | Rel-6 | Gert |  |  |
| 2429 | 26.2.2 | Modifications to RRC in 44.118 and 44.018 |  | 571d | 2002-04-19 A | 2004-06-25 A | 100% | 2002-04-19 | 2004-06-25 | 571d | finish no earlier than 2004-06-25 | G2 | 4568h | 4568h | FLOGER-SigPro | Nokia | benoist.sebire@nokia.com | Rel-6 | Gert |  |  |
| 2430 | 26.3 | **Security for a Flexible Layer One** |  | 356d | 2002-04-19 A | 2003-08-29 A | 100% | 2002-04-19 | 2003-08-29 | 356d |  | S3, G2 | 5663.03h | 5663.03h | FLOGER-SecFLO | Nokia | benoist.sebire@nokia.com | Rel-6 | Dionisio |  |  |
| 2431 | 26.3.1 | Ciphering in 44.060, 44.160, 44.018, 44.118 |  | 356d | 2002-04-19 A | 2003-08-29 A | 100% | 2002-04-19 | 2003-08-29 | 356d | finish no earlier than 2003-08-29 | S3, G2 | 2848h | 2848h | FLOGER-SecFLO | Nokia | benoist.sebire@nokia.com | Rel-6 | Dionisio | 44.060, 44.160, 44.018, 44.118 |  |
| 2432 | 26.4 | **Deleted - GERAN MS Conformance test for the Flexible Layer One - DELETE** |  | 0d | 2004-02-06 A | 2004-02-06 A | 100% | 2004-02-06 | 2004-02-06 | 0d |  | G4,G5 |  |  | FLOGER-Msconf | Nokia | benoist.sebire@nokia.com | Rel-6 | Paolo |  | GP-27 |
| 2433 | 26.4.1 | Deleted at TSG #27 - MS Test in 51.010 | milestone | 0d | 2004-02-06 A | 2004-02-06 A | 100% | 2004-02-06 | 2004-02-06 | 0d | finish no earlier than 2004-02-06 | G4,G5 |  |  | FLOGER-Msconf | Nokia | benoist.sebire@nokia.com | Rel-6 | Paolo |  | GP-22 |
| 2434 | 26.5 | **Deleted - GERAN BTS Conformance test for the Flexible Layer One - DELETE** |  | 0d | 2004-02-06 A | 2004-02-06 A | 100% | 2004-02-06 | 2004-02-06 | 0d |  | G3new |  |  | FLOGER-BTSconf | Nokia | benoist.sebire@nokia.com | Rel-6 | Ingbert |  | GP-27 |
| 2435 | 26.5.1 | Deleted at TGS #27 - BTS Test in 51.021 - DELETE | milestone | 0d | 2004-02-06 A | 2004-02-06 A | 100% | 2004-02-06 | 2004-02-06 | 0d | finish no earlier than 2004-02-06 | G3new |  |  | FLOGER-BTSconf | Nokia | benoist.sebire@nokia.com | Rel-6 | Ingbert |  | GP-22 |
| 2436 | 27 | Uplink TDOA feasibility study |  | 151d | 2001-11-30 A | 2002-06-28 A | 100% | 2001-11-30 | 2002-06-28 | 151d | finish no earlier than 2002-06-28 | GP | 1208h | 1208h | TDOAF | TruePosition | Bob Gross (rlgross@trueposition.com) | Rel-6 | Paolo | 45.811 |  |
| 2437 | 28 | **Multimedia Broadcast and Multicast Service** |  | 1781d? | 2001-05-11 A | 2008-03-07 A | 100% | 2001-05-11 | 2008-03-07 | 1781d? |  | S1,S2,S3,S4,S5,N1,N3,R2,R4,R5,T1,GP,G2,G3new | 125736h | 125736h | MBMS |  |  | Rel-6 | Alain |  |  |
| 2438 | 28.1 | Stage 1 for Multimedia Broadcast and Multicast Service |  | 232d | 2001-05-11 A | 2002-04-01 A | 100% | 2001-05-11 | 2002-04-01 | 232d | finish no earlier than 2002-04-01 | S1 | 1856h | 1856h | MBMS |  |  | Rel-6 | Alain | 22.146, 22.101 |  |
| 2439 | 28.2 | **Stage 2 for Multimedia Broadcast and Multicast Service** |  | 648d | 2001-09-24 A | 2004-03-17 A | 100% | 2001-09-24 | 2004-03-17 | 648d |  | S2 | 10408h | 10408h | MBMS |  |  | Rel-6 | Maurice |  |  |
| 2440 | 28.2.1 | TR on MBMS Architectural Study |  | 240d | 2001-09-24 A | 2002-08-23 A | 100% | 2001-09-24 | 2002-08-23 | 240d | finish no earlier than 2002-08-23 | S2 | 1920h | 1920h | MBMS |  |  | Rel-6 | Maurice | 23.846 |  |
| 2441 | 28.2.2 | Stage 2 MBMS Specification Work |  | 413d | 2002-08-19 A | 2004-03-17 A | 100% | 2002-08-19 | 2004-03-17 | 413d | finish no earlier than 2004-03-17 | S2 | 3304h | 3304h | MBMS |  |  | Rel-6 | Maurice | 23.246 |  |
| 2442 | 28.4 | Support of the MBMS in CN protocols |  | 647d | 2002-06-18 A | 2004-12-08 A | 100% | 2002-06-18 | 2004-12-08 | 647d | finish no earlier than 2004-12-08 | N1 | 5176h | 5176h | MBMS |  |  | Rel-6 | Frederic |  |  |
| 2443 | 765.4 | Gmb interface for MBMS (CN3 part) |  | 334d | 2003-08-29 A | 2004-12-08 A | 100% | 2003-08-29 | 2004-12-08 | 334d | finish no earlier than 2004-12-08 | N3 | 2672h | 2672h | MBMS |  |  | Rel-6 | Gwiho | 29.061 |  |
| 2444 | 28.5 | Security aspects of MBMS |  | 710d | 2002-07-01 A | 2005-03-18 A | 100% | 2002-07-01 | 2005-03-18 | 710d | finish no earlier than 2005-03-18 | S3 | 5680h | 5680h | MBMS |  | adrian.escott@three.co.uk | Rel-6 | Dionisio | new 33.246 |  |
| 2445 | 765.6 | MBMS Charging |  | 108d? | 2005-01-11 A | 2005-06-09 A | 100% | 2005-01-11 | 2005-06-09 | 108d? | start no earlier than 2005-01-11 | S5 | 864h | 864h | MBMS-CH |  |  | Rel-6 | Dionisio | 32.273 |  |
| 2446 | 28.1 | **MBMS User Services** |  | 743d? | 2003-05-13 A | 2006-03-16 A | 100% | 2003-05-13 | 2006-03-16 | 743d? |  | S1,S4 | 7632h | 7632h | MBMS |  |  | Rel-6 | Alain |  |  |
| 2447 | 28.1 | Stage 1 for MBMS User Services |  | 233d | 2003-05-13 A | 2004-04-01 A | 100% | 2003-05-13 | 2004-04-01 | 233d | start no earlier than 2003-05-13 | S1 | 1864h | 1864h | MBMS |  |  | Rel-6 | Alain | 22.246 |  |
| 2448 | 765.7.2 | Definition of MBMS user services, media codecs, formats and transport/application protocols using MBMS |  | 721d? | 2003-06-12 A | 2006-03-16 A | 100% | 2003-06-12 | 2006-03-16 | 721d? | finish no earlier than 2006-03-16 | S4 | 5768h | 5768h | MBMS-TSMBMS | Nokia | igor.curcio@nokia.com | Rel-6 | Paolo | 26.346, 26.936, 26.946 |  |
| 2449 | 28.3 | **Introduction of MBMS in RAN** |  | 967d? | 2002-01-01 A | 2005-09-14 A | 100% | 2002-01-01 | 2005-09-14 | 967d? |  | R2,R4 | 8256h | 8256h | MBMS-RAN | Nokia | juho.pirskanen@nokia.com | Rel-6 | Joern |  |  |
| 2450 | 765.8.1 | Introduction of MBMS in RAN (physical & upper layers, access network interfaces) |  | 771d? | 2002-01-01 A | 2004-12-14 A | 100% | 2002-01-01 | 2004-12-14 | 771d? | finish no earlier than 2004-12-14 | R2 | 6168h | 6168h | MBMS-RAN | Nokia | juho.pirskanen@nokia.com | Rel-6 | Joern | 25.346, 25.304, 25.321, 25.322, 25.323 |  |
| 2451 | 765.8.2 | UE Performance Requirements for MBMS |  | 261d? | 2004-09-15 A | 2005-09-14 A | 100% | 2004-09-15 | 2005-09-14 | 261d? | finish no earlier than 2005-09-15 | R4 | 2088h | 2088h | MBMS-RAN-RF | Ericsson | Torgny.Palenius@ericsson.com | Rel-6 | Issam | 25.101, 25.133 |  |

Notes:
- 2427: -
- 2428: -
- 2429: -
- 2430: -
- 2431: -
- 2432: -
- 2433: -
- 2434: -
- 2435: -
- 2436: -
- 2437: SP#13 Title renamed
- 2438: -
- 2439: -
- 2440: -
- 2441: -
- 2442: -
- 2443: -
- 2444: SP#17 approved WID S3-020433
- 2445: SP#28 completed
- 2446: -
- 2447: -
- 2448: -
- 2449: -
- 2450: -
- 2451: RP#25 approved WID RP-040370

| ID | WBS | Task | Type | Duration | Start | Finish | Complete | Baseline start | Baseline finish | Baseline duration | Constraint | Deadline | Resources | Work | Actual work | Text1 | Text6 | Text8 | Text3 | Text4 | Text5 | Text10 | Text12 |
| --- | --- | --- | --- | --- | --- | --- | --- | --- | --- | --- | --- | --- | --- | --- | --- | --- | --- | --- | --- | --- | --- | --- | --- |
| 2452 | 765.9 | **MBMS UE Conformance Testing** |  | 521d? | 2006-03-10 A | 2008-03-07 A | 100% | 2006-03-10 | 2008-03-07 | 521d? |  |  | R5,T1 | 17200h | 17200h | MBMS-UEConTest | Rel-6 | Ingbert |  |  |  |  |  |
| 2453 | 16.5.1 | RF/RRM Conformance Test Aspects – MBMS (FDD) |  | 461d | 2006-06-02 A | 2008-03-07 A | 100% | 2006-06-02 | 2008-03-07 | 461d | finish no earlier than 2008-03-07 | 2006-06-02 | R5,T1 | 3688h | 3688h | MBMS-RAN-RF_Test | Rel-6 | Ingbert | 34.108, 34.109, 34.121-1, 34.121-2 | Ericsson | leif.mattisson@ericsson.com | Fri 11/03/05 |  |
| 2454 | 765.9.2 | Conformance Test Aspects - MBMS for 3.84 Mcps and 7.68 Mcps TDD |  | 318d? | 2006-09-20 A | 2007-12-07 A | 100% | 2006-09-20 | 2007-12-07 | 318d? | finish no earlier than 2007-12-07 |  | R5,T1 | 2544h | 2544h | MBMS-UEConTest_TDH | Rel-6 | Ingbert | 34.108, 34.122, 34.123-1, 34.123-2, 34.123-3 | IPWireless | Timothy Speight (tspeight@ipwireless.com) |  |  |
| 2455 | 765.9.3 | Signalling Conformance Test Aspects – MBMS for LCR TDD |  | 318d? | 2006-09-20 A | 2007-12-07 A | 100% | 2006-09-20 | 2007-12-07 | 318d? | finish no earlier than 2007-12-07 |  | R5,T1 | 2544h | 2544h | MBMS-UEConTest_SIGTDL | Rel-6 | Ingbert | 34.108, 34.123-1, 34.123-2, 34.123-3 | Datang | zhaojian@datangmobile.cn |  |  |
| 2456 | 765.9.4 | Conformance Test Aspects – MBMS |  | 396d? | 2006-03-10 A | 2007-09-14 A | 100% | 2006-03-10 | 2007-09-14 | 396d? | finish no earlier than 2007-09-14 |  | R5,T1 | 3168h | 3168h | MBMS_Test | Rel-6 | Ingbert | 34.108, 34.123-1, 34.123-2, 34.123-3 | Qualcomm | Shubhang Vora (svora@qualcomm.com) |  |  |
| 2457 | 16.5.1 | Conformance Test Aspects - 1.28 Mcps TDD MBMS RF/RRM |  | 136d | 2007-06-01 A | 2007-12-07 A | 100% | 2007-06-01 | 2007-12-07 | 136d | finish no earlier than 2007-12-07 | 2006-06-02 | R5,T1 | 1088h | 1088h | MBMS-UEConTest_RFTDL | Rel-6 | Ingbert | 34.108, 34.109, 34.122 | Datang | chenxiaozhong@datangmobile.cn | Fri 11/03/05 |  |
| 2458 | 28.6 | **Support of MBMS in GERAN** |  | 892d? | 2001-08-30 A | 2005-01-28 A | 100% | 2001-08-30 | 2005-01-28 | 892d? |  |  | GP,G2,G3new | 65992h | 65992h | MBMS-GERAN | Rel-6 | Paolo |  |  |  |  |  |
| 2459 | 28.6.1 | MBMS Impact on the logical and physical channels |  | 631d | 2002-08-30 A | 2005-01-28 A | 100% | 2002-08-30 | 2005-01-28 | 631d | finish no earlier than 2005-01-28 |  | GP | 5048h | 5048h | MBMS-GERAN | Rel-6 | Paolo |  |  |  |  |  |
| 2460 | 28.6.4 | MBMS Re-synchronisation at cell change |  | 631d | 2002-08-30 A | 2005-01-28 A | 100% | 2002-08-30 | 2005-01-28 | 631d | finish no earlier than 2005-01-28 |  | G2 | 5048h | 5048h | MBMS-GERAN | Rel-6 | Gert |  |  |  |  |  |
| 2461 | 765.10.3 | Simultaneous support of MBMS services |  | 631d? | 2002-08-30 A | 2005-01-28 A | 100% | 2002-08-30 | 2005-01-28 | 631d? | finish no earlier than 2005-01-28 |  | GP | 5048h | 5048h | MBMS-GERAN | Rel-6 | Paolo |  |  |  |  |  |
| 2462 | 765.10.4 | Simultaneous support of MBMS and non-MBMS services |  | 892d? | 2001-08-30 A | 2005-01-28 A | 100% | 2001-08-30 | 2005-01-28 | 892d? | finish no earlier than 2005-01-28 |  | GP | 7136h | 7136h | MBMS-GERAN | Rel-6 | Paolo |  |  |  |  |  |
| 2463 | 765.10.5 | MBMS Resynchronization at cell change |  | 892d? | 2001-08-30 A | 2005-01-28 A | 100% | 2001-08-30 | 2005-01-28 | 892d? | finish no earlier than 2005-01-28 |  | GP | 7136h | 7136h | MBMS-GERAN | Rel-6 | Paolo |  |  |  |  |  |
| 2464 | 28.6.5 | MBMS Decision making process between point-to-point or point-to-multipoint configurations |  | 631d | 2002-08-30 A | 2005-01-28 A | 100% | 2002-08-30 | 2005-01-28 | 631d | finish no earlier than 2005-01-28 |  | GP | 5048h | 5048h | MBMS-GERAN | Rel-6 | Paolo |  |  |  |  |  |
| 2465 | 28.6.6 | MBMS channel allocations procedures to multiple MSs |  | 631d | 2002-08-30 A | 2005-01-28 A | 100% | 2002-08-30 | 2005-01-28 | 631d | finish no earlier than 2005-01-28 |  | GP | 5048h | 5048h | MBMS-GERAN | Rel-6 | Paolo |  |  |  |  |  |
| 2466 | 28.6.7 | MBMS Changes to the Gb interface |  | 631d | 2002-08-30 A | 2005-01-28 A | 100% | 2002-08-30 | 2005-01-28 | 631d | finish no earlier than 2005-01-28 |  | GP | 5048h | 5048h | MBMS-GERAN | Rel-6 | Paolo |  |  |  |  |  |
| 2467 | 28.6.8 | GERAN specific changes to the Iu-ps interface for MBMS |  | 631d | 2002-08-30 A | 2005-01-28 A | 100% | 2002-08-30 | 2005-01-28 | 631d | finish no earlier than 2005-01-28 |  | GP | 5048h | 5048h | MBMS-GERAN | Rel-6 | Paolo |  |  |  |  |  |
| 2468 | 28.6.9 | Interaction between MBMS and Iu-flex |  | 631d | 2002-08-30 A | 2005-01-28 A | 100% | 2002-08-30 | 2005-01-28 | 631d | finish no earlier than 2005-01-28 |  | GP | 5048h | 5048h | MBMS-GERAN | Rel-6 | Paolo |  |  |  |  |  |
| 2469 | 28.6.10 | MBMS Security aspects |  | 631d | 2002-08-30 A | 2005-01-28 A | 100% | 2002-08-30 | 2005-01-28 | 631d | finish no earlier than 2005-01-28 |  | GP | 5048h | 5048h | MBMS-GERAN | Rel-6 | Paolo |  |  |  |  |  |
| 2470 | 765.10.12 | MBMS-GERAN - MS conformance tests |  | 786d? | 2002-01-25 A | 2005-01-28 A | 100% | 2002-01-25 | 2005-01-28 | 786d? | finish no earlier than 2005-01-28 |  | G3new | 6288h | 6288h | MBMS-GERAN | Rel-6 | Ingbert |  |  |  |  |  |
| 2471 | 765.10.13 | Deleted - MS conformance tests - G5 | milestone | 0d? | 2003-06-27 A | 2003-06-27 A | 100% | 2003-06-27 | 2003-06-27 | 0d? | start no earlier than 2003-06-27 |  | G5 |  |  | MBMS-GERAN | Rel-6 | Paolo |  |  |  |  | GP-19 |
| 2472 | 29 | **Speech Recognition and Speech Enabled Services** |  | 1105d? | 2001-10-08 A | 2005-12-30 A | 100% | 2001-10-08 | 2005-12-30 | 1105d? |  |  | S1 | 20176h | 20176h | SRSES | Rel-6 | Alain |  |  |  |  |  |
| 2473 | 29.1 | Speech Enabled Services Based on Distributed Speech Recognition (DSR) |  | 115d | 2001-10-08 A | 2002-03-15 A | 100% | 2001-10-08 | 2002-03-15 | 115d | finish no earlier than 2002-03-15 |  | S1 | 920h | 920h | DSR | Rel-6 | Alain | 22.977, 22.941, 23.207, 22.243 | Qualcomm | Dwilliams@qualcomm.com |  |  |
| 2474 | 29.2 | TR on Architectural impacts |  | 212d | 2003-05-12 A | 2004-03-02 A | 100% | 2003-05-12 | 2004-03-02 | 212d | finish no earlier than 2004-03-02 |  | S2 | 1696h | 1696h | SRSES | Rel-6 | Maurice | 23.877 |  |  |  |  |
| 2475 | 766.3 | Codec Work to Support Speech Recognition Framework for Automated Voice Services |  | 568d? | 2002-10-15 A | 2004-12-16 A | 100% | 2002-10-15 | 2004-12-16 | 568d? | finish no earlier than 2004-12-16 |  | S4 | 4544h | 4544h | SRSES-Codec | Rel-6 | Paolo | 26.235, 26.236, 26.243, 26.177, 26.943 | Motorola | David Pearce (bdp003@motorola.com) |  |  |
| 2476 | 766.4 | Multimodal support |  | 522d? | 2004-01-01 A | 2005-12-30 A | 100% | 2004-01-01 | 2005-12-30 | 522d? | finish no earlier than 2005-06-30 |  | OMA | 4176h | 4176h | SRSES | Rel-6 | Paolo |  |  | OMA-LIAISON@mail.openmobilealliance.org | SP-24 |  |
| 2477 | 766.5 | Deleted - SES codec negotiation at Session Description Protocol (SDP) | milestone | 0d? | 2003-06-04 A | 2003-06-04 A | 100% | 2003-06-04 | 2003-06-04 | 0d? | start no earlier than 2003-06-04 |  | N1 |  |  | SRSES | Rel-6 | Frederic |  |  |  |  | NP-23 |

Notes:
- 2452: -
- 2453: -
- 2454: -
- 2455: -
- 2456: -
- 2457: -
- 2458: -
- 2459: -
- 2460: -
- 2461: -
- 2462: -
- 2463: -
- 2464: -
- 2465: -
- 2466: -
- 2467: -
- 2468: -
- 2469: -
- 2470: -
- 2471: -
- 2472: -
- 2473: -
- 2474: -
- 2475: -
- 2476: -
- 2477: Abandoned NP-23

| ID | WBS | Task | Type | Duration | Start | Finish | Complete | Baseline start | Baseline finish | Baseline duration | Constraint | Resources | Work | Actual work | Text1 | Text6 | Text8 | Text4 | Text5 | Text10 | Text12 |
| --- | --- | --- | --- | --- | --- | --- | --- | --- | --- | --- | --- | --- | --- | --- | --- | --- | --- | --- | --- | --- | --- |
| 2478 | 30 | **Generic User Profile Rel-6** |  | 889d | 2001-10-08 A | 2005-03-03 A | 100% | 2001-10-08 | 2005-03-03 | 889d |  | S1,S3 | 24295.8h | 24295.8h | GUP | Rel-6 | Alain |  |  |  |  |
| 2479 | 30.1 | Stage 1 - Requirements for Generic User Profile |  | 430d | 2001-10-08 A | 2003-05-30 A | 100% | 2001-10-08 | 2003-05-30 | 430d | finish no earlier than 2002-12-09 | S1 | 3440h | 3440h | GUP | Rel-6 | Alain | T-Mobile | kurt.bischinger@t-mobile.at |  |  |
| 2480 | 30.3 | Stage 2 - Architecture |  | 355d | 2002-01-28 A | 2003-06-06 A | 100% | 2002-01-28 | 2003-06-06 | 355d | finish no earlier than 2003-06-06 | S2 | 2840h | 2840h | GUP | Rel-6 | Maurice | Nokia | harri.o.koskinen@nokia.com |  |  |
| 2481 | 30.2 | Stage 2 - Data Description Method |  | 586d | 2002-12-05 A | 2005-03-03 A | 100% | 2002-12-05 | 2005-03-03 | 586d | finish no earlier than 2005-03-03 | N4 | 4688h | 4688h | GUP | Rel-6 | Kimmo | T-Mobile | kurt.bischinger@t-mobile.at |  |  |
| 2482 | 30.5 | Stage 3 - Network |  | 468.98d | 2003-05-19 A | 2005-03-03 A | 100% | 2003-05-19 | 2005-03-03 | 468.98d | finish no earlier than 2005-03-03 | N4 | 3751.83h | 3751.83h | GUP | Rel-6 | Kimmo |  |  |  |  |
| 2483 | 30.6 | Security aspects of GUP |  | 308d | 2002-07-16 A | 2003-09-18 A | 100% | 2002-07-16 | 2003-09-18 | 308d | finish no earlier than 2003-09-18 | S3 | 2464h | 2464h | GUP | Rel-6 | Dionisio | Lucent | Bradley Owen (bvowen@lucent.com) |  |  |
| 2484 | 31 | **Digital Rights Management** |  | 690d? | 2001-10-08 A | 2004-05-28 A | 100% | 2001-10-08 | 2004-05-28 | 690d? |  | S1 | 10152h | 10152h | DRM | Rel-6 | Alain |  |  |  |  |
| 2485 | 31.1 | Requirements for Digital Rights Management |  | 179d | 2001-10-08 A | 2002-06-13 A | 100% | 2001-10-08 | 2002-06-13 | 179d | finish no earlier than 2002-06-13 | S1 | 1432h | 1432h | DRM | Rel-6 | Alain | Openwave | nicholas.wood@openwave.com |  |  |
| 2486 | 768.2 | Stage 2 for Digital Rights Management |  | 107d? | 2004-01-01 A | 2004-05-28 A | 100% | 2004-01-01 | 2004-05-28 | 107d? | finish no earlier than 2004-05-28 | OMA | 856h | 856h | DRM | Rel-6 |  |  | OMA-LIAISON@mail.openmobilealliance.org | SP-24 |  |
| 2487 | 768.3 | Stage 3 for Digital Rights Management |  | 107d? | 2004-01-01 A | 2004-05-28 A | 100% | 2004-01-01 | 2004-05-28 | 107d? | finish no earlier than 2004-05-28 | OMA | 856h | 856h | DRM | Rel-6 |  |  | OMA-LIAISON@mail.openmobilealliance.org | SP-24 |  |
| 2488 | 31.3 | Security for Digital Rights Management |  | 186d | 2002-06-17 A | 2003-03-03 A | 100% | 2002-06-17 | 2003-03-03 | 186d | finish no earlier than 2003-03-03 | OMA | 1488h | 1488h | DRM | Rel-6 |  |  |  |  |  |
| 2489 | 768.5 | Deleted - Monitoring of Stages 2 and 3 progress (actual work to be done by OMA) | milestone | 0d? | 2003-03-21 A | 2003-03-21 A | 100% | 2003-03-21 | 2003-03-21 | 0d? | start no earlier than 2002-08-19 | S1 |  |  | DRM | Rel-6 | Alain |  |  |  | SP-19 |
| 2490 | 32 | **WLAN-UMTS Interworking Rel-6** |  | 1495d? | 2000-01-03 A | 2005-09-22 A | 100% | 2000-01-03 | 2005-09-22 | 1495d? |  | S1,S2,S3,S5,N1,N3,N4,T3 | 45472h | 45472h | WLAN | Rel-6 | Alain | Telenor | frederic.paint@telenor.com |  |  |
| 2491 | 32.1 | Technical Report on WLAN-UMTS Interworking |  | 901d? | 2000-01-03 A | 2003-06-13 A | 100% | 2000-01-03 | 2003-06-13 | 901d? | finish no earlier than 2003-06-13 | S1 | 7200h | 7200h | WLAN-TR | Rel-6 | Alain | T-mobile | Mark.Younge@t-mobile.com |  |  |
| 2492 | 769.2 | Stage 1 for WLAN-UMTS Interworking Rel-6 |  | 375d? | 2003-01-06 A | 2004-06-11 A | 100% | 2003-01-06 | 2004-06-11 | 375d? |  | S1 | 920h | 920h | WLAN-TS | Rel-6 | Alain | Telenor | frederic.paint@telenor.com | SP-24 |  |
| 2493 | 32.2 | Architecture Definition for scenarii 2 and 3 |  | 571d | 2002-03-25 A | 2004-05-31 A | 100% | 2002-03-25 | 2004-05-31 | 571d | finish no earlier than 2004-05-31 | S2 | 4568h | 4568h | WLAN | Rel-6 | Maurice |  |  |  |  |
| 2494 | 32.3 | Security aspects of WLAN-UMTS Interworking |  | 125d | 2002-09-30 A | 2003-03-21 A | 100% | 2002-09-30 | 2003-03-21 | 125d | finish no earlier than 2003-03-21 | S3 | 1000h | 1000h | WLAN | Rel-6 | Dionisio | Ericsson, BT | luis.lopez-soria@ece.ericsson.se, colin.blanchard@bt.com |  |  |
| 2495 | 769.5 | Stage 3 - CN4 aspects |  | 334d? | 2003-05-23 A | 2004-09-01 A | 100% | 2003-05-23 | 2004-09-01 | 334d? | finish no earlier than 2004-09-01 | N4 | 2672h | 2672h | WLAN-IW | Rel-6 | Kimmo | Nokia | raquel.rodriguez@nokia.com |  |  |
| 2496 | 769.6 | Stage 3 - CN3 aspects (Wi Interface for Scenario 3) |  | 355d? | 2003-05-23 A | 2004-09-30 A | 100% | 2003-05-23 | 2004-09-30 | 355d? | start no earlier than 2003-05-23 | N3 | 2840h | 2840h | WLAN | Rel-6 | Gwiho |  |  | SP-24 |  |
| 2497 | 769.7 | Stage 3 for scenario 2 |  | 339d? | 2003-05-23 A | 2004-09-08 A | 100% | 2003-05-23 | 2004-09-08 | 339d? | finish no earlier than 2004-09-08 | N1 | 2712h | 2712h | WLAN | Rel-6 | Frederic |  |  |  |  |
| 2498 | 769.8 | Stage 3 for scenario 3 |  | 404d? | 2003-05-23 A | 2004-12-08 A | 100% | 2003-05-23 | 2004-12-08 | 404d? | finish no earlier than 2004-12-08 | N1 | 3232h | 3232h | WLAN | Rel-6 | Frederic |  |  | SP-24 |  |
| 2499 | 769.9 | WLAN charging |  | 655d? | 2003-03-21 A | 2005-09-22 A | 100% | 2003-03-21 | 2005-09-22 | 655d? | finish no earlier than 2005-09-22 | S5 | 5240h | 5240h | WLAN-CH | Rel-6 | Dionisio | Nokia | Benni ALEXANDER |  |  |
| 2500 | 769.10 | USIM enhancements for WLAN Interworking |  | 391d? | 2003-09-05 A | 2005-03-04 A | 100% | 2003-09-05 | 2005-03-04 | 391d? | finish no earlier than 2005-03-04 | T3 | 3128h | 3128h | WLAN | Rel-6 | Xavier | Axalto | Jabellan@axalto.com |  |  |
| 2501 | 33 | **Priority Service** |  | 347d? | 2002-05-30 A | 2003-09-26 A | 100% | 2002-05-30 | 2003-09-26 | 347d? |  | S1 | 6464h | 6464h | PRIOR1 | Rel-6 | Alain | Telcordia | James Garrahan (jgarraha@telcordia.com) |  |  |
| 2502 | 33.1 | Feasibility Study on Priority Service |  | 1d | 2002-06-14 A | 2002-06-14 A | 100% | 2002-06-14 | 2002-06-14 | 1d | finish no earlier than 2002-06-14 | S1 | 8h | 8h | PRIOR-FS | Rel-6 | Alain | Telcordia | James Garrahan (jgarraha@telcordia.com) |  |  |
| 2503 | 33.2 | Stage 1 - Requirements for Priority Service |  | 340d | 2002-05-30 A | 2003-09-17 A | 100% | 2002-05-30 | 2003-09-17 | 340d | finish no earlier than 2003-09-17 | S1 | 2720h | 2720h | PRIOR-SR | Rel-6 | Alain | Telcordia | James Garrahan (jgarraha@telcordia.com) |  |  |
| 2504 | 770.3 | Priority service implementation guide |  | 131d? | 2003-03-28 A | 2003-09-26 A | 100% | 2003-03-28 | 2003-09-26 | 131d? | finish no earlier than 2003-09-26 | S1 | 1048h | 1048h | PRIOR1 | Rel-6 | Alain | Telcordia | James Garrahan (jgarraha@telcordia.com) |  |  |

Notes:
- 2478: -
- 2479: - / Text3: 22.240, 22.228
- 2480: - / Text3: 23.240
- 2481: TR approved in CN#26 / Text3: 23.241
- 2482: - / Text3: 29.240
- 2483: SP#19 approved WID / Text3: 33.102, 33.203, 33.210
- 2484: Foreseen start and completion dates introduced by MCC (no indication at all on the WID)
- 2485: -
- 2486: -
- 2487: -
- 2488: SA3 acknowledge role in WI at SA3#20. Active contribution S3#24, S3#25. S3 WID approved SP#17
- 2489: Replaced by UID 60005 and 60006
- 2490: -
- 2491: - / Text3: 22.934
- 2492: - / Text3: 22.101, 22.105
- 2493: - / Text3: 23.234
- 2494: SP#17 approved WID S3-020451 / Text3: 21.133, 33.106, 33.107, 33.108, 33.200, 33.203, 33.210, new 33.234
- 2495: WID approved at CN#19 / Text3: 29.234, 29.061
- 2496: - / Text3: 29.161
- 2497: -
- 2498: -
- 2499: - / Text3: 32.252
- 2500: - / Text3: 31.102
- 2501: -
- 2502: - / Text3: 22.950
- 2503: -
- 2504: - / Text3: 22.952

| ID | WBS | Task | Type | Duration | Start | Finish | Complete | Baseline start | Baseline finish | Baseline duration | Constraint | Deadline | Resources | Work | Actual work | Text1 | Text4 | Text5 | Text6 | Text8 | Text10 | Text12 |
| --- | --- | --- | --- | --- | --- | --- | --- | --- | --- | --- | --- | --- | --- | --- | --- | --- | --- | --- | --- | --- | --- | --- |
| 2505 | 34 | **Network Sharing** |  | 820d? | 2003-01-20 A | 2006-03-10 A | 100% | 2003-01-20 | 2006-03-10 | 820d? |  |  | S1,S2,N1,R2,R5 | 18696h | 18696h | NTShar | T-Mobile | michele.zarri@t-mobile.co.uk | Rel-6 | Alain |  |  |
| 2506 | 34.1 | Technical Report on Network Sharing |  | 240d? | 2003-01-20 A | 2003-12-19 A | 100% | 2003-01-20 | 2003-12-19 | 240d? |  |  | S1 | 1920h | 1920h | NTShar-TR | T-Mobile | michele.zarri@t-mobile.co.uk | Rel-6 | Alain |  |  |
| 2507 | 771.2 | Stage 1 - CRs to implement Network Sharing |  | 240d? | 2003-01-20 A | 2003-12-19 A | 100% | 2003-01-20 | 2003-12-19 | 240d? | finish no earlier than 2003-12-19 |  | S1 | 1920h | 1920h | NTSharCR | T-Mobile | michele.zarri@t-mobile.co.uk | Rel-6 | Alain |  |  |
| 2508 | 771.3 | Stage 2 for Network Sharing |  | 372d? | 2003-02-27 A | 2004-07-30 A | 100% | 2003-02-27 | 2004-07-30 | 372d? | finish no earlier than 2004-07-30 |  | S2 | 2976h | 2976h | NTShar | T-Mobile | michele.zarri@t-mobile.co.uk | Rel-6 | Maurice |  |  |
| 2509 | 771.4 | Network sharing - stage 3 |  | 404d? | 2003-05-23 A | 2004-12-08 A | 100% | 2003-05-23 | 2004-12-08 | 404d? | finish no earlier than 2004-12-08 |  | N1 | 3232h | 3232h | NTShar | T-Mobile | michele.zarri@t-mobile.co.uk | Rel-6 | Frederic |  |  |
| 2510 | 771.5 | Enhancement of the support of network sharing in the UTRAN | milestone | 0d | 2003-09-19 A | 2003-09-19 A | 100% | 2003-09-19 | 2003-09-19 | 0d |  |  | R2 |  |  | NTShar-UTRANEnh | TeliaSonera | Anders.Dahlen@TeliaSonera.com | Rel-6 | Joern |  |  |
| 2511 | 16.5.1 | Conformance Test Aspects – Network Sharing |  | 261d | 2005-03-11 A | 2006-03-10 A | 100% | 2005-03-11 | 2006-03-10 | 261d | finish no earlier than 2006-03-10 | 2006-03-10 | R5 | 2088h | 2088h | NTShar-UTRANEnh_Test | TeliaSonera | Niklas.Wiren@TeliaSonera.com | Rel-6 | Ingbert | Fri 11/03/05 |  |
| 2512 | 35 | **QoS Improvements** |  | 628d? | 2002-07-15 A | 2004-12-08 A | 100% | 2002-07-15 | 2004-12-08 | 628d? |  |  | S2,N3 | 13128h | 13128h | QoS1 | Nokia |  | Rel-6 | Maurice |  |  |
| 2513 | 35.1 | FS on Dynamic Policy control enhancements for end-to-end QoS |  | 465d | 2002-07-15 A | 2004-04-23 A | 100% | 2002-07-15 | 2004-04-23 | 465d | finish no earlier than 2004-04-23 |  | S2 | 3720h | 3720h | QoS1 | Nortel | Claire Mousset | Rel-6 | Maurice |  |  |
| 2514 | 772.2 | Definition of the Gq interface |  | 214d? | 2003-07-01 A | 2004-04-23 A | 100% | 2003-07-01 | 2004-04-23 | 214d? | finish no earlier than 2004-04-23 |  | S2 | 1712h | 1712h | QoS1 |  | Janne Rinne | Rel-6 | Maurice |  |  |
| 2515 | 772.3 | Gq interface specification for Dynamic Policy control enhancements – Stage 3 |  | 334d | 2003-08-29 A | 2004-12-08 A | 100% | 2003-08-29 | 2004-12-08 | 334d | finish no earlier than 2004-12-08 |  | N3 | 2672h | 2672h | QoS1 | Nokia | Anna.Sillanpaai@nokia.com | Rel-6 | Gwiho |  |  |
| 2516 | 36 | **Subscriber certificates** |  | 728d? | 2002-02-25 A | 2004-12-08 A | 100% | 2002-02-25 | 2004-12-08 | 728d? |  |  | S3,S2,N1,N4,T3,OMA | 12888h | 12888h | SEC1-SC | Nokia | valtteri.niemi@nokia.com | Rel-6 | Dionisio |  |  |
| 2517 | 36.1 | Stage 1 of Subscriber certificates |  | 144d | 2002-02-25 A | 2002-09-12 A | 100% | 2002-02-25 | 2002-09-12 | 144d | finish no earlier than 2002-09-12 |  | S3 | 1152h | 1152h | SEC1-SC | Nokia | valtteri.niemi@nokia.com | Rel-6 | Dionisio |  |  |
| 2518 | 36.2 | Architecture review |  | 24d | 2002-10-14 A | 2002-11-14 A | 100% | 2002-10-14 | 2002-11-14 | 24d | finish no earlier than 2002-11-14 |  | S2 | 192h | 192h | SEC1-SC | Nokia |  | Rel-6 | Maurice |  |  |
| 2519 | 773.3 | Stage 3 for Subscriber certificates |  | 313d? | 2003-09-19 A | 2004-11-30 A | 100% | 2003-09-19 | 2004-11-30 | 313d? | finish no earlier than 2004-11-30 |  | N4,T3 | 2504h | 2504h | SEC1-SC | Nokia | Lauri Laitinen | Rel-6 | Kimmo |  |  |
| 2520 | 773.4 | Stage 3 Ua & Ub interfaces |  | 288d? | 2003-11-03 A | 2004-12-08 A | 100% | 2003-11-03 | 2004-12-08 | 288d? | finish no earlier than 2004-12-08 |  | N1 | 2304h | 2304h | SEC1-SC | Nokia |  | Rel-6 | Frederic |  |  |
| 2521 | 773.5 | OMA dependencies on Subscriber certificates |  | 114d? | 2004-01-01 A | 2004-06-08 A | 100% | 2004-01-01 | 2004-06-08 | 114d? | finish no earlier than 2004-06-08 |  | OMA | 912h | 912h | SEC1-SC | Nokia | OMA-LIAISON@mail.openmobilealliance.org | Rel-6 |  | SP-24 |  |
| 2522 | 774 | **Rel-6 Open Service Access (OSA) enhancements** |  | 616d? | 2002-10-31 A | 2005-03-10 A | 100% | 2002-10-31 | 2005-03-10 | 616d? |  |  | N5 | 22576h | 22576h | OSA3 | Alcatel | Chelo.Abarca@alcatel.fr | Rel-6 | Kimmo |  |  |
| 2523 | 774.1 | Scope of the Open Service Access Release 6 |  | 66d? | 2003-03-28 A | 2003-06-27 A | 100% | 2003-03-28 | 2003-06-27 | 66d? | finish no earlier than 2003-06-27 |  | S1 | 528h | 528h | OSA3 |  |  | Rel-6 | Alain |  |  |
| 2524 | 774.2 | OSA Stage 2 |  | 150d? | 2004-08-13 A | 2005-03-10 A | 100% | 2004-08-13 | 2005-03-10 | 150d? | finish no earlier than 2005-03-10 |  | N5 | 1200h | 1200h | OSA3 |  |  | Rel-6 | Kimmo |  |  |
| 2525 | 774.3 | Multi Media Messaging function |  | 487d? | 2002-10-31 A | 2004-09-10 A | 100% | 2002-10-31 | 2004-09-10 | 487d? | finish no earlier than 2004-09-10 |  | N5 | 3896h | 3896h | OSA3 |  |  | Rel-6 | Kimmo |  |  |
| 2526 | 774.4 | Policy management extensions |  | 292d? | 2002-10-31 A | 2003-12-12 A | 100% | 2002-10-31 | 2003-12-12 | 292d? | finish no earlier than 2003-12-12 |  | N5 | 2336h | 2336h | OSA3 |  |  | Rel-6 | Kimmo |  |  |
| 2527 | 774.5 | TS on Presence and Availability Management (from the PRESNC WI) |  | 367d? | 2002-10-31 A | 2004-03-26 A | 100% | 2002-10-31 | 2004-03-26 | 367d? | finish no earlier than 2004-03-26 |  | N5 | 2936h | 2936h | OSA3 |  |  | Rel-6 | Kimmo |  |  |
| 2528 | 774.6 | OSA interfaces at different levels of abstractions (Parlay X, Web services) |  | 305d? | 2003-07-14 A | 2004-09-10 A | 100% | 2003-07-14 | 2004-09-10 | 305d? | finish no earlier than 2004-09-10 |  | N5 | 2440h | 2440h | OSA3 |  |  | Rel-6 | Kimmo |  |  |
| 2529 | 774.7 | Introduction of migration support mechanism |  | 290d? | 2002-10-31 A | 2003-12-10 A | 100% | 2002-10-31 | 2003-12-10 | 290d? | finish no earlier than 2003-12-12 |  | N5 | 2320h | 2320h | OSA3 |  |  | Rel-6 | Kimmo |  |  |
| 2530 | 774.8 | Framework Function for Federation |  | 225d? | 2003-02-03 A | 2003-12-12 A | 100% | 2003-02-03 | 2003-12-12 | 225d? | finish no earlier than 2003-12-12 |  | N5 | 1800h | 1800h | OSA3 |  |  | Rel-6 | Kimmo |  |  |
| 2531 | 774.9 | OMA potential overlaps with 3GPP OSA Stage 3 (Web services) |  | 196d? | 2003-12-18 A | 2004-09-16 A | 100% | 2003-12-18 | 2004-09-16 | 196d? | start no earlier than 2003-12-18 |  | OMA | 1568h | 1568h | OSA3 |  |  | Rel-6 |  | SP-24 |  |
| 2532 | 774.10 | Deleted - TR on Presence and Availability Management (from the PRESNC WI) | milestone | 0d? | 2004-09-17 A | 2004-09-17 A | 100% | 2004-09-17 | 2004-09-17 | 0d? | start no earlier than 2004-09-17 |  | N5 |  |  | OSA3 |  |  | Rel-6 | Kimmo |  | NP-24 |

Notes:
- 2505: -
- 2506: - / Text3: 22.951
- 2507: - / Text3: 22.011, 22.101, 22.115, 22.129
- 2508: - / Text3: 23.002, 23.060, 23.221, 23.236, new TS 23.251, TR 23.851
- 2509: - / Text3: 23.008, 23.122, 24.007, 24.008, 29.018
- 2510: - / Text3: 25.401, 25.413, 25.331, 25.304
- 2511: - / Text3: 34.108, 34.123-1, 34.123-2, 34.123-3
- 2512: - / Text3: 23.107, 23.207, 23.221
- 2513: - / Text3: 23.917 withdrawn (Contents all in 23.207)
- 2514: - / Text3: 23.207
- 2515: [DAB - 25.05.04] - Delayed to Sept - possibly Dec 2004 / Text3: 29.207, 29.208, 29.209
- 2516: SP#14 approved WID
- 2517: - / Text3: new (33.220, 33.221, 33.222, 33.246, 33.919)
- 2518: -
- 2519: Finished in CN4#26 / Text3: 23.003, 23.008, 29.109, 29.230, T3 31.102, 31.103, 31.111
- 2520: - / Text3: 24.109
- 2521: Updated according to SP-040420
- 2522: CN#25: Updated WID NP-040351 replaces NP-040144. / Text3: 22.127, 23.198, 29.198, 29.199, 29.998
- 2523: -
- 2524: Inherited by CN5 from SA2 at TSG#25 Sep 2004. SA2's 23.127 (OSA/VHE Stage 2) replaced from Rel-6 onwards by a new CN5 TS 23.198 (Stage 2 OSA-only). / Text3: 23.198 OSA Stage 2-ONLY replaces 23.127 (OSA/VHE) from Rel-6 onwards
- 2525: - / Text3: 29.198-15
- 2526: - / Text3: 29.198, 29.998
- 2527: N5#26: Split WI into TS & TR. / Text3: 29.198-14
- 2528: - / Text3: 29.199
- 2529: - / Text3: 29.198, 29.998
- 2530: - / Text3: 29.198, 29.998
- 2531: TSG#25 Approved CN5 29.199 Parlay X Web services. Ongoing 3GPP/OMA co-ordination to avoid OMA producing conflicting/OVERLAPING specs (NP-040283/SP-040493).
- 2532: N5#26:TR Completion 09/04; consistent with CN1 delayed Rel-6 completion.

| ID | WBS | Task | Duration | Start | Finish | Complete | Baseline start | Baseline finish | Baseline duration | Constraint | Resources | Work | Actual work | Text1 | Text4 | Text5 | Text6 | Text8 | Text12 |
| --- | --- | --- | --- | --- | --- | --- | --- | --- | --- | --- | --- | --- | --- | --- | --- | --- | --- | --- | --- |
| 2533 | 39 | **Addition of frequency bands to GSM (TAPS)** | 676d | 2002-06-28 A | 2005-01-28 A | 100% | 2002-06-28 | 2005-01-28 | 676d |  | GP | 16640h | 16640h | TAPS | Nokia | Torben Themsen | Rel-6 | Paolo |  |
| 2534 | 39.1 | **Addition of frequency bands to GSM – Changes to core specs** | 26d | 2002-11-15 A | 2002-12-20 A | 100% | 2002-11-15 | 2002-12-20 | 26d |  | G1 | 416h | 416h | TAPS-Specs | Nokia | Torben Themsen | Rel-6 | Paolo |  |
| 2535 | 39.1.1 | Changes to core specs | 26d | 2002-11-15 A | 2002-12-20 A | 100% | 2002-11-15 | 2002-12-20 | 26d | finish no earlier than 2002-12-20 | G1 | 208h | 208h | TAPS-Specs | Nokia | Torben Themsen | Rel-6 | Paolo |  |
| 2536 | 39.2 | **Deleted - Addition of frequency bands to GSM – Changes for conformance tests** | 676d | 2002-06-28 A | 2005-01-28 A | 100% | 2002-06-28 | 2005-01-28 | 676d |  | G4 | 10816h | 10816h | TAPS-Conf | Nokia | Torben Themsen | Rel-6 | Paolo | GP-23 |
| 2537 | 39.2.1 | Deleted - 51.010-1 Add testing | 676d | 2002-06-28 A | 2005-01-28 A | 100% | 2002-06-28 | 2005-01-28 | 676d | finish no earlier than 2005-01-28 | G4 | 5408h | 5408h | TAPS-Conf | Nokia | Torben Themsen | Rel-6 | Paolo | GP-23 |
| 2538 | 40 | **Seamless support of streaming services in A/Gb mode** | 1426d? | 2000-01-03 A | 2005-06-17 A | 100% | 2000-01-03 | 2005-06-17 | 1426d? |  | GP,S3 | 58656h | 58656h | SSStrea | Vodafone | José Luis Carrizo Martínez | Rel-6 | Paolo |  |
| 2539 | 40.1 | **Identification of requirements for streaming** | 46d? | 2003-06-27 A | 2003-08-29 A | 100% | 2003-06-27 | 2003-08-29 | 46d? |  | G1 | 736h | 736h | SSStrea | Vodafone | José Luis Carrizo Martínez | Rel-6 | Paolo |  |
| 2540 | 776.1.1 | Requirements for streaming | 46d? | 2003-06-27 A | 2003-08-29 A | 100% | 2003-06-27 | 2003-08-29 | 46d? | finish no earlier than 2003-08-29 | G1 | 368h | 368h | SSStrea | Vodafone | José Luis Carrizo Martínez | Rel-6 | Paolo |  |
| 2541 | 40.2 | **Performance study of cell change mechanisms** | 956d? | 2000-01-03 A | 2003-08-29 A | 100% | 2000-01-03 | 2003-08-29 | 956d? |  | G1 | 30568h | 30568h | SSStrea | Vodafone | José Luis Carrizo Martínez | Rel-6 | Paolo |  |
| 2542 | 776.2.1 | Performance of NACC | 956d? | 2000-01-03 A | 2003-08-29 A | 100% | 2000-01-03 | 2003-08-29 | 956d? | finish no earlier than 2003-08-29 | G1 | 7640h | 7640h | SSStrea | Vodafone | José Luis Carrizo Martínez | Rel-6 | Paolo |  |
| 2543 | 776.2.2 | Performance of cell change in DTM for the PS domain | 956d? | 2000-01-03 A | 2003-08-29 A | 100% | 2000-01-03 | 2003-08-29 | 956d? | finish no earlier than 2003-08-29 | G1 | 7640h | 7640h | SSStrea | Vodafone | José Luis Carrizo Martínez | Rel-6 | Paolo |  |
| 2544 | 776.2.3 | Handover for Seamless support of streaming services in A/Gb mode | 956d? | 2000-01-03 A | 2003-08-29 A | 100% | 2000-01-03 | 2003-08-29 | 956d? | finish no earlier than 2003-08-29 | G1 | 7640h | 7640h | SSStrea | Vodafone | José Luis Carrizo Martínez | Rel-6 | Paolo |  |
| 2545 | 40.3 | **Reduction of service interruption times and packet loss during mobility procedures** | 516d? | 2003-06-27 A | 2005-06-17 A | 100% | 2003-06-27 | 2005-06-17 | 516d? |  | G2 | 10800h | 10800h | SSStrea | Vodafone | José Luis Carrizo Martínez | Rel-6 | Gert |  |
| 2546 | 776.3.1 | optimizations of existing mechanisms/procedures | 106d? | 2003-06-27 A | 2003-11-21 A | 100% | 2003-06-27 | 2003-11-21 | 106d? | finish no earlier than 2003-11-21 | G2 | 848h | 848h | SSStrea | Vodafone | José Luis Carrizo Martínez | Rel-6 | Gert |  |
| 2547 | 776.3.2 | Inter-system NACC | 106d? | 2003-06-27 A | 2003-11-21 A | 100% | 2003-06-27 | 2003-11-21 | 106d? | finish no earlier than 2003-11-21 | G2 | 848h | 848h | SSStrea | Vodafone | José Luis Carrizo Martínez | Rel-6 | Gert |  |
| 2548 | 776.3.3 | PS Handover (within GERAN and between GERAN and UTRAN) | 516d? | 2003-06-27 A | 2005-06-17 A | 100% | 2003-06-27 | 2005-06-17 | 516d? | finish no earlier than 2003-11-21 | G2 | 4128h | 4128h | SSStrea | Vodafone | José Luis Carrizo Martínez | Rel-6 | Gert |  |
| 2549 | 776.3.4 | Dependency to other features of Reduction of service interruption times and packet loss during mobility procedures | 106d? | 2003-06-27 A | 2003-11-21 A | 100% | 2003-06-27 | 2003-11-21 | 106d? | finish no earlier than 2003-11-21 | G2 | 848h | 848h | SSStrea | Vodafone | José Luis Carrizo Martínez | Rel-6 | Gert |  |
| 2550 | 40.5 | **Deleted - MS conformance testing for Seamless support of streaming services in A/Gb mode** | 31d? | 2003-12-19 A | 2004-01-30 A | 100% | 2003-12-19 | 2004-01-30 | 31d? |  | G3new | 248h | 248h | SSStrea | Vodafone | José Luis Carrizo Martínez | Rel-6 | Ingbert | GP-27 |
| 2551 | 776.4.1 | Deleted - MS conformance tests for Seamless support of streaming services in A/Gb mode | 31d? | 2003-12-19 A | 2004-01-30 A | 100% | 2003-12-19 | 2004-01-30 | 31d? | finish no earlier than 2004-01-30 | G4,G5 | 248h | 248h | SSStrea | Vodafone | José Luis Carrizo Martínez | Rel-6 | Ingbert | GP-27 |
| 2552 | 776.5 | GERAN A/Gb mode security enhancements | 612d? | 2002-09-26 A | 2005-01-28 A | 100% | 2002-09-26 | 2005-01-28 | 612d? | finish no earlier than 2005-01-28 | S3 | 4896h | 4896h | SSStrea | Vodafone | peter.howard@vodafone.com | Rel-6 | Dionisio |  |
| 2553 | 41 | Performance characterisation of default codecs for PS conversational multimedia application | 455d | 2002-09-13 A | 2004-06-10 A | 100% | 2002-09-13 | 2004-06-10 | 455d | finish no earlier than 2004-06-10 | S4 | 3640h | 3640h | CODCAR | Nokia | pasi.s.ojala@nokia.com | Rel-6 | Paolo |  |
| 2554 | 43 | Study on Privacy Capability | 83d | 2003-11-10 A | 2004-03-03 A | 100% | 2003-11-10 | 2004-03-03 | 83d | start no earlier than 2003-11-10 | S1 | 664h | 664h | PrivCap | Lucent | Michael Boote (mboote@alcatel-lucent.com) | Rel-6 | Alain |  |
| 2555 | 44 | **Rel-6 Operations, Administration, Maintenance and Provisioning (OAM&P)** | 652d? | 2002-09-12 A | 2005-03-11 A | 100% | 2002-09-12 | 2005-03-11 | 652d? |  | S5 | 32299.5h | 32299.5h | OAM |  |  | Rel-6 | Dionisio |  |
| 2556 | 44.1 | Principles, high level Requirements and Architecture | 526d | 2002-09-12 A | 2004-09-16 A | 100% | 2002-09-12 | 2004-09-16 | 526d | finish no earlier than 2004-09-16 | S5 | 4208h | 4208h | OAM-AR | Motorola |  | Rel-6 | Dionisio |  |
| 2557 | 44.2 | Performance Management | 591d | 2002-09-12 A | 2004-12-16 A | 100% | 2002-09-12 | 2004-12-16 | 591d | finish no earlier than 2004-12-16 | S5 | 4728h | 4728h | OAM-PM | Nortel |  | Rel-6 | Dionisio |  |
| 2558 | 44.4 | Network Infrastructure Management | 591d | 2002-09-12 A | 2004-12-16 A | 100% | 2002-09-12 | 2004-12-16 | 591d | finish no earlier than 2004-12-16 | S5 | 4728h | 4728h | OAM-NIM | Ericsson | thomas.tovinger@ericsson.com | Rel-6 | Dionisio |  |

Notes:
- 2533: -
- 2534: -
- 2535: -
- 2536: -
- 2537: -
- 2538: -
- 2539: -
- 2540: -
- 2541: -
- 2542: -
- 2543: -
- 2544: -
- 2545: Completed at GERP#17
- 2546: -
- 2547: -
- 2548: -
- 2549: -
- 2550: Marked as stopped 10/2009
- 2551: Marked as stopped 10/2009
- 2552: SP#19 approved WID / Text3: 33.102
- 2553: - / Text3: 26.935
- 2554: - / Text3: 22.949
- 2555: SP#26: Updated WID SP-040766 was SP-020445. Completion delayed 12/04->03/05 due to OAM-Trace in CN1/4.
- 2556: SP#25 09/2004 completed / Text3: 32.101, 32.102
- 2557: SP#26 12/2004 completed / Text3: 32.401, 32.403, 52.402, 32.411, 32.412, 32.413, 32.432, 32.435, 32.436
- 2558: SP#26 12/2004 completed / Text3: 32.150/1/2, 32.805, 32.111-5, 32.313/4, 32.331/2/3/4/5, 32.341/2/3/4, 32.351/2/3/4, 32.361/2/3/4, 32.371/2/3/4, 32.804, 32.675, 32.690, 32.695, 32.71/2/3/4/5, 32.741/2/3/4/5

| ID | WBS | Task | Duration | Start | Finish | Complete | Baseline start | Baseline finish | Baseline duration | Constraint | Resources | Work | Actual work | Text1 | Text4 | Text5 | Text6 | Text8 | Text3 | Text10 | Text12 |
| --- | --- | --- | --- | --- | --- | --- | --- | --- | --- | --- | --- | --- | --- | --- | --- | --- | --- | --- | --- | --- | --- |
| 2559 | 44.5 | **Rel-6 Trace Management** | 646d? | 2002-09-20 A | 2005-03-11 A | 100% | 2002-09-20 | 2005-03-11 | 646d? |  | S5,N4,R3 | 13541.9h | 13541.9h | OAM-Trace | Nokia | kari.t.ronka@nokia.com | Rel-6 | Dionisio |  |  |  |
| 2560 | 779.4.1 | Subscriber and UE trace management | 585d | 2002-09-20 A | 2004-12-16 A | 100% | 2002-09-20 | 2004-12-16 | 585d | finish no earlier than 2004-12-16 | S5 | 4680h | 4680h | OAM-Trace | Nokia | kari.t.ronka@nokia.com | Rel-6 | Dionisio | 32.421, 32.422, 32.423, 52.008 |  |  |
| 2561 | 779.4.2 | Subscriber and equipment trace in UTRAN | 268d? | 2003-06-06 A | 2004-06-15 A | 100% | 2003-06-06 | 2004-06-15 | 268d? | finish no earlier than 2004-06-15 | R3 | 2144h | 2144h | OAM-Trace-RAN | Nortel | Yann Sehedi (sehedic@nortelnetworks.com) | Rel-6 | Juha | 25.413, 25.420, 25.423 |  |  |
| 2562 | 779.4.3 | Trace Management, Stage3 | 193.74d? | 2004-06-09 A | 2005-03-11 A | 100% | 2004-06-09 | 2005-03-11 | 193.74d? | finish no earlier than 2005-03-11 | N4 | 1549.92h | 1549.92h | OAM-Trace | Nokia | seppo.kauntola@nokia.com | Rel-6 | Kimmo | 23.205, 29.232, 29.060, 29.002, 29.228 |  |  |
| 2563 | 780 | **Rel-6 Charging Management** | 666d? | 2002-11-21 A | 2005-06-09 A | 100% | 2002-11-21 | 2005-06-09 | 666d? |  | S5 | 55320h | 55320h | CH | T-Mobile | karl-heinz.nenner@t-mobile.de | Rel-6 | Dionisio |  |  |  |
| 2564 | 780.1 | Charging architecture and principles | 390d? | 2003-03-21 A | 2004-09-16 A | 100% | 2003-03-21 | 2004-09-16 | 390d? | start no earlier than 2003-03-21 | S5 | 3120h | 3120h | CH |  |  | Rel-6 | Dionisio | 32.240 |  |  |
| 2565 | 780.2 | Charging Data Record (CDR) file format and transfer | 260d? | 2003-03-21 A | 2004-03-18 A | 100% | 2003-03-21 | 2004-03-18 | 260d? | start no earlier than 2003-03-21 | S5 | 2080h | 2080h | CH |  |  | Rel-6 | Dionisio | 32.297 |  |  |
| 2566 | 780.3 | CDR parameter description | 580d? | 2003-03-21 A | 2005-06-09 A | 100% | 2003-03-21 | 2005-06-09 | 580d? | finish no earlier than 2005-06-09 | S5 | 4640h | 4640h | CH |  |  | Rel-6 | Dionisio | 32.298 |  |  |
| 2567 | 780.4 | Diameter charging applications | 390d? | 2003-03-21 A | 2004-09-16 A | 100% | 2003-03-21 | 2004-09-16 | 390d? | start no earlier than 2003-03-21 | S5 | 3120h | 3120h | CH |  |  | Rel-6 | Dionisio | 32.299 |  |  |
| 2568 | 780.5 | Online Charging System (OCS) architecture study | 130d? | 2003-03-21 A | 2003-09-18 A | 100% | 2003-03-21 | 2003-09-18 | 130d? | start no earlier than 2003-03-21 | S5 | 1040h | 1040h | CH |  |  | Rel-6 | Dionisio | 32.815 |  |  |
| 2569 | 780.6 | OCS: Applications and interfaces | 455d? | 2003-03-21 A | 2004-12-16 A | 100% | 2003-03-21 | 2004-12-16 | 455d? | start no earlier than 2003-03-21 | S5 | 3640h | 3640h | CH |  |  | Rel-6 | Dionisio | 32.296 |  |  |
| 2570 | 780.7 | **Charging Management for Bearer level** | 390d? | 2003-03-21 A | 2004-09-16 A | 100% | 2003-03-21 | 2004-09-16 | 390d? |  | S5 | 11440h | 11440h | CH-BC | Nokia | Benni ALEXANDER | Rel-6 | Dionisio |  |  |  |
| 2571 | 780.7.1 | CS domain charging | 260d? | 2003-03-21 A | 2004-03-18 A | 100% | 2003-03-21 | 2004-03-18 | 260d? | start no earlier than 2003-03-21 | S5 | 2080h | 2080h | CH |  |  | Rel-6 | Dionisio | 32.250 |  |  |
| 2572 | 780.7.2 | PS domain charging | 390d? | 2003-03-21 A | 2004-09-16 A | 100% | 2003-03-21 | 2004-09-16 | 390d? | start no earlier than 2003-03-21 | S5 | 3120h | 3120h | CH |  |  | Rel-6 | Dionisio | 32.251 |  |  |
| 2573 | 780.7.3 | CDR transfer | 390d? | 2003-03-21 A | 2004-09-16 A | 100% | 2003-03-21 | 2004-09-16 | 390d? | start no earlier than 2003-03-21 | S5 | 3120h | 3120h | CH |  |  | Rel-6 | Dionisio | 32.295 |  |  |
| 2574 | 780.8 | Charging Management for the IMS | 455d? | 2003-03-21 A | 2004-12-16 A | 100% | 2003-03-21 | 2004-12-16 | 455d? | finish no earlier than 2004-12-16 | S5 | 3640h | 3640h | IMS2-CH | Ericsson | Patrik TEPPO | Rel-6 | Dionisio | 32.260 |  |  |
| 2575 | 780.9 | Charging Management for the Service domain | 580d? | 2003-03-21 A | 2005-06-09 A | 100% | 2003-03-21 | 2005-06-09 | 580d? | finish no earlier than 2005-06-09 | S5 | 4640h | 4640h | CH | Siemens | Gerald.Goermer@nsn.com | Rel-6 | Dionisio | 32.252, 32.270, 32.271, 32.272 |  |  |
| 2576 | 780.10 | **Overall architectural aspects of IP flow based bearer level charging** | 602d? | 2002-11-21 A | 2005-03-11 A | 100% | 2002-11-21 | 2005-03-11 | 602d? |  | S2 | 12632h | 12632h | CH-FBC |  |  | Rel-6 | Maurice | 23.125 |  |  |
| 2577 | 780.10.1 | Overall definition of FBC architecture | 334d? | 2002-11-21 A | 2004-03-02 A | 100% | 2002-11-21 | 2004-03-02 | 334d? | start no earlier than 2002-11-21 | S2 | 2672h | 2672h | CH-FBC |  |  | Rel-6 | Maurice |  | SP-24 |  |
| 2578 | 780.10.2 | Study on providing policy control with FBC | 130d? | 2004-02-02 A | 2004-07-30 A | 100% | 2004-02-02 | 2004-07-30 | 130d? | start no earlier than 2004-02-01 | S2 | 1040h | 1040h | CH-FBC |  |  | Rel-6 | Maurice |  | SP-24 |  |
| 2579 | 780.10.3 | Gx interface for flow based charging | 223d? | 2004-02-02 A | 2004-12-08 A | 100% | 2004-02-02 | 2004-12-08 | 223d? | start no earlier than 2004-02-01 | N3 | 1784h | 1784h | CH-FBC | Nokia | juha.a.rasanen@nokia.com | Rel-6 | Gwiho | 29.210 | SP-25 |  |
| 2580 | 780.10.4 | Rx interface for flow based charging | 290d? | 2004-02-02 A | 2005-03-11 A | 100% | 2004-02-02 | 2005-03-11 | 290d? | finish no earlier than 2005-03-11 | N3 | 2320h | 2320h | CH-FBC | Nortel | Javier Gonzalez Gallego | Rel-6 | Gwiho | 29.209 | SP-25 |  |
| 2581 | 13 | **Rel-6 UICC/USIM enhancements and interworking** | 1164d? | 2000-09-25 A | 2005-03-10 A | 100% | 2000-09-25 | 2005-03-10 | 1164d? |  | T3 | 43088h | 43088h | USAT1 |  |  | Rel-6 | Xavier |  |  |  |
| 2582 | 13.1 | **UICC API** | 777d | 2002-03-20 A | 2005-03-10 A | 100% | 2002-03-20 | 2005-03-10 | 777d |  | T3 | 15024h | 15024h | USAT1-API |  |  | Rel-6 | Xavier |  |  |  |
| 2583 | 13.1.1 | Rel-6 Java API Test specification | 59d | 2002-03-20 A | 2002-06-10 A | 100% | 2002-03-20 | 2002-06-10 | 59d | finish no earlier than 2002-09-20 | T3 | 472h | 472h | USAT1-API | Microelectrónica Española | Mario Pérez | Rel-6 | Xavier |  |  |  |
| 2584 | 781.1.2 | 2G/3G Java Card™ API based applet interworking | 255d | 2003-03-17 A | 2004-03-05 A | 100% | 2003-03-17 | 2004-03-05 | 255d | finish no earlier than 2004-02-19 | T3 | 2040h | 2040h | USAT1-API | Oberthur Card Systems | Stéphane Andrau | Rel-6 | Xavier |  |  |  |
| 2585 | 781.1.3 | (U)SIM API for Java Card Testing | 519d | 2003-03-17 A | 2005-03-10 A | 100% | 2003-03-17 | 2005-03-10 | 519d | finish no earlier than 2005-03-10 | T3 | 4152h | 4152h | USAT1-API | Axalto | Christophe Begassat (cbegassat@axalto.com) | Rel-6 | Xavier | 31.213 |  |  |
| 2586 | 13.1.2 | Deleted - Java API Test specification (TS 43.019 Rel-5) | 268d | 2002-05-30 A | 2003-06-09 A | 100% | 2002-05-30 | 2003-06-09 | 268d | finish no earlier than 2003-09-17 | T3 | 2144h | 2144h | USAT1-API | Microelectrónica Española | Mario Pérez | Rel-6 | Xavier |  |  | TP-20 |

Notes:
- 2559: SP#26 12/2004 SA5 completed 12/04. Signalling Based Trace Activation for IMS (SIP) moved to Rel-7. Reason: CN1 cannot complete 24.229 trace without IETF dependency => estimate 05/2005.
- 2560: SP#26 12/2004 completed
- 2561: -
- 2562: -
- 2563: SP#28 Target 09/2005 for WLAN Charging 32.252
- 2564: SP#25 09/2004 completed
- 2565: SP#23 03/2004 completed
- 2566: SP#28 06/2005 completed
- 2567: SP#25 09/2004 completed
- 2568: SP#21 09/2003 completed
- 2569: SP#26 12/2004 completed
- 2570: SP#28 Target 09/2005 for WLAN Charging 32.252
- 2571: SP#23 03/2004 completed
- 2572: SP#25 09/2004 completed
- 2573: SP#25 09/2004 completed
- 2574: SP#26 12/2004 completed
- 2575: SP#26: Updated WID SP-040778 was SP-030050. Target completion 06/2005. Consisting of MMS-CH, LCS-CH, WLAN-CH, POC-CH, MBMS-CH
- 2576: -
- 2577: -
- 2578: -
- 2579: -
- 2580: -
- 2581: -
- 2582: 8/3/2001: test spec is based on R99 core spec, so deleted from Workplan
- 2583: -
- 2584: -
- 2585: -
- 2586: MOVED to Rel-5 WP

| ID | WBS | Task | Type | Duration | Start | Finish | Complete | Baseline start | Baseline finish | Baseline duration | Constraint | Resources | Work | Actual work | Text1 | Text4 | Text5 | Text6 | Text8 | Text12 |
| --- | --- | --- | --- | --- | --- | --- | --- | --- | --- | --- | --- | --- | --- | --- | --- | --- | --- | --- | --- | --- |
| 2587 | 781.2 | **Rel-6 USIM toolkit enhancements** |  | 1160d? | 2000-09-25 A | 2005-03-04 A | 100% | 2000-09-25 | 2005-03-04 | 1160d? |  | T3 | 21848h | 21848h | USAT1-API-MULTOS | Aspects Software | Neil Livingston | Rel-6 | Xavier |  |
| 2588 | 781.2.1 | **C SIM API** |  | 525d | 2000-09-25 A | 2002-09-27 A | 100% | 2000-09-25 | 2002-09-27 | 525d |  | T3 | 9960h | 9960h | USAT1-API-MULTOS | Aspects Software | Neil Livingston | Rel-6 | Xavier |  |
| 2589 | 781.2.1.1 | Specification of C SIM API |  | 525d | 2000-09-25 A | 2002-09-27 A | 100% | 2000-09-25 | 2002-09-27 | 525d | finish no earlier than 2002-09-27 | T3 | 4200h | 4200h | USAT1-API-MULTOS | Aspects Software | Neil Livingston | Rel-6 | Xavier |  |
| 2590 | 781.2.1.2 | Test specification for C SIM API |  | 195d | 2001-01-01 A | 2001-09-28 A | 100% | 2001-01-01 | 2001-09-28 | 195d | finish no earlier than 2001-09-28 | T3 | 1560h | 1560h | USAT1-API-MULTOS | Aspects Software | Neil Livingston | Rel-6 | Xavier |  |
| 2591 | 781.2.2 | USIM application toolkit Conformance Test Specification for Mobile Equipments |  | 326d? | 2003-12-05 A | 2005-03-04 A | 100% | 2003-12-05 | 2005-03-04 | 326d? | start no earlier than 2003-12-05 | T3 | 2608h | 2608h | USAT1-API-MULTOS | Gemplus | Eric.laffont@gemplus.com | Rel-6 | Xavier |  |
| 2592 | 782 | **Packet Switched Streaming Services Rel-6** |  | 798d? | 2002-11-18 A | 2005-12-07 A | 100% | 2002-11-18 | 2005-12-07 | 798d? |  | S4,S1 | 13304h | 13304h | PSSrel6 | Ericsson | olle.franceschi@ericsson.com | Rel-6 | Paolo |  |
| 2593 | 782.1 | Stage 1 for Packet Switched Streaming Services Rel-6 |  | 86d? | 2002-11-18 A | 2003-03-17 A | 100% | 2002-11-18 | 2003-03-17 | 86d? | finish no earlier than 2003-03-17 | S1 | 688h | 688h | PSSrel6 | Ericsson |  | Rel-6 | Alain |  |
| 2594 | 782.2 | Stage 3 for Packet Switched Streaming Services Rel-6 |  | 779d? | 2002-12-13 A | 2005-12-07 A | 100% | 2002-12-13 | 2005-12-07 | 779d? | finish no earlier than 2005-12-07 | S4 | 6232h | 6232h | PSSrel6-Stage3 | Ericsson | olle.franceschi@ericsson.com | Rel-6 | Paolo |  |
| 2595 | 783 | AMR-WB extension for high audio quality |  | 779d | 2002-12-13 A | 2005-12-07 A | 100% | 2002-12-13 | 2005-12-07 | 779d | finish no earlier than 2005-12-07 | S4 | 6232h | 6232h | AMRWB+ | Nokia | janne.m.vainio@nokia.com | Rel-6 | Paolo |  |
| 2596 | 784 | Codec Enhancements for Packet Switched Conversational Multimedia Applications |  | 198d? | 2004-03-16 A | 2004-12-16 A | 100% | 2004-03-16 | 2004-12-16 | 198d? | finish no earlier than 2004-12-16 | S4 | 1584h | 1584h | CEPSCM | Nokia | miska.hannuksela@nokia.com | Rel-6 | Paolo |  |
| 2597 | 785 | 3G-324M Improvements |  | 198d? | 2004-03-16 A | 2004-12-16 A | 100% | 2004-03-16 | 2004-12-16 | 198d? | finish no earlier than 2004-12-16 | S4 | 1584h | 1584h | 3G-324MI | Ericsson | bo.burman@ericsson.com | Rel-6 | Paolo |  |
| 2598 | 786 | Single Antenna Receiver Interference Cancellation (SAIC) |  | 420.92d? | 2002-11-15 A | 2004-06-25 A | 100% | 2002-11-15 | 2004-06-25 | 420.92d? | finish no earlier than 2004-08-27 | GP,G1 | 3367.36h | 3367.36h | SAIC | Cingular | Marc Grant | Rel-6 | Paolo |  |
| 2599 | 787 | **Enhancement of dialled service for CAMEL** |  | 199d | 2003-03-28 A | 2003-12-31 A | 100% | 2003-03-28 | 2003-12-31 | 199d |  | S1,N2,N4 | 3184h | 3184h | EDCAMEL | Samsung | craig.bishop@samsung.com | Rel-6 | Alain |  |
| 2600 | 787.1 | Stages 2 and 3 for Enhancement of dialled service for CAMEL |  | 199d | 2003-03-28 A | 2003-12-31 A | 100% | 2003-03-28 | 2003-12-31 | 199d | finish no earlier than 2003-09-19 | N2,N4 | 1592h | 1592h | EDCAMEL | Samsung | Richard Brook | Rel-6 | Kimmo |  |
| 2601 | 788 | Study on Bandwidth and resource savings in CS networks |  | 273d? | 2003-06-01 A | 2004-06-16 A | 100% | 2003-06-01 | 2004-06-16 | 273d? | finish no earlier than 2004-06-16 | S2 | 2184h | 2184h | BARS |  |  | Rel-6 | Maurice |  |
| 2602 | 789 | **Multiple TBF in A/Gb mode** |  | 736d? | 2002-04-05 A | 2005-01-28 A | 100% | 2002-04-05 | 2005-01-28 | 736d? |  | GP,G2 | 17600h | 17600h | MULTBF | Ericsson | gunnar.mildh@era.ericsson.se | Rel-6 | Paolo |  |
| 2603 | 789.1 | **Multiple TBF in A/Gb mode - Core** |  | 366d? | 2002-04-05 A | 2003-08-29 A | 100% | 2002-04-05 | 2003-08-29 | 366d? |  | GP,G2 | 11712h | 11712h | MULTBF-Agbmode | Ericsson | gunnar.mildh@era.ericsson.se | Rel-6 | Paolo |  |
| 2604 | 789.1.1 | Multiple TBF Concept paper |  | 366d? | 2002-04-05 A | 2003-08-29 A | 100% | 2002-04-05 | 2003-08-29 | 366d? | finish no earlier than 2003-08-29 | GP,G2 | 2928h | 2928h | MULTBF-Agbmode |  |  | Rel-6 | Paolo |  |
| 2605 | 789.1.2 | Multiple TBF Stage 2 (43.064) CRs |  | 366d? | 2002-04-05 A | 2003-08-29 A | 100% | 2002-04-05 | 2003-08-29 | 366d? | finish no earlier than 2003-08-29 | GP,G2 | 2928h | 2928h | MULTBF-Agbmode |  |  | Rel-6 | Paolo |  |
| 2606 | 789.1.3 | Multiple TBF Stage 3 (44.060) CRs |  | 366d? | 2002-04-05 A | 2003-08-29 A | 100% | 2002-04-05 | 2003-08-29 | 366d? | finish no earlier than 2003-08-29 | GP,G2 | 2928h | 2928h | MULTBF-Agbmode |  |  | Rel-6 | Paolo |  |
| 2607 | 789.2 | Deleted - Multiple TBF in A/Gb mode – MS testing | milestone | 0d? | 2005-01-28 A | 2005-01-28 A | 100% | 2005-01-28 | 2005-01-28 | 0d? | start no earlier than 2005-01-28 | G3new |  |  | MULTBF-Testing | Ericsson | gunnar.mildh@era.ericsson.se | Rel-6 | Paolo | GP-27 |
| 2608 | 790 | **Alignment between the test-regimes for GERAN capable MS** |  | 526d? | 2003-08-29 A | 2005-09-02 A | 100% | 2003-08-29 | 2005-09-02 | 526d? |  | G3new | 4208h | 4208h | ALTERE | Ericsson | anthony.toubassi@sonyericsson.com | Rel-6 | Ingbert |  |
| 2609 | 790.1 | Determine the controversial test cases in the different test regimes and align them with 3GPP GERAN test specifications. Such test cases to be added to TS 51.010. |  | 526d? | 2003-08-29 A | 2005-09-02 A | 100% | 2003-08-29 | 2005-09-02 | 526d? | finish no earlier than 2005-09-02 | G3new | 4208h | 4208h | ALTERE-TC |  |  | Rel-6 | Ingbert |  |
| 2610 | 791 | Addition of U-TDOA in the CS domain |  | 111d? | 2003-11-21 A | 2004-04-23 A | 100% | 2003-11-21 | 2004-04-23 | 111d? | finish no earlier than 2004-04-23 | GP | 888h | 888h | UTDOACS | TruePosition | Bob Gross, Rhys Robinson (rlgross@trueposition.com) | Rel-6 | Paolo |  |
| 2611 | 792 | Addition of U-TDOA in the PS domain |  | 361d? | 2003-06-27 A | 2004-11-12 A | 100% | 2003-06-27 | 2004-11-12 | 361d? | finish no earlier than 2004-11-12 | GP | 2888h | 2888h | UTDOAPS | TruePosition | Bob Gross, Rhys Robinson (rlgross@trueposition.com) | Rel-6 | Paolo |  |

Notes:
- 2587: -
- 2588: - / Text3: 31.101, 31.102, 31.103, 31.111, 31.113, new 31.115, 31.116
- 2589: -
- 2590: -
- 2591: - / Text3: 31.124
- 2592: -
- 2593: 2nd resp SA4 / Text3: 22.233
- 2594: TR tbc by Sept. 05 / Text3: 26.233, 26.234, 26.244, 26.245, 26.246, 26.401, 26.402, 26.403, 26.404, 26.405, 26.406, 26.410, 26.411, 26.412, 26.273, 26.290, 26.304, 26.412, 26.274, 26.936
- 2595: TR tbc by Sept. 05 / Text3: 26.290, 26.304, 26.273, 26.274, 26.412, 26.936
- 2596: - / Text3: 26.235, 26.236
- 2597: - / Text3: 26.111, 26.911
- 2598: - / Text3: 45.903
- 2599: - / Text3: 22.078
- 2600: - / Text3: 23.008, 23.016, 23.018, 23.078, 29.002, 29.078
- 2601: - / Text3: 23.977
- 2602: GP#17 Nov 2003 Moved from Rel-5 UID_50058 MULTBF (Only Multiple TBF Concept paper produced in Rel-5)
- 2603: -
- 2604: -
- 2605: -
- 2606: -
- 2607: -
- 2608: -
- 2609: -
- 2610: Completed, except for potential LMU performance specs
- 2611: -

| ID | WBS | Task | Type | Duration | Start | Finish | Complete | Baseline start | Baseline finish | Baseline duration | Constraint | Resources | Work | Actual work | Text1 | Text4 | Text5 | Text6 | Text8 | Text12 | Text3 | Text10 |
| --- | --- | --- | --- | --- | --- | --- | --- | --- | --- | --- | --- | --- | --- | --- | --- | --- | --- | --- | --- | --- | --- | --- |
| 2612 | 793 | **Downlink Advanced Receiver Performance** |  | 466d? | 2003-11-21 A | 2005-09-02 A | 100% | 2003-11-21 | 2005-09-02 | 466d? |  | GP | 19160h | 19160h | DARP | Nokia | tommy.bysted@nokia.com | Rel-6 | Paolo |  |  |  |
| 2613 | 793.1 | DARP test scenarios |  | 201d? | 2003-11-21 A | 2004-08-27 A | 100% | 2003-11-21 | 2004-08-27 | 201d? | finish no earlier than 2004-08-27 | GP | 1608h | 1608h | DARP-TS | Nokia | tommy.bysted@nokia.com | Rel-6 | Paolo |  |  |  |
| 2614 | 793.2 | **DARP for GMSK modulated voice services** |  | 201d? | 2004-02-06 A | 2004-11-12 A | 100% | 2004-02-06 | 2004-11-12 | 201d? |  | GP | 4824h | 4824h | DARP-GMSK | Nokia | tommy.bysted@nokia.com | Rel-6 | Paolo |  |  |  |
| 2615 | 793.2.1 | Performance requirements in 45.005 for DARP for GMSK modulated voice services |  | 201d? | 2004-02-06 A | 2004-11-12 A | 100% | 2004-02-06 | 2004-11-12 | 201d? | finish no earlier than 2004-11-12 | GP | 1608h | 1608h | DARP-GMSK-Perf |  |  | Rel-6 | Paolo |  |  |  |
| 2616 | 793.2.2 | Radio subsystem link control in 45.008 for DARP for GMSK modulated voice services |  | 201d? | 2004-02-06 A | 2004-11-12 A | 100% | 2004-02-06 | 2004-11-12 | 201d? | finish no earlier than 2004-11-12 | GP | 1608h | 1608h | DARP-GMSK-LC |  |  | Rel-6 | Paolo |  |  |  |
| 2617 | 793.3 | **DARP for GPRS and EGPRS MCS1-MCS4** |  | 201d? | 2004-02-06 A | 2004-11-12 A | 100% | 2004-02-06 | 2004-11-12 | 201d? |  | GP | 4824h | 4824h | DARP-GPRSE | Nokia | tommy.bysted@nokia.com | Rel-6 | Paolo |  |  |  |
| 2618 | 793.3.1 | Performance requirements in 45.005 for DARP for GPRS and EGPRS MCS1-MCS4 |  | 201d? | 2004-02-06 A | 2004-11-12 A | 100% | 2004-02-06 | 2004-11-12 | 201d? | finish no earlier than 2004-11-12 | GP | 1608h | 1608h | DARP-GPRSE-Perf |  |  | Rel-6 | Paolo |  |  |  |
| 2619 | 793.3.2 | Radio subsystem link control in 45.008 for DARP for GPRS and EGPRS MCS1-MCS4 |  | 201d? | 2004-02-06 A | 2004-11-12 A | 100% | 2004-02-06 | 2004-11-12 | 201d? | finish no earlier than 2004-11-12 | GP | 1608h | 1608h | DARP-GPRSE-LC |  |  | Rel-6 | Paolo |  |  |  |
| 2620 | 793.4 | DARP Capability signalling |  | 256d? | 2003-11-21 A | 2004-11-12 A | 100% | 2003-11-21 | 2004-11-12 | 256d? | finish no earlier than 2004-11-12 | GP | 2048h | 2048h | DARP-CAPSIG | Nokia | tommy.bysted@nokia.com | Rel-6 | Paolo |  |  |  |
| 2621 | 793.5 | GERAN MS Conformance test for DARP |  | 266d? | 2004-08-27 A | 2005-09-02 A | 100% | 2004-08-27 | 2005-09-02 | 266d? | finish no earlier than 2005-06-24 | G3new | 2128h | 2128h | ARP-ConfTest | Nokia | tommy.bysted@nokia.com | Rel-6 | Ingbert |  |  |  |
| 2622 | 794 | **Reduction of PS service interruption in Dual Transfer Mode** |  | 416d? | 2003-11-21 A | 2005-06-24 A | 100% | 2003-11-21 | 2005-06-24 | 416d? |  | G2 | 8360h | 8360h | PSintDTM | Siemens | toby.proctor@roke.co.uk | Rel-6 | Gert |  |  |  |
| 2623 | 794.1 | Use case and requirement definition |  | 111d? | 2003-11-21 A | 2004-04-23 A | 100% | 2003-11-21 | 2004-04-23 | 111d? | finish no earlier than 2004-04-23 | G2 | 888h | 888h | PSintDTM-Req | Siemens | toby.proctor@roke.co.uk | Rel-6 | Gert |  |  |  |
| 2624 | 794.2 | Performance Study of Current Procedures |  | 111d? | 2003-11-21 A | 2004-04-23 A | 100% | 2003-11-21 | 2004-04-23 | 111d? | start no earlier than 2003-11-21 | G2 | 888h | 888h | PSintDTM-Perf | Siemens | toby.proctor@roke.co.uk | Rel-6 | Gert |  |  |  |
| 2625 | 794.3 | Reduction of service interruption times and packet loss during Dual Transfer Mode and mobility procedures |  | 146d? | 2004-04-23 A | 2004-11-12 A | 100% | 2004-04-23 | 2004-11-12 | 146d? | finish no earlier than 2004-11-12 | G2 | 1168h | 1168h | PSintDTM-Reduct | Siemens | toby.proctor@roke.co.uk | Rel-6 | Gert |  |  |  |
| 2626 | 794.4 | Deleted - MS Conformance testing - Reduction of PS service interruption in DTM |  | 261d? | 2004-06-25 A | 2005-06-24 A | 100% | 2004-06-25 | 2005-06-24 | 261d? | finish no earlier than 2005-06-24 | G3new | 2088h | 2088h | PSintDTM-ConfMS |  |  | Rel-6 | Ingbert | GP-25 |  |  |
| 2627 | 794.5 | Deleted - BTS Conformance testing - Reduction of PS service interruption in DTM | milestone | 0d? | 2005-06-24 A | 2005-06-24 A | 100% | 2005-06-24 | 2005-06-24 | 0d? | finish no earlier than 2005-06-24 | G3new |  |  | PSintDTM-ConfBTS |  |  | Rel-6 | Ingbert | GP-25 |  |  |
| 2628 | 795 | CAMEL prepay interworking with SCUDIF |  | 216.3d | 2003-12-08 A | 2004-10-05 A | 100% | 2003-12-08 | 2004-10-05 | 216.3d |  | N4,N3,S1 | 1730.4h | 1730.4h | SCCAMEL | Nokia | Keijo.Palviainen@Nokia.Com | Rel-6 | Kimmo |  | 22.078, 23.078, 29.078, 29.002, 23.172 |  |
| 2629 | 796 | **Circuit Switched Video and Voice Service Improvements** |  | 430d? | 2004-01-12 A | 2005-09-02 A | 100% | 2004-01-12 | 2005-09-02 | 430d? |  | S2,N1 | 9256h | 9256h | CS_VSS | Vodafone | John Watson | Rel-6 | Alain |  |  |  |
| 2630 | 796.1 | Deleted - Stage 1 - Requirements |  | 199d | 2004-01-12 A | 2004-10-14 A | 100% | 2004-01-12 | 2004-10-14 | 199d | finish no earlier than 2004-10-14 | S1 | 1592h | 1592h | CS_VSS | Vodafone | John Watson | Rel-6 | Alain | SP-26 | 22.101 |  |
| 2631 | 796.2 | Stage 2 Study on architecture alternatives |  | 244d? | 2004-01-12 A | 2004-12-16 A | 100% | 2004-01-12 | 2004-12-16 | 244d? | finish no earlier than 2004-08-13 | S2 | 1952h | 1952h | CS_VSS | Vodafone | Chris Pudney | Rel-6 | Maurice |  | 23.903 | SP-24 |
| 2632 | 796.3 | Deleted - Stage 2 description on Redial |  | 164d? | 2004-05-03 A | 2004-12-16 A | 100% | 2004-05-03 | 2004-12-16 | 164d? | finish no earlier than 2004-12-16 | S2 | 1312h | 1312h | CS_VSS | Vodafone | Chris Pudney | Rel-6 | Maurice | SP-26 |  | SP-24 |
| 2633 | 796.4 | Switching between voice and video call - Redial solution |  | 120d? | 2005-01-03 A | 2005-06-17 A | 100% | 2005-01-03 | 2005-06-17 | 120d? | start no earlier than 2005-01-03 | N1 | 960h | 960h | CS_VSS | Vodafone |  | Rel-6 | Frederic |  | 23.009, 24.008 |  |
| 2634 | 796.5 | Deleted - CS_VSS - GERAN2 Part | milestone | 0d | 2005-09-02 A | 2005-09-02 A | 100% | 2005-09-02 | 2005-09-02 | 0d | start no earlier than 2005-09-02 | G2 |  |  | CS_VSS | Vodafone |  | Rel-6 | Gert | GP-26 |  |  |
| 2635 | 796.6 | Deleted - CS_VSS - CN3 Part | milestone | 0d? | 2004-10-14 A | 2004-10-14 A | 100% | 2004-10-14 | 2004-10-14 | 0d? | start no earlier than 2004-10-14 | N3 |  |  | CS_VSS | Vodafone |  | Rel-6 | Gwiho | TP-26 |  |  |
| 2636 | 797 | Reorganisation of CS Data Specifications |  | 14d? | 2004-11-19 A | 2004-12-08 A | 100% | 2004-11-19 | 2004-12-08 | 14d? | finish no earlier than 2004-12-24 | N3 | 112h | 112h | CS Data | Siemens | Thomas.Belling@nsn.com | Rel-6 | Gwiho |  | 23.910, 29.007, new 23.202 |  |

Notes:
- 2612: -
- 2613: -
- 2614: -
- 2615: -
- 2616: -
- 2617: -
- 2618: -
- 2619: -
- 2620: -
- 2621: -
- 2622: -
- 2623: -
- 2624: -
- 2625: -
- 2626: -
- 2627: -
- 2628: -
- 2629: -
- 2630: -
- 2631: -
- 2632: -
- 2633: -
- 2634: -
- 2635: -
- 2636: Created at TSG#27 as 100 % complete

| ID | WBS | Task | Type | Duration | Start | Finish | Complete | Baseline start | Baseline finish | Baseline duration | Constraint | Resources | Work | Actual work | Text1 | Text4 | Text6 | Text8 | Text3 | Text5 | Text12 |
| --- | --- | --- | --- | --- | --- | --- | --- | --- | --- | --- | --- | --- | --- | --- | --- | --- | --- | --- | --- | --- | --- |
| 2637 | 798 | **Generic Access to A/Gb Interface (GAAI)** |  | 411d? | 2004-06-25 A | 2006-01-20 A | 100% | 2004-06-25 | 2006-01-20 | 411d? |  | GP | 9160h | 9160h | GAAI | Motorola | Rel-6 | Paolo |  |  |  |
| 2638 | 798.1 | FS on GAAI |  | 46d? | 2004-06-25 A | 2004-08-27 A | 100% | 2004-06-25 | 2004-08-27 | 46d? | finish no earlier than 2004-08-27 | GP | 368h | 368h | GAAG | Motorola | Rel-6 | Paolo | 43.901 |  |  |
| 2639 | 798.2 | GAAI – Stage 2 |  | 161d? | 2004-08-27 A | 2005-04-08 A | 100% | 2004-08-27 | 2005-04-08 | 161d? | finish no earlier than 2005-04-08 | GP | 1288h | 1288h | GAAI-Stage2 | Ericsson | Rel-6 | Paolo | 43.318 | jari.vikberg@ericsson.com |  |
| 2640 | 798.3 | GAAI – Stage 3 |  | 161d? | 2004-08-27 A | 2005-04-08 A | 100% | 2004-08-27 | 2005-04-08 | 161d? | finish no earlier than 2005-04-08 | GP | 1288h | 1288h | GAAI-Stage3 |  | Rel-6 | Paolo | 44.318 |  |  |
| 2641 | 798.4 | MS Conformance Test for GAAI |  | 366d? | 2004-08-27 A | 2006-01-20 A | 100% | 2004-08-27 | 2006-01-20 | 366d? | finish no earlier than 2006-01-20 | GP | 2928h | 2928h | GAAI-CT |  | Rel-6 | Ingbert |  |  |  |
| 2642 | 799 | **Support of PS Handover for GERAN A/Gb mode** |  | 473d? | 2003-11-03 A | 2005-08-24 A | 100% | 2003-11-03 | 2005-08-24 | 473d? |  | GP,G2 | 11352h | 11352h | SPSHAGB | Ericsson | Rel-6 | Paolo |  | gunnar.hedby@ericsson.com |  |
| 2643 | 799.1 | Stage 2 for Support of PS Handover for GERAN A/Gb mode |  | 473d? | 2003-11-03 A | 2005-08-24 A | 100% | 2003-11-03 | 2005-08-24 | 473d? | finish no earlier than 2005-09-02 | GP,G2 | 3784h | 3784h | SPSHAGB-Stage2 | Ericsson | Rel-6 | Paolo | 43.129 | gunnar.hedby@ericsson.com |  |
| 2644 | 799.2 | PS handover for Support of PS Handover for GERAN A/Gb mode |  | 473d? | 2003-11-03 A | 2005-08-24 A | 100% | 2003-11-03 | 2005-08-24 | 473d? | finish no earlier than 2005-09-02 | GP,G2 | 3784h | 3784h | SPSHAGB-PSHO | Ericsson | Rel-6 | Paolo |  | gunnar.hedby@ericsson.com |  |
| 2645 | 799.3 | Definition of radio resource management functionality for Support of PS Handover for GERAN A/Gb mode |  | 473d? | 2003-11-03 A | 2005-08-24 A | 100% | 2003-11-03 | 2005-08-24 | 473d? | finish no earlier than 2005-09-02 | GP,G2 | 3784h | 3784h | SPSHAGB-RRM | Ericsson | Rel-6 | Paolo |  | gunnar.hedby@ericsson.com |  |
| 2646 | 800 | Study on (U)SIM Security Reuse by Peripheral Devices on Local Interfaces |  | 127d? | 2003-07-03 A | 2003-12-26 A | 100% | 2003-07-03 | 2003-12-26 | 127d? | finish no earlier than 2003-12-26 | S3 | 1016h | 1016h |  | Toshiba | Rel-6 | Dionisio | 33.817 | Raziq Yaqub (ryaqub@tari.toshiba.com) |  |
| 2647 | 801 | Study on Security for early IMS |  | 127d? | 2004-10-01 A | 2005-03-28 A | 100% | 2004-10-01 | 2005-03-28 | 127d? | finish no earlier than 2003-12-26 | S3 | 1016h | 1016h | SEC-IMS | Vodafone | Rel-6 | Dionisio | 33.978 | Peter.Howard@vodafone.com |  |
| 2648 | 802 | (Small) Technical Enhancements and Improvements for Rel-6 | milestone | 0d? | 2006-06-02 A | 2006-06-02 A | 100% | 2006-06-02 | 2006-06-02 | 0d? |  | All |  |  | TEI6 |  | Rel-6 | all |  |  |  |
| 2649 | 803 | Test - (Small) Technical Enhancements and Improvements for Rel-6 |  | 503d? | 2006-06-02 A | 2008-05-06 A | 100% | 2006-06-02 | 2008-05-06 | 503d? | start no earlier than 2006-06-02 | R5,T1 | 4024h | 4024h | TEI6_Test |  | Rel-6 | Ingbert | 34.108,34.121-1/2,34.122,34.123-1/2/3 |  |  |
| 2650 | 804 | Deleted - Study of Feature Interactions Requirements | milestone | 0d? | 2004-09-16 A | 2004-09-16 A | 100% | 2004-09-16 | 2004-09-16 | 0d? | finish no earlier than 2004-10-01 | S1 |  |  | FINTER |  | Rel-6 | Alain |  |  | SP-25 |
| 2651 | 805 | Deleted - Enhancements of VGCS in public networks for communication of public authority officials |  | 7d? | 2005-08-24 A | 2005-09-02 A | 100% | 2005-08-24 | 2005-09-02 | 7d? | start no earlier than 2005-08-24 | GP,G2 | 56h | 56h | EVGCS | Siemens | Rel-6 | Paolo | 44.018, 44.068, 48.008 | kenneth.isaacs@roke.co.uk | GP-26 |
| 2652 | 806 | **Deleted - Support of Conversational Services in A/Gb mode via the PS domain** |  | 64d? | 2003-11-21 A | 2004-02-19 A | 100% | 2003-11-21 | 2004-02-19 | 64d? |  | GP,N1 | 1024h | 1024h | SCSAGB | Ericsson | Rel-6 | Paolo |  | David Bladsjö (david.bladsjo@ericsson.com) | GP-18 |
| 2653 | 806.1 | Deleted - Creation of a TR | milestone | 0d? | 2003-11-21 A | 2003-11-21 A | 100% | 2003-11-21 | 2003-11-21 | 0d? | start no earlier than 2003-11-21 | GP |  |  | SCSAGB-TR | Ericsson | Rel-6 | Paolo |  | David Bladsjö (david.bladsjo@ericsson.com) | GP-17 |
| 2654 | 806.2 | Deleted - Stage 2 | milestone | 0d? | 2003-11-21 A | 2003-11-21 A | 100% | 2003-11-21 | 2003-11-21 | 0d? | finish no earlier than 2003-11-21 | GP |  |  | SCSAGB-Stage2 | Ericsson | Rel-6 | Paolo |  | David Bladsjö (david.bladsjo@ericsson.com) | GP-17 |
| 2655 | 806.3 | Deleted - Radio Channel Support | milestone | 0d? | 2003-11-21 A | 2003-11-21 A | 100% | 2003-11-21 | 2003-11-21 | 0d? | finish no earlier than 2003-11-21 | GP |  |  | SCSAGB-RCS | Ericsson | Rel-6 | Paolo |  | David Bladsjö (david.bladsjo@ericsson.com) | GP-17 |
| 2656 | 806.4 | Deleted - Definition of radio resource management functionality | milestone | 0d? | 2003-11-21 A | 2003-11-21 A | 100% | 2003-11-21 | 2003-11-21 | 0d? | finish no earlier than 2003-11-21 | GP |  |  | SCSAGB-RRM | Ericsson | Rel-6 | Paolo |  | David Bladsjö (david.bladsjo@ericsson.com) | GP-17 |
| 2657 | 806.5 | Deleted - replaced by 50561 - PS Handover |  | 64d | 2003-11-21 A | 2004-02-19 A | 100% | 2003-11-21 | 2004-02-19 | 64d | start no earlier than 2003-11-21 | GP,N1 | 512h | 512h | SCSAGB-PSH | Ericsson | Rel-6 | Paolo |  | David Bladsjö (david.bladsjo@ericsson.com) | GP-18 |
| 2658 | 806.6 | Deleted - Modifications to FLO | milestone | 0d? | 2003-11-21 A | 2003-11-21 A | 100% | 2003-11-21 | 2003-11-21 | 0d? | finish no earlier than 2003-11-21 | GP |  |  | SCSAGB-FLO | Ericsson | Rel-6 | Paolo |  | David Bladsjö (david.bladsjo@ericsson.com) | RP-29 |
| 2659 | 807 | Deleted - Rel-6 Evolutions of the transport in the UTRAN | milestone | 0d | 2003-12-31 A | 2003-12-31 A | 100% | 2003-12-31 | 2003-12-31 | 0d | start no earlier than 2003-12-31 | RP |  |  | ETRAN | Alcatel | Rel-6 | Issam |  | Francois Courau | RP-22 |
| 2660 | 808 | Release 5 Features |  | 325d? | 2001-03-30 A | 2002-06-28 A | 100% | 2001-03-30 | 2002-06-28 | 325d? |  | NP,GP, RP,SP,TP | 2600h | 2600h |  |  | Rel-5 | All |  |  |  |
| 2661 | 75 | IP transport in the UTRAN |  | 445d | 2000-07-17 A | 2002-03-29 A | 100% | 2000-07-17 | 2002-03-29 | 445d | finish no earlier than 2002-03-29 | R3 | 3560h | 3560h | ETRAN-IPtrans | Alcatel | Rel-5 | Juha |  | Nicolas Drevon |  |
| 2662 | 76 | FS on Usage of SUA |  | 205d | 2001-03-12 A | 2001-12-21 A | 100% | 2001-03-12 | 2001-12-21 | 205d | finish no earlier than 2001-12-21 | N4 | 1640h | 1640h | SS7IP |  | Rel-5 | Kimmo |  |  |  |

Notes:
- 2637: -
- 2638: Feasibility Study
- 2639: -
- 2640: -
- 2641: Marked as closed 12/2008 (was marked 90% complete)
- 2642: Replaces SCSAGB- Originally Started Nov 2003 as GP-030443
- 2643: Replaces SCSAGB-Stage2
- 2644: Replaces SCSAGB-PSH
- 2645: Replaces SCSAGB-RRM
- 2646: SP#20 approved WID
- 2647: SP#24 approved WID. SP#46 withdrawn TR 33.978 from Rel-8 onwards
- 2648: "Joker" WI, to be used for a Rel 6 CR not related to any feature and with very limited impact on the system. Moved in from Stoyan/Testing WP
- 2649: "Joker" WI, to be used for small modifications applicable to Rel 4 conformance testing
- 2650: SP#25 stopped
- 2651: GP#26 moved to Rel-7 as UID_11045 Enhancements of VGCS in public networks for communication of public authority officials
- 2652: -
- 2653: -
- 2654: Started
- 2655: Not started
- 2656: Not started
- 2657: Started
- 2658: Not started
- 2659: Generic feature
- 2660: -
- 2661: -
- 2662: -

| ID | WBS | Task | Duration | Start | Finish | Complete | Baseline start | Baseline finish | Baseline duration | Constraint | Deadline | Resources | Work | Actual work | Text1 | Text4 | Text5 | Text6 | Text8 | Text3 | Text7 | Text10 | Text12 |
| --- | --- | --- | --- | --- | --- | --- | --- | --- | --- | --- | --- | --- | --- | --- | --- | --- | --- | --- | --- | --- | --- | --- | --- |
| 2663 | 77 | **High Speed Downlink Packet Access** | 1550d? | 2001-04-02 A | 2007-03-09 A | 100% | 2001-04-02 | 2007-03-09 | 1550d? |  |  | R2,R5 | 31488h | 31488h | HSDPA | Motorola | Ravi Kuchibhotla | Rel-5 | Joern |  |  |  |  |
| 2664 | 77.1 | Physical Layer for High Speed Downlink Packet Access | 257d | 2001-04-05 A | 2002-03-29 A | 100% | 2001-04-05 | 2002-03-29 | 257d | finish no earlier than 2002-03-29 |  | R1 | 2056h | 2056h | HSDPA-Phys | Motorola | Amitabha Ghosh (qa0047@email.mot.com) | Rel-5 | Patrick |  |  |  |  |
| 2665 | 77.2 | Layer 2 and 3 aspects | 257d | 2001-04-05 A | 2002-03-29 A | 100% | 2001-04-05 | 2002-03-29 | 257d | finish no earlier than 2002-03-29 |  | R2 | 2056h | 2056h | HSDPA-L23 | Motorola | Ravi Kuchibhotla | Rel-5 | Joern |  |  |  |  |
| 2666 | 77.3 | Iub/Iur protocol aspects - for High Speed Downlink Packet Access | 260d | 2001-04-02 A | 2002-03-29 A | 100% | 2001-04-02 | 2002-03-29 | 260d | finish no earlier than 2002-03-29 |  | R3 | 2080h | 2080h | HSDPA-IubIur | Motorola | Mike Diesen | Rel-5 | Juha |  |  |  |  |
| 2667 | 77.4 | RF Radio Transmission/ Reception, System Performance Requirements and Conformance Testing | 565d | 2001-04-09 A | 2003-06-06 A | 100% | 2001-04-09 | 2003-06-06 | 565d | finish no earlier than 2003-06-06 |  | R4 | 4520h | 4520h | HSDPA-RF | Motorola | Howard Benn | Rel-5 | Issam |  |  |  |  |
| 2668 | 811.5 | Conformance Testing of HSDPA | 786d | 2003-09-19 A | 2006-09-22 A | 100% | 2003-09-19 | 2006-09-22 | 786d | finish no earlier than 2006-09-22 |  | R5 | 6288h | 6288h | HSDPA_Test | Motorola | carolyn.taylor@motorola.com | Rel-5 | Ingbert | 34.108, 34.121, 34.122, 34.123-1, 34.123-2, 34.123-3 | TSG | 19/9/2003 |  |
| 2669 | 811.6 | Conformance Testing of HCR TDD HSDPA | 261d? | 2006-03-10 A | 2007-03-09 A | 100% | 2006-03-10 | 2007-03-09 | 261d? | finish no earlier than 2007-03-09 |  | R5 | 2088h | 2088h | HSDPA_HCRTDD_Test | IPWireless | drichards@ipwireless.com | Rel-5 | Ingbert | 34.108, 34.122, 34.123-1, 34.123-2, 34.123-3 |  |  |  |
| 2670 | 78 | **Rel-5 Improvements of Radio Interface** | 535d | 2000-08-14 A | 2002-08-30 A | 100% | 2000-08-14 | 2002-08-30 | 535d |  |  | RP | 30376h | 30376h | RInImp |  |  | Rel-5 |  |  |  |  |  |
| 2671 | 78.1 | **Base station classification for TDD** | 480d | 2000-08-14 A | 2002-06-14 A | 100% | 2000-08-14 | 2002-06-14 | 480d |  |  | R4 | 9208h | 9208h | RInImp-BSClass | Nokia | antti.toskala@nokia.com | Rel-5 | Issam |  |  |  |  |
| 2672 | 78.1.1 | TDD Base station classification | 410d | 2000-08-14 A | 2002-03-08 A | 100% | 2000-08-14 | 2002-03-08 | 410d | finish no earlier than 2002-03-08 |  | R4 | 3280h | 3280h | RInImp-BSClass-TDD | Nokia | antti.toskala@nokia.com | Rel-5 | Issam |  |  |  |  |
| 2673 | 78.1.2 | Base Station Classification for 1.28 Mcps TDD option | 261d | 2001-06-15 A | 2002-06-14 A | 100% | 2001-06-15 | 2002-06-14 | 261d | finish no earlier than 2002-06-14 |  | R4 | 2088h | 2088h | RInImp-BSClass-LCRTDD | Siemens | Meik.Kottkamp@siemens.com | Rel-5 | Issam |  |  |  |  |
| 2674 | 78.2 | Enhancement on the DSCH hard split mode | 271d | 2001-03-16 A | 2002-03-29 A | 100% | 2001-03-16 | 2002-03-29 | 271d | finish no earlier than 2002-03-29 |  | R1 | 2168h | 2168h | RInImp-DSCHhsp | Samsung | Jaeyoel KIM | Rel-5 | Patrick |  |  |  |  |
| 2675 | 78.3 | Hybrid ARQ II/III | 355d | 2000-08-21 A | 2001-12-28 A | 100% | 2000-08-21 | 2001-12-28 | 355d | finish no earlier than 2001-12-28 |  | R2 | 2840h | 2840h | RInImp-HARQ | Siemens | armin.sitte@siemens.com | Rel-5 | Joern |  |  |  | RP-14 |
| 2676 | 78.4 | FS on USTS | 355d | 2000-08-14 A | 2001-12-21 A | 100% | 2000-08-14 | 2001-12-21 | 355d | finish no earlier than 2001-12-21 |  | R1 | 2840h | 2840h | RInImp-USTS | SK Telecom | D. Kim | Rel-5 | Patrick |  |  |  |  |
| 2677 | 78.5 | FS on UE antenna efficiency test method performance requirements | 255d | 2000-09-25 A | 2001-09-14 A | 100% | 2000-09-25 | 2001-09-14 | 255d | finish no earlier than 2001-09-14 |  | R4 | 2040h | 2040h | RInImp-UEAnTM | Allgon | O. Edvardsson | Rel-5 | Issam |  |  |  |  |
| 2678 | 78.6 | FS on the re-introduction of the downlink SIR measurement | 200d | 2001-03-12 A | 2001-12-14 A | 100% | 2001-03-12 | 2001-12-14 | 200d | finish no earlier than 2001-12-14 |  | R4 | 1600h | 1600h | RInImp-SIR | Ericsson | Torgny.Palenius@ericsson.com | Rel-5 | Issam |  |  |  |  |
| 2679 | 78.7 | FS on mitigating the effect of CPICH interference at the UE | 255d | 2001-03-19 A | 2002-03-08 A | 100% | 2001-03-19 | 2002-03-08 | 255d | finish no earlier than 2002-03-08 |  | R4 | 2040h | 2040h | RInImp-CPICH_Intf | Intel | shimon.moshavi@INTEL.COM | Rel-5 | Issam |  |  |  |  |
| 2680 | 78.8 | **Deleted - Conformance Test Spec. improvements in Radio Interface** | 140d | 2002-02-18 A | 2002-08-30 A | 100% | 2002-02-18 | 2002-08-30 | 140d |  |  | T1 | 3360h | 3360h |  |  |  | Rel-5 | Ingbert |  |  |  | TP-17 |
| 2681 | 78.8.1 | Deleted - Testing improvement of inter-frequency and inter-system measurement | 140d | 2002-02-18 A | 2002-08-30 A | 100% | 2002-02-18 | 2002-08-30 | 140d | finish no earlier than 2002-08-30 |  | T1 | 1120h | 1120h |  |  |  | Rel-5 | Ingbert |  |  |  | TP-17 |
| 2682 | 78.8.2 | Deleted - Testing Hybrid ARQ II/III | 140d | 2002-02-18 A | 2002-08-30 A | 100% | 2002-02-18 | 2002-08-30 | 140d | finish no earlier than 2002-08-30 |  | T1 | 1120h | 1120h |  |  |  | Rel-5 | Ingbert |  |  |  | TP-17 |
| 2683 | 79 | **Rel-5 RAN improvements** | 1561d? | 2001-03-16 A | 2007-03-09 A | 100% | 2001-03-16 | 2007-03-09 | 1561d? |  |  | RP | 49424h | 49424h | RANimp |  |  | Rel-5 |  |  |  |  |  |
| 2684 | 79.1 | **RRM optimization for Iur and Iub** | 318d | 2001-03-16 A | 2002-06-04 A | 100% | 2001-03-16 | 2002-06-04 | 318d |  |  | R3 | 8904h | 8904h | RANimp-RRMopt | Ericsson | Gert-Jan.van.Lieshout@eln.ericsson.se | Rel-5 | Juha |  |  |  |  |
| 2685 | 79.1.1 | Iur common transport channel efficiency optimization | 271d | 2001-03-16 A | 2002-03-29 A | 100% | 2001-03-16 | 2002-03-29 | 271d | finish no earlier than 2002-03-29 |  | R3 | 2168h | 2168h | RANimp-RRMopt-ctc | Ericsson | Shahrokh Amirijoo | Rel-5 | Juha |  |  |  |  |
| 2686 | 79.1.2 | Iur neighbouring cell reporting efficiency optimization | 271d | 2001-03-16 A | 2002-03-29 A | 100% | 2001-03-16 | 2002-03-29 | 271d | finish no earlier than 2002-03-29 |  | R3 | 2168h | 2168h | RANimp-RRMopt-ncr | Ericsson | Shahrokh Amirijoo | Rel-5 | Juha |  |  |  |  |
| 2687 | 79.1.3 | FS Introduction of direct transport bearers between SRNC and Node-B | 253d | 2001-06-15 A | 2002-06-04 A | 100% | 2001-06-15 | 2002-06-04 | 253d | finish no earlier than 2002-06-28 |  | R3 | 2024h | 2024h | RAN-imp-RRMopt-DTB | Ericsson | Risto Sepponen | Rel-5 | Juha |  |  |  |  |
| 2688 | 79.2 | RL Timing Adjustment | 271d | 2001-03-16 A | 2002-03-29 A | 100% | 2001-03-16 | 2002-03-29 | 271d | finish no earlier than 2002-03-29 |  | R3 | 2168h | 2168h | RANimp-RLTA | Ericsson | Elena Voltolina | Rel-5 | Juha |  |  |  |  |
| 2689 | 79.3 | Separation of resource reservation and radio link activation | 271d | 2001-03-16 A | 2002-03-29 A | 100% | 2001-03-16 | 2002-03-29 | 271d | finish no earlier than 2002-03-29 |  | R3 | 2168h | 2168h | RANimp-SepRR | Ericsson | Gert-Jan.van.Lieshout@eln.ericsson.se | Rel-5 | Juha |  |  |  |  |
| 2690 | 79.4 | FS SRNS Relocation Procedure Enhancement | 318d | 2001-06-15 A | 2002-09-03 A | 100% | 2001-06-15 | 2002-09-03 | 318d | finish no earlier than 2002-09-06 |  | R3 | 2544h | 2544h | RANimp-SRNS | Nokia | Olivier Guyot | Rel-5 | Juha |  |  |  |  |
| 2691 | 79.5 | FS Improvement of Radio Resource Management across RNS and RNS/PSS | 201d | 2001-03-16 A | 2001-12-21 A | 100% | 2001-03-16 | 2001-12-21 | 201d | finish no earlier than 2001-12-21 |  | R3 | 1608h | 1608h | RANimp-ImpRRM | Nokia | antti.toskala@nokia.com | Rel-5 | Juha |  |  |  |  |
| 2692 | 79.6 | Re-arrangements of Iub transport bearers | 271d | 2001-03-16 A | 2002-03-29 A | 100% | 2001-03-16 | 2002-03-29 | 271d | finish no earlier than 2002-03-29 |  | R3 | 2168h | 2168h | RANimp-TTPS | Nokia | antti.toskala@nokia.com | Rel-5 | Juha |  |  |  |  |
| 2693 | 79.7 | RAB support enhancement for Rel-5 | 325d | 2001-04-02 A | 2002-06-28 A | 100% | 2001-04-02 | 2002-06-28 | 325d |  |  | R2 | 2600h | 2600h | RANimp-RABSE5 | Nokia | Juha Mikola | Rel-5 | Joern |  |  |  |  |
| 2694 | 16.5.1 | Testing of ROHC performance | 391d | 2005-09-09 A | 2007-03-09 A | 100% | 2005-09-09 | 2007-03-09 | 391d | finish no earlier than 2007-03-09 | 2006-06-02 | R5 | 3128h | 3128h | RANimp-RABSE5_Test | Nokia | jarkko.hellsten@nokia.com | Rel-5 | Ingbert | 34.108, 34.123-1, 34.123-2, 34.123-3 |  | Fri 11/03/05 |  |
| 2695 | 79.8 | Beamforming requirements for UE | 61d | 2001-09-21 A | 2001-12-14 A | 100% | 2001-09-21 | 2001-12-14 | 61d | finish no earlier than 2001-12-14 |  | R1 | 488h | 488h | RANimp-BFR-UE | Nokia | Jussi Kähtävä (juha.mikola@nokia.com) | Rel-5 | Patrick |  |  |  |  |
| 2696 | 79.9 | Support of Site Selection Diversity Transmission in UTRAN | 123d | 2001-12-14 A | 2002-06-04 A | 100% | 2001-12-14 | 2002-06-04 | 123d | finish no earlier than 2002-06-04 |  | R1 | 984h | 984h | RANimp-SSDT | NEC |  | Rel-5 | Patrick |  |  |  |  |
| 2697 | 79.10 | Node B Synchronisation for 1.28 Mcps TDD | 271d | 2001-03-16 A | 2002-03-29 A | 100% | 2001-03-16 | 2002-03-29 | 271d | finish no earlier than 2002-03-29 |  | R1 | 2168h | 2168h | RANimp-NBSLCR | CATT | Jinling HU | Rel-5 | Patrick |  |  |  |  |

Notes:
- 2663: -
- 2664: -
- 2665: -
- 2666: -
- 2667: -
- 2668: -
- 2669: -
- 2670: -
- 2671: -
- 2672: -
- 2673: -
- 2674: -
- 2675: Stopped at RP#14; work on this task was performed as part of High Speed Downlink Packet Access feature
- 2676: -
- 2677: -
- 2678: -
- 2679: -
- 2680: Marked as stopped 12/2008
- 2681: Marked as stopped 12/2008
- 2682: Marked as stopped 12/2008
- 2683: -
- 2684: -
- 2685: -
- 2686: -
- 2687: FS was closed and introduction of WI not agreed at RAN #16
- 2688: -
- 2689: -
- 2690: -
- 2691: FS was closed and WI was introduced at RAN #14
- 2692: -
- 2693: RFC 3095 context relocation
- 2694: -
- 2695: -
- 2696: RP-020356
- 2697: -

| ID | WBS | Task | Duration | Start | Finish | Complete | Baseline start | Baseline finish | Baseline duration | Constraint | Deadline | Resources | Work | Actual work | Text3 | Text6 | Text8 | Text12 | Text1 | Text4 | Text5 | Text10 |
| --- | --- | --- | --- | --- | --- | --- | --- | --- | --- | --- | --- | --- | --- | --- | --- | --- | --- | --- | --- | --- | --- | --- |
| 2698 | 79.12 | **Deleted - Conformance Test Aspects - RAN Improvements** | 565d? | 2002-01-01 A | 2004-03-01 A | 100% | 2002-01-01 | 2004-03-01 | 565d? |  |  | T1 | 8008h | 8008h | 0% | Rel-5 | Ingbert | TP-23 |  |  |  |  |
| 2699 | 79.12.1 | Deleted - Testing Radio access bearer support enhancements | 175d | 2002-01-01 A | 2002-09-02 A | 100% | 2002-01-01 | 2002-09-02 | 175d | finish no earlier than 2002-09-02 |  | T1 | 1400h | 1400h |  | Rel-5 | Ingbert | TP-17 |  |  |  |  |
| 2700 | 813.12.2 | Deleted - General changes to TS34.121 and TS34.122 corresponding to release 5 | 261d? | 2003-03-03 A | 2004-03-01 A | 100% | 2003-03-03 | 2004-03-01 | 261d? | finish no earlier than 2004-03-01 |  | T1 | 2088h | 2088h | 34.108, 34.121, 34.122 | Rel-5 | Ingbert | TP-23 | RANimp-test |  |  |  |
| 2701 | 80 | UTRAN Sharing in Connected Mode | 197d | 2001-12-03 A | 2002-09-03 A | 100% | 2001-12-03 | 2002-09-03 | 197d | finish no earlier than 2002-09-06 |  | R3 | 1576h | 1576h |  | Rel-5 | Juha |  | NETSHARE | Ericsson | Martin Israelsson |  |
| 2702 | 81 | **Provisioning of IP-based multimedia services** | 1806d | 2000-01-03 A | 2006-12-01 A | 100% | 2000-01-03 | 2006-12-01 | 1806d |  |  | S1,S2,S3,S5,NP,T3,T1,R5 | 205676h | 205676h |  | Rel-5 | Alain |  | IMS | Openwave | Mark Cataldo |  |
| 2703 | 81.1 | **Call control and roaming to support IMS in UMTS** | 1806d | 2000-01-03 A | 2006-12-01 A | 100% | 2000-01-03 | 2006-12-01 | 1806d |  |  | S2,R5 | 95312h | 95312h |  | Rel-5 | Maurice |  | IMS-CCR | Lucent | Liz Daniel |  |
| 2704 | 81.1.1 | Stage 1 for Call control and roaming to support IMS in UMTS | 215d | 2000-02-21 A | 2000-12-15 A | 100% | 2000-02-21 | 2000-12-15 | 215d | finish no earlier than 2000-09-21 |  | S1 | 1720h | 1720h | 22.228 | Rel-5 | Alain |  | IMS-CCR | Motorola | Mark Cataldo |  |
| 2705 | 81.1.2 | Stage 2 (Architecture and Main flows) | 246d | 2000-04-14 A | 2001-03-23 A | 100% | 2000-04-14 | 2001-03-23 | 246d | finish no earlier than 2001-03-23 |  | S2 | 1968h | 1968h | 23.228 | Rel-5 | Maurice |  | IMS-CCR | Lucent | Liz Daniel |  |
| 2706 | 81.1.3 | Impact on MM/CC/SM | 400d | 2000-08-28 A | 2002-03-08 A | 100% | 2000-08-28 | 2002-03-08 | 400d | finish no earlier than 2002-03-08 |  | N1 | 3200h | 3200h |  | Rel-5 | Frederic |  | IMS-CCR-IWMM | Lucent | Keith Drage (drage@alcatel-lucent.com) |  |
| 2707 | 81.1.4 | **SIP Call Control protocol for the IMS** | 385d | 2000-10-02 A | 2002-03-22 A | 100% | 2000-10-02 | 2002-03-22 | 385d |  |  | N1 | 12320h | 12320h | 24.228, 24.229, 23.218 | Rel-5 | Frederic |  | IMS-CCR | Lucent | Keith Drage (drage@alcatel-lucent.com) |  |
| 2708 | 81.1.4.1 | IMS signalling flows | 385d | 2000-10-02 A | 2002-03-22 A | 100% | 2000-10-02 | 2002-03-22 | 385d | finish no earlier than 2002-03-22 |  | N1 | 3080h | 3080h | 24.228 | Rel-5 | Frederic |  | IMS-CCR |  |  |  |
| 2709 | 81.1.4.2 | IMS stage 3 | 385d | 2000-10-02 A | 2002-03-22 A | 100% | 2000-10-02 | 2002-03-22 | 385d | finish no earlier than 2002-03-22 |  | N1 | 3080h | 3080h | 24.229 | Rel-5 | Frederic |  | IMS-CCR |  |  |  |
| 2710 | 81.1.4.3 | IMS Session Handling; stage 2 | 385d | 2000-10-02 A | 2002-03-22 A | 100% | 2000-10-02 | 2002-03-22 | 385d | finish no earlier than 2002-03-22 |  | N1 | 3080h | 3080h | 23.218 | Rel-5 | Frederic |  | IMS-CCR |  |  |  |
| 2711 | 16.5.1 | Conformance Test Aspects – IMS Call Control | 451d | 2005-03-11 A | 2006-12-01 A | 100% | 2005-03-11 | 2006-12-01 | 451d |  | 2006-06-02 | R5 | 3608h | 3608h | 34.108, 34.229-1, 34.229-2, 34.229-3 | Rel-5 | Ingbert |  | IMS-CCR_Test | Motorola | Jacob.John@motorola.com | Fri 11/03/05 |
| 2712 | 81.1.4.4 | **Main IETF dependencies** | 641d | 2000-01-03 A | 2002-06-14 A | 100% | 2000-01-03 | 2002-06-14 | 641d |  |  | NP | 58048h | 58048h |  | Rel-5 | Kimmo |  | IMS | Lucent |  |  |
| 2713 | 81.1.4.4.1 | IETF: RFC 3261 (Session Initiation Protocol) | 346d | 2000-11-24 A | 2002-03-22 A | 100% | 2000-11-24 | 2002-03-22 | 346d | finish no earlier than 2002-03-22 |  | N1 | 2768h | 2768h |  | Rel-5 | Frederic |  | IMS | Lucent |  |  |
| 2714 | 81.1.4.4.2 | IETF: RFC 3262 (Reliability of provisional responses) | 346d | 2000-11-24 A | 2002-03-22 A | 100% | 2000-11-24 | 2002-03-22 | 346d | finish no earlier than 2002-03-22 |  | N1 | 2768h | 2768h |  | Rel-5 | Frederic |  | IMS | Lucent |  |  |
| 2715 | 81.1.4.4.3 | IETF: RFC 3312 (Without COMET)(Integration of resource management and SIP) | 382d | 2000-11-24 A | 2002-05-13 A | 100% | 2000-11-24 | 2002-05-13 | 382d | finish no earlier than 2002-05-13 |  | N1 | 3056h | 3056h |  | Rel-5 | Frederic |  | IMS | Lucent |  |  |
| 2716 | 81.1.4.4.4 | IETF: RFC 3323 (SIP extensions for caller identity and privacy) | 382d | 2000-11-24 A | 2002-05-13 A | 100% | 2000-11-24 | 2002-05-13 | 382d | finish no earlier than 2002-05-13 |  | N1 | 3056h | 3056h |  | Rel-5 | Frederic |  | IMS | Lucent |  |  |
| 2717 | 81.1.4.4.5 | IETF: RFC 3313 (SIP extensions for media authorization) | 382d | 2000-11-24 A | 2002-05-13 A | 100% | 2000-11-24 | 2002-05-13 | 382d | finish no earlier than 2002-05-13 |  | N1 | 3056h | 3056h |  | Rel-5 | Frederic |  | IMS | Lucent |  |  |
| 2718 | 81.1.4.4.6 | IETF: RFC 3265 (specific event notification) | 346d | 2000-11-24 A | 2002-03-22 A | 100% | 2000-11-24 | 2002-03-22 | 346d | finish no earlier than 2002-03-22 |  | N1 | 2768h | 2768h |  | Rel-5 | Frederic |  | IMS | Lucent |  |  |
| 2719 | 81.1.4.4.7 | IETF: RFC editor Queue (refer method) | 401d | 2000-11-24 A | 2002-06-07 A | 100% | 2000-11-24 | 2002-06-07 | 401d | finish no earlier than 2002-06-07 |  | N1 | 3208h | 3208h |  | Rel-5 | Frederic |  | IMS | Lucent |  |  |
| 2720 | 81.1.4.4.8 | IETF: RFC editor Queue (DHCP options for SIP servers) | 382d | 2000-11-24 A | 2002-05-13 A | 100% | 2000-11-24 | 2002-05-13 | 382d | finish no earlier than 2002-05-13 |  | N1 | 3056h | 3056h |  | Rel-5 | Frederic |  | IMS | Lucent |  |  |
| 2721 | 81.1.4.4.10 | IETF: RFC 3267 (AMR and AMR WB RTP and SDP) | 346d | 2000-11-24 A | 2002-03-22 A | 100% | 2000-11-24 | 2002-03-22 | 346d | finish no earlier than 2002-03-22 |  | N1 | 2768h | 2768h |  | Rel-5 | Frederic |  | IMS | Lucent |  |  |
| 2722 | 81.1.4.4.11 | IETF: RFC 3266 (IPv6 support within SDP) | 581d | 2000-01-03 A | 2002-03-22 A | 100% | 2000-01-03 | 2002-03-22 | 581d | finish no earlier than 2002-03-22 |  | N1 | 4640h | 4640h |  | Rel-5 | Frederic |  | IMS | Lucent |  |  |
| 2723 | 81.1.4.4.12 | IETF: RFC 3311 (The Update method) | 382d | 2000-11-24 A | 2002-05-13 A | 100% | 2000-11-24 | 2002-05-13 | 382d | finish no earlier than 2002-05-13 |  | N1 | 3056h | 3056h |  | Rel-5 | Frederic |  | IMS | Lucent |  |  |
| 2724 | 81.1.4.4.13 | IETF: RFC 3324 (Network Asserted Identity) | 382d | 2000-11-24 A | 2002-05-13 A | 100% | 2000-11-24 | 2002-05-13 | 382d | finish no earlier than 2002-05-13 |  | N1 | 3056h | 3056h |  | Rel-5 | Frederic |  | IMS | Lucent |  |  |
| 2725 | 81.1.4.4.14 | IETF: RFC editor Queue (Various 3GPP Private Extensions) | 382d | 2000-11-24 A | 2002-05-13 A | 100% | 2000-11-24 | 2002-05-13 | 382d | finish no earlier than 2002-05-13 |  | N1 | 3056h | 3056h |  | Rel-5 | Frederic |  | IMS | Lucent |  |  |

Notes:
- 2698: Marked as stopped 12/2008
- 2699: Marked as stopped 12/2008
- 2700: Marked as stopped 12/2008
- 2701: Formerly 'Shared Network support in connected mode', renamed at RAN #16.
- 2702: -
- 2703: -
- 2704: Issues include e.g.: Roaming requirements, Requirements on supplementary services, Interworking requirements
- 2705: Issues include e.g.: Mobile IP, RAB selection principles, Optimized VoIP bearer mechanisms, SIP multimedia protocol
- 2706: Per 26/2-02: This is understood to be the PCO & TFT CRs which CN1 provides to TSGN #15 for approval. If this is correct understanding, then the task is 100 % complete.
- 2707: TSGN_10 approved the change:CN1 - SA2 SIP joint meeting spotted one more place for improvement: work tasks with ID 1998 and 1278 are actually subtasks under of single CN1 WT. One WI has been approved for the CN1 WT with title "SIP Call Control protocol
- 2708: 24.228
- 2709: 24.229
- 2710: 23.218
- 2711: -
- 2712: -
- 2713: -
- 2714: -
- 2715: -
- 2716: -
- 2717: -
- 2718: -
- 2719: -
- 2720: -
- 2721: -
- 2722: -
- 2723: -
- 2724: -
- 2725: -

| ID | WBS | Task | Duration | Start | Finish | Complete | Baseline start | Baseline finish | Baseline duration | Constraint | Resources | Work | Actual work | Text1 | Text6 | Text8 | Text3 | Text4 | Text5 |
| --- | --- | --- | --- | --- | --- | --- | --- | --- | --- | --- | --- | --- | --- | --- | --- | --- | --- | --- | --- |
| 2726 | 81.1.4.5 | **Addressing** | 380d | 2000-10-09 A | 2002-03-22 A | 100% | 2000-10-09 | 2002-03-22 | 380d |  | S2 | 7744h | 7744h | IMS | Rel-5 | Maurice |  |  |  |
| 2727 | 81.1.4.5.1 | Architectural issues | 235d | 2000-10-09 A | 2001-08-31 A | 100% | 2000-10-09 | 2001-08-31 | 235d | finish no earlier than 2001-03-16 | S2 | 1880h | 1880h | IMS | Rel-5 | Maurice |  |  |  |
| 2728 | 81.1.4.5.2 | Impact on HSS | 353d | 2000-11-15 A | 2002-03-22 A | 100% | 2000-11-15 | 2002-03-22 | 353d | finish no earlier than 2002-03-22 | N4 | 2824h | 2824h | IMS | Rel-5 | Kimmo |  |  |  |
| 2729 | 81.1.4.6 | **Service Examples (Work stopped)** | 304d | 2001-04-17 A | 2002-06-14 A | 100% | 2001-04-17 | 2002-06-14 | 304d |  | S1 | 4864h | 4864h | IMS-Sex | Rel-5 | Alain | 22.928 | Motorola | Mark Cataldo |
| 2730 | 81.1.4.6.1 | IMS Framework Report (work stopped) | 304d | 2001-04-17 A | 2002-06-14 A | 100% | 2001-04-17 | 2002-06-14 | 304d | finish no earlier than 2002-06-14 | S1 | 2432h | 2432h | IMS-FrWk | Rel-5 | Alain | 22.941 | SBC | Randolph Wohlert (rwohlert@tri.sbc.com) |
| 2731 | 81.2 | **Access Security for IMS** | 190d | 2001-10-08 A | 2002-06-28 A | 100% | 2001-10-08 | 2002-06-28 | 190d |  | S3,T3 | 4120h | 4120h | IMS-ASEC | Rel-5 | Dionisio |  | Ericsson | krister.boman@emw.ericsson.se |
| 2732 | 81.2.2 | IMS impacts on UICC (ISIM application) | 185d | 2001-10-08 A | 2002-06-21 A | 100% | 2001-10-08 | 2002-06-21 | 185d | finish no earlier than 2002-06-21 | T3 | 1480h | 1480h | IMS-ASEC | Rel-5 | Xavier | 33.102, new TS 31.103 | Vodafone | Jeremy Norris |
| 2733 | 81.2.3 | Deleted - SIP extensions for Integrity protection | 140d | 2001-12-17 A | 2002-06-28 A | 100% | 2001-12-17 | 2002-06-28 | 140d | finish no earlier than 2002-06-28 | N1 | 1120h | 1120h | IMS-ASEC | Rel-5 | Frederic |  |  |  |
| 2734 | 81.3 | Security Aspects of Requirement for Network Configuration Independence | 130d | 2001-07-02 A | 2001-12-28 A | 100% | 2001-07-02 | 2001-12-28 | 130d | finish no earlier than 2001-12-28 | S3 | 1040h | 1040h | SEC1-NCI | Rel-5 | Dionisio | 33.203 | AT&T Wireless | hugh.shieh@attws.com |
| 2735 | 81.4 | IMS Lawful Interception | 410d | 2000-09-04 A | 2002-03-29 A | 100% | 2000-09-04 | 2002-03-29 | 410d | finish no earlier than 2002-03-29 | S3 | 3280h | 3280h | IMS-LI | Rel-5 | Dionisio | 33.106, 33.107, new 33.108 | Reg TP | berthold.wilhelm@regtp.de |
| 2736 | 81.5 | Charging and OAM&P for IMS | 383d | 2000-12-25 A | 2002-06-12 A | 100% | 2000-12-25 | 2002-06-12 | 383d | finish no earlier than 2002-06-12 | S5 | 3064h | 3064h | IMS-OAM | Rel-5 | Dionisio | 32-series |  |  |
| 2737 | 81.6 | **Multimedia codecs and protocols for conversational PS services** | 568d | 2000-07-26 A | 2002-09-27 A | 100% | 2000-07-26 | 2002-09-27 | 568d |  | S4 | 15640h | 15640h | IMS-CODEC | Rel-5 | Paolo | 26.235, 26.236 | Toshiba, Nokia | B. Aronson (Toshiba), pasi.s.ojala@nokia.com |
| 2738 | 81.6.1 | Codecs | 427d | 2000-07-26 A | 2002-03-14 A | 100% | 2000-07-26 | 2002-03-14 | 427d | finish no earlier than 2001-03-21 | S4 | 3416h | 3416h |  | Rel-5 | Paolo | 26.235, 26.236 |  |  |
| 2739 | 81.6.2 | Transport protocols | 1d | 2002-03-12 A | 2002-03-12 A | 100% | 2002-03-12 | 2002-03-12 | 1d | finish no earlier than 2002-03-12 | S4 | 8h | 8h | IMS-CODEC | Rel-5 | Paolo | 26.236 | Nokia | P. Ojala |
| 2740 | 81.6.4 | recommendation for QoS parameter values for various media types | 195d | 2001-12-31 A | 2002-09-27 A | 100% | 2001-12-31 | 2002-09-27 | 195d | finish no earlier than 2002-09-27 | S4 | 1560h | 1560h |  | Rel-5 | Paolo |  |  |  |
| 2741 | 81.6.5 | IETF: RFC 3310 (HTTP Digest Authentication using AKA) | 382d | 2000-11-24 A | 2002-05-13 A | 100% | 2000-11-24 | 2002-05-13 | 382d | finish no earlier than 2002-05-13 | N1 | 3056h | 3056h | IMS-CODEC | Rel-5 | Frederic |  |  |  |
| 2742 | 81.6.6 | IETF: RFC 3329 (Security mechanism agreement for SIP connections) | 382d | 2000-11-24 A | 2002-05-13 A | 100% | 2000-11-24 | 2002-05-13 | 382d | finish no earlier than 2002-05-13 | N1 | 3056h | 3056h | IMS-CODEC | Rel-5 | Frederic |  |  |  |
| 2743 | 81.7 | **SIP message compression** | 185d | 2001-09-24 A | 2002-06-07 A | 100% | 2001-09-24 | 2002-06-07 | 185d |  | S2 | 3128h | 3128h |  | Rel-5 | Maurice |  |  |  |
| 2744 | 81.7.1 | Stage 2 for SIP message compression | 25d | 2001-09-24 A | 2001-10-26 A | 100% | 2001-09-24 | 2001-10-26 | 25d | finish no earlier than 2001-10-26 | S2 | 200h | 200h |  | Rel-5 | Maurice |  |  |  |
| 2745 | 81.7.2 | Compression signalling | 181d | 2001-09-28 A | 2002-06-07 A | 100% | 2001-09-28 | 2002-06-07 | 181d | finish no earlier than 2002-06-07 | N1 | 1448h | 1448h |  | Rel-5 | Frederic |  |  |  |
| 2746 | 81.8 | **Stage 3 description of IMS interfaces** | 383d | 2001-03-14 A | 2002-08-30 A | 100% | 2001-03-14 | 2002-08-30 | 383d |  | NP | 29531.6h | 29531.6h |  | Rel-5 | Kimmo |  |  |  |
| 2747 | 81.8.1 | Cx interface (HSS to CSCF) | 135.95d | 2001-03-14 A | 2002-06-07 A | 100% | 2001-03-14 | 2002-06-07 | 135.95d | finish no earlier than 2002-06-07 | N4 | 1087.58h | 1087.58h |  | Rel-5 | Kimmo |  |  |  |
| 2748 | 81.8.2 | Mp interface (MRFC - MRFP) enhancements | 258d | 2001-03-14 A | 2002-03-08 A | 100% | 2001-03-14 | 2002-03-08 | 258d | finish no earlier than 2002-06-07 | N4 | 2064h | 2064h |  | Rel-5 | Kimmo |  |  |  |
| 2749 | 81.8.3 | Mw interface (CSCF to P-CSCF) | 323d | 2001-03-14 A | 2002-06-07 A | 100% | 2001-03-14 | 2002-06-07 | 323d | finish no earlier than 2002-06-07 | N1 | 2584h | 2584h |  | Rel-5 | Frederic |  |  |  |
| 2750 | 81.8.4 | Mr interface (CSCF to MRF) | 273d | 2001-03-14 A | 2002-03-29 A | 100% | 2001-03-14 | 2002-03-29 | 273d | finish no earlier than 2002-03-29 | N1 | 2184h | 2184h |  | Rel-5 | Frederic |  |  |  |
| 2751 | 81.8.5 | Dx interface (I-CSCF to SLF) | 323d | 2001-03-14 A | 2002-06-07 A | 100% | 2001-03-14 | 2002-06-07 | 323d | finish no earlier than 2002-06-07 | N4 | 2584h | 2584h |  | Rel-5 | Kimmo |  |  |  |
| 2752 | 81.8.6 | Go interface (GGSN to PCF) | 323d | 2001-03-14 A | 2002-06-07 A | 100% | 2001-03-14 | 2002-06-07 | 323d | finish no earlier than 2002-06-07 | N3 | 2584h | 2584h |  | Rel-5 | Gwiho |  |  |  |
| 2753 | 81.8.7 | ISC (IMS Service Control) Interface | 323d | 2001-03-14 A | 2002-06-07 A | 100% | 2001-03-14 | 2002-06-07 | 323d | finish no earlier than 2002-06-07 | N1 | 2584h | 2584h |  | Rel-5 | Frederic |  |  |  |
| 2754 | 81.8.8 | Sh interface (HSS to AS) | 82d | 2002-02-14 A | 2002-06-07 A | 100% | 2002-02-14 | 2002-06-07 | 82d | finish no earlier than 2002-06-07 | N4 | 656h | 656h |  | Rel-5 | Kimmo |  |  |  |
| 2755 | 81.8.9 | Si interface (HSS to IM-SSF) | 162.5d | 2002-01-16 A | 2002-08-30 A | 100% | 2002-01-16 | 2002-08-30 | 162.5d | finish no earlier than 2002-06-07 | N4 | 1300h | 1300h |  | Rel-5 | Kimmo |  |  |  |
| 2756 | 81.8.10 | Gm interface (UE to CSCF) | 323d | 2001-03-14 A | 2002-06-07 A | 100% | 2001-03-14 | 2002-06-07 | 323d | finish no earlier than 2002-06-07 | N1 | 2584h | 2584h |  | Rel-5 | Frederic |  |  |  |
| 2757 | 81.8.11 | Mi interface (CSCF to BGCF) | 323d | 2001-03-14 A | 2002-06-07 A | 100% | 2001-03-14 | 2002-06-07 | 323d | finish no earlier than 2002-06-07 | N1 | 2584h | 2584h |  | Rel-5 | Frederic |  |  |  |
| 2758 | 81.8.12 | Mj interface (BGCF to MGCF) | 323d | 2001-03-14 A | 2002-06-07 A | 100% | 2001-03-14 | 2002-06-07 | 323d | finish no earlier than 2002-06-07 | N1 | 2584h | 2584h |  | Rel-5 | Frederic |  |  |  |
| 2759 | 81.8.13 | Mk interface (BGCF to BGCF) | 323d | 2001-03-14 A | 2002-06-07 A | 100% | 2001-03-14 | 2002-06-07 | 323d | finish no earlier than 2002-06-07 | N1 | 2584h | 2584h |  | Rel-5 | Frederic |  |  |  |
| 2760 | 81.9 | Support of VHE/OSA by entities and protocols of the IMS (e.g. CSCF) | 186d | 2001-09-21 A | 2002-06-07 A | 100% | 2001-09-21 | 2002-06-07 | 186d | finish no earlier than 2002-06-07 | N5 | 1488h | 1488h | IMS-ONOSA | Rel-5 | Kimmo | 29.198, 29.998 | Ericsson | Ard.Jan.Moerdijk@eln.ericsson.se |

Notes:
- 2726: -
- 2727: -
- 2728: Covered by 29.228 & 29228
- 2729: -
- 2730: -
- 2731: -
- 2732: -
- 2733: CN1 is not aware of any requirements and is not doing anything on this task
- 2734: Consider security aspects in SA2 TS 23.228 clause 4.4 & annex C
- 2735: SP#17 completed
- 2736: -
- 2737: -
- 2738: -
- 2739: -
- 2740: -
- 2741: -
- 2742: -
- 2743: -
- 2744: -
- 2745: -
- 2746: -
- 2747: -
- 2748: [DAB 08-03-02] - No work required in CN4
- 2749: -
- 2750: -
- 2751: CN4#11 30/11/01: No inputs received in CN4 / 14/02/02 Completed(introduced in 29.228)
- 2752: [DAB - 23/05/03] - 100 % complete
- 2753: -
- 2754: CN4#11 30/11/01: No inputs received in CN4 / CN4#12bis 14/02/02: WID approved / 17th May 100% complete. 3GPP TS 29.329 will be sent for approval in CN#16
- 2755: SA16: Part of Rel5 only if completed in September 02. Marked as closed 12/2008 (was marked 72% complete)
- 2756: -
- 2757: -
- 2758: -
- 2759: -
- 2760: -

| ID | WBS | Task | Duration | Start | Finish | Predecessors | Complete | Baseline start | Baseline finish | Baseline duration | Constraint | Resources | Work | Actual work | Text1 | Text4 | Text5 | Text6 | Text8 | Text12 | Text3 |
| --- | --- | --- | --- | --- | --- | --- | --- | --- | --- | --- | --- | --- | --- | --- | --- | --- | --- | --- | --- | --- | --- |
| 2761 | 81.10 | **CAMEL control of IMS services** | 365d | 2001-04-16 A | 2002-09-06 A |  | 100% | 2001-04-16 | 2002-09-06 | 365d |  | N2 | 9952h | 9952h | IMS-CAMEL | Lucent | Angelica Remoquillo | Rel-5 | Kimmo |  |  |
| 2762 | 81.10.1 | Stage2 work 'general' | 365d | 2001-04-16 A | 2002-09-06 A |  | 100% | 2001-04-16 | 2002-09-06 | 365d | finish no earlier than 2002-09-06 | N2 | 2920h | 2920h |  |  |  | Rel-5 | Kimmo |  |  |
| 2763 | 81.10.2 | Stage3 work 'CAP' | 175d | 2002-01-07 A | 2002-09-06 A |  | 100% | 2002-01-07 | 2002-09-06 | 175d | finish no earlier than 2002-09-06 | N2 | 1400h | 1400h |  |  |  | Rel-5 | Kimmo |  |  |
| 2764 | 81.10.3 | Stage2 work 'Si interface' | 175d | 2002-01-07 A | 2002-09-06 A |  | 100% | 2002-01-07 | 2002-09-06 | 175d | finish no earlier than 2002-09-06 | N2 | 1400h | 1400h |  |  |  | Rel-5 | Kimmo |  |  |
| 2765 | 81.10.4 | Stage3 work 'Si interface' | 82d | 2002-02-14 A | 2002-06-07 A |  | 100% | 2002-02-14 | 2002-06-07 | 82d | finish no earlier than 2002-06-07 | N4 | 656h | 656h |  |  |  | Rel-5 | Kimmo |  |  |
| 2766 | 81.10.5 | Deleted - SDM issues for CAMEL control of IMS | 82d | 2002-02-14 A | 2002-06-07 A |  | 100% | 2002-02-14 | 2002-06-07 | 82d | finish no earlier than 2002-06-07 | N4 | 656h | 656h |  |  |  | Rel-5 | Kimmo | NP-17 |  |
| 2767 | 81.11 | Pre-pay/real-time charging in IMS | 196d | 2001-06-15 A | 2002-03-15 A |  | 100% | 2001-06-15 | 2002-03-15 | 196d | finish no earlier than 2002-03-15 | S1 | 1568h | 1568h |  |  |  | Rel-5 | Alain |  |  |
| 2768 | 81.12 | **IMS Charging** | 289d | 2001-08-06 A | 2002-09-12 A |  | 100% | 2001-08-06 | 2002-09-12 | 289d |  | S2,S5 | 6632h | 6632h | OAM-CH | T-Mobile | karl-heinz.nenner@t-mobile.de | Rel-5 | Dionisio |  | 32.225 |
| 2769 | 81.12.1 | Charging Implications of IMS architecture | 75d | 2001-08-06 A | 2001-11-16 A |  | 100% | 2001-08-06 | 2001-11-16 | 75d | finish no earlier than 2001-11-16 | S2 | 600h | 600h |  |  |  | Rel-5 | Maurice |  |  |
| 2770 | 81.12.2 | Charging management for IMS (off-line & on-line) | 214d | 2001-11-19 A | 2002-09-12 A | 2769 | 100% | 2001-11-19 | 2002-09-12 | 214d | finish no earlier than 2002-09-12 | S5 | 1712h | 1712h | OAM-CH |  |  | Rel-5 | Dionisio |  | 32.225 |
| 2771 | 86.1.6.10 | Billing, accounting and call detail record aspects | 251d | 2001-09-27 A | 2002-09-12 A |  | 100% | 2001-09-27 | 2002-09-12 | 251d | finish no earlier than 2002-09-12 | S5 | 2008h | 2008h | OAM-CH | T-Mobile | Karl-Heinz.Nenner@T-MOBILE.DE | Rel-5 | Dionisio |  | 32.225 |
| 2772 | 81.13 | **Other IETF dependencies** | 401d | 2000-11-24 A | 2002-06-07 A |  | 100% | 2000-11-24 | 2002-06-07 | 401d |  | NP | 9624h | 9624h |  |  |  | Rel-5 |  |  |  |
| 2773 | 81.13.1 | IETF: draft-ietf-aaa-diameter - should be CN4 | 401d | 2000-11-24 A | 2002-06-07 A |  | 100% | 2000-11-24 | 2002-06-07 | 401d | finish no earlier than 2002-06-07 | NP | 3208h | 3208h |  |  |  | Rel-5 |  |  |  |
| 2774 | 81.13.2 | IETF: draft-johansson-aaa-diameter-mm-app - should be CN4 | 401d | 2000-11-24 A | 2002-06-07 A |  | 100% | 2000-11-24 | 2002-06-07 | 401d | finish no earlier than 2002-06-07 | NP | 3208h | 3208h |  |  |  | Rel-5 |  |  |  |
| 2775 | 81.15 | Conformance Test Aspects - Provisioning of IMS | 205d | 2002-03-18 A | 2002-12-27 A |  | 100% | 2002-03-18 | 2002-12-27 | 205d | finish no earlier than 2002-12-27 | T1 | 1640h | 1640h | IMS-TEST |  |  | Rel-5 | Ingbert |  |  |
| 2776 | 81.16 | Testing of support for IMS - prose | 270d | 2002-09-18 A | 2003-09-30 A |  | 100% | 2002-09-18 | 2003-09-30 | 270d | finish no earlier than 2003-09-30 | T1 | 2160h | 2160h |  | Anritsu | dan.fox@eu.anritsu.com | Rel-5 | Ingbert |  | 34.108, 34.123 |
| 2777 | 81.17 | Testing of support for IMS - TTCN | 381d | 2002-09-18 A | 2004-03-03 A |  | 100% | 2002-09-18 | 2004-03-03 | 381d | finish no earlier than 2004-03-03 | T1 | 3048h | 3048h |  | Anritsu | dan.fox@eu.anritsu.com | Rel-5 | Ingbert |  | 34.108, 34.123 |
| 2778 | 82 | **Extended Transparent End-to-End PS Streaming Service** | 313d? | 2002-01-03 A | 2003-03-17 A |  | 100% | 2002-01-03 | 2003-03-17 | 313d? |  | S4 | 6224h | 6224h | PSS-E | Ericsson | olle.franceschi@ericsson.com | Rel-5 | Paolo |  | 26.233, 26.234 |
| 2779 | 82.1 | **Stage 1 for Extended Transparent End-to-End PS Streaming Service** | 86d? | 2002-11-18 A | 2003-03-17 A |  | 100% | 2002-11-18 | 2003-03-17 | 86d? |  | S1 | 1376h | 1376h |  | Vodafone | stephen.wolak@vodafone.com | Rel-5 | Alain |  | 22.233 |
| 2780 | 816.1.1 | Interaction with other services | 86d? | 2002-11-18 A | 2003-03-17 A |  | 100% | 2002-11-18 | 2003-03-17 | 86d? | finish no earlier than 2003-03-17 | S1 | 688h | 688h |  | Vodafone | stephen.wolak@vodafone.com | Rel-5 | Alain |  | 22.233 |
| 2781 | 82.2 | Stage 2 (version Rel-5 of TS 26.234) | 51d | 2002-01-03 A | 2002-03-14 A |  | 100% | 2002-01-03 | 2002-03-14 | 51d | finish no earlier than 2002-03-26 | S4 | 408h | 408h |  |  |  | Rel-5 | Paolo |  | 26.234 |
| 2782 | 82.3 | RTP usage model | 242d | 2002-01-03 A | 2002-12-06 A |  | 100% | 2002-01-03 | 2002-12-06 | 242d | finish no earlier than 2002-12-06 | S4 | 1936h | 1936h |  |  |  | Rel-5 | Paolo |  | 26.937 |
| 2783 | 83 | **Rel-5 Open Service Access (OSA) enhancements** | 955d | 1999-04-27 A | 2002-12-20 A |  | 100% | 1999-04-27 | 2002-12-20 | 955d |  | S1,S3 | 65008h | 65008h | OSA1 | Siemens | Joerg Swetina (joerg.swetina@nw.neclab.eu) | Rel-5 | Alain |  | 22.127, 23.127, 29.198-x, 29.998-x |
| 2784 | 83.1 | General Stage 2 for Rel-5 | 194d | 2001-09-11 A | 2002-06-07 A |  | 100% | 2001-09-11 | 2002-06-07 | 194d |  | S2 | 1232h | 1232h |  |  |  | Rel-5 | Maurice |  |  |

Notes:
- 2761: -
- 2762: DAB 12.12.01 split into cn4 and cn2 parts
- 2763: DAB 12.12.01 split into cn4 and cn2 parts
- 2764: DAB 12.12.01 split into cn4 and cn2 parts
- 2765: [DAB 08-03-02] - UID 12004 is MASTER of UID 14998 / 17 May need to be recearch possible impact on 23.008 & 23.016, changes to 29.002 are done.
- 2766: Marked as stopped 12/2008
- 2767: Marked as closed 12/2008 (was marked 60% complete)
- 2768: -
- 2769: -
- 2770: -
- 2771: -
- 2772: Was introduced at SP#13 by Ileana Leuca (exact position in the WP and related WG have to be defined)
- 2773: Marked as closed 12/2008 (was marked 90% complete)
- 2774: Marked as closed 12/2008 (was marked 50% complete)
- 2775: The task is a BB, individual work items were considered but are constrained by lack of supporting companies. Marked as stopped 12/2008
- 2776: Marked as stopped 12/2008
- 2777: Marked as stopped 12/2008
- 2778: -
- 2779: 2nd resp SA4
- 2780: 2nd resp SA4. Marked as closed 12/2008 (was marked 65% complete)
- 2781: 2nd resp SA2
- 2782: Marked as closed 12/2008 (was marked 90% complete)
- 2783: -
- 2784: Marked as closed 12/2008 (was marked 47% complete)

| ID | WBS | Task | Duration | Start | Finish | Predecessors | Complete | Baseline start | Baseline finish | Baseline duration | Constraint | Resources | Work | Actual work | Text1 | Text6 | Text8 | Text3 | Text4 | Text5 |
| --- | --- | --- | --- | --- | --- | --- | --- | --- | --- | --- | --- | --- | --- | --- | --- | --- | --- | --- | --- | --- |
| 2785 | 83.2 | **OSA APIs for Multimedia Call Control** | 499d | 2000-07-11 A | 2002-06-07 A |  | 100% | 2000-07-11 | 2002-06-07 | 499d |  | S2 | 5960h | 5960h | OSA1-CSCF | Rel-5 | Maurice |  |  |  |
| 2786 | 83.2.1 | Stage 1 for OSA APIs for Multimedia Call Control | 438d | 2000-07-11 A | 2002-03-14 A |  | 100% | 2000-07-11 | 2002-03-14 | 438d | finish no earlier than 2002-03-14 | S1 | 3504h | 3504h |  | Rel-5 | Alain | 22.127 | Siemens | Manfred.leitgeb@siemens.at |
| 2787 | 83.2.2 | Stages 2 and 3 for Multimedia Call Control | 194d | 2001-09-11 A | 2002-06-07 A |  | 100% | 2001-09-11 | 2002-06-07 | 194d | finish no earlier than 2002-06-07 | N5 | 1552h | 1552h |  | Rel-5 | Kimmo | 29.198-04 |  |  |
| 2788 | 83.3 | Generic user interaction - Stage 3 | 194d | 2001-09-11 A | 2002-06-07 A |  | 100% | 2001-09-11 | 2002-06-07 | 194d | finish no earlier than 2002-06-07 | N5 | 1552h | 1552h |  | Rel-5 | Kimmo | 29.198-05 |  |  |
| 2789 | 83.4 | OSA Charging - Stage 3 | 194d | 2001-09-11 A | 2002-06-07 A |  | 100% | 2001-09-11 | 2002-06-07 | 194d | finish no earlier than 2002-06-07 | N5 | 1552h | 1552h |  | Rel-5 | Kimmo | 29.198-12 |  |  |
| 2790 | 83.5 | Call Control Service Mapping; Multiparty Call Control SIP - Stage 3 | 194d | 2001-09-11 A | 2002-06-07 A |  | 100% | 2001-09-11 | 2002-06-07 | 194d | finish no earlier than 2002-06-07 | N5 | 1552h | 1552h |  | Rel-5 | Kimmo | 29.998-04-4 |  |  |
| 2791 | 83.6 | WSDL APIs for SOAP/HTTP - Stage 3 | 455d | 2000-09-11 A | 2002-06-07 A |  | 100% | 2000-09-11 | 2002-06-07 | 455d | finish no earlier than 2002-06-07 | N5 | 3640h | 3640h |  | Rel-5 | Kimmo | 29.198, 29.998 |  |  |
| 2792 | 83.7 | **OSA Security** | 639d | 2000-07-11 A | 2002-12-20 A |  | 100% | 2000-07-11 | 2002-12-20 | 639d |  | S3 | 15000h | 15000h | OSA1-SEC | Rel-5 | Dionisio | 33.102 | Ericsson | colin.blanchard@bt.com |
| 2793 | 83.7.1 | Stage 1 for OSA Security | 349d | 2000-07-11 A | 2001-11-09 A |  | 100% | 2000-07-11 | 2001-11-09 | 349d | finish no earlier than 2001-11-09 | S1 | 2792h | 2792h |  | Rel-5 | Alain | 22.127 | Siemens | Manfred.leitgeb@siemens.at |
| 2794 | 83.7.2 | OSA Stage 3 | 430d | 2000-10-23 A | 2002-06-14 A |  | 100% | 2000-10-23 | 2002-06-14 | 430d | finish no earlier than 2002-06-14 | S3 | 3440h | 3440h | OSA1-SEC | Rel-5 | Dionisio | 33.102 | BT, Ericsson | colin.blanchard@bt.com |
| 2795 | 83.7.3 | security related SCF(s) definition | 186d | 2001-09-21 A | 2002-06-07 A |  | 100% | 2001-09-21 | 2002-06-07 | 186d | finish no earlier than 2002-06-07 | N5 | 1488h | 1488h |  | Rel-5 | Kimmo | 29.198, 29.998 | Ericsson | Ard.Jan.Moerdijk@eln.ericsson.se |
| 2796 | 83.7.4 | OSA changes required from supporting platforms, e.g. gsmSCF, HLR | 69d | 2000-09-11 A | 2000-12-14 A |  | 100% | 2000-09-11 | 2000-12-14 | 69d | finish no earlier than 2000-12-14 | S3 | 552h | 552h | OSA1-SEC | Rel-5 | Dionisio | 33.102 | BT, Ericsson | colin.blanchard@bt.com |
| 2797 | 817.7.5 | OSA Security (moved from Rel-6) | 202d | 2002-03-14 A | 2002-12-20 A |  | 100% | 2002-03-14 | 2002-12-20 | 202d | finish no earlier than 2002-12-20 | S3 | 1616h | 1616h | OSA1-SEC | Rel-5 | Dionisio | 33.102 | BT, Ericsson | colin.blanchard@bt.com |
| 2798 | 83.8 | **Interactions OSA - e-commerce** | 815d | 1999-04-27 A | 2002-06-07 A |  | 100% | 1999-04-27 | 2002-06-07 | 815d |  | S2 | 6152h | 6152h | OSA1-ECOM | Rel-5 | Maurice |  |  |  |
| 2799 | 83.8.1 | Stage 1 for Interactions OSA - e-commerce | 439d | 1999-04-27 A | 2000-12-28 A |  | 100% | 1999-04-27 | 2000-12-28 | 439d | finish no earlier than 2000-12-28 | S1 | 3504h | 3504h |  | Rel-5 | Alain | 22.127 | Siemens | Joerg Swetina (joerg.swetina@nw.neclab.eu) |
| 2800 | 83.8.2 | Stages 2 and 3 for Interactions OSA - e-commerce | 186d | 2001-09-21 A | 2002-06-07 A |  | 100% | 2001-09-21 | 2002-06-07 | 186d | finish no earlier than 2002-06-07 | N5 | 1488h | 1488h |  | Rel-5 | Kimmo | 29.198, 29.998 | Ericsson | Ard.Jan.Moerdijk@eln.ericsson.se |
| 2801 | 83.9 | Policy Management - Stage 3 | 194d | 2001-09-11 A | 2002-06-07 A |  | 100% | 2001-09-11 | 2002-06-07 | 194d | finish no earlier than 2002-06-07 | N5 | 1552h | 1552h |  | Rel-5 | Kimmo | 29.198-13 |  |  |
| 2802 | 83.10 | Presence and Availability Management (PAM) - Stage 3 | 194d | 2001-09-11 A | 2002-06-07 A |  | 100% | 2001-09-11 | 2002-06-07 | 194d | finish no earlier than 2002-06-07 | N5 | 1552h | 1552h |  | Rel-5 | Kimmo | 29.198-14 |  |  |
| 2803 | 83.11 | **LCS - OSA interfaces** | 455d | 2000-09-11 A | 2002-06-07 A |  | 100% | 2000-09-11 | 2002-06-07 | 455d |  | S1 | 5656h | 5656h | OSA1-LCSI | Rel-5 | Alain |  | Siemens | Joerg Swetina (joerg.swetina@nw.neclab.eu) |
| 2804 | 83.11.1 | Stage 1 for LCS - OSA interfaces | 65d | 2000-09-11 A | 2000-12-08 A |  | 100% | 2000-09-11 | 2000-12-08 | 65d | finish no earlier than 2000-12-08 | S1 | 520h | 520h |  | Rel-5 | Alain | 22.127 | Siemens | Joerg Swetina (joerg.swetina@nw.neclab.eu) |
| 2805 | 83.11.2 | Stage 2 for LCS - OSA interfaces | 1d | 2000-12-11 A | 2000-12-11 A | 2804 | 100% | 2000-12-11 | 2000-12-11 | 1d | finish no earlier than 2000-12-11 | S2 | 8h | 8h |  | Rel-5 | Maurice | 23.127 | Ericsson | Christophe GOURRAUD |
| 2806 | 83.11.3 | Stage 3 for LCS - OSA interfaces | 186d | 2001-09-21 A | 2002-06-07 A | 2805 | 100% | 2001-09-21 | 2002-06-07 | 186d | finish no earlier than 2002-06-07 | N5 | 1488h | 1488h |  | Rel-5 | Kimmo | 29.198, 29.998 | Ericsson | Ard.Jan.Moerdijk@eln.ericsson.se |
| 2807 | 817.12 | Access to User Profile | 145d | 2001-06-01 A | 2001-12-20 A |  | 100% | 2001-06-01 | 2001-12-20 | 145d | finish no earlier than 2001-12-20 | S1 | 1160h | 1160h | OSA2-UP | Rel-5 | Alain |  |  |  |
| 2808 | 817.13 | **Retrieval of Terminal capabilities** | 634d | 2000-07-11 A | 2002-12-13 A |  | 100% | 2000-07-11 | 2002-12-13 | 634d |  | S2 | 10808h | 10808h | OSA2-TC | Rel-5 | Maurice |  |  |  |
| 2809 | 817.13.1 | Stage 1 for Retrieval of Terminal capabilities | 132d | 2000-07-11 A | 2001-01-10 A |  | 100% | 2000-07-11 | 2001-01-10 | 132d | finish no earlier than 2001-01-10 | S1 | 1056h | 1056h |  | Rel-5 | Alain | 22.127 | Siemens | Joerg Swetina (joerg.swetina@nw.neclab.eu) |
| 2810 | 817.13.2 | Stages 2 and 3 for Retrieval of Terminal capabilities | 321d | 2001-09-21 A | 2002-12-13 A | 2809 | 100% | 2001-09-21 | 2002-12-13 | 321d | finish no earlier than 2002-12-13 | N5 | 2568h | 2568h |  | Rel-5 | Kimmo | 29.198, 29.998 | Ericsson | Ard.Jan.Moerdijk@eln.ericsson.se |
| 2811 | 817.13.3 | Provisioning of the terminal capabilities | 445d | 2001-04-02 A | 2002-12-13 A |  | 100% | 2001-04-02 | 2002-12-13 | 445d | finish no earlier than 2002-12-13 | T2 | 3560h | 3560h |  | Rel-5 |  | 23.057 |  |  |

Notes:
- 2785: For Rel5 even if completed by March
- 2786: -
- 2787: -
- 2788: -
- 2789: -
- 2790: -
- 2791: -
- 2792: SP#8 approved WID
- 2793: -
- 2794: SP#8 approved WID
- 2795: -
- 2796: SP#8 approved WID
- 2797: SP#8 approved WID
- 2798: -
- 2799: Marked as closed 12/2008 (was marked 95% complete)
- 2800: -
- 2801: -
- 2802: -
- 2803: az: CN#13 - changed to Rel5
- 2804: -
- 2805: az 24/05/01: Rel4 completion 90->100%.
- 2806: -
- 2807: -
- 2808: -
- 2809: -
- 2810: -
- 2811: According to T2 SWG1 M. Cataldo this is automatically supported by the MExE support of UAProf therefore 100% complete

| ID | WBS | Task | Duration | Start | Finish | Predecessors | Complete | Baseline start | Baseline finish | Baseline duration | Constraint | Resources | Work | Actual work | Text1 | Text4 | Text5 | Text6 | Text8 | Text3 |
| --- | --- | --- | --- | --- | --- | --- | --- | --- | --- | --- | --- | --- | --- | --- | --- | --- | --- | --- | --- | --- |
| 2812 | 84 | **CAMEL phase 4** | 625d | 2000-04-17 A | 2002-09-06 A |  | 100% | 2000-04-17 | 2002-09-06 | 625d |  | S1 | 41104h | 41104h | CAMEL4 | Nokia | keijo.palviainen@nokia.com | Rel-5 | Alain |  |
| 2813 | 84.1 | Service requirements | 565d | 2000-04-17 A | 2002-06-14 A |  | 100% | 2000-04-17 | 2002-06-14 | 565d | finish no earlier than 2002-06-14 | S1 | 4520h | 4520h |  |  |  | Rel-5 | Alain |  |
| 2814 | 84.2 | Call Party Handling | 500d | 2000-07-10 A | 2002-06-07 A |  | 100% | 2000-07-10 | 2002-06-07 | 500d | finish no earlier than 2002-06-07 | N2 | 4000h | 4000h | CAMEL4-CPH |  |  | Rel-5 | Kimmo |  |
| 2815 | 84.3 | Mid call procedure for MO and MT calls | 495d | 2000-07-17 A | 2002-06-07 A |  | 100% | 2000-07-17 | 2002-06-07 | 495d | finish no earlier than 2002-06-07 | N2 | 3960h | 3960h | CAMEL4-MCP |  |  | Rel-5 | Kimmo |  |
| 2816 | 84.4 | Interactions with Optimal Routing | 430d | 2000-07-17 A | 2002-03-08 A |  | 100% | 2000-07-17 | 2002-03-08 | 430d | finish no earlier than 2002-03-08 | N2 | 3440h | 3440h | CAMEL4-IOR |  |  | Rel-5 | Kimmo |  |
| 2817 | 84.5 | Inclusion of flexible tone injection | 430d | 2000-07-17 A | 2002-03-08 A |  | 100% | 2000-07-17 | 2002-03-08 | 430d | finish no earlier than 2002-03-08 | N2 | 3440h | 3440h | CAMEL4-IFTI |  |  | Rel-5 | Kimmo |  |
| 2818 | 84.6 | CSE control over MT SMS | 430d | 2000-07-17 A | 2002-03-08 A |  | 100% | 2000-07-17 | 2002-03-08 | 430d | finish no earlier than 2002-03-08 | N2 | 3440h | 3440h | CAMEL4-CCSMS |  |  | Rel-5 | Kimmo |  |
| 2819 | 84.7 | Notification of GPRS mobility management to CSE | 331d | 2001-03-02 A | 2002-06-07 A |  | 100% | 2001-03-02 | 2002-06-07 | 331d | finish no earlier than 2002-06-07 | N2 | 2648h | 2648h | CAMEL4-NMM |  |  | Rel-5 | Kimmo |  |
| 2820 | 84.8 | Provision of location information of called subscriber | 266d | 2001-03-02 A | 2002-03-08 A |  | 100% | 2001-03-02 | 2002-03-08 | 266d | finish no earlier than 2002-03-08 | N2 | 2128h | 2128h | CAMEL4-LOCB |  |  | Rel-5 | Kimmo |  |
| 2821 | 84.9 | Inclusion of ODB data in the CSE_HLR interface | 175d | 2001-07-09 A | 2002-03-08 A |  | 100% | 2001-07-09 | 2002-03-08 | 175d | finish no earlier than 2002-03-08 | N2 | 1400h | 1400h | CAMEL4-ODB |  |  | Rel-5 | Kimmo |  |
| 2822 | 84.10 | Location information during an ongoing call (Handover DP) | 280d | 2001-05-14 A | 2002-06-07 A |  | 100% | 2001-05-14 | 2002-06-07 | 280d | finish no earlier than 2002-06-07 | N2 | 2240h | 2240h | CAMEL4-HODP |  |  | Rel-5 | Kimmo |  |
| 2823 | 84.11 | GPRS Any Time Interrogation | 240d | 2001-07-09 A | 2002-06-07 A |  | 100% | 2001-07-09 | 2002-06-07 | 240d | finish no earlier than 2002-06-07 | N2 | 1920h | 1920h | CAMEL4-ATI |  |  | Rel-5 | Kimmo |  |
| 2824 | 84.12 | Transfer of IMEI (with SW version) to CSE | 240d | 2001-07-09 A | 2002-06-07 A |  | 100% | 2001-07-09 | 2002-06-07 | 240d | finish no earlier than 2002-06-07 | N2 | 1920h | 1920h | CAMEL4-ATI |  |  | Rel-5 | Kimmo |  |
| 2825 | 84.13 | Handling of partial implementations of CAMEL4 | 131d | 2002-03-08 A | 2002-09-06 A |  | 100% | 2002-03-08 | 2002-09-06 | 131d | finish no earlier than 2002-06-07 | N2 | 1048h | 1048h | CAMEL4-SUB |  |  | Rel-5 | Kimmo |  |
| 2826 | 85 | **Rel-5 MExE enhancements** | 250d | 2001-03-26 A | 2002-03-08 A |  | 100% | 2001-03-26 | 2002-03-08 | 250d |  | T2 | 2880h | 2880h | MEXE5 |  |  | Rel-5 | Kimmo |  |
| 2827 | 85.1 | MExE Rel-5 Improvements and Investigations | 110d | 2001-03-26 A | 2002-03-08 A |  | 100% | 2001-03-26 | 2002-03-08 | 110d | finish no earlier than 2001-12-17 | T2 | 880h | 880h | MEXE5-ENHANC | Motorola | Mark Cataldo | Rel-5 | Kimmo | 22.057, 23.057 |
| 2828 | 86 | **Wideband Telephony Service - AMR** | 1036d | 2000-01-01 A | 2003-12-19 A |  | 100% | 2000-01-01 | 2003-12-19 | 1036d |  | S4 | 75408h | 75408h | AMRWB | Siemens | Imre.Varga@mch.siemens.de | Rel-5 | Paolo |  |
| 2829 | 86.1 | **Specification** | 636d | 2000-01-01 A | 2002-06-07 A |  | 100% | 2000-01-01 | 2002-06-07 | 636d |  | S4 | 19984h | 19984h |  |  |  | Rel-5 | Paolo |  |
| 2830 | 86.1.1 | Stage 1 for Wideband Telephony Service - AMR | 125d | 2001-10-01 A | 2002-03-22 A |  | 100% | 2001-10-01 | 2002-03-22 | 125d | finish no earlier than 2002-03-22 | S1 | 1000h | 1000h |  |  |  | Rel-5 | Alain |  |
| 2831 | 86.1.2 | **Stage 2 for Wideband Telephony Service - AMR** | 77d | 2000-01-03 A | 2000-04-17 A |  | 100% | 2000-01-03 | 2000-04-17 | 77d |  | S4 | 1232h | 1232h |  |  |  | Rel-5 | Paolo |  |
| 2832 | 86.1.2.1 | Design Constraints for Wideband Telephony Service - AMR | 27d | 2000-01-03 A | 2000-02-07 A |  | 100% | 2000-01-03 | 2000-02-07 | 27d |  | S4 | 208h | 208h |  |  |  | Rel-5 | Paolo |  |
| 2833 | 86.1.2.2 | General Description for Wideband Telephony Service - AMR | 51d | 2000-02-07 A | 2000-04-17 A | 2832 | 100% | 2000-02-07 | 2000-04-17 | 51d | start no earlier than 2000-09-25 | S4 | 408h | 408h |  |  |  | Rel-5 | Paolo |  |
| 2834 | 86.1.3 | Feasibility Study for Wideband Telephony Service - AMR | 26d | 2000-04-28 A | 2000-06-02 A | 2833 | 100% | 2000-04-28 | 2000-06-02 | 26d | finish no earlier than 2000-06-02 | S4 | 208h | 208h |  |  |  | Rel-5 | Paolo | 26.901 |
| 2835 | 86.1.4 | N1 Aspects for Wideband Telephony Service - AMR | 66d | 2001-09-21 A | 2001-12-21 A |  | 100% | 2001-09-21 | 2001-12-21 | 66d | finish no earlier than 2001-12-21 | N1 | 528h | 528h |  |  |  | Rel-5 | Frederic |  |
| 2836 | 86.1.5 | N4 work for Wideband Telephony Service - AMR | 83d | 2002-02-13 A | 2002-06-07 A |  | 100% | 2002-02-13 | 2002-06-07 | 83d | finish no earlier than 2002-06-07 | N4 | 664h | 664h |  |  |  | Rel-5 | Kimmo |  |

Notes:
- 2812: -
- 2813: -
- 2814: -
- 2815: -
- 2816: -
- 2817: -
- 2818: -
- 2819: -
- 2820: -
- 2821: Added on May 29, 2001
- 2822: -
- 2823: -
- 2824: -
- 2825: stage2 and stage3 CRs for approval at CN#17
- 2826: -
- 2827: -
- 2828: -
- 2829: -
- 2830: -
- 2831: -
- 2832: -
- 2833: -
- 2834: S4,TD SP-000024: TR 26.901 v.4.0.0
- 2835: Some of N1 tasks: Indication of supported codecs by the MS, Bearer cap negociation, codec indication to MS... / One common set of codec negotiation procedures will be specified as in ID1657.
- 2836: CN4#11 30/11/01: No inputs to CN4 at this meeting / 14/02/02 work started 50% reached / 17 May work is done 100%

| ID | WBS | Task | Duration | Start | Finish | Predecessors | Complete | Baseline start | Baseline finish | Baseline duration | Constraint | Resources | Work | Actual work | Text6 | Text8 | Text1 | Text3 | Text12 | Text4 | Text5 |
| --- | --- | --- | --- | --- | --- | --- | --- | --- | --- | --- | --- | --- | --- | --- | --- | --- | --- | --- | --- | --- | --- |
| 2837 | 86.1.6 | **Codec issues** | 636d | 2000-01-03 A | 2002-06-07 A |  | 100% | 2000-01-03 | 2002-06-07 | 636d |  | S4 | 9496h | 9496h | Rel-5 | Paolo |  |  |  |  |  |
| 2838 | 86.1.6.1 | Codec qualification | 86d | 2000-02-02 A | 2000-05-31 A |  | 100% | 2000-02-02 | 2000-05-31 | 86d | finish no earlier than 2000-05-31 | S4 | 688h | 688h | Rel-5 | Paolo |  |  |  |  |  |
| 2839 | 86.1.6.2 | Codec selection tests | 102d | 2000-06-01 A | 2000-10-20 A | 2838 | 100% | 2000-06-01 | 2000-10-20 | 102d | finish no earlier than 2000-10-20 | S4 | 816h | 816h | Rel-5 | Paolo |  |  |  |  |  |
| 2840 | 86.1.6.3 | Codec selection | 5d | 2000-10-23 A | 2000-10-27 A | 2839 | 100% | 2000-10-23 | 2000-10-27 | 5d | finish no earlier than 2000-10-27 | S4 | 40h | 40h | Rel-5 | Paolo |  |  |  |  |  |
| 2841 | 86.1.6.4 | TFO AMR-WB | 63d | 2001-12-18 A | 2002-03-14 A |  | 100% | 2001-12-18 | 2002-03-14 | 63d | finish no earlier than 2002-03-14 | S4 | 504h | 504h | Rel-5 | Paolo | AMRWB-TFO |  |  |  |  |
| 2842 | 86.1.6.5 | Other codec issues (verif., characterization) | 441d | 2000-09-29 A | 2002-06-07 A |  | 100% | 2000-09-29 | 2002-06-07 | 441d | finish no earlier than 2002-06-07 | S4 | 3528h | 3528h | Rel-5 | Paolo |  | 26.976 |  |  |  |
| 2843 | 86.1.6.6 | AMR-WB and narrrowband interworking | 121d | 2001-09-27 A | 2002-03-14 A |  | 100% | 2001-09-27 | 2002-03-14 | 121d | finish no earlier than 2002-03-14 | S4 | 968h | 968h | Rel-5 | Paolo | AMRWB-IWG |  |  |  |  |
| 2844 | 86.1.6.7 | Interworking with fixed broadband networks | 121d | 2001-09-27 A | 2002-03-14 A |  | 100% | 2001-09-27 | 2002-03-14 | 121d | finish no earlier than 2002-03-14 | S4 | 968h | 968h | Rel-5 | Paolo |  |  |  |  |  |
| 2845 | 86.1.6.8 | Tones and announcements | 121d | 2001-09-27 A | 2002-03-14 A |  | 100% | 2001-09-27 | 2002-03-14 | 121d | finish no earlier than 2002-03-14 | S4 | 968h | 968h | Rel-5 | Paolo |  |  |  |  |  |
| 2846 | 86.1.6.9 | Deleted - WB Conferencing and WB Voice Group calls | 1d | 2000-01-03 A | 2000-01-03 A |  | 100% | 2000-01-03 | 2000-01-03 | 1d | finish no earlier than 2000-01-03 | S1 | 8h | 8h | Rel-5 | Alain |  |  | SP-07 |  |  |
| 2847 | 86.1.8 | **Conformance tests (CRs to 34 series)** | 74d | 2000-01-01 A | 2000-04-12 A |  | 100% | 2000-01-01 | 2000-04-12 | 74d |  | T1 | 1768h | 1768h | Rel-5 | Ingbert |  |  |  |  |  |
| 2848 | 86.1.8.1 | **Terminal Acoustic Characteristics** | 74d | 2000-01-01 A | 2000-04-12 A |  | 100% | 2000-01-01 | 2000-04-12 | 74d |  | S4 | 1176h | 1176h | Rel-5 | Paolo |  |  |  |  |  |
| 2849 | 86.1.8.1.1 | Definition for Terminal Acoustic Characteristics | 22d | 2000-01-01 A | 2000-01-31 A |  | 100% | 2000-01-01 | 2000-01-31 | 22d | finish no earlier than 2000-01-28 | S4 | 168h | 168h | Rel-5 | Paolo |  | 26.131 |  |  |  |
| 2850 | 86.1.8.1.2 | Test specification for Terminal Acoustic Characteristics | 52d | 2000-02-01 A | 2000-04-12 A | 2849 | 100% | 2000-02-01 | 2000-04-12 | 52d | finish no earlier than 2000-03-13 | S4 | 416h | 416h | Rel-5 | Paolo |  | 26.132 |  |  |  |
| 2851 | 86.2 | Floating-point ANSI-C code for the AMR-WB speech codec | 123d | 2001-09-25 A | 2002-03-14 A |  | 100% | 2001-09-25 | 2002-03-14 | 123d | finish no earlier than 2002-03-14 | S4 | 984h | 984h | Rel-5 | Paolo | AMRWB-FP | 26.204 |  | Nokia | janne.m.vainio@nokia.com |
| 2852 | 86.3 | **Support of AMR-WB in GERAN: GMSK and 8PSK WB FR / HR** | 651d | 2000-01-03 A | 2002-06-28 A |  | 100% | 2000-01-03 | 2002-06-28 | 651d |  | GP | 23488h | 23488h | Rel-5 | Paolo | GAMRWB |  |  |  |  |
| 2853 | 86.3.1 | Channel coding in 45.003 for Support of AMR-WB in GERAN: GMSK and 8PSK WB FR / HR | 591d | 2000-01-03 A | 2002-04-05 A |  | 100% | 2000-01-03 | 2002-04-05 | 591d |  | GP | 4720h | 4720h | Rel-5 | Paolo |  |  |  |  |  |
| 2854 | 86.3.2 | Signalling for the A interface | 391d | 2000-01-03 A | 2001-06-29 A |  | 100% | 2000-01-03 | 2001-06-29 | 391d | finish no earlier than 2001-06-29 | GP | 3120h | 3120h | Rel-5 | Paolo |  |  |  |  |  |
| 2855 | 86.3.3 | Signalling for Iu | 651d | 2000-01-03 A | 2002-06-28 A |  | 100% | 2000-01-03 | 2002-06-28 | 651d | finish no earlier than 2002-06-28 | GP | 5200h | 5200h | Rel-5 | Paolo |  |  |  |  |  |
| 2856 | 86.3.4 | Receiver performance in TS 45.005 | 325d | 2001-04-02 A | 2002-06-28 A |  | 100% | 2001-04-02 | 2002-06-28 | 325d | finish no earlier than 2002-06-28 | GP | 2600h | 2600h | Rel-5 | Paolo |  |  |  |  |  |
| 2857 | 86.3.5 | Link Adaptation in 45.009 | 330d | 2001-03-26 A | 2002-06-28 A |  | 100% | 2001-03-26 | 2002-06-28 | 330d | finish no earlier than 2002-06-28 | GP | 2640h | 2640h | Rel-5 | Paolo |  |  |  |  |  |
| 2858 | 86.4 | **Deleted - GERAN MS conformance test for AMR-WB** | 1036d | 2000-01-03 A | 2003-12-19 A |  | 100% | 2000-01-03 | 2003-12-19 | 1036d |  | GP | 16568h | 16568h | Rel-5 | Paolo |  |  |  |  |  |
| 2859 | 86.4.1 | Deleted - MS test for AMR-WB | 1036d | 2000-01-03 A | 2003-12-19 A |  | 100% | 2000-01-03 | 2003-12-19 | 1036d | finish no earlier than 2003-12-19 | GP | 8280h | 8280h | Rel-5 | Paolo |  |  | GP-17 |  |  |
| 2860 | 86.5 | GERAN BTS conformance test for AMR-WB | 762d | 2000-01-03 A | 2002-12-02 A |  | 100% | 2000-01-03 | 2002-12-02 | 762d |  | GP | 6096h | 6096h | Rel-5 | Paolo |  |  |  |  |  |

Notes:
- 2837: -
- 2838: -
- 2839: -
- 2840: -
- 2841: -
- 2842: ANSI C-Code , Test Sequences, Speech Transcoding Functions, Error Concealment of lost frames, Source Controlled Bit-Rate Operation, Voice Activity Detector, Frame Structure
- 2843: -
- 2844: -
- 2845: -
- 2846: -
- 2847: -
- 2848: -
- 2849: -
- 2850: -
- 2851: -
- 2852: -
- 2853: 50098 -> 50298
- 2854: -
- 2855: -
- 2856: -
- 2857: -
- 2858: Not started 02/2003. Marked as stopped 12/2008
- 2859: Marked as stopped 12/2008
- 2860: -

| ID | WBS | Task | Duration | Start | Finish | Complete | Baseline start | Baseline finish | Baseline duration | Constraint | Resources | Work | Actual work | Text1 | Text6 | Text8 | Text4 | Text5 |
| --- | --- | --- | --- | --- | --- | --- | --- | --- | --- | --- | --- | --- | --- | --- | --- | --- | --- | --- |
| 2861 | 11 | **Rel-5 Terminal interfaces** | 223d | 2001-05-14 A | 2002-03-20 A | 100% | 2001-05-14 | 2002-03-20 | 223d |  | T2 | 3568h | 3568h | TI | Rel-5 | Kimmo |  |  |
| 2862 | 87 | Terminal local model enhancements | 223d | 2001-05-14 A | 2002-03-20 A | 100% | 2001-05-14 | 2002-03-20 | 223d | finish no earlier than 2002-03-20 | T2 | 1784h | 1784h | TLM5 | Rel-5 |  |  |  |
| 2863 | 88 | **Rel-5 Location Services enhancements** | 845d | 2000-04-03 A | 2003-06-27 A | 100% | 2000-04-03 | 2003-06-27 | 845d |  | S2,S1,S3,S5,N4,R2,R3,GP | 87364h | 87364h | LCS1 | Rel-5 | Maurice | Nokia | Jan Kall |
| 2864 | 88.1 | **UE positioning for Rel-5 Location Services enhancements** | 315d | 2001-01-15 A | 2002-03-29 A | 100% | 2001-01-15 | 2002-03-29 | 315d |  | R2 | 6120h | 6120h | LCS1-UEpos | Rel-5 | Issam |  |  |
| 2865 | 88.1.1 | UE positioning enhancements for 1.28 Mcps TDD | 255d | 2001-04-09 A | 2002-03-29 A | 100% | 2001-04-09 | 2002-03-29 | 255d | finish no earlier than 2002-03-29 | R2 | 2040h | 2040h | LCS-128Pos | Rel-5 | Joern | CATT | Xiaohua Mei |
| 2866 | 88.1.2 | Open SMLC-SRNC Interface within the UTRAN to support A-GPS Positioning | 195d | 2001-01-15 A | 2001-10-12 A | 100% | 2001-01-15 | 2001-10-12 | 195d |  | R2 | 1560h | 1560h | LCS-INTF | Rel-5 | Joern | Qualcomm | Kirk Burroughs |
| 2867 | 88.2 | **Event Based and Periodic LCS** | 535d | 2000-05-22 A | 2002-06-07 A | 100% | 2000-05-22 | 2002-06-07 | 535d |  | S1,S2,N4 | 6288h | 6288h | LCS1-EBP | Rel-5 | Alain | Pacific Bell Wireless | Randolph Wohlert (rwohlert@tri.sbc.com) |
| 2868 | 88.2.1 | Stage 1 for Event based and Periodic LCS | 130d | 2000-05-22 A | 2000-11-17 A | 100% | 2000-05-22 | 2000-11-17 | 130d | finish no earlier than 2000-07-21 | S1 | 1040h | 1040h | LCS1-EBP | Rel-5 | Alain | Pacific Bell Wireless | Randolph Wohlert (rwohlert@tri.sbc.com) |
| 2869 | 88.2.2 | Stage 2 for Event based and Periodic LCS | 60d | 2000-11-06 A | 2001-01-26 A | 100% | 2000-11-06 | 2001-01-26 | 60d | finish no earlier than 2001-01-26 | S2 | 480h | 480h | LCS1-EBP | Rel-5 | Maurice |  |  |
| 2870 | 88.2.3 | Impact on MAP | 61d | 2002-03-15 A | 2002-06-07 A | 100% | 2002-03-15 | 2002-06-07 | 61d | finish no earlier than 2002-06-07 | N4 | 488h | 488h | LCS1-EBP | Rel-5 | Kimmo |  |  |
| 2871 | 88.3 | **Location Services for GERAN in A/Gb Mode** | 485d | 2000-04-03 A | 2002-02-08 A | 100% | 2000-04-03 | 2002-02-08 | 485d |  | GP | 14760h | 14760h | LCS-GERAN | Rel-5 | Paolo | Nokia | Margaret Livingston |
| 2872 | 88.3.1 | GERAN LCS Stage 2 (first release) | 485d | 2000-04-03 A | 2002-02-08 A | 100% | 2000-04-03 | 2002-02-08 | 485d | finish no earlier than 2002-02-08 | GP,S2,G1,G2 | 3880h | 3880h | LCS-GERAN | Rel-5 | Paolo | Nokia | Margaret Livingston |
| 2873 | 88.3.2 | Gb interface support for LCS | 370d | 2000-04-03 A | 2001-08-31 A | 100% | 2000-04-03 | 2001-08-31 | 370d | finish no earlier than 2001-08-31 | GP | 2960h | 2960h | LCS-GERAN | Rel-5 | Paolo | Nokia | Margaret Livingston |
| 2874 | 88.3.3 | L3 protocol support for LCS | 305d | 2000-04-03 A | 2001-06-01 A | 100% | 2000-04-03 | 2001-06-01 | 305d | finish no earlier than 2001-06-01 | GP | 2440h | 2440h | LCS-GERAN | Rel-5 | Paolo | Nokia | Margaret Livingston |
| 2875 | 88.3.4 | Stage 3 for Location Services for GERAN in A/Gb Mode | 305d | 2000-04-03 A | 2001-06-01 A | 100% | 2000-04-03 | 2001-06-01 | 305d | finish no earlier than 2001-06-01 | GP | 2440h | 2440h | LCS-GERAN | Rel-5 | Paolo | Nokia | Margaret Livingston |
| 2876 | 88.4 | **Location Services for GERAN in Iu Mode** | 585d | 2000-04-03 A | 2002-06-28 A | 100% | 2000-04-03 | 2002-06-28 | 585d |  | S2,G1,G2,R2,R3 | 20996h | 20996h | LCS-GERAN | Rel-5 | Paolo | Nokia | Margaret Livingston |
| 2877 | 88.4.1 | GERAN LCS Stage 2 | 585d | 2000-04-03 A | 2002-06-28 A | 100% | 2000-04-03 | 2002-06-28 | 585d | finish no earlier than 2002-06-28 | S2,G1,G2 | 4680h | 4680h | LCS-GERAN | Rel-5 | Paolo | Nokia | Margaret Livingston |
| 2878 | 88.4.2 | Iu-ps interface support for LCS | 585d | 2000-04-03 A | 2002-06-28 A | 100% | 2000-04-03 | 2002-06-28 | 585d | finish no earlier than 2002-06-28 | R2,R3 | 4680h | 4680h | LCS-GERAN | Rel-5 | Paolo | Nokia | Margaret Livingston |
| 2879 | 88.4.3 | Iu-cs interface support for LCS | 585d | 2000-04-03 A | 2002-06-28 A | 100% | 2000-04-03 | 2002-06-28 | 585d | finish no earlier than 2002-06-28 | R2,R3 | 4680h | 4680h | LCS-GERAN | Rel-5 | Paolo | Nokia | Margaret Livingston |
| 2880 | 88.4.4 | Iur-g interface support for LCS | 62.5d | 2002-01-23 A | 2002-04-19 A | 100% | 2002-01-23 | 2002-04-19 | 62.5d | finish no earlier than 2002-04-19 | G1,G2 | 500h | 500h | LCS-GERAN | Rel-5 | Paolo | Nokia | Margaret Livingston |
| 2881 | 88.4.5 | RRC protocol support for LCS | 75d | 2001-08-20 A | 2001-11-30 A | 100% | 2001-08-20 | 2001-11-30 | 75d | finish no earlier than 2001-11-30 | G1,G2,R2,R3 | 600h | 600h | LCS-GERAN | Rel-5 | Paolo | Nokia | Margaret Livingston |
| 2882 | 88.4.6 | Additional impacts on Broadcast of LCS data on packet channels | 77.5d | 2001-08-20 A | 2001-12-05 A | 100% | 2001-08-20 | 2001-12-05 | 77.5d | finish no earlier than 2001-12-05 | G1,G2,R2,R3 | 620h | 620h | LCS-GERAN | Rel-5 | Paolo | Nokia | Margaret Livingston |
| 2883 | 88.4.7 | Stage 3 for Location Services for GERAN in Iu Mode | 69.5d | 2002-03-25 A | 2002-06-28 A | 100% | 2002-03-25 | 2002-06-28 | 69.5d | finish no earlier than 2002-06-28 | G1,G2,R2,R3 | 556h | 556h | LCS-GERAN | Rel-5 | Paolo | Nokia | Margaret Livingston |
| 2884 | 88.5 | **GERAN MS Conformance test for LCS** | 280d | 2002-06-03 A | 2003-06-27 A | 100% | 2002-06-03 | 2003-06-27 | 280d |  | GP | 6720h | 6720h | LCS-GERAN-MSconf | Rel-5 | Paolo |  |  |
| 2885 | 88.5.1 | LCS MS test case work plan (Release 98/99/4) | 280d | 2002-06-03 A | 2003-06-27 A | 100% | 2002-06-03 | 2003-06-27 | 280d | finish no earlier than 2003-06-27 | G4,G5 | 2240h | 2240h | LCS-GERAN-MSconf | Rel-5 | Paolo |  |  |
| 2886 | 88.5.2 | LCS MS test cases | 280d | 2002-06-03 A | 2003-06-27 A | 100% | 2002-06-03 | 2003-06-27 | 280d | finish no earlier than 2003-06-27 | G4,G5 | 2240h | 2240h | LCS-GERAN-MSconf | Rel-5 | Paolo |  |  |

Notes:
- 2861: -
- 2862: - / Text3: 23.227
- 2863: -
- 2864: -
- 2865: - / Text3: 25.123, 25.224, 25.225, 25.302, 25.303, 25.304, 25.305, 25.331, 25.420, 25.423, 25.430, 25.433, new TR 25.859
- 2866: RP#13 completed
- 2867: -
- 2868: Evaluate Event based and Periodic LCS to be included in R00, corresponding Stage 1 description / Text3: 22.071
- 2869: Marked as closed 12/2008 (was marked 51% complete)
- 2870: Possible impact on UTRAN of LCS quality level request / 17 May No stage 2 for event-based & periodic LCS. Work 100% completefor current stage 2
- 2871: -
- 2872: -
- 2873: -
- 2874: -
- 2875: -
- 2876: -
- 2877: -
- 2878: -
- 2879: -
- 2880: FFS
- 2881: -
- 2882: -
- 2883: -
- 2884: -
- 2885: Marked as closed 12/2008 (was marked 60% complete)
- 2886: Marked as closed 12/2008 (was marked 60% complete)

| ID | WBS | Task | Duration | Start | Finish | Predecessors | Complete | Baseline start | Baseline finish | Baseline duration | Constraint | Resources | Work | Actual work | Text1 | Text6 | Text8 | Text12 | Text3 | Text4 | Text5 |
| --- | --- | --- | --- | --- | --- | --- | --- | --- | --- | --- | --- | --- | --- | --- | --- | --- | --- | --- | --- | --- | --- |
| 2887 | 88.6 | **Deleted - GERAN BTS Conformance test for LCS** | 280d | 2002-06-03 A | 2003-06-27 A |  | 100% | 2002-06-03 | 2003-06-27 | 280d |  | GP | 6720h | 6720h | LCS-GERAN-BTSconf | Rel-5 | Paolo | GP-15 |  |  |  |
| 2888 | 88.6.1 | Deleted - LCS BTS test case work plan (Release 98/99/4) | 280d | 2002-06-03 A | 2003-06-27 A |  | 100% | 2002-06-03 | 2003-06-27 | 280d | finish no earlier than 2003-06-27 | G4,G5 | 2240h | 2240h |  | Rel-5 | Paolo | GP-15 |  |  |  |
| 2889 | 88.6.2 | Deleted - LCS BTS test cases | 280d | 2002-06-03 A | 2003-06-27 A |  | 100% | 2002-06-03 | 2003-06-27 | 280d | finish no earlier than 2003-06-27 | G4,G5 | 2240h | 2240h |  | Rel-5 | Paolo | GP-15 |  |  |  |
| 2890 | 88.7 | LCS interoperation stage 2 aspects | 480d | 2000-08-28 A | 2002-06-28 A |  | 100% | 2000-08-28 | 2002-06-28 | 480d |  | S2 | 3840h | 3840h |  | Rel-5 | Maurice |  |  |  |  |
| 2891 | 88.8 | **LCS interoperability aspects to GERAN** | 480d | 2000-08-28 A | 2002-06-28 A |  | 100% | 2000-08-28 | 2002-06-28 | 480d |  | GP,S5 | 7680h | 7680h | LCS-GERAN | Rel-5 | Paolo |  |  |  |  |
| 2892 | 88.8.1 | Co-ordinated development of GSM LCS Phase 2 and UMTS LCS, S2 and GERAN | 480d | 2000-08-28 A | 2002-06-28 A |  | 100% | 2000-08-28 | 2002-06-28 | 480d | finish no earlier than 2002-06-28 | GP,S2,S5,R2,R3,G2,G1 | 3840h | 3840h | LCS-GERAN | Rel-5 | Paolo |  |  |  |  |
| 2893 | 88.9 | FS on LCS support in the IMS | 90d | 2001-02-12 A | 2002-01-18 A |  | 100% | 2001-02-12 | 2002-01-18 | 90d | start no earlier than 2001-02-12 | S1 | 720h | 720h |  | Rel-5 | Alain |  |  |  |  |
| 2894 | 88.10 | Charging and OAM&P for LCS enhancements | 201d | 2001-09-21 A | 2002-06-28 A |  | 100% | 2001-09-21 | 2002-06-28 | 201d | finish no earlier than 2002-06-28 | S5 | 1608h | 1608h | LCS1-OAM | Rel-5 | Dionisio |  | 32.200-series |  |  |
| 2895 | 88.11 | New security aspects of LCS | 446d | 2000-04-14 A | 2001-12-28 A |  | 100% | 2000-04-14 | 2001-12-28 | 446d | finish no earlier than 2001-12-28 | S3,S2 | 3568h | 3568h | LCS1-SEC | Rel-5 | Dionisio |  | 23.271, 43.059 | Nokia | valtteri.niemi@nokia.com |
| 2896 | 88.12 | Specification for the Le interface | 45d | 2002-01-14 A | 2002-03-15 A |  | 100% | 2002-01-14 | 2002-03-15 | 45d | start no earlier than 2002-01-14 | S2 | 360h | 360h | LCS1-Le | Rel-5 | Maurice |  |  |  |  |
| 2897 | 88.13 | Deleted - CHECK STATUS - Inter-GMLC interface | 153d | 2002-05-30 A | 2002-12-30 A |  | 100% | 2002-05-30 | 2002-12-30 | 153d | finish no earlier than 2002-12-30 | S2 | 1224h | 1224h |  | Rel-5 | Maurice | SP-10 |  |  |  |
| 2898 | 89 | **Rel-5 Security enhancements** | 615d | 2000-02-21 A | 2002-06-28 A |  | 100% | 2000-02-21 | 2002-06-28 | 615d |  | S3 | 29974.9h | 29974.9h |  | Rel-5 | Dionisio |  |  | Vodafone | Peter.Howard@vodafone.com |
| 2899 | 89.1 | **Rel-5 Network Domain Security** | 615d | 2000-02-21 A | 2002-06-28 A |  | 100% | 2000-02-21 | 2002-06-28 | 615d |  | S3 | 25054.9h | 25054.9h | SEC1-NDS | Rel-5 | Dionisio |  | new 33.200 (exists also for Rel-4) | Telenor | Geir-myrdahl.koien@telenor.com |
| 2900 | 89.1.3 | Rel-5 IP network layer security (NDS/IP) | 457d | 2000-06-15 A | 2002-03-15 A |  | 100% | 2000-06-15 | 2002-03-15 | 457d | finish no earlier than 2002-03-15 | S3 | 3656h | 3656h | SEC1-NDS-IP | Rel-5 | Dionisio |  | new 33.210 | Telenor | Geir-myrdahl.koien@telenor.com |
| 2901 | 89.1.1 | **Deleted - Control plane protection in core network (e.g., GTP, CAP, MAP/IP, provided by IPsec)** | 541d | 2000-05-12 A | 2002-06-07 A |  | 100% | 2000-05-12 | 2002-06-07 | 541d |  | S3 | 7118.9h | 7118.9h |  | Rel-5 | Dionisio | SP-16 |  |  |  |
| 2902 | 89.1.1.1 | Deleted - Main aspects of User plane protection in core network (e.g., provided by IPsec) | 290d | 2000-05-12 A | 2001-06-21 A |  | 100% | 2000-05-12 | 2001-06-21 | 290d | finish no earlier than 2001-06-21 | S3 | 2320h | 2320h |  | Rel-5 | Dionisio | SP-12 |  |  |  |
| 2903 | 89.1.1.2 | Deleted - Integration of GTP signalling security architecture - for User plane protection in core network (e.g., provided by IPsec) | 191d | 2001-09-14 A | 2002-06-07 A |  | 100% | 2001-09-14 | 2002-06-07 | 191d | finish no earlier than 2002-06-07 | N4 | 1528h | 1528h |  | Rel-5 | Kimmo | NP-16 |  |  |  |
| 2904 | 89.1.2 | **Deleted - User plane protection in core network (e.g., provided by IPsec)** | 615d | 2000-02-21 A | 2002-06-28 A |  | 100% | 2000-02-21 | 2002-06-28 | 615d |  | S3 | 9360h | 9360h |  | Rel-5 | Dionisio | SP-16 |  |  |  |
| 2905 | 89.1.2.1 | Deleted -Main aspects of User plane protection in core network (e.g., provided by IPsec) | 349d | 2000-02-21 A | 2001-06-21 A |  | 100% | 2000-02-21 | 2001-06-21 | 349d | finish no earlier than 2001-06-21 | S3 | 2792h | 2792h |  | Rel-5 | Dionisio | SP-12 |  |  |  |
| 2906 | 89.1.2.2 | Deleted - Integration of GTP signalling security architecture - for User plane protection in core network (e.g., provided by IPsec) | 206d | 2001-09-14 A | 2002-06-28 A |  | 100% | 2001-09-14 | 2002-06-28 | 206d | finish no earlier than 2002-06-28 | N4 | 1648h | 1648h |  | Rel-5 | Kimmo | NP-16 |  |  |  |
| 2907 | 90 | **Intra Domain Connection of RAN Nodes to Multiple CN Nodes** | 455d | 2000-10-02 A | 2002-06-28 A |  | 100% | 2000-10-02 | 2002-06-28 | 455d |  | S2,N1,N4,R3,GP | 15672h | 15672h | IUFLEX | Rel-5 | Alain |  | 23.236 | Ericsson | stephen.terrill@ericsson.com |
| 2908 | 90.1 | Overall System Architecture for Intra Domain Connection of RAN Nodes to Multiple CN Nodes | 188d | 2001-01-03 A | 2001-09-21 A |  | 100% | 2001-01-03 | 2001-09-21 | 188d | finish no earlier than 2001-06-01 | S2 | 1504h | 1504h |  | Rel-5 | Maurice |  |  |  |  |
| 2909 | 90.2 | Stage 3: RAN node selecting CN node | 130d | 2001-09-24 A | 2002-03-22 A | 2908 | 100% | 2001-09-24 | 2002-03-22 | 130d | finish no earlier than 2002-03-22 | R3 | 1040h | 1040h |  | Rel-5 | Juha |  |  | Vodafone | Brendan.McWilliams@gb.vodafone.co.uk |
| 2910 | 90.3 | N1 work for Intra Domain Connection of RAN Nodes to Multiple CN Nodes | 205d | 2001-09-17 A | 2002-06-28 A |  | 100% | 2001-09-17 | 2002-06-28 | 205d | start no earlier than 2001-09-17 | N1 | 1640h | 1640h |  | Rel-5 | Frederic |  | 24.008 and check 29.018 |  |  |
| 2911 | 90.4 | N4 work for Intra Domain Connection of RAN Nodes to Multiple CN Nodes | 375d | 2000-10-02 A | 2002-03-08 A |  | 100% | 2000-10-02 | 2002-03-08 | 375d | finish no earlier than 2002-03-15 | N4 | 3000h | 3000h |  | Rel-5 | Kimmo |  |  |  |  |

Notes:
- 2887: Not started 02/3003. Marked as stopped 12/2008
- 2888: Marked as stopped 12/2008
- 2889: Marked as stopped 12/2008
- 2890: Marked as closed 12/2008 (was marked 17% complete)
- 2891: -
- 2892: -
- 2893: Marked as closed 12/2008 (was marked 75% complete)
- 2894: -
- 2895: SP#9 updated WID S3-000609 (Location services security)
- 2896: -
- 2897: Marked as stopped 12/2008
- 2898: Added BB UE authentication and rapporteur added. TO BE DELETED
- 2899: SP#9 approved WID SP-000420 (S3-000606 Network domain security). S3#17: All due in Rel5. (WI Update at S3#18). Replaced by NDS-IP and NDS-MAP. TO BE DELETED OR MOVED TO HISTORY FILE
- 2900: SP#12 WID updated SP-000420 (S3-000606) =>SP-010326 (S3-010286)
- 2901: Marked as stopped 12/2008
- 2902: TO BE DELETED. Marked as stopped 12/2008
- 2903: Waiting for input from SA3!.... Marked as stopped 12/2008
- 2904: TO BE DELETED. Marked as stopped 12/2008
- 2905: -
- 2906: 14/02/2002 requirements are not clear/not received...Marked as closed 12/2008 (was marked 95 complete)
- 2907: No clear indication on the end date. Put to Rel5 by AS.
- 2908: -
- 2909: Not identified
- 2910: -
- 2911: DAB 12.12.01 - % complete to 66% / 14/02/02 Work completed

| ID | WBS | Task | Duration | Start | Finish | Complete | Baseline start | Baseline finish | Baseline duration | Constraint | Resources | Work | Actual work | Text1 | Text4 | Text5 | Text6 | Text8 | Text12 | Text3 |
| --- | --- | --- | --- | --- | --- | --- | --- | --- | --- | --- | --- | --- | --- | --- | --- | --- | --- | --- | --- | --- |
| 2912 | 90.5 | **GERAN work for Intra Domain Connection of RAN Nodes to Multiple CN Nodes** | 101d | 2002-02-08 A | 2002-06-28 A | 100% | 2002-02-08 | 2002-06-28 | 101d |  | GP | 4848h | 4848h | IDCRAN-GERAN | Ericsson | ingemar.backlund@era.ericsson.se | Rel-5 | Paolo |  |  |
| 2913 | 90.5.1 | Stage 2 (changes to ) | 101d | 2002-02-08 A | 2002-06-28 A | 100% | 2002-02-08 | 2002-06-28 | 101d | finish no earlier than 2002-06-28 | G1 | 808h | 808h |  |  |  | Rel-5 | Paolo |  |  |
| 2914 | 90.5.2 | 43.051 Introduction of support for IDNNS in GERAN Iu mode | 101d | 2002-02-08 A | 2002-06-28 A | 100% | 2002-02-08 | 2002-06-28 | 101d | finish no earlier than 2002-06-28 | G1 | 808h | 808h |  |  |  | Rel-5 | Paolo |  |  |
| 2915 | 90.5.3 | Stage 3 (changes to ) | 101d | 2002-02-08 A | 2002-06-28 A | 100% | 2002-02-08 | 2002-06-28 | 101d | finish no earlier than 2002-06-28 | G2 | 808h | 808h |  |  |  | Rel-5 | Gert |  |  |
| 2916 | 90.5.4 | 48.016 Use of Gb interface concepts when a network applies IDNNS | 101d | 2002-02-08 A | 2002-06-28 A | 100% | 2002-02-08 | 2002-06-28 | 101d | finish no earlier than 2002-06-28 | G2 | 808h | 808h |  |  |  | Rel-5 | Gert |  |  |
| 2917 | 90.5.5 | 48.018 Include MSC/VLR identity in CS IMSI paging | 101d | 2002-02-08 A | 2002-06-28 A | 100% | 2002-02-08 | 2002-06-28 | 101d | finish no earlier than 2002-06-28 | G2 | 808h | 808h |  |  |  | Rel-5 | Gert |  |  |
| 2918 | 91 | **Deleted - GERAN improvements 3 (new transport layer on interface A)** | 446d | 2001-04-06 A | 2002-12-20 A | 100% | 2001-04-06 | 2002-12-20 | 446d |  | GP | 14272h | 14272h | GEIMP3 |  |  | Rel-5 | Paolo |  |  |
| 2919 | 91.1 | **Deleted - Evolution of the transport for A** | 446d | 2001-04-06 A | 2002-12-20 A | 100% | 2001-04-06 | 2002-12-20 | 446d |  | GP | 10704h | 10704h | GEIMP3-EtA |  |  | Rel-5 | Paolo | GP-12 |  |
| 2920 | 91.1.1 | Deleted - Definition of a new A/Ater interface Transport Layer option based on the Iu Interface Transport Layer | 446d | 2001-04-06 A | 2002-12-20 A | 100% | 2001-04-06 | 2002-12-20 | 446d | finish no earlier than 2002-12-20 | GP | 3568h | 3568h |  |  |  | Rel-5 | Paolo | GP-12 |  |
| 2921 | 91.1.2 | Deleted - Adaptation of the Layer 3 BSSMAP procedures as required | 446d | 2001-04-06 A | 2002-12-20 A | 100% | 2001-04-06 | 2002-12-20 | 446d | finish no earlier than 2002-12-20 | GP | 3568h | 3568h |  |  |  | Rel-5 | Paolo | GP-12 |  |
| 2922 | 92 | **Rel-5 Charging Management & Operations, Administration, Maintenance and Provisioning (OAM&P)** | 264d | 2001-09-10 A | 2002-09-12 A | 100% | 2001-09-10 | 2002-09-12 | 264d |  | S5 | 9976h | 9976h | OAM |  |  | Rel-5 | Dionisio |  |  |
| 2923 | 92.1 | Rel-5 Principles, high level Requirements and Architecture | 205d | 2001-09-17 A | 2002-06-28 A | 100% | 2001-09-17 | 2002-06-28 | 205d | finish no earlier than 2002-06-28 | S5 | 1640h | 1640h | OAM-AR/PR | Motorola |  | Rel-5 | Dionisio |  | 32.101, 32.102 |
| 2924 | 92.2 | Rel-5 Performance Management | 259d | 2001-09-17 A | 2002-09-12 A | 100% | 2001-09-17 | 2002-09-12 | 259d | finish no earlier than 2002-09-12 | S5 | 2072h | 2072h | OAM-PM | Nortel |  | Rel-5 | Dionisio |  | 32.4xy, 52.402 |
| 2925 | 92.3 | Rel-5 Charging Management | 264d | 2001-09-10 A | 2002-09-12 A | 100% | 2001-09-10 | 2002-09-12 | 264d | finish no earlier than 2002-09-12 | S5 | 2112h | 2112h | OAM-CH | T-Mobile | Karl-Heinz.Nenner@T-MOBILE.DE | Rel-5 | Dionisio |  | 32.200, 32.205, 32.215, 32.225, 32.235 |
| 2926 | 92.4 | Rel-5 Network Infrastructure Management | 255d | 2001-09-21 A | 2002-09-12 A | 100% | 2001-09-21 | 2002-09-12 | 255d | finish no earlier than 2002-09-12 | S5 | 2040h | 2040h | OAM-NIM | Ericsson | thomas.tovinger@ericsson.com | Rel-5 | Dionisio |  | 32.6xy, 32.3xy |
| 2927 | 93 | **GERAN enhancements for streaming services 1 (RLC enhancements)** | 430d | 2000-11-06 A | 2002-06-28 A | 100% | 2000-11-06 | 2002-06-28 | 430d |  | GP | 8944h | 8944h |  |  |  | Rel-5 | Paolo |  |  |
| 2928 | 93.1 | Concept for GERAN enhancements for streaming services 1 (RLC enhancements) | 258d | 2000-11-06 A | 2001-10-31 A | 100% | 2000-11-06 | 2001-10-31 | 258d | finish no earlier than 2001-10-31 | GP | 2064h | 2064h |  |  |  | Rel-5 | Paolo |  |  |
| 2929 | 93.2 | RLC protocol enhancement (SDU Discard) | 430d | 2000-11-06 A | 2002-06-28 A | 100% | 2000-11-06 | 2002-06-28 | 430d | finish no earlier than 2002-06-28 | GP | 3440h | 3440h |  |  |  | Rel-5 | Paolo |  |  |
| 2930 | 94 | **GERAN enhancements for streaming services 2 (usage of ECSD)** | 430d | 2000-11-06 A | 2002-06-28 A | 100% | 2000-11-06 | 2002-06-28 | 430d |  | GP | 19840h | 19840h |  | Ericsson | Frank Muller | Rel-5 | Paolo |  |  |
| 2931 | 94.1 | Usage of ECSD Concept | 380d | 2000-11-06 A | 2002-04-19 A | 100% | 2000-11-06 | 2002-04-19 | 380d | finish no earlier than 2002-04-19 | GP | 3040h | 3040h |  |  |  | Rel-5 | Paolo |  |  |
| 2932 | 94.2 | Stage 2 for GERAN enhancements for streaming services 2 (usage of ECSD) | 380d | 2000-11-06 A | 2002-04-19 A | 100% | 2000-11-06 | 2002-04-19 | 380d | finish no earlier than 2002-04-19 | GP | 3040h | 3040h |  |  |  | Rel-5 | Paolo |  |  |
| 2933 | 94.3 | Stage 3 for GERAN enhancements for streaming services 2 (usage of ECSD) | 430d | 2000-11-06 A | 2002-06-28 A | 100% | 2000-11-06 | 2002-06-28 | 430d | finish no earlier than 2002-06-28 | GP | 3440h | 3440h |  |  |  | Rel-5 | Paolo |  |  |
| 2934 | 94.4 | RLC PDU formats | 430d | 2000-11-06 A | 2002-06-28 A | 100% | 2000-11-06 | 2002-06-28 | 430d | finish no earlier than 2002-06-28 | GP | 3440h | 3440h |  |  |  | Rel-5 | Paolo |  |  |
| 2935 | 94.5 | MAC header | 430d | 2000-11-06 A | 2002-06-28 A | 100% | 2000-11-06 | 2002-06-28 | 430d | finish no earlier than 2002-06-28 | GP | 3440h | 3440h |  |  |  | Rel-5 | Paolo |  |  |

Notes:
- 2912: Accept changes Gb over IP
- 2913: -
- 2914: -
- 2915: -
- 2916: Closed, accept changes for Gb over IP
- 2917: -
- 2918: Terminated - not standardized. Marked as stopped 12/2008
- 2919: TERMINATED - NOT STANDARDIZED. Marked as stopped 12/2008
- 2920: TERMINATED - NOT STANDARDIZED. Marked as stopped 12/2008
- 2921: TERMINATED - NOT STANDARDIZED. Marked as stopped 12/2008
- 2922: -
- 2923: -
- 2924: -
- 2925: -
- 2926: -
- 2927: -
- 2928: -
- 2929: -
- 2930: AWS, Nokia, Ericsson, Nortel, Siemens, Motorola, Vodafone
- 2931: -
- 2932: -
- 2933: -
- 2934: -
- 2935: -

| ID | WBS | Task | Duration | Start | Finish | Predecessors | Complete | Baseline start | Baseline finish | Baseline duration | Constraint | Resources | Work | Actual work | Text1 | Text4 | Text5 | Text6 | Text8 |
| --- | --- | --- | --- | --- | --- | --- | --- | --- | --- | --- | --- | --- | --- | --- | --- | --- | --- | --- | --- |
| 2936 | 95 | **GERAN/UTRAN interface evolution 1 (evolution of Iu PS)** | 476d | 2000-09-01 A | 2002-06-28 A |  | 100% | 2000-09-01 | 2002-06-28 | 476d |  | GP,R3 | 10688h | 10688h | GERUEV1 | SBC | Marc Grant | Rel-5 | Paolo |
| 2937 | 95.1 | **Evolution of Iu ps** | 476d | 2000-09-01 A | 2002-06-28 A |  | 100% | 2000-09-01 | 2002-06-28 | 476d |  | GP,R3 | 7248h | 7248h | GERUEV1-IuPS |  |  | Rel-5 | Paolo |
| 2938 | 95.1.1 | Identification of GERAN requirements on Iu ps | 326d | 2000-09-01 A | 2001-11-30 A |  | 100% | 2000-09-01 | 2001-11-30 | 326d | finish no earlier than 2001-11-30 | GP,R3 | 2608h | 2608h | GERUEV1-IuPS |  |  | Rel-5 | Paolo |
| 2939 | 95.1.2 | Update of Evolution of Iu ps specifications | 150d | 2001-12-03 A | 2002-06-28 A | 2938 | 100% | 2001-12-03 | 2002-06-28 | 150d | finish no earlier than 2002-06-28 | GP,R3 | 1200h | 1200h | GERUEV1-IuPS |  |  | Rel-5 | Paolo |
| 2940 | 96 | **GERAN/UTRAN interface evolution 2 (evolution of Iu CS)** | 476d | 2000-09-01 A | 2002-06-28 A |  | 100% | 2000-09-01 | 2002-06-28 | 476d |  | GP,R3 | 12816h | 12816h | GERUEV2 |  |  | Rel-5 | Paolo |
| 2941 | 96.1 | **Evolution of Iu cs** | 476d | 2000-09-01 A | 2002-06-28 A |  | 100% | 2000-09-01 | 2002-06-28 | 476d |  | GP,R3 | 10016h | 10016h | GERUEV2-IuCS | Lucent | Krishna Balachandran | Rel-5 | Paolo |
| 2942 | 96.1.1 | Identification of GERAN requirements on Iu cs | 426d | 2000-09-01 A | 2002-06-24 A |  | 100% | 2000-09-01 | 2002-06-24 | 426d | finish no earlier than 2002-04-19 | GP,R3 | 3408h | 3408h | GERUEV2-IuCS |  |  | Rel-5 | Paolo |
| 2943 | 96.1.2 | Update of Evolution of Iu cs specifications | 476d | 2000-09-01 A | 2002-06-28 A |  | 100% | 2000-09-01 | 2002-06-28 | 476d | finish no earlier than 2002-06-28 | GP,R3 | 3808h | 3808h | GERUEV2-IuCS |  |  | Rel-5 | Paolo |
| 2944 | 97 | **End to End QoS for PS Domain including IMS** | 480d | 2000-08-28 A | 2002-06-28 A |  | 100% | 2000-08-28 | 2002-06-28 | 480d |  | S2,S5,N3 | 10592h | 10592h | E2EQoS | Ericsson | Johnson.oyama@era.ericcson.se | Rel-5 | Maurice |
| 2945 | 97.1 | E2E QoSConcept and Architecture | 178d | 2001-01-03 A | 2001-09-07 A |  | 100% | 2001-01-03 | 2001-09-07 | 178d | finish no earlier than 2001-09-07 | S2 | 1424h | 1424h |  |  |  | Rel-5 | Maurice |
| 2946 | 97.2 | E2E QoS interworking | 465d | 2000-08-28 A | 2002-06-07 A |  | 100% | 2000-08-28 | 2002-06-07 | 465d | finish no earlier than 2002-06-07 | N3 | 3720h | 3720h | E2EQoS-IW | Lucent | Daisuke Yokota (yokota@lucent.com) | Rel-5 | Gwiho |
| 2947 | 97.3 | QoS Management (Provisioning and Monitoring) | 201d | 2001-09-21 A | 2002-06-28 A |  | 100% | 2001-09-21 | 2002-06-28 | 201d | finish no earlier than 2002-06-28 | S5 | 1608h | 1608h | E2EQoS-OAM |  |  | Rel-5 | Dionisio |
| 2948 | 98 | **Rel-5 Messaging enhancements** | 467d | 2001-06-15 A | 2003-03-31 A |  | 100% | 2001-06-15 | 2003-03-31 | 467d |  | T2 | 19000h | 19000h | MESS5 |  |  | Rel-5 | Kimmo |
| 2949 | 98.1 | **Rel-5 Multimedia Messaging (MMS) enhancements** | 467d | 2001-06-15 A | 2003-03-31 A |  | 100% | 2001-06-15 | 2003-03-31 | 467d |  | T2 | 11688h | 11688h | MESS5-MMS | Siemens | Josef.Laumen@SAL.SIEMENS.DE | Rel-5 | Alain |
| 2950 | 98.1.1 | Definition of service requirements for MESS5-MMS | 196d | 2001-06-15 A | 2002-03-15 A |  | 100% | 2001-06-15 | 2002-03-15 | 196d | finish no earlier than 2002-03-15 | S1 | 1568h | 1568h | MESS5-SR | Siemens | Josef.Laumen@SAL.SIEMENS.DE | Rel-5 | Alain |
| 2951 | 98.1.2 | Technical realization of MESS5-MMS | 256d | 2001-06-15 A | 2002-06-07 A |  | 100% | 2001-06-15 | 2002-06-07 | 256d | finish no earlier than 2002-06-07 | T2 | 2048h | 2048h |  | Siemens | Josef.Laumen@SAL.SIEMENS.DE | Rel-5 |  |
| 2952 | 98.1.3 | WAP Forum dependency: MM1 stage 3 | 467d | 2001-06-15 A | 2003-03-31 A |  | 100% | 2001-06-15 | 2003-03-31 | 467d | finish no earlier than 2003-03-31 | T2 | 3736h | 3736h |  |  |  | Rel-5 |  |
| 2953 | 98.1.4 | MMS formats and codecs for MESS5-MMS | 75d | 2001-12-03 A | 2002-03-15 A |  | 100% | 2001-12-03 | 2002-03-15 | 75d | finish no earlier than 2002-03-15 | S4 | 600h | 600h |  |  |  | Rel-5 | Paolo |
| 2954 | 98.2 | **Enhanced Messaging Service (EMS) enhancements** | 191d | 2001-06-15 A | 2002-03-08 A |  | 100% | 2001-06-15 | 2002-03-08 | 191d |  | T2 | 3584h | 3584h | MESS5-EMS | Ericsson | Alan.Baldwin@EML.ERICSSON.SE | Rel-5 | Kimmo |
| 2955 | 98.2.1 | Definition of service requirements for Enhanced Messaging Service (EMS) enhancements | 66d | 2001-06-15 A | 2001-09-14 A |  | 100% | 2001-06-15 | 2001-09-14 | 66d | finish no earlier than 2001-09-14 | S1 | 528h | 528h |  | Ericsson | Alan.Baldwin@EML.ERICSSON.SE | Rel-5 | Alain |
| 2956 | 98.2.2 | Technical realization of Enhanced Messaging Service (EMS) enhancements | 191d | 2001-06-15 A | 2002-03-08 A |  | 100% | 2001-06-15 | 2002-03-08 | 191d | finish no earlier than 2002-03-08 | T2 | 1528h | 1528h |  | Ericsson | Alan.Baldwin@EML.ERICSSON.SE | Rel-5 | Kimmo |
| 2957 | 99 | **GERAN Inter BSC NACC improvements over the Gb Interface** | 215d | 2001-09-03 A | 2002-06-28 A |  | 100% | 2001-09-03 | 2002-06-28 | 215d |  | GP | 8200h | 8200h | GERNACC |  |  | Rel-5 | Paolo |
| 2958 | 99.1 | **Modification of core network protocols for GERAN Inter BSC NACC over Gb Interface** | 165d | 2001-09-03 A | 2002-04-19 A |  | 100% | 2001-09-03 | 2002-04-19 | 165d |  | N4,S2 | 4064h | 4064h | GERNACC-Cnmod |  |  | Rel-5 | Kimmo |
| 2959 | 99.1.1 | Stage 2 - Concept | 43d | 2001-09-03 A | 2001-10-31 A |  | 100% | 2001-09-03 | 2001-10-31 | 43d | finish no earlier than 2001-10-31 | N4,S2 | 344h | 344h |  |  |  | Rel-5 | Kimmo |
| 2960 | 99.1.2 | Stage 2 - 23.060 change - Definition of Inter BSC NACC | 165d | 2001-09-03 A | 2002-04-19 A |  | 100% | 2001-09-03 | 2002-04-19 | 165d | finish no earlier than 2002-04-19 | N4,S2 | 1320h | 1320h |  |  |  | Rel-5 | Kimmo |
| 2961 | 99.1.3 | Stage 3 (changes to TS 29.060) | 135d | 2001-09-03 A | 2002-03-08 A |  | 100% | 2001-09-03 | 2002-03-08 | 135d | finish no earlier than 2002-03-08 | N4 | 1080h | 1080h |  |  |  | Rel-5 | Kimmo |

Notes:
- 2936: SBC, Motorola, Nokia, Ericsson, Nortel
- 2937: -
- 2938: -
- 2939: -
- 2940: -
- 2941: Lucent, Ericsson, AWS, Nortel
- 2942: -
- 2943: -
- 2944: -
- 2945: - / Text3: 23.207
- 2946: [DAB - 30/07/02] - % complete to 95% (if we exclude Diffserv). Marked as closed 12/2008 (was marked 95% complete) / Text3: 29.208, 29.207, 27.060, 29.061, 24.008, 24.228, , 24.229, 29.060, 29.163
- 2947: - / Text3: 32-series
- 2948: support of UAProf, so this in my opinion is 100% complete
- 2949: -
- 2950: - / Text3: 22.140
- 2951: stage 3 MM7 is missing / Text3: 23.140
- 2952: Marked as closed 12/2008 (was marked 80% complete)
- 2953: - / Text3: 26.140
- 2954: - / Text3: 23.040
- 2955: -
- 2956: - / Text3: 23.040
- 2957: -
- 2958: -
- 2959: -
- 2960: -
- 2961: IP 30/11/01: Input awaited from GERAN2 to CN4 / 17 May Work complete 100%

| ID | WBS | Task | Duration | Start | Finish | Complete | Baseline start | Baseline finish | Baseline duration | Constraint | Resources | Work | Actual work | Text1 | Text6 | Text8 | Text12 | Text3 | Text4 | Text5 |
| --- | --- | --- | --- | --- | --- | --- | --- | --- | --- | --- | --- | --- | --- | --- | --- | --- | --- | --- | --- | --- |
| 2962 | 99.2 | **Modification of Gb protocols for GERAN Inter BSC NACC over Gb Interface** | 151d | 2001-11-30 A | 2002-06-28 A | 100% | 2001-11-30 | 2002-06-28 | 151d |  | GP | 2416h | 2416h | GERNACC-Gbmod | Rel-5 | Paolo |  |  |  |  |
| 2963 | 99.2.1 | Stage 3 (changes to TS 48.018) | 151d | 2001-11-30 A | 2002-06-28 A | 100% | 2001-11-30 | 2002-06-28 | 151d | finish no earlier than 2002-06-28 | GP | 1208h | 1208h |  | Rel-5 | Paolo |  |  |  |  |
| 2964 | 100 | **Enhanced Power Control** | 540d | 2001-11-26 A | 2003-12-19 A | 100% | 2001-11-26 | 2003-12-19 | 540d |  | GP | 12840h | 12840h | EPC | Rel-5 | Paolo |  |  |  |  |
| 2965 | 100.1 | Realization of Enhanced power control and signalling support | 5d | 2001-11-26 A | 2001-11-30 A | 100% | 2001-11-26 | 2001-11-30 | 5d | finish no earlier than 2001-11-30 | GP | 40h | 40h |  | Rel-5 | Paolo |  |  |  |  |
| 2966 | 100.2 | Deleted - GERAN MS Conformance test for Enhanced Power Control | 530d | 2001-12-10 A | 2003-12-19 A | 100% | 2001-12-10 | 2003-12-19 | 530d | finish no earlier than 2003-12-19 | GP | 4240h | 4240h |  | Rel-5 | Paolo | GP-17 |  |  |  |
| 2967 | 100.3 | Deleted - GERAN BTS Conformance test for Enhanced Power Control | 530d | 2001-12-10 A | 2003-12-19 A | 100% | 2001-12-10 | 2003-12-19 | 530d | finish no earlier than 2003-12-19 | GP | 4240h | 4240h |  | Rel-5 | Paolo | GP-17 |  |  |  |
| 2968 | 101 | **8PSK AMR HR** | 530d | 2001-12-10 A | 2003-12-19 A | 100% | 2001-12-10 | 2003-12-19 | 530d |  | GP | 21080h | 21080h | 8PSK-AH | Rel-5 | Paolo |  |  |  |  |
| 2969 | 101.1 | **Definition of channel coding, performance requirements and signalling support** | 145d | 2001-12-10 A | 2002-06-28 A | 100% | 2001-12-10 | 2002-06-28 | 145d |  | GP | 10440h | 10440h |  | Rel-5 | Paolo |  |  |  |  |
| 2970 | 101.1.1 | Concept | 145d | 2001-12-10 A | 2002-06-28 A | 100% | 2001-12-10 | 2002-06-28 | 145d | finish no earlier than 2002-06-28 | GP | 1160h | 1160h |  | Rel-5 | Paolo |  |  |  |  |
| 2971 | 101.1.2 | Changes to 44.018 | 145d | 2001-12-10 A | 2002-06-28 A | 100% | 2001-12-10 | 2002-06-28 | 145d | finish no earlier than 2002-06-28 | G2 | 1160h | 1160h |  | Rel-5 | Gert |  |  |  |  |
| 2972 | 101.1.3 | Changes to 45.001 | 145d | 2001-12-10 A | 2002-06-28 A | 100% | 2001-12-10 | 2002-06-28 | 145d | finish no earlier than 2002-06-28 | G1 | 1160h | 1160h |  | Rel-5 | Paolo |  |  |  |  |
| 2973 | 101.1.4 | Changes to 45.002 | 145d | 2001-12-10 A | 2002-06-28 A | 100% | 2001-12-10 | 2002-06-28 | 145d | finish no earlier than 2002-06-28 | G1 | 1160h | 1160h |  | Rel-5 | Paolo |  |  |  |  |
| 2974 | 101.1.5 | Changes to 45.003 | 145d | 2001-12-10 A | 2002-06-28 A | 100% | 2001-12-10 | 2002-06-28 | 145d | finish no earlier than 2002-06-28 | G1 | 1160h | 1160h |  | Rel-5 | Paolo |  |  |  |  |
| 2975 | 101.1.6 | Changes to 45.005 | 145d | 2001-12-10 A | 2002-06-28 A | 100% | 2001-12-10 | 2002-06-28 | 145d | finish no earlier than 2002-06-28 | G1 | 1160h | 1160h |  | Rel-5 | Paolo |  |  |  |  |
| 2976 | 101.1.7 | Changes to 24.008 | 145d | 2001-12-10 A | 2002-06-28 A | 100% | 2001-12-10 | 2002-06-28 | 145d | finish no earlier than 2002-06-28 | G2 | 1160h | 1160h |  | Rel-5 | Gert |  |  |  |  |
| 2977 | 101.1.8 | Changes to 48.058 | 145d | 2001-12-10 A | 2002-06-28 A | 100% | 2001-12-10 | 2002-06-28 | 145d | finish no earlier than 2002-06-28 | G2 | 1160h | 1160h |  | Rel-5 | Gert |  |  |  |  |
| 2978 | 101.2 | Deleted - GERAN MS Conformance test for 8PSK HR | 530d | 2001-12-10 A | 2003-12-19 A | 100% | 2001-12-10 | 2003-12-19 | 530d | finish no earlier than 2003-12-19 | GP | 4240h | 4240h |  | Rel-5 | Paolo | GP-17 |  |  |  |
| 2979 | 101.3 | GERAN BTS Conformance test for 8PSK HR | 270d | 2001-12-10 A | 2002-12-20 A | 100% | 2001-12-10 | 2002-12-20 | 270d | finish no earlier than 2002-12-20 | GP | 2160h | 2160h |  | Rel-5 | Paolo |  |  |  |  |
| 2980 | 102 | Service Change and UDI Fallback | 175d | 2001-10-08 A | 2002-06-07 A | 100% | 2001-10-08 | 2002-06-07 | 175d | finish no earlier than 2002-06-07 | N3 | 1400h | 1400h | SCUDIF | Rel-5 | Gwiho |  | 29.007, 27.001, 24.008 | Ericsson | Rune.Werner.Wiik@ericsson.no |
| 2981 | 103 | **Rel-5 USIM toolkit enhancements** | 865d | 2000-06-05 A | 2003-09-26 A | 100% | 2000-06-05 | 2003-09-26 | 865d |  | T3 | 24352h | 24352h | USAT1-Interpr | Rel-5 | Xavier |  |  | G & D | Michael Meyer |
| 2982 | 103.1 | Deleted - Test specification for USIM toolkit security mechanisms | 349d | 2002-05-28 A | 2003-09-26 A | 100% | 2002-05-28 | 2003-09-26 | 349d | finish no earlier than 2003-09-26 | T3 | 2792h | 2792h |  | Rel-5 | Xavier | TP-21 |  | Gemplus | Sophie Viallet |
| 2983 | 103.2 | **Protocol Standardisation of a SIM Toolkit Interpreter** | 688d | 2000-06-05 A | 2003-01-22 A | 100% | 2000-06-05 | 2003-01-22 | 688d |  | T3 | 12512h | 12512h | USAT1-Interpr | Rel-5 | Xavier |  | 27.103 | G & D | Michael Meyer |
| 2984 | 103.2.1 | Stage 1 for Protocol Standardisation of a SIM Toolkit Interpreter | 205d | 2000-06-05 A | 2001-03-16 A | 100% | 2000-06-05 | 2001-03-16 | 205d | finish no earlier than 2001-03-16 | T3 | 1640h | 1640h | USAT1-Interpr | Rel-5 | Xavier |  |  |  |  |
| 2985 | 103.2.2 | Stage 2 and 3 | 308d | 2001-01-03 A | 2002-03-08 A | 100% | 2001-01-03 | 2002-03-08 | 308d | finish no earlier than 2002-03-08 | T3 | 2464h | 2464h | USAT1-Interpr | Rel-5 | Xavier |  |  |  |  |
| 2986 | 103.2.3 | Test specification for Protocol Standardisation of a SIM Toolkit Interpreter | 363d | 2001-09-03 A | 2003-01-22 A | 100% | 2001-09-03 | 2003-01-22 | 363d | finish no earlier than 2003-01-22 | T3 | 2904h | 2904h | USAT1-Interpr | Rel-5 | Xavier |  |  | Gemplus | Gérald MAUNIER |

Notes:
- 2962: -
- 2963: -
- 2964: -
- 2965: Completed 11/2001
- 2966: Not started. Marked as stopped 12/2008
- 2967: Not started. Marked as stopped 12/2008
- 2968: Completed for Rel-5
- 2969: -
- 2970: -
- 2971: -
- 2972: -
- 2973: -
- 2974: -
- 2975: -
- 2976: -
- 2977: -
- 2978: Marked as stopped 12/2008
- 2979: -
- 2980: -
- 2981: -
- 2982: Marked as stopped 12/2008
- 2983: 28/5/2001: T3-19 proposed that since the stage 2 and 3 will not be presented to TP-12 for approval as expected, the WI will be moved to rel-5, with completion expected at TP-13.
- 2984: 5/10/2001: Stage one comepeted at TP-12.
- 2985: 5/10/2001: TS 31.112 and 31.113 approved at TP-13. TS 31.114 to be presented to TP-14.
- 2986: 5/10/2001: Work started on test specification. Marked as closed 12/2008 (was marked 12% complete)

| ID | WBS | Task | Type | Duration | Start | Finish | Complete | Baseline start | Baseline finish | Baseline duration | Constraint | Resources | Work | Actual work | Text1 | Text4 | Text5 | Text6 | Text8 | Text12 |
| --- | --- | --- | --- | --- | --- | --- | --- | --- | --- | --- | --- | --- | --- | --- | --- | --- | --- | --- | --- | --- |
| 2987 | 103.4 | **(U)SIM API** |  | 133d | 2002-03-20 A | 2002-09-20 A | 100% | 2002-03-20 | 2002-09-20 | 133d |  | T3 | 2128h | 2128h | USAT1-API | Microelectrónica Española | Mario Pérez | Rel-5 | Xavier |  |
| 2988 | 103.4.1 | Rel-5 Java API Test specification |  | 133d | 2002-03-20 A | 2002-09-20 A | 100% | 2002-03-20 | 2002-09-20 | 133d | finish no earlier than 2002-09-20 | T3 | 1064h | 1064h | USAT1-API | Microelectrónica Española | Mario Pérez | Rel-5 | Xavier |  |
| 2989 | 104 | (Small) Technical Enhancements and Improvements for Rel-5 | milestone | 0d? | 2000-01-03 A | 2000-01-03 A | 100% | 2000-01-03 | 2000-01-03 | 0d? |  | All |  |  | TEI5 |  |  | Rel-5 | all |  |
| 2990 | 839 | Test - (Small) Technical Enhancements and Improvements for Rel-5 |  | 2349d? | 2000-01-03 A | 2008-12-31 A | 100% | 2000-01-03 | 2008-12-31 | 2349d? | finish no earlier than 2008-12-31 | R5,T1 | 18792h | 18792h | TEI5_Test |  |  | Rel-5 | Ingbert |  |
| 2991 | 105 | Technical Report on UE Functionality Split |  | 87d | 2000-01-03 A | 2000-05-01 A | 100% | 2000-01-03 | 2000-05-01 | 87d |  | S1 | 688h | 688h | UESPLIT | Motorola | jian.j.wu@motorola.com | Rel-5 | Alain |  |
| 2992 | 106 | **User Equipment Management** |  | 267d | 2001-06-21 A | 2002-06-28 A | 100% | 2001-06-21 | 2002-06-28 | 267d |  | S5 | 3752h | 3752h | UEM | Vodafone | john.mudge@vf.vodafone.co.uk | Rel-5 | Dionisio |  |
| 2993 | 106.1 | FS on User Equipment (UE) Management |  | 267d | 2001-06-21 A | 2002-06-28 A | 100% | 2001-06-21 | 2002-06-28 | 267d | finish no earlier than 2002-06-28 | S5 | 2136h | 2136h | OAM-UEM | Vodafone | john.mudge@vf.vodafone.co.uk | Rel-5 | Dionisio |  |
| 2994 | 107 | **Flow control supporting an MS with multiple data flows with different QoS over the Gb interface** |  | 50d | 2002-06-24 A | 2002-08-30 A | 100% | 2002-06-24 | 2002-08-30 | 50d |  | GP | 1288h | 1288h | FlowCon | Ericsson | ingemar.backlund@era.ericsson.se | Rel-5 | Paolo |  |
| 2995 | 107.1 | **Update of stage 2 specifications** |  | 50d | 2002-06-24 A | 2002-08-30 A | 100% | 2002-06-24 | 2002-08-30 | 50d |  | GP | 808h | 808h |  |  |  | Rel-5 | Paolo |  |
| 2996 | 107.1.1 | Concept document 23.060 (changes to) |  | 46d | 2002-06-28 A | 2002-08-30 A | 100% | 2002-06-28 | 2002-08-30 | 46d | finish no earlier than 2002-08-30 | S2 | 368h | 368h |  |  |  | Rel-5 | Maurice |  |
| 2997 | 107.1.2 | Flow Control |  | 5d | 2002-06-24 A | 2002-06-28 A | 100% | 2002-06-24 | 2002-06-28 | 5d | finish no earlier than 2002-06-28 | GP | 40h | 40h |  |  |  | Rel-5 | Paolo |  |
| 2998 | 107.2 | **Modification of BSSGP protocol** |  | 5d | 2002-06-24 A | 2002-06-28 A | 100% | 2002-06-24 | 2002-06-28 | 5d |  | GP | 80h | 80h |  | Ericsson | ingemar.backlund@era.ericsson.se | Rel-5 | Paolo |  |
| 2999 | 107.2.1 | Stage 3 (changes to 48.018) |  | 5d | 2002-06-24 A | 2002-06-28 A | 100% | 2002-06-24 | 2002-06-28 | 5d | finish no earlier than 2002-06-28 | G2 | 40h | 40h |  |  |  | Rel-5 | Gert |  |
| 3000 | 108 | **Deleted - Multiple TBF in A/Gb mode - Phase 1** |  | 421d | 2002-04-19 A | 2003-11-28 A | 100% | 2002-04-19 | 2003-11-28 | 421d |  | GP | 17480h | 17480h | MULTBF | Ericsson | gunnar.mildh@era.ericsson.se | Rel-5 | Paolo | GP-17 |
| 3001 | 108.1 | **Deleted - Multiple TBF in A/Gb mode - Core** |  | 351d | 2002-04-19 A | 2003-08-22 A | 100% | 2002-04-19 | 2003-08-22 | 351d |  | GP | 8112h | 8112h | MULTBF-Agbmode |  |  | Rel-5 | Paolo | GP-17 |
| 3002 | 108.1.1 | Deleted - Multiple TBF Concept paper |  | 351d | 2002-04-19 A | 2003-08-22 A | 100% | 2002-04-19 | 2003-08-22 | 351d | finish no earlier than 2003-08-22 | GP | 2808h | 2808h | MULTBF-Agbmode |  |  | Rel-5 | Paolo | GP-17 |
| 3003 | 108.1.2 | Deleted - Multiple TBF Stage 2 (43.064) CRs |  | 156d | 2002-04-19 A | 2002-11-22 A | 100% | 2002-04-19 | 2002-11-22 | 156d | finish no earlier than 2002-11-22 | G1 | 1248h | 1248h | MULTBF-Agbmode |  |  | Rel-5 | Paolo | GP-12 |
| 3004 | 108.1.3 | Deleted - Multiple TBF Stage 3 (44.060) CRs |  | 156d | 2002-04-19 A | 2002-11-22 A | 100% | 2002-04-19 | 2002-11-22 | 156d | finish no earlier than 2002-11-22 | G2 | 1248h | 1248h | MULTBF-Agbmode |  |  | Rel-5 | Gert | GP-12 |
| 3005 | 108.2 | **Deleted - Multiple TBF in A/Gb mode - Phase 1 – MS testing** |  | 375d | 2002-06-24 A | 2003-11-28 A | 100% | 2002-06-24 | 2003-11-28 | 375d |  | GP | 6000h | 6000h |  | Ericsson | ingemar.backlund@era.ericsson.se | Rel-5 | Paolo | GP-17 |
| 3006 | 108.2.1 | Deleted - MS conformance tests for Multiple TBF in A/Gb mode |  | 375d | 2002-06-24 A | 2003-11-28 A | 100% | 2002-06-24 | 2003-11-28 | 375d | finish no earlier than 2003-11-28 | G4 | 3000h | 3000h |  |  |  | Rel-5 | Paolo | GP-17 |
| 3007 | 109 | **Alignment of 3G functional split and Iu** |  | 922d | 2000-06-08 A | 2003-12-19 A | 100% | 2000-06-08 | 2003-12-19 | 922d |  | GP | 126664h | 126664h | GER3GAL | Ericsson | Frank Muller | Rel-5 | Paolo |  |
| 3008 | 109.1 | **GERAN user / control plane** |  | 540d | 2000-08-07 A | 2002-08-30 A | 100% | 2000-08-07 | 2002-08-30 | 540d |  | GP | 36232h | 36232h | GER3GAL-GUCOPL | Ericsson | Frank Muller | Rel-5 | Paolo |  |
| 3009 | 109.1.1 | **Alignment with UMTS bearer concept** |  | 540d | 2000-08-07 A | 2002-08-30 A | 100% | 2000-08-07 | 2002-08-30 | 540d |  | GP | 24952h | 24952h |  |  |  | Rel-5 | Paolo |  |
| 3010 | 109.1.1.1 | Enhanced power control - for Alignment with UMTS bearer concept |  | 1d | 2001-08-31 A | 2001-08-31 A | 100% | 2001-08-31 | 2001-08-31 | 1d | finish no earlier than 2001-08-31 | GP | 8h | 8h |  |  |  | Rel-5 | Paolo |  |
| 3011 | 109.1.1.2 | Stage 2 - for Alignment with UMTS bearer concept |  | 235d | 2000-08-07 A | 2001-06-29 A | 100% | 2000-08-07 | 2001-06-29 | 235d | finish no earlier than 2001-06-29 | GP | 1880h | 1880h |  |  |  | Rel-5 | Paolo |  |
| 3012 | 109.1.1.3 | Adoption of the UTRAN PDCP |  | 295d | 2000-11-06 A | 2001-12-21 A | 100% | 2000-11-06 | 2001-12-21 | 295d | finish no earlier than 2001-12-21 | GP | 2360h | 2360h |  |  |  | Rel-5 | Paolo |  |
| 3013 | 109.1.1.4 | Development of RLC / MAC |  | 261d | 2001-08-31 A | 2002-08-30 A | 100% | 2001-08-31 | 2002-08-30 | 261d | finish no earlier than 2002-08-30 | GP | 2088h | 2088h |  |  |  | Rel-5 | Paolo |  |
| 3014 | 109.1.1.5 | Development of GERAN RRC |  | 266d | 2001-06-22 A | 2002-06-28 A | 100% | 2001-06-22 | 2002-06-28 | 266d | finish no earlier than 2002-06-28 | GP | 2128h | 2128h |  |  |  | Rel-5 | Paolo |  |
| 3015 | 109.1.1.6 | Ciphering and integrity protection concept paper |  | 166d | 2001-08-31 A | 2002-04-19 A | 100% | 2001-08-31 | 2002-04-19 | 166d | finish no earlier than 2002-04-19 | GP | 1328h | 1328h |  |  |  | Rel-5 | Paolo |  |
| 3016 | 109.1.1.7 | Multiple TBF or equivalent Concept paper |  | 116d | 2001-08-31 A | 2002-02-08 A | 100% | 2001-08-31 | 2002-02-08 | 116d | finish no earlier than 2002-02-08 | GP | 928h | 928h |  |  |  | Rel-5 | Paolo |  |
| 3017 | 109.1.1.8 | Paging concept |  | 166d | 2001-08-31 A | 2002-04-19 A | 100% | 2001-08-31 | 2002-04-19 | 166d | finish no earlier than 2002-04-19 | GP | 1328h | 1328h |  |  |  | Rel-5 | Paolo |  |
| 3018 | 109.1.1.9 | Dedicated Physical subchannels, includes traffic and control channels |  | 66d | 2001-08-31 A | 2001-11-30 A | 100% | 2001-08-31 | 2001-11-30 | 66d | finish no earlier than 2001-11-30 | GP | 528h | 528h |  |  |  | Rel-5 | Paolo |  |
| 3019 | 109.1.1.10 | Iu support and broadcast concept |  | 166d | 2001-08-31 A | 2002-04-19 A | 100% | 2001-08-31 | 2002-04-19 | 166d | finish no earlier than 2002-04-19 | GP | 1328h | 1328h |  |  |  | Rel-5 | Paolo |  |
| 3020 | 109.1.1.11 | Impact of using RLC instead of LAPDm concept |  | 116d | 2001-08-31 A | 2002-02-08 A | 100% | 2001-08-31 | 2002-02-08 | 116d | finish no earlier than 2002-02-08 | GP | 928h | 928h |  |  |  | Rel-5 | Paolo |  |
| 3021 | 109.1.1.12 | Contention resolution, mobile station identity, and access concept |  | 66d | 2001-08-31 A | 2001-11-30 A | 100% | 2001-08-31 | 2001-11-30 | 66d | finish no earlier than 2001-11-30 | GP | 528h | 528h |  |  |  | Rel-5 | Paolo |  |
| 3022 | 109.1.1.13 | PDCP concept |  | 166d | 2001-08-31 A | 2002-04-19 A | 100% | 2001-08-31 | 2002-04-19 | 166d | finish no earlier than 2002-04-19 | GP | 1328h | 1328h |  |  |  | Rel-5 | Paolo |  |
| 3023 | 109.1.1.14 | Downlink delayed TBF release |  | 261d | 2001-08-31 A | 2002-08-30 A | 100% | 2001-08-31 | 2002-08-30 | 261d | finish no earlier than 2002-08-30 | GP | 2088h | 2088h |  |  |  | Rel-5 | Paolo |  |
| 3024 | 109.1.1.15 | Add transparent RLC Concept |  | 116d | 2001-08-31 A | 2002-02-08 A | 100% | 2001-08-31 | 2002-02-08 | 116d | finish no earlier than 2002-02-08 | GP | 928h | 928h |  |  |  | Rel-5 | Paolo |  |
| 3025 | 109.1.1.16 | Handover concept |  | 116d | 2001-08-31 A | 2002-02-08 A | 100% | 2001-08-31 | 2002-02-08 | 116d | finish no earlier than 2002-02-08 | GP | 928h | 928h |  |  |  | Rel-5 | Paolo |  |

Notes:
- 2987: 8/3/2001: test spec is based on R99 core spec, so deleted from Workplan
- 2988: -
- 2989: "Joker" WI, to be used for a Rel 5 CR not related to any feature and with very limited impact on the system
- 2990: "Joker" WI, to be used for small modifications applicable to Rel 5 conformance testing. Moved in from Stoyan/testing WP. / Text3: 34.108, 34.109, 34.121-1, 34.121-2, 34.122, 34.123-1, 34.123-2, 34.123-3, 34.171, 34.229-1, 34.229-2, 34.229-3
- 2991: - / Text3: new TR 22.944
- 2992: - / Text3: 32.802
- 2993: - / Text3: 32.802
- 2994: 50101 -> 50201
- 2995: 50102 -> 50202
- 2996: -
- 2997: 50103 -> 50203
- 2998: -
- 2999: -
- 3000: GP#17 Nov 2003 Moved to Rel-6 as UID_50600 MULTBF (Only Multiple TBF Concept paper produced in Rel-5)
- 3001: Marked as closed 12/2008 (was marked 26% complete)
- 3002: Marked as closed 12/2008 (was marked 50% complete)
- 3003: Marked as stopped 12/2008
- 3004: Marked as stopped 12/2008
- 3005: 08/08: duplicate UID_50106=-> 50206. Marked as stopped 12/2008
- 3006: Not started. Marked as stopped 12/2008
- 3007: AWS, Nokia, Ericsson, Nortel, Siemens, Vodafone
- 3008: AWS, Nokia, Ericsson, Nortel, Siemens, Vodafone
- 3009: -
- 3010: -
- 3011: -
- 3012: Responsible is GERAN; RAN WG2 help may be needed.
- 3013: -
- 3014: -
- 3015: -
- 3016: -
- 3017: -
- 3018: -
- 3019: -
- 3020: -
- 3021: -
- 3022: -
- 3023: -
- 3024: -
- 3025: -

| ID | WBS | Task | Duration | Start | Finish | Complete | Baseline start | Baseline finish | Baseline duration | Constraint | Resources | Work | Actual work | Text6 | Text8 | Text1 | Text4 | Text5 |
| --- | --- | --- | --- | --- | --- | --- | --- | --- | --- | --- | --- | --- | --- | --- | --- | --- | --- | --- |
| 3026 | 109.1.2 | **Physical layer alignment with UMTS bearer concept** | 280d | 2000-11-06 A | 2001-11-30 A | 100% | 2000-11-06 | 2001-11-30 | 280d |  | GP | 6960h | 6960h | Rel-5 | Paolo |  |  |  |
| 3027 | 109.1.2.1 | PDTCH/TCH in 45.003 | 155d | 2000-11-06 A | 2001-06-08 A | 100% | 2000-11-06 | 2001-06-08 | 155d | finish no earlier than 2001-06-08 | GP | 1240h | 1240h | Rel-5 | Paolo |  |  |  |
| 3028 | 109.1.2.2 | Control channels in 45.003 | 155d | 2000-11-06 A | 2001-06-08 A | 100% | 2000-11-06 | 2001-06-08 | 155d | finish no earlier than 2001-06-08 | GP | 1240h | 1240h | Rel-5 | Paolo |  |  |  |
| 3029 | 109.1.2.3 | Receiver performance in 45.005 for PDTCH/TCH and control channels | 280d | 2000-11-06 A | 2001-11-30 A | 100% | 2000-11-06 | 2001-11-30 | 280d | finish no earlier than 2001-11-30 | GP | 2240h | 2240h | Rel-5 | Paolo |  |  |  |
| 3030 | 109.2 | **Iu rg interface** | 430d | 2000-11-06 A | 2002-06-28 A | 100% | 2000-11-06 | 2002-06-28 | 430d |  | GP,RP | 39560h | 39560h | Rel-5 | Paolo | GER3GAL-Iurg | Ericsson | Frank Muller |
| 3031 | 109.2.1 | **Inter BSS interface** | 430d | 2000-11-06 A | 2002-06-28 A | 100% | 2000-11-06 | 2002-06-28 | 430d |  | GP,RP | 20640h | 20640h | Rel-5 | Paolo |  |  |  |
| 3032 | 109.2.1.1 | Identification of requirements for Inter BSS interface | 430d | 2000-11-06 A | 2002-06-28 A | 100% | 2000-11-06 | 2002-06-28 | 430d | finish no earlier than 2002-06-28 | GP | 3440h | 3440h | Rel-5 | Paolo |  |  |  |
| 3033 | 109.2.1.2 | Stage 2 for Inter BSS interface | 430d | 2000-11-06 A | 2002-06-28 A | 100% | 2000-11-06 | 2002-06-28 | 430d | finish no earlier than 2002-06-28 | GP | 3440h | 3440h | Rel-5 | Paolo |  |  |  |
| 3034 | 109.2.1.3 | Adoption of relevant parts from Iur - for Inter BSS interface | 430d | 2000-11-06 A | 2002-06-28 A | 100% | 2000-11-06 | 2002-06-28 | 430d | finish no earlier than 2002-06-28 | GP | 3440h | 3440h | Rel-5 | Paolo |  |  |  |
| 3035 | 109.2.1.4 | Complementation with GERAN specifics - for Inter BSS interface | 430d | 2000-11-06 A | 2002-06-28 A | 100% | 2000-11-06 | 2002-06-28 | 430d | finish no earlier than 2002-06-28 | GP | 3440h | 3440h | Rel-5 | Paolo |  |  |  |
| 3036 | 109.2.1.5 | Stage 3 for Inter BSS interface | 430d | 2000-11-06 A | 2002-06-28 A | 100% | 2000-11-06 | 2002-06-28 | 430d | finish no earlier than 2002-06-28 | GP | 3440h | 3440h | Rel-5 | Paolo |  |  |  |
| 3037 | 109.2.2 | **Inter BSS-RNS interface** | 430d | 2000-11-06 A | 2002-06-28 A | 100% | 2000-11-06 | 2002-06-28 | 430d |  | GP,RP | 15480h | 15480h | Rel-5 | Paolo |  |  |  |
| 3038 | 109.2.2.1 | Identification of requirements for Inter BSS-RNS interface | 430d | 2000-11-06 A | 2002-06-28 A | 100% | 2000-11-06 | 2002-06-28 | 430d | start no earlier than 2000-11-06 | GP,R3 | 3440h | 3440h | Rel-5 | Paolo |  |  |  |
| 3039 | 109.2.2.2 | Stage 2 for Inter BSS-RNS interface | 430d | 2000-11-06 A | 2002-06-28 A | 100% | 2000-11-06 | 2002-06-28 | 430d | finish no earlier than 2002-06-28 | GP,R3 | 3440h | 3440h | Rel-5 | Paolo |  |  |  |
| 3040 | 109.2.2.3 | Adoption of relevant parts from Iur - for Inter BSS-RNS interface | 430d | 2000-11-06 A | 2002-06-28 A | 100% | 2000-11-06 | 2002-06-28 | 430d | finish no earlier than 2002-06-28 | GP,R3 | 3440h | 3440h | Rel-5 | Paolo |  |  |  |
| 3041 | 109.2.2.4 | Complementation with GERAN specifics - for Inter BSS-RNS interface | 107.5d | 2002-01-30 A | 2002-06-28 A | 100% | 2002-01-30 | 2002-06-28 | 107.5d | finish no earlier than 2002-06-28 | GP,R3 | 860h | 860h | Rel-5 | Paolo |  |  |  |
| 3042 | 109.2.2.5 | Stage 3 for Inter BSS-RNS interface | 107.5d | 2002-01-30 A | 2002-06-28 A | 100% | 2002-01-30 | 2002-06-28 | 107.5d | finish no earlier than 2002-06-28 | GP,R3 | 860h | 860h | Rel-5 | Paolo |  |  |  |
| 3043 | 109.3 | **Voice over GERAN PS and CS concept** | 430d | 2000-11-06 A | 2002-06-28 A | 100% | 2000-11-06 | 2002-06-28 | 430d |  | GP,R3 | 18520h | 18520h | Rel-5 | Paolo |  |  |  |
| 3044 | 109.3.1 | Architecture for A, Iu cs and Iu ps | 430d | 2000-11-06 A | 2002-06-28 A | 100% | 2000-11-06 | 2002-06-28 | 430d | finish no earlier than 2002-06-28 | GP,R3 | 3440h | 3440h | Rel-5 | Paolo |  |  |  |
| 3045 | 109.3.2 | Transcoder position/operation | 115d | 2000-11-06 A | 2001-04-13 A | 100% | 2000-11-06 | 2001-04-13 | 115d | finish no earlier than 2001-04-13 | GP | 920h | 920h | Rel-5 | Paolo |  |  |  |
| 3046 | 109.3.3 | Handover for Voice over GERAN PS and CS | 430d | 2000-11-06 A | 2002-06-28 A | 100% | 2000-11-06 | 2002-06-28 | 430d | finish no earlier than 2002-06-28 | GP,R3 | 3440h | 3440h | Rel-5 | Paolo |  |  |  |
| 3047 | 109.3.4 | RTP payload | 430d | 2000-11-06 A | 2002-06-28 A | 100% | 2000-11-06 | 2002-06-28 | 430d | finish no earlier than 2002-06-28 | GP,R3 | 3440h | 3440h | Rel-5 | Paolo |  |  |  |
| 3048 | 109.3.5 | Codec renegotiation concept | 365d | 2000-11-06 A | 2002-03-29 A | 100% | 2000-11-06 | 2002-03-29 | 365d | finish no earlier than 2002-03-29 | GP,R3 | 2920h | 2920h | Rel-5 | Paolo |  |  |  |
| 3049 | 109.3.6 | LA | 115d | 2000-11-06 A | 2001-04-13 A | 100% | 2000-11-06 | 2001-04-13 | 115d | finish no earlier than 2001-04-13 | GP | 920h | 920h | Rel-5 | Paolo |  |  |  |

Notes:
- 3026: -
- 3027: -
- 3028: -
- 3029: -
- 3030: AWS, Nokia, Ericsson, Nortel, Siemens, Vodafone
- 3031: -
- 3032: -
- 3033: -
- 3034: -
- 3035: -
- 3036: -
- 3037: -
- 3038: -
- 3039: -
- 3040: -
- 3041: -
- 3042: -
- 3043: -
- 3044: -
- 3045: -
- 3046: -
- 3047: -
- 3048: -
- 3049: -

| ID | WBS | Task | Duration | Start | Finish | Complete | Baseline start | Baseline finish | Baseline duration | Constraint | Resources | Work | Actual work | Text6 | Text8 | Text12 | Text1 | Text4 | Text5 | Text3 |
| --- | --- | --- | --- | --- | --- | --- | --- | --- | --- | --- | --- | --- | --- | --- | --- | --- | --- | --- | --- | --- |
| 3050 | 109.4 | **Deleted - GERAN MS Conformance test for GERAN interface evolution** | 660d | 2001-06-11 A | 2003-12-19 A | 100% | 2001-06-11 | 2003-12-19 | 660d |  | GP | 10560h | 10560h | Rel-5 | Paolo | GP-17 |  |  |  |  |
| 3051 | 109.4.1 | Deleted - MS test for GERAN interface evolution | 660d | 2001-06-11 A | 2003-12-19 A | 100% | 2001-06-11 | 2003-12-19 | 660d | finish no earlier than 2003-12-19 | GP | 5280h | 5280h | Rel-5 | Paolo | GP-17 |  |  |  |  |
| 3052 | 109.5 | **GERAN BSS Conformance test for GERAN interface evolution** | 922d | 2000-06-08 A | 2003-12-19 A | 100% | 2000-06-08 | 2003-12-19 | 922d |  | GP | 14752h | 14752h | Rel-5 | Paolo |  |  |  |  |  |
| 3053 | 109.5.1 | Deleted - BSS test | 922d | 2000-06-08 A | 2003-12-19 A | 100% | 2000-06-08 | 2003-12-19 | 922d | finish no earlier than 2003-12-19 | GP | 7376h | 7376h | Rel-5 | Paolo | GP-17 |  |  |  |  |
| 3054 | 110 | **GERAN support for IMS** | 690d | 2000-05-01 A | 2002-12-20 A | 100% | 2000-05-01 | 2002-12-20 | 690d |  | GP | 35998.4h | 35998.4h | Rel-5 | Paolo |  | GERIMS | Nokia | Shkumbin Hamiti |  |
| 3055 | 110.1 | **GERAN Header adaptation** | 690d | 2000-05-01 A | 2002-12-20 A | 100% | 2000-05-01 | 2002-12-20 | 690d |  | GP,S2,RP | 12302.8h | 12302.8h | Rel-5 | Paolo |  | GERIMS-HEADAPT | Nokia | Shkumbin Hamiti |  |
| 3056 | 110.1.1 | Definition of compression and removal modes for PDCP protocol | 15.05d | 2000-05-01 A | 2000-06-09 A | 100% | 2000-05-01 | 2000-06-09 | 15.05d | finish no earlier than 2000-09-01 | GP,S2,RP | 120.4h | 120.4h | Rel-5 | Paolo |  |  |  |  |  |
| 3057 | 110.1.2 | Conceptual description in stage 2 | 393d | 2000-05-01 A | 2001-10-31 A | 100% | 2000-05-01 | 2001-10-31 | 393d | finish no earlier than 2001-10-31 | GP,S2,RP | 3144h | 3144h | Rel-5 | Paolo |  |  |  |  |  |
| 3058 | 110.1.3 | Necessary changes on stage 3 regarding header removal | 439.8d | 2000-11-06 A | 2002-12-20 A | 100% | 2000-11-06 | 2002-12-20 | 439.8d | finish no earlier than 2002-12-20 | GP,S2,RP | 3518.4h | 3518.4h | Rel-5 | Paolo |  |  |  |  |  |
| 3059 | 110.2 | **Deleted - GERAN Radio access bearer design for IMS** | 430d | 2000-11-06 A | 2002-06-28 A | 100% | 2000-11-06 | 2002-06-28 | 430d |  | GP,S2,RP | 9287.6h | 9287.6h | Rel-5 | Paolo | GP-10 | GERIMS-RABDES | Nokia | Shkumbin Hamiti |  |
| 3060 | 110.2.1 | **Deleted - MuM control signalling for conversational multimedia services** | 430d | 2000-11-06 A | 2002-06-28 A | 100% | 2000-11-06 | 2002-06-28 | 430d |  | GP,S2,RP | 5847.6h | 5847.6h | Rel-5 | Paolo | GP-10 |  |  |  |  |
| 3061 | 110.2.1.1 | Deleted - Identification of requirements for MuM control signalling for conversational multimedia services | 330d | 2000-11-06 A | 2002-02-08 A | 100% | 2000-11-06 | 2002-02-08 | 330d | finish no earlier than 2002-02-08 | GP,S2,RP | 2640h | 2640h | Rel-5 | Paolo | GP-08 |  |  |  |  |
| 3062 | 110.2.1.2 | Deleted - Necessary modifications due to SIP | 40d | 2002-05-06 A | 2002-06-28 A | 100% | 2002-05-06 | 2002-06-28 | 40d | finish no earlier than 2002-06-28 | GP,S2,RP | 320h | 320h | Rel-5 | Paolo | GP-10 |  |  |  |  |
| 3063 | 110.3 | **Deleted - GERAN MS Conformance test for support of IMS** | 400d | 2001-06-11 A | 2002-12-20 A | 100% | 2001-06-11 | 2002-12-20 | 400d |  | GP | 6400h | 6400h | Rel-5 | Paolo | GP-12 | GERIMS-MSconf | Nokia | Shkumbin Hamiti |  |
| 3064 | 110.3.1 | Deleted - MS test for support of IMS | 400d | 2001-06-11 A | 2002-12-20 A | 100% | 2001-06-11 | 2002-12-20 | 400d | finish no earlier than 2002-12-20 | G4 | 3200h | 3200h | Rel-5 | Paolo | GP-12 |  |  |  |  |
| 3065 | 110.4 | Deleted - GERAN BTS Conformance test for support of IMS | 400d | 2001-06-11 A | 2002-12-20 A | 100% | 2001-06-11 | 2002-12-20 | 400d |  | GP | 3200h | 3200h | Rel-5 | Paolo | GP-12 | GERIMS-BTSconf | Nokia | Shkumbin Hamiti |  |
| 3066 | 846 | MS Conformance Testing of Dual Transfer Mode | 65d? | 2002-11-11 A | 2003-02-07 A | 100% | 2002-11-11 | 2003-02-07 | 65d? | finish no earlier than 2003-02-07 | G4,G5 | 520h | 520h | Rel-5 | Paolo |  | MSCTDTM | Vodafone | Dave Fox |  |
| 3067 | 847 | **Handling of early Ues** | 911d? | 2000-01-03 A | 2003-06-27 A | 100% | 2000-01-03 | 2003-06-27 | 911d? |  | S2 | 4488h | 4488h | Rel-5 | Maurice |  | LATE_UE |  |  |  |
| 3068 | 847.1 | Feasibility Study on Handling of early Ues | 50d? | 2002-10-07 A | 2002-12-13 A | 100% | 2002-10-07 | 2002-12-13 | 50d? | finish no earlier than 2002-12-13 | S2 | 400h | 400h | Rel-5 | Maurice |  |  |  |  |  |
| 3069 | 847.2 | Stage 2 for Handling of early Ues | 125d? | 2003-01-06 A | 2003-06-27 A | 100% | 2003-01-06 | 2003-06-27 | 125d? | start no earlier than 2003-01-06 | S2 | 1000h | 1000h | Rel-5 | Maurice |  |  |  |  |  |
| 3070 | 847.3 | FS for the Early Mobile Handling in UTRAN | 195d | 2002-09-09 A | 2003-06-06 A | 100% | 2002-09-09 | 2003-06-06 | 195d | finish no earlier than 2003-06-06 | R2 | 1560h | 1560h | Rel-5 | Joern |  | FSEarlyUE | Vodafone | alan.law@vodafone.com |  |
| 3071 | 847.4 | Note: Stage 3 RAN part not shown | 1d | 2000-01-03 A | 2000-01-03 A | 100% | 2000-01-03 | 2000-01-03 | 1d |  | RP | 8h | 8h | Rel-5 |  |  |  |  |  |  |
| 3072 | 848 | Release 4 Features | 326d? | 2000-01-03 A | 2001-03-30 A | 100% | 2000-01-03 | 2001-03-30 | 326d? |  | NP,GP, RP,SP,TP | 2608h | 2608h | Rel-4 | All |  |  |  |  |  |
| 3073 | 15 | **Miscellaneous UE Conformance Testing Activities** | 958d | 2001-04-02 A | 2004-12-01 A | 100% | 2001-04-02 | 2004-12-01 | 958d |  | T1 | 36360h | 36360h | Rel-4 | Ingbert |  | MISTST1 |  |  |  |
| 3074 | 15.1 | Optimization of Test Time, RF Aspects (FDD) | 508d | 2001-09-24 A | 2003-09-03 A | 100% | 2001-09-24 | 2003-09-03 | 508d | finish no earlier than 2003-09-03 | T1 | 4064h | 4064h | Rel-4 | Ingbert |  | MISTST1-OpFDD |  |  | 34.121 |
| 3075 | 15.2 | Optimization of Test Time, RF Aspects (TDD) | 508d | 2001-09-24 A | 2003-09-03 A | 100% | 2001-09-24 | 2003-09-03 | 508d | finish no earlier than 2003-09-03 | T1 | 4064h | 4064h | Rel-4 | Ingbert |  | MISTST1-OpTDD |  |  | 34.122 |
| 3076 | 15.3 | Extensions to R99 Test cases | 139.4w | 2001-04-02 A | 2003-12-02 A | 100% | 2001-04-02 | 2003-12-02 | 139.4w | finish no earlier than 2003-12-02 | T1 | 5576h | 5576h | Rel-4 | Ingbert |  | MISTST1-Ext |  |  | 34.123 p 1,2 |
| 3077 | 15.4 | Extension to R99 Test cases - TTCN | 439d | 2002-06-28 A | 2004-03-03 A | 100% | 2002-06-28 | 2004-03-03 | 439d | finish no earlier than 2004-03-03 | T1 | 3512h | 3512h | Rel-4 | Ingbert |  |  |  |  |  |
| 3078 | 15.5 | Creation of R99 TCs for TDD - prose | 719d | 2001-10-01 A | 2004-07-01 A | 100% | 2001-10-01 | 2004-07-01 | 719d | finish no earlier than 2004-07-01 | T1 | 5752h | 5752h | Rel-4 | Ingbert |  | MISTST1-TDD |  |  | 34.123-1 |
| 3079 | 15.6 | Deleted - Creation of R99 TCs for TDD - TTCN | 587d | 2002-09-03 A | 2004-12-01 A | 100% | 2002-09-03 | 2004-12-01 | 587d | finish no earlier than 2004-12-01 | T1 | 4696h | 4696h | Rel-4 | Ingbert | TP-26 |  |  |  |  |
| 3080 | 15.7 | Deleted - Review all other work items for impact on new or exiting 34 series specs. | 25.8w | 2002-07-02 A | 2002-12-27 A | 100% | 2002-07-02 | 2002-12-27 | 25.8w | finish no earlier than 2002-12-27 | T1 | 1032h | 1032h | Rel-4 | Ingbert | TP-18 | MISTST1 |  |  | 34.121,122,123,125 |

Notes:
- 3050: Not started. Marked as stopped 12/2008
- 3051: Not started. Marked as stopped 12/2008
- 3052: Not started. Marked as stopped 12/2008
- 3053: Not started. Marked as stopped 12/2008
- 3054: AWS, Nokia, Ericsson, Nortel, Siemens, Motorola
- 3055: AWS, Nokia, Ericsson, Nortel, Siemens, Motorola
- 3056: -
- 3057: -
- 3058: -
- 3059: TERMINATED - NOT STANDARDIZED. Marked as stopped 12/2008
- 3060: TERMINATED - NOT STANDARDIZED. Marked as stopped 12/2008
- 3061: TERMINATED - NOT STANDARDIZED
- 3062: TERMINATED - NOT STANDARDIZED
- 3063: TERMINATED - NOT STANDARDIZED. Marked as stopped 12/2008
- 3064: TERMINATED - NOT STANDARDIZED. Marked as stopped 12/2008
- 3065: TERMINATED - NOT STANDARDIZED. Marked as stopped 12/2008
- 3066: Needed to complete DTM (R99)
- 3067: -
- 3068: -
- 3069: -
- 3070: -
- 3071: -
- 3072: -
- 3073: -
- 3074: It is believed that the current R99 test spec. can be optimised for faster overall test times. Marked as stopped 12/2008 (was 70% complete)
- 3075: It is believed that the current R99 test spec. can be optimised for faster overall test times
- 3076: Further test coverage of the R99 specification to cover supplementry services. Marked as stopped 12/2008 (was 70% complete)
- 3077: Marked as closed 12/2008 (was marked 50% complete)
- 3078: Marked as closed 12/2008 (was marked 50% complete)
- 3079: Marked as stopped 12/2008
- 3080: Marked as stopped 12/2008

| ID | WBS | Task | Duration | Start | Finish | Predecessors | Complete | Baseline start | Baseline finish | Baseline duration | Constraint | Resources | Work | Actual work | Text1 | Text6 | Text8 | Text3 | Text4 | Text5 |
| --- | --- | --- | --- | --- | --- | --- | --- | --- | --- | --- | --- | --- | --- | --- | --- | --- | --- | --- | --- | --- |
| 3081 | 46 | **Real Time Facsimile** | 89d | 2000-02-22 A | 2000-06-23 A |  | 100% | 2000-02-22 | 2000-06-23 | 89d |  | S1 | 4376h | 4376h | FAX-RT | Rel-4 | Alain |  |  |  |
| 3082 | 46.1 | **Real Time Fax** | 89d | 2000-02-22 A | 2000-06-23 A |  | 100% | 2000-02-22 | 2000-06-23 | 89d |  | S2 | 3664h | 3664h | FAX-RT | Rel-4 | Maurice |  |  |  |
| 3083 | 46.1.1 | Terminal capabilities, AT commands | 89d | 2000-02-22 A | 2000-06-23 A |  | 100% | 2000-02-22 | 2000-06-23 | 89d | finish no earlier than 2000-06-23 | T2 | 712h | 712h | FAX-RT | Rel-4 |  | 21.904, 27.007 |  |  |
| 3084 | 46.1.2 | Signalling aspects (e.g. ICM) | 89d | 2000-02-22 A | 2000-06-23 A |  | 100% | 2000-02-22 | 2000-06-23 | 89d | start no earlier than 2000-02-22 | N1 | 712h | 712h | FAX-RT | Rel-4 | Frederic |  |  |  |
| 3085 | 46.1.3 | Service provision | 89d | 2000-02-22 A | 2000-06-23 A |  | 100% | 2000-02-22 | 2000-06-23 | 89d | finish no earlier than 2000-06-23 | N3 | 712h | 712h | FAX-RT | Rel-4 | Gwiho | 23.146 |  |  |
| 3086 | 46.1.4 | Review whether service/stage 1 aspects need to be aligned | 51d | 2000-04-14 A | 2000-06-23 A |  | 100% | 2000-04-14 | 2000-06-23 | 51d | finish no earlier than 2000-12-14 | S1 | 408h | 408h | FAX-RT | Rel-4 | Alain |  |  |  |
| 3087 | 46.1.5 | Review whether architecture/stage 2 aspects need to be aligned | 51d | 2000-04-14 A | 2000-06-23 A |  | 100% | 2000-04-14 | 2000-06-23 | 51d | finish no earlier than 2000-12-14 | S2 | 408h | 408h | FAX-RT | Rel-4 | Maurice |  |  |  |
| 3088 | 47 | Transparent End-to-End PS mobile streaming application | 253d | 2000-04-03 A | 2001-03-21 A |  | 100% | 2000-04-03 | 2001-03-21 | 253d | finish no earlier than 2000-12-29 | S4 | 2024h | 2024h | PSTREAM | Rel-4 | Paolo | 26.233, 26.234 |  |  |
| 3089 | 48 | **Multimedia Messaging** | 277d | 2000-02-22 A | 2001-03-14 A |  | 100% | 2000-02-22 | 2001-03-14 | 277d |  | T2,S1 | 9992h | 9992h | MMS | Rel-4 | Kimmo | 22.140, 23.140 | Siemens | Josef.Laumen@SAL.SIEMENS.DE |
| 3090 | 48.1 | Definition of service requirements for Multimedia Messaging | 72d | 2000-02-22 A | 2000-05-31 A |  | 100% | 2000-02-22 | 2000-05-31 | 72d | start no earlier than 2000-02-22 | S1 | 576h | 576h | MMS | Rel-4 | Alain |  |  |  |
| 3091 | 48.2 | Review of definition of service requirements | 205d | 2000-06-01 A | 2001-03-14 A | 3090 | 100% | 2000-06-01 | 2001-03-14 | 205d | finish no earlier than 2000-09-08 | T2 | 1640h | 1640h | MMS | Rel-4 | Kimmo | 22.140, 23.140 | Siemens |  |
| 3092 | 48.3 | **Technical Realisation** | 243d | 2000-04-10 A | 2001-03-14 A |  | 100% | 2000-04-10 | 2001-03-14 | 243d |  | T2 | 7776h | 7776h | MMS | Rel-4 | Kimmo | 22.140, 23.140 | Siemens | Josef.Laumen@SAL.SIEMENS.DE |
| 3093 | 48.3.1 | Review of definition of reference Achitecture model | 243d | 2000-04-10 A | 2001-03-14 A |  | 100% | 2000-04-10 | 2001-03-14 | 243d | finish no earlier than 2001-03-14 | T2 | 1944h | 1944h | MMS | Rel-4 | Kimmo | 22.140, 23.140 | Siemens | Josef.Laumen@SAL.SIEMENS.DE |
| 3094 | 48.3.2 | Fulfill Requirements of Stage 1 | 243d | 2000-04-10 A | 2001-03-14 A |  | 100% | 2000-04-10 | 2001-03-14 | 243d | finish no earlier than 2001-03-14 | T2 | 1944h | 1944h | MMS | Rel-4 | Kimmo | 22.140, 23.140 | Siemens | Josef.Laumen@SAL.SIEMENS.DE |
| 3095 | 48.3.3 | Definition of MMS primitives in Stage 2 | 243d | 2000-04-10 A | 2001-03-14 A |  | 100% | 2000-04-10 | 2001-03-14 | 243d | finish no earlier than 2001-03-14 | T2 | 1944h | 1944h | MMS | Rel-4 | Kimmo | 22.140, 23.140 | Siemens | Josef.Laumen@SAL.SIEMENS.DE |
| 3096 | 49 | **Transcoder-Free Operation** | 326d | 2000-01-03 A | 2001-03-30 A |  | 100% | 2000-01-03 | 2001-03-30 | 326d |  | N4,S2,N1 | 10448h | 10448h | TrFO | Rel-4 | Kimmo |  |  |  |
| 3097 | 49.1 | **Out-of-Band Transcoder Control solution** | 326d | 2000-01-03 A | 2001-03-30 A |  | 100% | 2000-01-03 | 2001-03-30 | 326d |  | N4 | 8448h | 8448h | TrFO-OoBTC | Rel-4 | Kimmo |  | NEC | Toshiyuki Tamura (tamurato@aj.jp.nec.com) |
| 3098 | 49.1.1 | implementation in UTRAN | 145d | 2000-09-11 A | 2001-03-30 A |  | 100% | 2000-09-11 | 2001-03-30 | 145d | finish no earlier than 2001-03-30 | R3 | 1160h | 1160h | TrFO-OoBTC-UTRAN | Rel-4 | Juha | 25.401, 25.410, 25.413, 25.415, 23.153 | Siemens | Alexander Vesely |
| 3099 | 49.1.2 | Impact on architecture, Principles and Terminology | 211d | 2000-01-03 A | 2000-10-20 A |  | 100% | 2000-01-03 | 2000-10-20 | 211d | finish no earlier than 2000-10-20 | S2 | 1680h | 1680h | TrFO-OoBTC | Rel-4 | Maurice |  |  |  |
| 3100 | 49.1.3 | Codec Negotiation between UE and MSC | 125d | 2000-08-14 A | 2001-02-02 A |  | 100% | 2000-08-14 | 2001-02-02 | 125d | finish no earlier than 2001-02-02 | N1 | 1000h | 1000h | TrFO-OoBTC | Rel-4 | Frederic | 24.008, 23.009, 23.108, (29.002) | Motorola | Andrew Howell |
| 3101 | 49.1.4 | Codec Negotiation inter MSC | 125d | 2000-07-03 A | 2000-12-22 A |  | 100% | 2000-07-03 | 2000-12-22 | 125d | finish no earlier than 2000-12-22 | N4 | 1000h | 1000h | TrFO-OoBTC | Rel-4 | Kimmo |  |  |  |
| 3102 | 49.1.5 | Bearer establishment inter MSC | 125d | 2000-07-03 A | 2000-12-22 A |  | 100% | 2000-07-03 | 2000-12-22 | 125d | finish no earlier than 2000-12-22 | N4 | 1000h | 1000h | TrFO-OoBTC | Rel-4 | Kimmo | 23.153 |  |  |
| 3103 | 49.2 | **Speech Transcoder: Location and Control at the UMTS Core Network Border** | 125d | 2000-04-10 A | 2000-09-29 A |  | 100% | 2000-04-10 | 2000-09-29 | 125d |  | S2 | 2000h | 2000h | TrFO-STLC | Rel-4 | Maurice |  |  |  |
| 3104 | 49.2.1 | Transcoder at Edge | 125d | 2000-04-10 A | 2000-09-29 A |  | 100% | 2000-04-10 | 2000-09-29 | 125d | finish no earlier than 2000-09-29 | NP | 1000h | 1000h | TrFO-STLC | Rel-4 | Kimmo |  |  |  |

Notes:
- 3081: -
- 3082: postponed from R99 to R00, SP-000169
- 3083: -
- 3084: -
- 3085: -
- 3086: -
- 3087: -
- 3088: -
- 3089: -
- 3090: -
- 3091: -
- 3092: -
- 3093: -
- 3094: e.g. minimum set of media formats, media format conversion, personalization of MMS.
- 3095: -
- 3096: Lead given to CN4 from CN / [DAB 28/11/00]
- 3097: -
- 3098: moved according to NP-000575
- 3099: e.g. study cascading TrFO/TFO/TrFO
- 3100: the link to NP-000085has been deleted because refering to a R99 status sheet / One common set of codec negotiation procedures will be specified as in ID1656.
- 3101: Bearer establishment inter MSC. TS 23.153 R99 part complete. capabilities moved to annex + list of open issues
- 3102: Bearer establishment inter MSC. TS 23.153 R99 part complete. capabilities moved to annex. / See NP-000127 / Open issues: / Handling of Conference Calls; / Handling of Multi Party Supplementary Services; / Handling of Handover UMTS to GSM; / Handling of Sending a ...
- 3103: WI description and Tdoc S2-99352 / Speech Transcoder: Location and Control at the UMTS Core Network Border
- 3104: WI description and Tdoc S2-99352...

| ID | WBS | Task | Duration | Start | Finish | Complete | Baseline start | Baseline finish | Baseline duration | Constraint | Resources | Work | Actual work | Text1 | Text6 | Text8 | Text4 | Text5 |
| --- | --- | --- | --- | --- | --- | --- | --- | --- | --- | --- | --- | --- | --- | --- | --- | --- | --- | --- |
| 3105 | 50 | **GERAN improvements 1 (Gb over IP)** | 225d | 2000-05-09 A | 2001-03-19 A | 100% | 2000-05-09 | 2001-03-19 | 225d |  | GP | 6472h | 6472h | GEIMP1 | Rel-4 | Paolo |  |  |
| 3106 | 50.1 | **Gb over IP (Ip-fication of Gb)** | 225d | 2000-05-09 A | 2001-03-19 A | 100% | 2000-05-09 | 2001-03-19 | 225d |  | GP | 4672h | 4672h | GbIP | Rel-4 | Paolo |  |  |
| 3107 | 50.1.1 | Concept of Gb over IP (Ip-fication of Gb) | 134d | 2000-05-09 A | 2000-11-10 A | 100% | 2000-05-09 | 2000-11-10 | 134d |  | GP | 1072h | 1072h |  | Rel-4 | Paolo |  |  |
| 3108 | 50.1.2 | Changes to 08.16, 08.18 | 225d | 2000-05-09 A | 2001-03-19 A | 100% | 2000-05-09 | 2001-03-19 | 225d |  | GP | 1800h | 1800h |  | Rel-4 | Paolo |  |  |
| 3109 | 51 | **GERAN improvements 2 (NACC)** | 677d | 2000-11-06 A | 2003-06-10 A | 100% | 2000-11-06 | 2003-06-10 | 677d |  | GP | 19224h | 19224h | GEIMP2 | Rel-4 | Paolo |  |  |
| 3110 | 51.1 | **Gb enhancements** | 155d | 2000-11-06 A | 2001-06-08 A | 100% | 2000-11-06 | 2001-06-08 | 155d |  | GP | 7440h | 7440h | Gben | Rel-4 | Paolo |  |  |
| 3111 | 51.1.1 | **Intra BSC NACC (Network Assisted Cell Change)** | 155d | 2000-11-06 A | 2001-06-08 A | 100% | 2000-11-06 | 2001-06-08 | 155d |  | GP | 6200h | 6200h |  | Rel-4 | Paolo |  |  |
| 3112 | 51.1.1.1 | Concept | 155d | 2000-11-06 A | 2001-06-08 A | 100% | 2000-11-06 | 2001-06-08 | 155d | finish no earlier than 2001-06-08 | GP | 1240h | 1240h |  | Rel-4 | Paolo |  |  |
| 3113 | 51.1.1.2 | Changes in 03.64 | 155d | 2000-11-06 A | 2001-06-08 A | 100% | 2000-11-06 | 2001-06-08 | 155d | finish no earlier than 2001-06-08 | GP | 1240h | 1240h |  | Rel-4 | Paolo |  |  |
| 3114 | 51.1.1.3 | Changes in 04.60 | 155d | 2000-11-06 A | 2001-06-08 A | 100% | 2000-11-06 | 2001-06-08 | 155d | finish no earlier than 2001-06-08 | GP | 1240h | 1240h |  | Rel-4 | Paolo |  |  |
| 3115 | 51.1.1.4 | Changes in 44.008 | 155d | 2000-11-06 A | 2001-06-08 A | 100% | 2000-11-06 | 2001-06-08 | 155d | finish no earlier than 2001-06-08 | GP | 1240h | 1240h |  | Rel-4 | Paolo |  |  |
| 3116 | 51.3 | **MS conformance test for Intra BSC NACC** | 398d | 2001-11-30 A | 2003-06-10 A | 100% | 2001-11-30 | 2003-06-10 | 398d |  | GP | 6368h | 6368h | GEIMP2-Msconf | Rel-4 | Paolo |  |  |
| 3117 | 51.3.1 | Changes in 51.010 | 398d | 2001-11-30 A | 2003-06-10 A | 100% | 2001-11-30 | 2003-06-10 | 398d | finish no earlier than 2003-12-19 | G5,G4 | 3184h | 3184h |  | Rel-4 | Paolo |  |  |
| 3118 | 52 | **GERAN improvements 4 (Delayed TBF)** | 105d | 2001-01-15 A | 2001-06-08 A | 100% | 2001-01-15 | 2001-06-08 | 105d |  | GP | 3960h | 3960h | GEIMP4 | Rel-4 | Paolo |  |  |
| 3119 | 52.1 | **Gb enhancements 2** | 105d | 2001-01-15 A | 2001-06-08 A | 100% | 2001-01-15 | 2001-06-08 | 105d |  | GP | 3120h | 3120h | GEIMP4-Gben2 | Rel-4 | Paolo |  |  |
| 3120 | 52.1.1 | Stage 2 for Gb enhancements 2 | 105d | 2001-01-15 A | 2001-06-08 A | 100% | 2001-01-15 | 2001-06-08 | 105d | finish no earlier than 2001-06-08 | GP | 840h | 840h |  | Rel-4 | Paolo |  |  |
| 3121 | 52.1.2 | **Stage 3 (changes in 44.060)** | 60d | 2001-01-15 A | 2001-04-06 A | 100% | 2001-01-15 | 2001-04-06 | 60d |  | G2 | 1440h | 1440h |  | Rel-4 | Gert |  |  |
| 3122 | 52.1.2.1 | Definition of enhanced countdown procedure | 60d | 2001-01-15 A | 2001-04-06 A | 100% | 2001-01-15 | 2001-04-06 | 60d | finish no earlier than 2001-04-06 | G2 | 480h | 480h |  | Rel-4 | Gert |  |  |
| 3123 | 52.1.2.2 | Definition of enhanced TBF release procedure | 60d | 2001-01-15 A | 2001-04-06 A | 100% | 2001-01-15 | 2001-04-06 | 60d | finish no earlier than 2001-04-06 | G2 | 480h | 480h |  | Rel-4 | Gert |  |  |
| 3124 | 52.1.2.3 | Definition of USF=FREE type polling mechanism on PDCH | 60d | 2001-01-15 A | 2001-04-06 A | 100% | 2001-01-15 | 2001-04-06 | 60d | finish no earlier than 2001-04-06 | G2 | 480h | 480h |  | Rel-4 | Gert |  |  |
| 3125 | 53 | **Low Chip Rate TDD option** | 880d | 2000-07-19 A | 2003-12-02 A | 100% | 2000-07-19 | 2003-12-02 | 880d |  | R1 | 27488h | 27488h | LCRTDD | Rel-4 | Patrick | CWTS | G. Yang |
| 3126 | 53.1 | Physical layer for Low Chip Rate TDD option | 183d | 2000-07-19 A | 2001-03-30 A | 100% | 2000-07-19 | 2001-03-30 | 183d | finish no earlier than 2001-03-30 | R1 | 1464h | 1464h | LCRTDD-Phys | Rel-4 | Patrick | CWTS | G. Yang |
| 3127 | 53.2 | Layer 2 and layer 3 protocol aspects | 183d | 2000-07-19 A | 2001-03-30 A | 100% | 2000-07-19 | 2001-03-30 | 183d | finish no earlier than 2001-03-30 | R2 | 1464h | 1464h | LCRTDD-L23 | Rel-4 | Joern | CWTS | Y. Liu |
| 3128 | 53.3 | RF radio transmission/reception, system performance requirements and conformance testing | 165d | 2000-08-14 A | 2001-03-30 A | 100% | 2000-08-14 | 2001-03-30 | 165d | finish no earlier than 2001-03-30 | R4 | 1320h | 1320h | LCRTDD-RF | Rel-4 | Issam | CWTS | D. Zhang |
| 3129 | 53.4 | UE radio access capability | 165d | 2000-08-14 A | 2001-03-30 A | 100% | 2000-08-14 | 2001-03-30 | 165d | finish no earlier than 2001-03-30 | R2 | 1320h | 1320h | LCRTDD-UErac | Rel-4 | Joern | CWTS | Y. Liu |
| 3130 | 53.5 | Iub/Iur protocol aspects - for Low Chip Rate TDD option | 165d | 2000-08-14 A | 2001-03-30 A | 100% | 2000-08-14 | 2001-03-30 | 165d | finish no earlier than 2001-03-30 | R3 | 1320h | 1320h | LCRTDD-IubIur | Rel-4 | Juha | CWTS | Y. Liu |

Notes:
- 3105: -
- 3106: -
- 3107: -
- 3108: -
- 3109: -
- 3110: -
- 3111: -
- 3112: -
- 3113: -
- 3114: -
- 3115: -
- 3116: -
- 3117: az 05/08: duplicated UID_50099 => 50299. Marked as closed 12/2008 (was marked 50% complete)
- 3118: -
- 3119: -
- 3120: -
- 3121: -
- 3122: -
- 3123: -
- 3124: -
- 3125: -
- 3126: -
- 3127: -
- 3128: -
- 3129: -
- 3130: -

| ID | WBS | Task | Duration | Start | Finish | Predecessors | Complete | Baseline start | Baseline finish | Baseline duration | Constraint | Resources | Work | Actual work | Text6 | Text8 | Text3 | Text12 | Text1 | Text4 | Text5 |
| --- | --- | --- | --- | --- | --- | --- | --- | --- | --- | --- | --- | --- | --- | --- | --- | --- | --- | --- | --- | --- | --- |
| 3131 | 53.6 | **Low chiprate TDD interworking with GERAN** | 101d | 2000-09-01 A | 2001-01-19 A | 3130 | 100% | 2000-09-01 | 2001-01-19 | 101d |  | GP | 1616h | 1616h | Rel-4 | Paolo |  |  |  |  |  |
| 3132 | 53.6.1 | Handover and Cell Selection / Reselection to UTRA 1.28 Mcps TDD | 101d | 2000-09-01 A | 2001-01-19 A |  | 100% | 2000-09-01 | 2001-01-19 | 101d | finish no earlier than 2001-01-19 | GP | 808h | 808h | Rel-4 | Paolo |  |  |  |  |  |
| 3133 | 53.8 | **Conformance Test Aspects - Low Chip Rate TDD** | 577d | 2001-09-17 A | 2003-12-02 A | 3131 | 100% | 2001-09-17 | 2003-12-02 | 577d |  | T1 | 12088h | 12088h | Rel-4 | Ingbert |  |  |  |  |  |
| 3134 | 53.8.1 | Testing Layer 2 and layer 3 protocol aspects | 468d | 2001-09-17 A | 2003-07-02 A |  | 100% | 2001-09-17 | 2003-07-02 | 468d | finish no earlier than 2003-07-02 | T1 | 3744h | 3744h | Rel-4 | Ingbert | 34.123-1, 34.123-2 |  |  |  |  |
| 3135 | 53.8.2 | Deleted - Testing Layer 2 and layer 3 protocol aspects - TTCN | 261d | 2002-12-03 A | 2003-12-02 A |  | 100% | 2002-12-03 | 2003-12-02 | 261d | finish no earlier than 2003-12-02 | T1 | 2088h | 2088h | Rel-4 | Ingbert | 34.123-3 | TP-22 |  |  |  |
| 3136 | 53.8.3 | Testing RF Radio Transmission and Reception | 205d | 2001-09-17 A | 2002-06-28 A |  | 100% | 2001-09-17 | 2002-06-28 | 205d | finish no earlier than 2002-06-28 | T1 | 1640h | 1640h | Rel-4 | Ingbert |  |  |  |  |  |
| 3137 | 54 | **Enable bearer independent CS architecture** | 566d | 2000-01-03 A | 2002-03-01 A |  | 100% | 2000-01-03 | 2002-03-01 | 566d |  | S2,N3,N4 | 18952h | 18952h | Rel-4 | Maurice |  |  | CSSPLIT | Siemens | Alexander Milinski |
| 3138 | 54.1 | **Enable bearer-independent call control** | 425d | 2000-01-03 A | 2001-08-16 A |  | 100% | 2000-01-03 | 2001-08-16 | 425d |  | N4 | 12344h | 12344h | Rel-4 | Kimmo |  |  | CSSPLIT | Ericsson | Heinz-Peter.Keutmann@eed.ericsson.se |
| 3139 | 54.1.1 | Architecture and Stage 2 description | 181d | 2000-01-03 A | 2000-09-08 A |  | 100% | 2000-01-03 | 2000-09-08 | 181d | finish no earlier than 2000-09-08 | S2 | 1440h | 1440h | Rel-4 | Maurice | 23.002 |  | CSSPLIT |  |  |
| 3140 | 54.1.2 | Standardisation of protocols (control & user planes) over Nb interface | 64d | 2001-01-02 A | 2001-03-30 A |  | 100% | 2001-01-02 | 2001-03-30 | 64d | finish no earlier than 2001-03-30 | N3 | 512h | 512h | Rel-4 | Gwiho |  |  | CSSPLIT |  |  |
| 3141 | 54.1.3 | Standardisation of protocols over reference points between MSC server and Gateway MSC server | 130d | 2000-09-25 A | 2001-03-23 A |  | 100% | 2000-09-25 | 2001-03-23 | 130d | finish no earlier than 2001-03-23 | N4 | 1040h | 1040h | Rel-4 | Kimmo |  |  | CSSPLIT |  |  |
| 3142 | 54.1.4 | Standardisation of detailed stage 2 description | 180d | 2000-07-17 A | 2001-03-23 A |  | 100% | 2000-07-17 | 2001-03-23 | 180d | finish no earlier than 2001-03-23 | N4 | 1440h | 1440h | Rel-4 | Kimmo |  |  | CSSPLIT |  |  |
| 3143 | 54.1.5 | **Bearer control between MSC server and MGW** | 250d | 2000-09-01 A | 2001-08-16 A |  | 100% | 2000-09-01 | 2001-08-16 | 250d |  | N4 | 4512h | 4512h | Rel-4 | Kimmo |  |  | CSSPLIT |  |  |
| 3144 | 54.1.5.1 | stage 3 - protocol issues | 250d | 2000-09-01 A | 2001-08-16 A |  | 100% | 2000-09-01 | 2001-08-16 | 250d | finish no earlier than 2001-08-16 | N4 | 2000h | 2000h | Rel-4 | Kimmo |  |  |  |  |  |
| 3145 | 54.1.5.2 | stage 3 - parameter value issues | 64d | 2001-01-02 A | 2001-03-30 A |  | 100% | 2001-01-02 | 2001-03-30 | 64d | finish no earlier than 2001-03-30 | N3 | 512h | 512h | Rel-4 | Gwiho |  |  |  |  |  |
| 3146 | 54.4 | Deleted - Conformance Test Aspects - Enable bearer independent CS architecture | 260d | 2001-03-05 A | 2002-03-01 A |  | 100% | 2001-03-05 | 2002-03-01 | 260d |  | T1 | 2080h | 2080h | Rel-4 | Ingbert |  | TP-15 | CSSPLIT-TEST |  |  |
| 3147 | 55 | **MExE enhancements Rel-4** | 511d | 2000-01-03 A | 2001-12-14 A |  | 100% | 2000-01-03 | 2001-12-14 | 511d |  | T2,S3 | 19032h | 19032h | Rel-4 | Kimmo |  |  | MEXE |  |  |
| 3148 | 55.1 | **MExE Security Analysis Activity** | 474d | 2000-02-22 A | 2001-12-14 A |  | 100% | 2000-02-22 | 2001-12-14 | 474d |  | S3,T2 | 8464h | 8464h | Rel-4 | Dionisio |  |  | MEXE-SEC | BT | Andrew.Myers@bt.com |
| 3149 | 55.1.1 | Stage 3 for MExE Security | 370d | 2000-07-17 A | 2001-12-14 A |  | 100% | 2000-07-17 | 2001-12-14 | 370d | finish no earlier than 2001-12-14 | S3 | 2960h | 2960h | Rel-4 | Dionisio | 21.133, 33.102 |  | MEXE-SEC | BT | Andrew.Myers@bt.com |
| 3150 | 55.1.2 | Terminal aspects for MExE Security | 214d | 2000-02-22 A | 2000-12-15 A |  | 100% | 2000-02-22 | 2000-12-15 | 214d | finish no earlier than 2000-12-15 | T2 | 1712h | 1712h | Rel-4 |  | 23.057 |  | MEXE-SEC | BT | Andrew.Myers@bt.com |
| 3151 | 55.2 | **MExE Rel-4 Improvements and Investigations** | 251d | 2000-01-03 A | 2000-12-15 A |  | 100% | 2000-01-03 | 2000-12-15 | 251d |  | T2 | 6480h | 6480h | Rel-4 | Kimmo | 22.057, 23.057 |  | MEXE-ENHANC | Motorola | Mark Cataldo |
| 3152 | 55.2.1 | 3rd MExE classmark | 251d | 2000-01-03 A | 2000-12-15 A |  | 100% | 2000-01-03 | 2000-12-15 | 251d | finish no earlier than 2000-12-15 | T2 | 2000h | 2000h | Rel-4 | Kimmo | 22.057, 23.057 |  |  | Motorola | Mark Cataldo |
| 3153 | 55.2.2 | FS on Secure download mechanism and capabilities to support SDR concepts | 225d | 2000-02-07 A | 2000-12-15 A |  | 100% | 2000-02-07 | 2000-12-15 | 225d | finish no earlier than 2000-12-15 | T2 | 1800h | 1800h | Rel-4 | Kimmo | 22.057, 23.057 |  |  | Motorola | Mark Cataldo |
| 3154 | 55.2.3 | FS on Support of MP3/MPEG4 content | 225d | 2000-02-07 A | 2000-12-15 A |  | 100% | 2000-02-07 | 2000-12-15 | 225d | finish no earlier than 2000-12-15 | T2 | 1800h | 1800h | Rel-4 | Kimmo | 22.057, 23.057 |  |  | Motorola | Mark Cataldo |

Notes:
- 3131: -
- 3132: -
- 3133: -
- 3134: Marked as closed 12/2008 (was marked 60% complete)
- 3135: Marked as stopped 12/2008
- 3136: duration set to 6 months (was 0), finish date set
- 3137: -
- 3138: DAB 12.12.01 should be 100% hence closed
- 3139: R00 stage 2 at least 80 % complete in TSGS #8 21.-23.6.2000
- 3140: -
- 3141: -
- 3142: -
- 3143: -
- 3144: -
- 3145: -
- 3146: Marked as stopped 12/2008
- 3147: -
- 3148: SP#12 updated WID
- 3149: -
- 3150: -
- 3151: -
- 3152: Additional features for MExE R2000
- 3153: -
- 3154: -

| ID | WBS | Task | Duration | Start | Finish | Complete | Baseline start | Baseline finish | Baseline duration | Constraint | Resources | Work | Actual work | Text1 | Text6 | Text8 | Text3 | Text4 | Text5 |
| --- | --- | --- | --- | --- | --- | --- | --- | --- | --- | --- | --- | --- | --- | --- | --- | --- | --- | --- | --- |
| 3155 | 56 | **Tandem Free aspects for 3G and between 2G and 3G systems** | 344d | 2000-02-22 A | 2001-06-15 A | 100% | 2000-02-22 | 2001-06-15 | 344d |  | S4 | 9696h | 9696h | TFO | Rel-4 | Paolo |  |  |  |
| 3156 | 56.1 | **Tandem Free AMR** | 344d | 2000-02-22 A | 2001-06-15 A | 100% | 2000-02-22 | 2001-06-15 | 344d |  | S4 | 6944h | 6944h | TFO-AMR | Rel-4 | Paolo |  |  |  |
| 3157 | 56.1.1 | Specification of Tandem Free AMR | 284d | 2000-02-22 A | 2001-03-23 A | 100% | 2000-02-22 | 2001-03-23 | 284d | start no earlier than 2000-02-22 | S4 | 2272h | 2272h |  | Rel-4 | Paolo | 28.062 |  |  |
| 3158 | 56.1.2 | **Impact of Tandem Free AMR on:** | 115d | 2001-01-08 A | 2001-06-15 A | 100% | 2001-01-08 | 2001-06-15 | 115d |  | NP | 1920h | 1920h |  | Rel-4 | Kimmo |  |  |  |
| 3159 | 56.1.2.1 | CN | 60d | 2001-03-26 A | 2001-06-15 A | 100% | 2001-03-26 | 2001-06-15 | 60d | finish no earlier than 2001-06-15 | NP | 480h | 480h |  | Rel-4 | Kimmo |  |  |  |
| 3160 | 56.1.2.2 | GERAN | 65d | 2001-01-08 A | 2001-04-06 A | 100% | 2001-01-08 | 2001-04-06 | 65d | finish no earlier than 2001-04-06 | GP | 520h | 520h |  | Rel-4 | Paolo |  |  |  |
| 3161 | 57 | **Advanced Speech Call Items enhancements_Rel-4** | 334d | 2000-12-03 A | 2002-03-14 A | 100% | 2000-12-03 | 2002-03-14 | 334d |  | N1 | 5925.6h | 5925.6h | ASCI | Rel-4 | Frederic |  | Nortel | sonia.garapaty@nortelnetworks.com |
| 3162 | 57.1 | Stage 2 for Advanced Speech Call Items enhancements_Rel-4 (ASCI) | 326.7d | 2000-12-03 A | 2002-03-14 A | 100% | 2000-12-03 | 2002-03-14 | 326.7d | finish no earlier than 2002-03-14 | N4 | 2613.6h | 2613.6h |  | Rel-4 | Kimmo | 23.067, 24.067 | Sagem | Vivien Perlic |
| 3163 | 57.2 | Stages 2 and 3 on A interface | 80d | 2000-12-03 A | 2001-03-23 A | 100% | 2000-12-03 | 2001-03-23 | 80d | finish no earlier than 2001-03-23 | N1 | 640h | 640h |  | Rel-4 | Frederic | 44.068, 44.069, 24.008 | Nortel | sonia.garapaty@nortelnetworks.com |
| 3164 | 58 | **700 MHz spectrum support** | 776d | 2000-01-03 A | 2002-12-20 A | 100% | 2000-01-03 | 2002-12-20 | 776d |  | GP | 20016h | 20016h | 700SS | Rel-4 | Paolo |  |  |  |
| 3165 | 58.1 | **GERAN support for the 700 MHz band** | 276d | 2000-01-03 A | 2001-01-19 A | 100% | 2000-01-03 | 2001-01-19 | 276d |  | GP | 8808h | 8808h |  | Rel-4 | Paolo |  |  |  |
| 3166 | 58.1.1 | Signalling support | 276d | 2000-01-03 A | 2001-01-19 A | 100% | 2000-01-03 | 2001-01-19 | 276d | finish no earlier than 2001-01-19 | GP | 2200h | 2200h |  | Rel-4 | Paolo |  |  |  |
| 3167 | 58.1.2 | Physical layer definitions - for GERAN support for the 700 MHz band | 276d | 2000-01-03 A | 2001-01-19 A | 100% | 2000-01-03 | 2001-01-19 | 276d | finish no earlier than 2001-01-19 | GP | 2200h | 2200h |  | Rel-4 | Paolo |  |  |  |
| 3168 | 58.1.3 | Receiver performance and RF budget | 276d | 2000-01-03 A | 2001-01-19 A | 100% | 2000-01-03 | 2001-01-19 | 276d | finish no earlier than 2001-01-19 | GP | 2200h | 2200h |  | Rel-4 | Paolo |  |  |  |
| 3169 | 58.2 | GERAN MS Conformance test for 700 MHz band | 175d | 2001-04-02 A | 2001-11-30 A | 100% | 2001-04-02 | 2001-11-30 | 175d |  | GP | 1400h | 1400h |  | Rel-4 | Paolo |  |  |  |
| 3170 | 58.3 | GERAN BTS Conformance test for 700 MHz band | 450d | 2001-04-02 A | 2002-12-20 A | 100% | 2001-04-02 | 2002-12-20 | 450d |  | GP | 3600h | 3600h |  | Rel-4 | Paolo |  |  |  |
| 3171 | 59 | Operator Determined Barring for Packet Oriented Services | 208d | 2000-06-01 A | 2001-03-19 A | 100% | 2000-06-01 | 2001-03-19 | 208d | finish no earlier than 2001-03-19 | NP | 1664h | 1664h | ODB | Rel-4 | Kimmo |  | NEC | Toshiyuki Tamura (tamurato@aj.jp.nec.com) |
| 3172 | 60 | **UMTS QoS Architecture for PS Domain** | 759d | 2000-01-03 A | 2002-11-27 A | 100% | 2000-01-03 | 2002-11-27 | 759d |  | S2,S5,R3,GP | 35600h | 35600h | QoSPS | Rel-4 | Maurice |  | Ericsson | Ina.widegren@era.ericsson.se |
| 3173 | 60.1 | Architecture | 153d | 2000-06-05 A | 2001-01-03 A | 100% | 2000-06-05 | 2001-01-03 | 153d | finish no earlier than 2001-01-03 | S2 | 1224h | 1224h |  | Rel-4 | Maurice | 23.107 |  |  |
| 3174 | 60.2 | Charging and OAM&P for QoS Management | 201d | 2001-09-21 A | 2002-06-28 A | 100% | 2001-09-21 | 2002-06-28 | 201d | finish no earlier than 2002-06-28 | S5 | 1608h | 1608h | QoSPS-OAM | Rel-4 | Dionisio | 32-series |  |  |
| 3175 | 60.3 | **RAB Quality of Service (re)Negotiation over Iu** | 155d | 2000-08-21 A | 2001-03-23 A | 100% | 2000-08-21 | 2001-03-23 | 155d |  | R3 | 3648h | 3648h | QoSPS-MAPEND-RABQoS | Rel-4 | Juha | 25.413 | Ericsson | anders.molander@ericsson.com |
| 3176 | 60.3.1 | RAB Quality of Service Negotiation over Iu | 155d | 2000-08-21 A | 2001-03-23 A | 100% | 2000-08-21 | 2001-03-23 | 155d | finish no earlier than 2001-03-23 | R3 | 1240h | 1240h | QoSPS-MAPEND-RABQoS-Negot | Rel-4 | Juha |  | Ericsson | anders.molander@ericsson.com |
| 3177 | 60.3.2 | RAB Quality of Service Negotiation over Iu during relocation | 16d | 2001-03-02 A | 2001-03-23 A | 100% | 2001-03-02 | 2001-03-23 | 16d | start no earlier than 2001-03-02 | R3 | 128h | 128h | QoSPS-MAPEND-RABQoS-NegotReloc | Rel-4 | Juha |  |  |  |
| 3178 | 60.3.3 | RAB Quality of Service Re-Negotiation over Iu | 130d | 2000-09-25 A | 2001-03-23 A | 100% | 2000-09-25 | 2001-03-23 | 130d | finish no earlier than 2001-03-23 | R3 | 1040h | 1040h | QoSPS-MAPEND-RABQoS-ReNegot | Rel-4 | Juha |  | Motorola | S. Irwin |

Notes:
- 3155: RAN and CN to verify no problems for GSM terminals roaming in 3G R99
- 3156: RAN and CN to verify UMTS_AMR_2 support
- 3157: -
- 3158: "Implementation" changed to "Impact on:" by A. Sultan (for better wording)
- 3159: RAN and CN to verify UMTS_AMR_2 support
- 3160: End date Modified from June to March to have it in Rel4
- 3161: Approved at CN#10
- 3162: CN4#11 30/11/02: no inputs received in CN4
- 3163: -
- 3164: -
- 3165: -
- 3166: -
- 3167: -
- 3168: -
- 3169: -
- 3170: -
- 3171: Completed WI missing from the P-plan Added for tracking
- 3172: -
- 3173: -
- 3174: -
- 3175: -
- 3176: -
- 3177: -
- 3178: -

| ID | WBS | Task | Duration | Start | Finish | Complete | Baseline start | Baseline finish | Baseline duration | Constraint | Resources | Work | Actual work | Text1 | Text6 | Text8 | Text12 | Text4 | Text5 | Text3 |
| --- | --- | --- | --- | --- | --- | --- | --- | --- | --- | --- | --- | --- | --- | --- | --- | --- | --- | --- | --- | --- |
| 3179 | 60.4 | **GERAN QoS Aspects - Handovers: maintenance of real-time QoS while moving between cells in the PLMN including inter-SGSN and SRNS relocation or possibly other mechanisms** | 501d | 2000-01-03 A | 2001-11-30 A | 100% | 2000-01-03 | 2001-11-30 | 501d |  | GP | 14456h | 14456h | GERQoS | Rel-4 | Paolo |  |  |  |  |
| 3180 | 60.4.1 | **Handover Concept for the PS domain** | 501d | 2000-01-03 A | 2001-11-30 A | 100% | 2000-01-03 | 2001-11-30 | 501d |  | GP | 10448h | 10448h |  | Rel-4 | Paolo |  |  |  |  |
| 3181 | 60.4.1.1 | Stable RT handover report 25.936 including header removal | 14d | 2000-01-03 A | 2000-01-19 A | 100% | 2000-01-03 | 2000-01-19 | 14d | start no earlier than 2000-01-03 | GP | 104h | 104h |  | Rel-4 | Paolo |  |  |  |  |
| 3182 | 60.4.1.2 | Update of stage 2 | 293d | 2000-01-03 A | 2001-02-13 A | 100% | 2000-01-03 | 2001-02-13 | 293d | finish no earlier than 2001-02-13 | GP | 2336h | 2336h |  | Rel-4 | Paolo |  |  |  |  |
| 3183 | 60.4.1.3 | Update of relevant stage 3 specs -> RRC | 501d | 2000-01-03 A | 2001-11-30 A | 100% | 2000-01-03 | 2001-11-30 | 501d | finish no earlier than 2001-11-30 | G2 | 4000h | 4000h |  | Rel-4 | Gert |  |  |  |  |
| 3184 | 60.5 | **Deleted - GERAN MS Conformance test for inter-system and intra-system Packet data real-time Handover** | 324d | 2001-08-31 A | 2002-11-27 A | 100% | 2001-08-31 | 2002-11-27 | 324d |  | G4,R3 | 12960h | 12960h | GERQoS-Mstest | Rel-4 | Paolo | GP-12 |  |  |  |
| 3185 | 60.5.1 | **Deleted - Handover for the PS domain** | 324d | 2001-08-31 A | 2002-11-27 A | 100% | 2001-08-31 | 2002-11-27 | 324d |  | G4,R3 | 10368h | 10368h |  | Rel-4 | Paolo | GP-12 |  |  |  |
| 3186 | 60.5.1.1 | Deleted - Stable RT handover report 25.936 including header removal | 324d | 2001-08-31 A | 2002-11-27 A | 100% | 2001-08-31 | 2002-11-27 | 324d | finish no earlier than 2002-11-27 | G4,R3 | 2592h | 2592h |  | Rel-4 | Paolo | GP-12 |  |  |  |
| 3187 | 60.5.1.2 | Deleted - Update of stage 2 | 324d | 2001-08-31 A | 2002-11-27 A | 100% | 2001-08-31 | 2002-11-27 | 324d | finish no earlier than 2002-11-27 | G4,R3 | 2592h | 2592h |  | Rel-4 | Paolo | GP-12 |  |  |  |
| 3188 | 60.5.1.3 | Deleted - Update of relevant stage 3 specs | 324d | 2001-08-31 A | 2002-11-27 A | 100% | 2001-08-31 | 2002-11-27 | 324d | finish no earlier than 2002-11-27 | G4,R3 | 2592h | 2592h |  | Rel-4 | Paolo | GP-12 |  |  |  |
| 3189 | 60.6 | PS-domain handover for real-time services | 155d | 2000-08-28 A | 2001-03-30 A | 100% | 2000-08-28 | 2001-03-30 | 155d | finish no earlier than 2001-03-30 | R3 | 1240h | 1240h | QoSPS-PSdoRTS | Rel-4 | Juha |  | Nokia | atte.lansisalmi@nokia.com |  |
| 3190 | 60.7 | Deleted - RAB QoS Renegotiation at Relocation | 58d | 2001-01-03 A | 2001-03-23 A | 100% | 2001-01-03 | 2001-03-23 | 58d | finish no earlier than 2001-03-23 | R3 | 464h | 464h |  | Rel-4 | Juha | RP-11 |  |  | 25.851, 25.946 |
| 3191 | 61 | (Small) Technical Enhancements and Improvements for Rel-4 | 326d? | 2000-01-03 A | 2001-03-30 A | 100% | 2000-01-03 | 2001-03-30 | 326d? |  | All | 2608h | 2608h | TEI4 | Rel-4 | all |  |  |  |  |
| 3192 | 866 | Test - (Small) Technical Enhancements and Improvements for Rel-4 | 326d? | 2000-01-03 A | 2001-03-30 A | 100% | 2000-01-03 | 2001-03-30 | 326d? | finish no earlier than 2008-12-31 | R5,T1 | 2608h | 2608h | TEI4_Test | Rel-4 | Ingbert |  |  |  |  |
| 3193 | 62 | **Rel-4 Evolutions of the transport in the UTRAN** | 525d | 2000-08-21 A | 2002-08-23 A | 100% | 2000-08-21 | 2002-08-23 | 525d |  | RP | 8600h | 8600h | ETRAN | Rel-4 | Issam |  | Alcatel | Francois Courau |  |
| 3194 | 62.1 | QoS optimization for AAL2 connections over Iub and Iur interfaces | 160d | 2000-08-21 A | 2001-03-30 A | 100% | 2000-08-21 | 2001-03-30 | 160d | finish no earlier than 2001-03-30 | R3 | 1280h | 1280h | ETRAN-QoSAAL2 | Rel-4 | Juha |  | Japan Telecom | T. Yoshimura |  |
| 3195 | 62.2 | Transport bearer modification procedure on Iub, Iur, and Iu | 130d | 2000-10-02 A | 2001-03-30 A | 100% | 2000-10-02 | 2001-03-30 | 130d | finish no earlier than 2001-03-30 | R3 | 1040h | 1040h | ETRAN-MigrMod | Rel-4 | Juha |  | Japan Telecom | T. Yoshimura |  |
| 3196 | 62.3 | **Deleted - Conformance Test Aspects of Rel-4 evolutions of the transport in UTRAN** | 130d | 2002-02-25 A | 2002-08-23 A | 100% | 2002-02-25 | 2002-08-23 | 130d |  | T1 | 2080h | 2080h |  | Rel-4 | Ingbert | TP-17 |  |  |  |
| 3197 | 62.3.1 | Deleted - Testing RAB support enhancements | 130d | 2002-02-25 A | 2002-08-23 A | 100% | 2002-02-25 | 2002-08-23 | 130d | finish no earlier than 2002-08-23 | T1 | 1040h | 1040h | CT-RABS? | Rel-4 | Ingbert | TP-17 |  |  | 34.108, 34. 121, 34.122, 34.123 p 1,2, 34.123 pt 3 |
| 3198 | 63 | **Rel-4 Evolutions of the transport in the CN** | 215d | 2000-05-29 A | 2001-03-23 A | 100% | 2000-05-29 | 2001-03-23 | 215d |  | N4,N1,N2,S2 | 7968h | 7968h | CNTRSP | Rel-4 | Kimmo |  |  |  |  |
| 3199 | 63.1 | **IP Transport of CN protocols (e.g. CAP, MAP)** | 77d | 2000-12-07 A | 2001-03-23 A | 100% | 2000-12-07 | 2001-03-23 | 77d |  | N4 | 2808h | 2808h | SS7IP | Rel-4 | Kimmo |  |  |  |  |
| 3200 | 63.1.1 | **Stage 3 for IP Transport of CN protocols (e.g. CAP, MAP)** | 77d | 2000-12-07 A | 2001-03-23 A | 100% | 2000-12-07 | 2001-03-23 | 77d |  | N4 | 2192h | 2192h |  | Rel-4 | Kimmo |  |  |  |  |
| 3201 | 63.1.1.1 | CAP | 77d | 2000-12-07 A | 2001-03-23 A | 100% | 2000-12-07 | 2001-03-23 | 77d | finish no earlier than 2001-03-23 | N2 | 616h | 616h |  | Rel-4 | Kimmo |  |  |  |  |
| 3202 | 63.1.1.2 | MAP | 77d | 2000-12-07 A | 2001-03-23 A | 100% | 2000-12-07 | 2001-03-23 | 77d | finish no earlier than 2001-03-23 | N4 | 616h | 616h |  | Rel-4 | Kimmo |  |  |  |  |
| 3203 | 63.1.1.3 | BSSAP+ | 43d | 2001-01-15 A | 2001-03-14 A | 100% | 2001-01-15 | 2001-03-14 | 43d | finish no earlier than 2001-03-14 | N1 | 344h | 344h | SS7IP-BSSAP+ | Rel-4 | Frederic |  |  |  |  |

Notes:
- 3179: -
- 3180: -
- 3181: -
- 3182: -
- 3183: -
- 3184: Still exist? To be clarified by GERAN4/5. Marked as stopped 12/2008
- 3185: Marked as stopped 12/2008
- 3186: Marked as stopped 12/2008
- 3187: Marked as stopped 12/2008
- 3188: Marked as stopped 12/2008
- 3189: -
- 3190: Marked as stopped 12/2008
- 3191: "Joker" WI, to be used for a Rel 4 CR not related to any feature and with very limited impact on the system
- 3192: "Joker" WI, to be used for small modifications applicable to Rel 4 conformance testing. Moved in from the Stoyan/Testing WP
- 3193: -
- 3194: -
- 3195: -
- 3196: Marked as stopped 12/2008
- 3197: Marked as stopped 12/2008
- 3198: -
- 3199: -
- 3200: -
- 3201: -
- 3202: -
- 3203: -

| ID | WBS | Task | Duration | Start | Finish | Complete | Baseline start | Baseline finish | Baseline duration | Constraint | Resources | Work | Actual work | Text4 | Text5 | Text6 | Text8 | Text1 | Text3 | Text12 |
| --- | --- | --- | --- | --- | --- | --- | --- | --- | --- | --- | --- | --- | --- | --- | --- | --- | --- | --- | --- | --- |
| 3204 | 63.2 | **FS on Transport and control separation in the PS CN domain** | 215d | 2000-05-29 A | 2001-03-23 A | 100% | 2000-05-29 | 2001-03-23 | 215d |  | S2 | 3440h | 3440h | Ericsson | Juan-Antonio.Ibanez@eed.ericsson.se | Rel-4 | Maurice |  |  |  |
| 3205 | 63.2.1 | Architectural impacts | 215d | 2000-05-29 A | 2001-03-23 A | 100% | 2000-05-29 | 2001-03-23 | 215d | finish no earlier than 2001-03-23 | S2 | 1720h | 1720h |  |  | Rel-4 | Maurice |  |  |  |
| 3206 | 64 | **Rel-4 Improvements of Radio Interface** | 700d | 2000-07-10 A | 2003-03-14 A | 100% | 2000-07-10 | 2003-03-14 | 700d |  | RP | 28624h | 28624h |  |  | Rel-4 |  | RInImp |  |  |
| 3207 | 64.1 | UTRA repeater specification (master) | 183d | 2000-07-10 A | 2001-03-21 A | 100% | 2000-07-10 | 2001-03-21 | 183d | finish no earlier than 2001-03-21 | R4 | 1464h | 1464h | Mikom, Allgon | T. Kummetz, Mikom; Alf Ahlström, Allgon | Rel-4 | Issam | RInImp-REP |  |  |
| 3208 | 64.2 | DSCH power control improvement in soft handover | 140d | 2000-09-11 A | 2001-03-23 A | 100% | 2000-09-11 | 2001-03-23 | 140d | finish no earlier than 2001-03-23 | R1 | 1120h | 1120h | Nokia | antti.toskala@nokia.com | Rel-4 | Patrick | RInImp-DSCHsho |  |  |
| 3209 | 64.3 | UMTS 1800 | 320d | 2000-09-25 A | 2001-12-14 A | 100% | 2000-09-25 | 2001-12-14 | 320d | finish no earlier than 2001-12-14 | R4 | 2560h | 2560h | Motorola | Howard Benn | Rel-4 | Issam | RInImp-UMTS18 |  |  |
| 3210 | 64.4 | UMTS 1900 | 195d | 2001-03-19 A | 2001-12-14 A | 100% | 2001-03-19 | 2001-12-14 | 195d | finish no earlier than 2001-12-14 | R4 | 1560h | 1560h | Motorola | Howard Benn | Rel-4 | Issam | RInImp-UMTS19 | 25.101 |  |
| 3211 | 64.5 | FS on High Speed downlink packet access | 155d | 2000-08-21 A | 2001-03-23 A | 100% | 2000-08-21 | 2001-03-23 | 155d | finish no earlier than 2001-03-23 | R2 | 1240h | 1240h | Motorola | Amitabha Ghosh (qa0047@email.mot.com) | Rel-4 | Joern | RInImp-HSDPA |  |  |
| 3212 | 64.6 | Deleted - FS on improved common DL channel for Cell-FACH state | 340d | 2000-09-11 A | 2001-12-28 A | 100% | 2000-09-11 | 2001-12-28 | 340d | finish no earlier than 2001-12-28 | R2 | 2720h | 2720h | GBT | J. Kwak | Rel-4 | Joern | RInImp-DLCFACH |  | RP-14 |
| 3213 | 64.7 | **Conformance Test Spec. Rel-4 improvements in Radio Interface** | 375d | 2001-10-08 A | 2003-03-14 A | 100% | 2001-10-08 | 2003-03-14 | 375d |  | T1 | 12360h | 12360h |  |  | Rel-4 | Ingbert |  |  |  |
| 3214 | 64.7.1 | Deleted - Testing Improved usage of downlink resource in FDD for CCTrCHs of dedicated type | 140d | 2002-02-18 A | 2002-08-30 A | 100% | 2002-02-18 | 2002-08-30 | 140d | finish no earlier than 2002-08-30 | T1 | 1120h | 1120h |  |  | Rel-4 | Ingbert |  |  | TP-17 |
| 3215 | 64.7.2 | Deleted - Testing Terminal Power saving features | 140d | 2002-02-18 A | 2002-08-30 A | 100% | 2002-02-18 | 2002-08-30 | 140d | finish no earlier than 2002-08-30 | T1 | 1120h | 1120h |  |  | Rel-4 | Ingbert |  |  | TP-17 |
| 3216 | 64.7.3 | Deleted - Testing DSCH power control improvement in soft handover | 140d | 2002-02-18 A | 2002-08-30 A | 100% | 2002-02-18 | 2002-08-30 | 140d | finish no earlier than 2002-08-30 | T1 | 1120h | 1120h |  |  | Rel-4 | Ingbert |  |  | TP-17 |
| 3217 | 64.7.4 | Testing UMTS 1800 | 180d | 2001-10-08 A | 2002-06-14 A | 100% | 2001-10-08 | 2002-06-14 | 180d | finish no earlier than 2002-06-14 | T1 | 1440h | 1440h |  |  | Rel-4 | Ingbert |  | 34.108, 34,121, 34.122, 34.123-1 |  |
| 3218 | 64.7.5 | Testing UMTS 1900 | 180d | 2001-10-08 A | 2002-06-14 A | 100% | 2001-10-08 | 2002-06-14 | 180d | finish no earlier than 2002-06-14 | T1 | 1440h | 1440h |  |  | Rel-4 | Ingbert |  | 34.108, 34,121, 34.122, 34.123-1 |  |
| 3219 | 64.7.6 | Testing UMTS 1800 - TTCN | 195d | 2002-06-17 A | 2003-03-14 A | 100% | 2002-06-17 | 2003-03-14 | 195d | finish no earlier than 2003-03-14 | T1 | 1560h | 1560h |  |  | Rel-4 | Ingbert |  | 34.123-3 |  |
| 3220 | 64.7.7 | Testing UMTS 1900 - TTCN | 195d | 2002-06-17 A | 2003-03-14 A | 100% | 2002-06-17 | 2003-03-14 | 195d | finish no earlier than 2003-03-14 | T1 | 1560h | 1560h |  |  | Rel-4 | Ingbert |  | 34.123-3 |  |
| 3221 | 65 | **Rel-4 RAN improvements** | 938d? | 2000-08-14 A | 2004-03-17 A | 100% | 2000-08-14 | 2004-03-17 | 938d? |  | RP | 29336h | 29336h |  |  | Rel-4 |  | RANimp |  |  |
| 3222 | 65.1 | Node B synchronization for TDD | 160d | 2000-08-14 A | 2001-03-23 A | 100% | 2000-08-14 | 2001-03-23 | 160d | finish no earlier than 2001-03-23 | R1 | 1280h | 1280h | Siemens | S. Oestreich | Rel-4 | Patrick | RANimp-NBsync |  |  |
| 3223 | 65.2 | RAB support enhancement for Rel-4 | 155d | 2000-08-21 A | 2001-03-23 A | 100% | 2000-08-21 | 2001-03-23 | 155d | finish no earlier than 2001-03-23 | R2 | 1240h | 1240h | Ericsson | M. Israelsson, A. Krishnarajah | Rel-4 | Joern | RANimp-RABSE |  |  |
| 3224 | 65.4 | **Deleted - Conformance Test Aspects - Rel-4 RAN Improvements** | 577d? | 2002-01-01 A | 2004-03-17 A | 100% | 2002-01-01 | 2004-03-17 | 577d? |  | T1 | 19312h | 19312h |  |  | Rel-4 | Ingbert |  |  | TP-23 |
| 3225 | 65.4.1 | Deleted - Testing Radio access bearer support enhancments | 175d | 2002-01-01 A | 2002-09-02 A | 100% | 2002-01-01 | 2002-09-02 | 175d | finish no earlier than 2002-09-02 | T1 | 1400h | 1400h |  |  | Rel-4 | Ingbert |  |  | TP-17 |
| 3226 | 65.4.2 | Deleted - Testing RAB support enhancements-Robust Header Compression | 332d | 2002-05-28 A | 2003-09-03 A | 100% | 2002-05-28 | 2003-09-03 | 332d | finish no earlier than 2003-09-03 | T1 | 2656h | 2656h |  |  | Rel-4 | Ingbert | RABimp-RoCH | 34.123-1, -2 | TP-21 |
| 3227 | 65.4.3 | Deleted - Testing RAB support enhancements-Robust Header Compression - TTCN | 472d | 2002-05-28 A | 2004-03-17 A | 100% | 2002-05-28 | 2004-03-17 | 472d | finish no earlier than 2004-03-17 | T1 | 3776h | 3776h |  |  | Rel-4 | Ingbert |  | 34.123-3 | TP-23 |
| 3228 | 65.4.4 | Testing of Extended Robut Header Compression | 270d | 2002-09-18 A | 2003-09-30 A | 100% | 2002-09-18 | 2003-09-30 | 270d | finish no earlier than 2003-09-30 | T1 | 2160h | 2160h |  |  | Rel-4 | Ingbert | Ext-RoHC | 34.123-1, -2 |  |
| 3229 | 65.4.5 | Deleted - Testing of Extended Robut Header Compression - TTCN | 325d | 2002-09-18 A | 2003-12-16 A | 100% | 2002-09-18 | 2003-12-16 | 325d | finish no earlier than 2003-12-16 | T1 | 2600h | 2600h |  |  | Rel-4 | Ingbert |  | 34.123-3 | TP-22 |
| 3230 | 870.3.6 | Deleted - General changes to TS34.121 corresponding to release 4 | 263d? | 2003-03-03 A | 2004-03-03 A | 100% | 2003-03-03 | 2004-03-03 | 263d? | finish no earlier than 2004-03-03 | T1 | 2104h | 2104h |  |  | Rel-4 | Ingbert | RANimp-test | 34.108, 34.121 | TP-23 |

Notes:
- 3204: -
- 3205: -
- 3206: -
- 3207: -
- 3208: -
- 3209: -
- 3210: -
- 3211: -
- 3212: Stopped at RP#14
- 3213: -
- 3214: Marked as stopped 12/2008
- 3215: Marked as stopped 12/2008
- 3216: Marked as stopped 12/2008
- 3217: -
- 3218: -
- 3219: -
- 3220: -
- 3221: -
- 3222: -
- 3223: 29 Nov 2000: split into ROHC and non-ROHC part; 5 Mar 2001: splitting off of ROHC for Rel-4 agreed by R2
- 3224: Marked as stopped 12/2008
- 3225: Marked as stopped 12/2008
- 3226: UID changed. Marked as stopped 12/2008
- 3227: UID changed. Marked as stopped 12/2008
- 3228: Marked as closed 12/2008 (was marked 15% complete)
- 3229: Marked as stopped 12/2008
- 3230: Marked as stopped 12/2008

| ID | WBS | Task | Duration | Start | Finish | Complete | Baseline start | Baseline finish | Baseline duration | Constraint | Resources | Work | Actual work | Text1 | Text4 | Text6 | Text8 | Text12 | Text5 | Text11 |
| --- | --- | --- | --- | --- | --- | --- | --- | --- | --- | --- | --- | --- | --- | --- | --- | --- | --- | --- | --- | --- |
| 3231 | 66 | **Rel-4 Emergency call enhancements** | 628d | 2000-01-03 A | 2002-05-28 A | 100% | 2000-01-03 | 2002-05-28 | 628d |  | N1,S1,T1 | 3600h | 3600h | EMC1 | Ericsson | Rel-4 | Frederic |  |  |  |
| 3232 | 66.1 | **For CS based calls** | 628d | 2000-01-03 A | 2002-05-28 A | 100% | 2000-01-03 | 2002-05-28 | 628d |  | N1 | 3600h | 3600h | EMC1-CS | Ericsson | Rel-4 | Frederic |  |  |  |
| 3233 | 66.1.1 | Distinction in CS domain of emergency call types to different emergency services | 40d | 2000-05-01 A | 2000-06-23 A | 100% | 2000-05-01 | 2000-06-23 | 40d | finish no earlier than 2000-06-23 | S1 | 320h | 320h | EMC1-CS |  | Rel-4 | Alain |  |  |  |
| 3234 | 66.1.2 | Distinction in CS domain of emergency calls to different emergency types | 22d | 2000-08-24 A | 2000-09-22 A | 100% | 2000-08-24 | 2000-09-22 | 22d | finish no earlier than 2000-09-22 | N1 | 176h | 176h | EMC1-CS |  | Rel-4 | Frederic |  |  |  |
| 3235 | 66.1.3 | Deleted - Conformance Test Aspects - Emergency call enhancements | 151d | 2000-01-03 A | 2000-07-28 A | 100% | 2000-01-03 | 2000-07-28 | 151d |  | T1 | 1200h | 1200h | EMC1-CS |  | Rel-4 | Ingbert | TP-08 |  |  |
| 3236 | 66.1.4 | Testing CS based emergency calls | 67d | 2002-02-25 A | 2002-05-28 A | 100% | 2002-02-25 | 2002-05-28 | 67d | finish no earlier than 2002-05-28 | T1 | 536h | 536h | EMC1-CS |  | Rel-4 | Ingbert |  |  |  |
| 3237 | 66.1.5 | Testing CS based emergency calls - TTCN | 134d | 2001-11-22 A | 2002-05-28 A | 100% | 2001-11-22 | 2002-05-28 | 134d | finish no earlier than 2002-05-28 | T1 | 1072h | 1072h | EMC1-CS |  | Rel-4 | Ingbert |  |  |  |
| 3238 | 67 | **Rel-4 Terminal interfaces** | 315d | 2000-01-03 A | 2001-03-15 A | 100% | 2000-01-03 | 2001-03-15 | 315d |  | T2 | 14296h | 14296h | TI |  | Rel-4 | Kimmo |  |  |  |
| 3239 | 67.1 | **AT commands enhancements** | 314d | 2000-01-03 A | 2001-03-14 A | 100% | 2000-01-03 | 2001-03-14 | 314d |  | T2 | 5016h | 5016h | TI-ATC |  | Rel-4 | Kimmo |  |  |  |
| 3240 | 67.1.1 | Specification of AT commands for new services | 314d | 2000-01-03 A | 2001-03-14 A | 100% | 2000-01-03 | 2001-03-14 | 314d | finish no earlier than 2001-03-14 | T2 | 2504h | 2504h |  |  | Rel-4 | Kimmo |  |  |  |
| 3241 | 67.2 | **Wide Area Data Synchronization** | 314d | 2000-01-03 A | 2001-03-14 A | 100% | 2000-01-03 | 2001-03-14 | 314d |  | T2 | 5016h | 5016h | TI-WADS |  | Rel-4 | Kimmo |  |  |  |
| 3242 | 67.2.1 | Continues evolution of Synchronization protocol | 314d | 2000-01-03 A | 2001-03-14 A | 100% | 2000-01-03 | 2001-03-14 | 314d | finish no earlier than 2001-03-14 | T2 | 2504h | 2504h | TI-SYNC-EVOL |  | Rel-4 | Kimmo |  |  |  |
| 3243 | 67.3 | Terminal local model | 218d | 2000-05-16 A | 2001-03-15 A | 100% | 2000-05-16 | 2001-03-15 | 218d | finish no earlier than 2001-03-15 | T2 | 1744h | 1744h | TLM | Ericsson | Rel-4 | Kimmo |  | Olga.Tome@ECS.ERICSSON.SE |  |
| 3244 | 68 | **Rel-4 Location Services enhancements** | 455d | 2000-04-03 A | 2001-12-28 A | 100% | 2000-04-03 | 2001-12-28 | 455d |  | S2,S1,T2,N1,N4,R3,R2 | 27431.2h | 27431.2h | LCS1 | Nokia | Rel-4 | Maurice |  | Jan Kall |  |
| 3245 | 68.1 | CBS interactions | 455d | 2000-04-03 A | 2001-12-28 A | 100% | 2000-04-03 | 2001-12-28 | 455d | finish no earlier than 2001-12-28 | T2 | 3640h | 3640h | LCS1-CBS |  | Rel-4 |  |  |  |  |
| 3246 | 68.2 | LCS support in the CS domain | 180d | 2000-05-15 A | 2001-01-19 A | 100% | 2000-05-15 | 2001-01-19 | 180d | finish no earlier than 2001-01-19 | S2 | 1440h | 1440h | LCS1-CS |  | Rel-4 | Maurice |  |  |  |
| 3247 | 68.3 | **LCS support in the PS domain** | 435d | 2000-05-01 A | 2001-12-28 A | 100% | 2000-05-01 | 2001-12-28 | 435d |  | S2,S1,N1,N4 | 13560h | 13560h | LCS1-PS |  | Rel-4 | Maurice |  |  |  |
| 3248 | 68.3.1 | Stage 1 for LCS support in the PS domain | 40d | 2000-07-03 A | 2000-08-25 A | 100% | 2000-07-03 | 2000-08-25 | 40d | start no earlier than 2000-07-03 | S1 | 320h | 320h | LCS1-PS | Pacific Bell Wireless | Rel-4 | Alain |  | Randolph Wohlert (rwohlert@tri.sbc.com) |  |
| 3249 | 68.3.2 | Stage 2 for LCS support in the PS domain | 190d | 2000-05-01 A | 2001-01-19 A | 100% | 2000-05-01 | 2001-01-19 | 190d | finish no earlier than 2001-01-19 | S2,R2,G1 | 1520h | 1520h | LCS1-PS |  | Rel-4 | Maurice |  |  |  |
| 3250 | 68.3.3 | **Stage 3 for LCS support in the PS domain** | 355d | 2000-08-21 A | 2001-12-28 A | 100% | 2000-08-21 | 2001-12-28 | 355d |  | N1,N4 | 8240h | 8240h | LCS1-PS |  | Rel-4 | Frederic |  |  |  |
| 3251 | 68.3.3.1 | Layer 3 LCS signalling UE (MS) -SGSN (UMTS PS and and GSM-GPRS) | 355d | 2000-08-21 A | 2001-12-28 A | 100% | 2000-08-21 | 2001-12-28 | 355d | finish no earlier than 2001-12-28 | N1 | 2840h | 2840h | LCS1-PS | Nokia | Rel-4 | Frederic |  | Janne Muhonen |  |
| 3252 | 68.3.3.2 | MAP impacts of LCS | 160d | 2000-08-21 A | 2001-03-30 A | 100% | 2000-08-21 | 2001-03-30 | 160d | finish no earlier than 2001-03-30 | N4 | 1280h | 1280h | LCS1-PS |  | Rel-4 | Kimmo |  |  |  |
| 3253 | 68.3.3.3 | GTP signalling for LCS | 160d | 2000-08-21 A | 2001-03-30 A | 100% | 2000-08-21 | 2001-03-30 | 160d | finish no earlier than 2001-03-30 | N4 | 1280h | 1280h | LCS1-PS |  | Rel-4 | Kimmo |  |  |  |
| 3254 | 68.4 | **UE positioning Rel-4** | 260d | 2000-04-03 A | 2001-03-30 A | 100% | 2000-04-03 | 2001-03-30 | 260d |  | R3,R2 | 5151.2h | 5151.2h | LCS1-UEpos |  | Rel-4 | Issam |  |  | RP-010045 |
| 3255 | 68.4.1 | Iub/Iur interfaces for methods Rel 99 | 233.9d | 2000-04-03 A | 2001-03-30 A | 100% | 2000-04-03 | 2001-03-30 | 233.9d | finish no earlier than 2001-03-30 | R3 | 1871.2h | 1871.2h | LCS1-UEpos-IubIur | Ericsson | Rel-4 | Juha |  | Yun-Chao Hu | RP-010045 |
| 3256 | 68.4.2 | UE positioning enhancements - IPDL for TDD | 150d | 2000-08-28 A | 2001-03-23 A | 100% | 2000-08-28 | 2001-03-23 | 150d | finish no earlier than 2001-03-23 | R2 | 1200h | 1200h | LCS1-UEpos-enh | Siemens | Rel-4 | Joern |  | Armin Sitte | RP-010045 |

Notes:
- 3231: -
- 3232: WI approved in TSG_10
- 3233: -
- 3234: Calls to different emergency services such as ambulance, fire brigade, police, etc. can be routed to respective different emergency centres. / NP-000447 is the stage 3 changes for CS call control protocol. / Text3: 24.008
- 3235: UID changed. Marked as stopped 12/2008
- 3236: - / Text3: 34.123-1
- 3237: - / Text3: 34.123-3
- 3238: -
- 3239: - / Text3: 27.007
- 3240: goal not completely achieved because of missing input / Text3: 27.007
- 3241: AS: Rel5 changed to Rel4 according to SP#10 decision, milestone on testing added
- 3242: - / Text3: 27.903, 27.103
- 3243: - / Text3: 23.227
- 3244: -
- 3245: - / Text3: 23.041
- 3246: Only MAP impact foreseen so far. To be further split if needed.
- 3247: -
- 3248: To be also considered: External LCS client identity, and Privacy options when PDP-context and when no PDP-context is established / Text3: 22.071
- 3249: SP#10 completed / Text3: 25.305 (UTRAN part), new 23.271 (CN part by S2, 43.059 (GERAN part)
- 3250: -
- 3251: -
- 3252: -
- 3253: -
- 3254: -
- 3255: - / Text3: 25.401, 25.420, 25.423, 25.430, 25.433, new TR 25.850
- 3256: 5 Mar 2001: split of IPDL for TDD agreed by R2 / Text3: new TR 25.847

| ID | WBS | Task | Duration | Start | Finish | Complete | Baseline start | Baseline finish | Baseline duration | Constraint | Resources | Work | Actual work | Text1 | Text6 | Text8 | Text3 | Text4 | Text5 | Text12 |
| --- | --- | --- | --- | --- | --- | --- | --- | --- | --- | --- | --- | --- | --- | --- | --- | --- | --- | --- | --- | --- |
| 3257 | 69 | **Rel-4 UICC/(U)SIM enhancements and interworking** | 175d | 2000-07-24 A | 2001-03-23 A | 100% | 2000-07-24 | 2001-03-23 | 175d |  | T3 | 2800h | 2800h | UICC1 | Rel-4 | Xavier |  |  |  |  |
| 3258 | 69.1 | Common PCN Handset Specification (CPHS) | 175d | 2000-07-24 A | 2001-03-23 A | 100% | 2000-07-24 | 2001-03-23 | 175d | finish no earlier than 2001-03-23 | T3 | 1400h | 1400h | UICC1-CPHS | Rel-4 | Xavier | 27.103 | One2One |  |  |
| 3259 | 70 | **Rel-4 (U)SIM toolkit enhancements** | 210d | 2000-06-05 A | 2001-03-23 A | 100% | 2000-06-05 | 2001-03-23 | 210d |  | T3 | 3360h | 3360h | USAT1-LocLnk | Rel-4 | Xavier |  | Gemplus | Jean-Francois Rubon |  |
| 3260 | 70.1 | USAT local link | 210d | 2000-06-05 A | 2001-03-23 A | 100% | 2000-06-05 | 2001-03-23 | 210d | finish no earlier than 2001-03-23 | T3 | 1680h | 1680h | USAT1-LocLnk | Rel-4 | Xavier |  | Gemplus | Jean-Francois Rubon |  |
| 3261 | 71 | **Rel-4 Security enhancements** | 576d | 2000-01-03 A | 2002-03-15 A | 100% | 2000-01-03 | 2002-03-15 | 576d |  | S3,N4,N1 | 23640h | 23640h | SEC1 | Rel-4 | Dionisio |  | Vodafone | Peter.Howard@vodafone.com |  |
| 3262 | 54.2 | Rel-4 Lawful Interception | 155d | 2000-08-21 A | 2001-03-23 A | 100% | 2000-08-21 | 2001-03-23 | 155d | finish no earlier than 2001-03-23 | S3 | 1240h | 1240h | SEC1-LI | Rel-4 | Dionisio | 33.107 |  |  |  |
| 3263 | 71.1 | Evolution of GSM CS algorithms (e.g. A5/3 development and deployment) | 272d | 2000-01-03 A | 2001-01-15 A | 100% | 2000-01-03 | 2001-01-15 | 272d | finish no earlier than 2001-01-15 | S3 | 2168h | 2168h | SEC1-CSALGO1 | Rel-4 | Dionisio | 33.102, 33.103, 33.105 | DTI, BIS | cbrookson@iee.org |  |
| 3264 | 71.2 | **Evolution of GSM PS algorithms (e.g. GEA 2 deployment)** | 219d | 2000-02-22 A | 2000-12-22 A | 100% | 2000-02-22 | 2000-12-22 | 219d |  | S3,N4,N1 | 4272h | 4272h | SEC1-PSALGO1 | Rel-4 | Dionisio | 33.102, 33.103, 33.105 | DTI, BIS | cbrookson@iee.org |  |
| 3265 | 71.2.1 | Deleted - Main aspects of Evolution of GSM PS algorithms (e.g. GEA 2 deployment) | 199d | 2000-02-22 A | 2000-11-24 A | 100% | 2000-02-22 | 2000-11-24 | 199d | finish no earlier than 2000-11-24 | S3 | 1592h | 1592h | SEC1-PSALGO1 | Rel-4 | Dionisio |  | DTI, BIS | cbrookson@iee.org |  |
| 3266 | 71.2.2 | Impact on GTP | 200d | 2000-03-20 A | 2000-12-22 A | 100% | 2000-03-20 | 2000-12-22 | 200d | finish no earlier than 2000-12-22 | N4 | 1600h | 1600h | SEC1-PSALGO1 | Rel-4 | Kimmo |  | DTI, BIS | cbrookson@iee.org |  |
| 3267 | 71.2.3 | GEA capability indication in MS CM | 135d | 2000-06-19 A | 2000-12-22 A | 100% | 2000-06-19 | 2000-12-22 | 135d | finish no earlier than 2000-12-22 | N1 | 1080h | 1080h | SEC1-PSALGO1-GEACAP | Rel-4 | Frederic |  | Vodafone Airtouch | Duncan Mills |  |
| 3268 | 71.3 | **Deleted - MAP application layer security** | 576d | 2000-01-03 A | 2002-03-15 A | 100% | 2000-01-03 | 2002-03-15 | 576d |  | S3 | 11352h | 11352h | SEC1-MAPAL | Rel-4 | Dionisio |  |  |  | SP-15 |
| 3269 | 71.3.1 | Deleted - Main aspects of MAP application layer security | 199d | 2000-02-21 A | 2001-03-29 A | 100% | 2000-02-21 | 2001-03-29 | 199d | start no earlier than 2000-02-21 | S3 | 1592h | 1592h |  | Rel-4 | Dionisio |  |  |  | SP-11 |
| 3270 | 71.3.2 | Deleted - Other stage 3 aspects | 199d | 2000-02-22 A | 2000-11-24 A | 100% | 2000-02-22 | 2000-11-24 | 199d | finish no earlier than 2000-11-24 | N4 | 1592h | 1592h |  | Rel-4 | Kimmo |  |  |  | CP-10 |
| 3271 | 71.3.3 | Deleted - Visibility and Configurability of security | 576d | 2000-01-03 A | 2002-03-15 A | 100% | 2000-01-03 | 2002-03-15 | 576d | finish no earlier than 2002-03-15 | S3 | 4600h | 4600h | SEC1-VCS | Rel-4 | Dionisio |  | France Telecom | Sebastien.nguyenngoc@rd.francetelecom.com | SP-15 |
| 3272 | 72 | **Rel-4 Charging and OAM&P** | 221d | 2000-12-01 A | 2001-10-05 A | 100% | 2000-12-01 | 2001-10-05 | 221d |  | S5 | 10472h | 10472h | OAM | Rel-4 | Dionisio |  |  |  |  |
| 3273 | 72.1 | Rel-4 Principles, high level Requirements and Architecture | 145d | 2000-12-01 A | 2001-06-21 A | 100% | 2000-12-01 | 2001-06-21 | 145d | finish no earlier than 2001-06-21 | S5 | 1160h | 1160h | OAM-AR/PR | Rel-4 | Dionisio | 32.101, 32.102 | Motorola, Telia | Michael.Truss@motorola.com, Tommy.R.Berggren@TELIA.SE |  |
| 3274 | 72.2 | Rel-4 Performance Management | 216d | 2000-12-01 A | 2001-09-28 A | 100% | 2000-12-01 | 2001-09-28 | 216d | finish no earlier than 2001-06-21 | S5 | 1728h | 1728h |  | Rel-4 | Dionisio | 32.4xy, 52.402 | T-Mobile | karl-heinz.nenner@t-mobile.de |  |
| 3275 | 72.3 | Fault Management | 221d | 2000-12-01 A | 2001-10-05 A | 100% | 2000-12-01 | 2001-10-05 | 221d | finish no earlier than 2001-06-21 | S5 | 1768h | 1768h |  | Rel-4 | Dionisio | 32.111-1/4 | Lucent |  |  |
| 3276 | 72.4 | Configuration Management | 145d | 2000-12-01 A | 2001-06-21 A | 100% | 2000-12-01 | 2001-06-21 | 145d | finish no earlier than 2001-06-21 | S5 | 1160h | 1160h | OAM-CM | Rel-4 | Dionisio | 32.106-1/8 | Ericsson | thomas.tovinger@ericsson.com |  |
| 3277 | 72.5 | Rel-4 Charging Management | 216d | 2000-12-01 A | 2001-09-28 A | 100% | 2000-12-01 | 2001-09-28 | 216d | finish no earlier than 2001-06-21 | S5 | 1728h | 1728h | OAM-CH | Rel-4 | Dionisio | 32.200, 32.205, 32.215, 32.235 | T-Mobile | karl-heinz.nenner@t-mobile.de |  |
| 3278 | 72.6 | UTRAN Operations and Maintenance procedures | 145d | 2000-12-01 A | 2001-06-21 A | 100% | 2000-12-01 | 2001-06-21 | 145d | finish no earlier than 2001-06-21 | S5 | 1160h | 1160h | UOAM | Rel-4 | Dionisio | 32.800 | Mannesmann Mobilfunk | bert.boden@d2mannesmann.de |  |
| 3279 | 73 | **Global Text Telephony** | 2537d? | 2000-01-03 A | 2009-09-18 A | 100% | 2000-01-03 | 2009-09-18 | 2537d? |  | S1,S2,S4,T1,R5 | 44928h | 44928h | GTT | Rel-4 | Maurice |  | Ericsson | gunnar.hellstrom@omnitor.se |  |
| 3280 | 73.1 | Stage 1 for Global Text Telephony | 188d | 2000-04-05 A | 2000-12-22 A | 100% | 2000-04-05 | 2000-12-22 | 188d | finish no earlier than 2000-12-22 | S1 | 1504h | 1504h | GTT | Rel-4 | Alain | 22.226 |  |  |  |
| 3281 | 73.2 | Stage 2 for Global Text Telephony | 206d | 2000-01-03 A | 2000-10-13 A | 100% | 2000-01-03 | 2000-10-13 | 206d |  | S2 | 1640h | 1640h | GTT | Rel-4 | Maurice | 23.226 |  |  |  |

Notes:
- 3257: -
- 3258: 28/5/2001: CRs approved at TP-11. WI complete.
- 3259: -
- 3260: 25/5/2001:CR was approved at TP-11. WI is complete
- 3261: -
- 3262: Requirements capture: S3#14 (Aug 00), Feature specification: S3#15 (Sep 00), Definition of architecture. Should be included in general LI work mentioned above.
- 3263: SP#8 approved WID
- 3264: SP#8 approved WID
- 3265: Complete TSG#09 (09/2000). S3#17: Proposed for deletion. TO BE DELETED
- 3266: -
- 3267: -
- 3268: REPLACED BY NDS-MAP and NDS-IP. Completed Auto Key Management -> Rel-6. Marked as stopped 12/2008
- 3269: UID changed. Marked as stopped 12/2008
- 3270: UID changed. Marked as stopped 12/2008
- 3271: CR approved at SA3#21 awaiting comments from CN1. Marked as stopped 12/2008
- 3272: SP#13 approved WID
- 3273: -
- 3274: -
- 3275: -
- 3276: -
- 3277: -
- 3278: -
- 3279: SP#12 updated WID SP-000162=>SP-010340
- 3280: -
- 3281: -

| ID | WBS | Task | Duration | Start | Finish | Complete | Baseline start | Baseline finish | Baseline duration | Constraint | Resources | Work | Actual work | Text1 | Text6 | Text8 | Text9 | Text12 |
| --- | --- | --- | --- | --- | --- | --- | --- | --- | --- | --- | --- | --- | --- | --- | --- | --- | --- | --- |
| 3282 | 73.3 | **Specification of Cellular Text telephone Modem** | 136d | 2000-09-11 A | 2001-03-19 A | 100% | 2000-09-11 | 2001-03-19 | 136d |  | S4 | 2704h | 2704h | GTT-CTM | Rel-4 | Paolo |  |  |
| 3283 | 73.3.1 | General description and C-code | 66d | 2000-09-11 A | 2000-12-11 A | 100% | 2000-09-11 | 2000-12-11 | 66d | finish no earlier than 2000-12-11 | S4 | 528h | 528h | GTT-CTM | Rel-4 | Paolo |  |  |
| 3284 | 73.3.2 | Minimum Performance requirements | 136d | 2000-09-11 A | 2001-03-19 A | 100% | 2000-09-11 | 2001-03-19 | 136d | finish no earlier than 2001-03-19 | S4 | 1088h | 1088h | GTT-CTM | Rel-4 | Paolo |  |  |
| 3285 | 73.5 | Deleted - Conformance Test Aspects - Global Text Telephony | 2348d? | 2000-09-21 A | 2009-09-18 A | 100% | 2000-09-21 | 2009-09-18 | 2348d? | finish no earlier than 2009-09-18 | R5,T1 | 18784h | 18784h | GTT_Test | Rel-4 | Ingbert | PCG-23 | RP-45 |
| 3286 | 879 | Release 1999 Features | 261d? | 1999-01-01 A | 1999-12-31 A | 100% | 1999-01-01 | 1999-12-31 | 261d? |  | NP,SP,TP,SMG | 2088h | 2088h |  | R99 | All |  |  |
| 3287 | 880 | **UMTS Features** | 261d? | 1999-01-01 A | 1999-12-31 A | 100% | 1999-01-01 | 1999-12-31 | 261d? |  | S1,S2,S4,SMG,N3,N4,RP | 25056h | 25056h |  | R99 | Alain |  |  |
| 3288 | 880.1 | UMTS_SERVICES | 261d? | 1999-01-01 A | 1999-12-31 A | 100% | 1999-01-01 | 1999-12-31 | 261d? | start no earlier than 1999-01-01 | S1 | 2088h | 2088h | UMTS_SERVICES | R99 | Alain |  |  |
| 3289 | 880.2 | UMTS phase 1 | 261d? | 1999-01-01 A | 1999-12-31 A | 100% | 1999-01-01 | 1999-12-31 | 261d? | start no earlier than 1999-01-01 | S1 | 2088h | 2088h | UMTS1 | R99 | Alain |  |  |
| 3290 | 880.3 | UMTS Capabilities | 261d? | 1999-01-01 A | 1999-12-31 A | 100% | 1999-01-01 | 1999-12-31 | 261d? | start no earlier than 1999-01-01 | S1 | 2088h | 2088h | UMTS_Capabil | R99 | Alain |  |  |
| 3291 | 880.4 | Architecture of the GSM-UMTS platform | 261d? | 1999-01-01 A | 1999-12-31 A | 100% | 1999-01-01 | 1999-12-31 | 261d? | start no earlier than 1999-01-01 | S2,N4 | 2088h | 2088h |  | R99 | Maurice |  |  |
| 3292 | 880.5 | UMTS Terrestrial Radio Access Network | 261d? | 1999-01-01 A | 1999-12-31 A | 100% | 1999-01-01 | 1999-12-31 | 261d? | start no earlier than 1999-01-01 | RP | 2088h | 2088h | UTRAN | R99 | Joern |  |  |
| 3293 | 880.6 | UMTS 1800, UMTS 1900 | 261d? | 1999-01-01 A | 1999-12-31 A | 100% | 1999-01-01 | 1999-12-31 | 261d? | start no earlier than 1999-01-01 | R2 | 2088h | 2088h | Rlnlmp19, Rlnlmp18 | R99 | Joern |  |  |
| 3294 | 880.7 | Mandatory speech codec for narrowband telephony service | 261d? | 1999-01-01 A | 1999-12-31 A | 100% | 1999-01-01 | 1999-12-31 | 261d? | start no earlier than 1999-01-01 | S4 | 2088h | 2088h | Mandatory_Speech_Codec, AMR-NB, AMR | R99 | Paolo |  |  |
| 3295 | 880.8 | Codec for low bitrate multimedia telephony service | 261d? | 1999-01-01 A | 1999-12-31 A | 100% | 1999-01-01 | 1999-12-31 | 261d? | start no earlier than 1999-01-01 | S4 | 2088h | 2088h | Low_bit_rate_codec_for_MM_Tel., H.324M | R99 | Paolo |  |  |
| 3296 | 880.9 | 3G Audio-Visual Terminal characteristics | 261d? | 1999-01-01 A | 1999-12-31 A | 100% | 1999-01-01 | 1999-12-31 | 261d? | start no earlier than 1999-01-01 | S4 | 2088h | 2088h | WI5TAC, 3G-AVT, Terminal_Acoustic_Characteristics | R99 | Paolo |  |  |
| 3297 | 880.10 | Updates_for_UMTS | 261d? | 1999-01-01 A | 1999-12-31 A | 100% | 1999-01-01 | 1999-12-31 | 261d? | start no earlier than 1999-01-01 | N3 | 2088h | 2088h | Updates_for_UMTS | R99 | Gwiho |  |  |
| 3298 | 880.11 | UMTS | 261d? | 1999-01-01 A | 1999-12-31 A | 100% | 1999-01-01 | 1999-12-31 | 261d? | start no earlier than 1999-01-01 | N3 | 2088h | 2088h | UMTS | R99 | Gwiho |  |  |
| 3299 | 881 | **UMTS and GSM Features** | 261d? | 1999-01-01 A | 1999-12-31 A | 100% | 1999-01-01 | 1999-12-31 | 261d? |  | S1,S2,SMG,T2,N1,N2,N3,N4,R2,R3 | 114840h | 114840h |  | R99 | Alain |  |  |
| 3300 | 881.1 | Multimedia Messaging Service | 261d? | 1999-01-01 A | 1999-12-31 A | 100% | 1999-01-01 | 1999-12-31 | 261d? | start no earlier than 1999-01-01 | T2 | 2088h | 2088h | MMS | R99 |  |  |  |
| 3301 | 881.2 | Location Services | 261d? | 1999-01-01 A | 1999-12-31 A | 100% | 1999-01-01 | 1999-12-31 | 261d? | start no earlier than 1999-01-01 | S1,S2,S3,SMG1,SMG2,SMG12,N1,N2,N4,R2,R3 | 2088h | 2088h | LCS | R99 | Alain |  |  |
| 3302 | 881.3 | **Customised Application for Mobile network Enhanced Logic Phase 3** | 261d? | 1999-01-01 A | 1999-12-31 A | 100% | 1999-01-01 | 1999-12-31 | 261d? |  | S1,S2,N2,N4 | 6264h | 6264h | CAMEL3 | R99 | Alain |  |  |
| 3303 | 881.3.1 | Global view | 261d? | 1999-01-01 A | 1999-12-31 A | 100% | 1999-01-01 | 1999-12-31 | 261d? | start no earlier than 1999-01-01 | S1,S2,N2,N4 | 2088h | 2088h | CAMEL3 | R99 | Alain |  |  |
| 3304 | 881.3.2 | Multiple Subscriber Profile (MSP) based on CAMEL phase 3 | 261d? | 1999-01-01 A | 1999-12-31 A | 100% | 1999-01-01 | 1999-12-31 | 261d? | start no earlier than 1999-01-01 | S1 | 2088h | 2088h | CAMEL3 | R99 | Alain |  |  |
| 3305 | 881.4 | Short Message Service enhancements / Enhanced Messaging Service (EMS) | 261d? | 1999-01-01 A | 1999-12-31 A | 100% | 1999-01-01 | 1999-12-31 | 261d? | start no earlier than 1999-01-01 | T2 | 2088h | 2088h | EMS | R99 |  |  |  |
| 3306 | 881.5 | Mobile Station Execution Environment | 261d? | 1999-01-01 A | 1999-12-31 A | 100% | 1999-01-01 | 1999-12-31 | 261d? | start no earlier than 1999-01-01 | S1,SMG1,T2 | 2088h | 2088h | MExE | R99 | Alain |  |  |
| 3307 | 881.6 | MS_Classmark | 261d? | 1999-01-01 A | 1999-12-31 A | 100% | 1999-01-01 | 1999-12-31 | 261d? | start no earlier than 1999-01-01 | N1 | 2088h | 2088h | MS_Classmark | R99 | Frederic |  |  |

Notes:
- 3282: -
- 3283: - / Text3: 26.226, 26.230
- 3284: - / Text3: 26.231
- 3285: RP#45 work item abandoned/closed (it was never really started)
- 3286: -
- 3287: -
- 3288: - / Text3: 22.101
- 3289: - / Text3: 22.100
- 3290: Requirement for high quality speech in UMTS Phase 1 but not in R99 / Text3: 22.105
- 3291: wid Architecture overview of the GSM-UMTS System, Architecture the GSM-UMTS Platform and New Access Network to Core Network (BSS-NSS) interface / Text3: 23.002, 23.008, 23.060, 23.101, 23.110
- 3292: - / Text3: 22.011, 22.038, 22.060, 22.078, 22.100, 22.101, 22.105, 22.115, 22.129, 23.002, 23.060, 24.007, 24.008, 25.101, 25.102, 25.104, 25.105, 25.113, 25.123, 25.133, 25.141, 25.142, 25.201, 25.211, 25.212, 25.213, 25.214, 25.215, 25.221, 25.222, 25.223, 25.224,
- 3293: - / Text3: 25.307 CR#0002, 0003 Inclusion of release independent RF related information
- 3294: Define the default speech codec for UMTS (both for FDD and TDD). Definition limited to selection of one codec among several existing ones/proposed codecs: GSM AMR, IS127 EVRC, ITU G.729 and MPEG-4 speech codec. / Text3: 04.08, 05.01, 05.02, 05.03, 05.05, 05.08, 05.09, 05.09, 05.50, 08.60, 08.61, 11.21, 26.071, 26.073, 26.074, 26.090, 26.091, 26.092, 26.093, 26.094, 26.101, 26.102, 26.103, 26.104, 26.975
- 3295: - / Text3: 26.104, 26.110, 26.111, 26.911, 26.912, 26.915
- 3296: - / Text3: 26.131, 26.132
- 3297: - / Text3: 24.022, 27.001, 29.007
- 3298: - / Text3: 27.060, 29.061
- 3299: -
- 3300: MMS allows users to send/receive messages e.g. almost unlimited text length, images, audio and video clips and new content types. R99 only includes the concept. MMS stage 3 is not included in 23.140. Rel-4 adds detailed architecture and protocols. / Text3: 22.140, 23.040, 23.140
- 3301: LCS provide ability to localize a terminal / Text3: 02.07, 03.71, 04.31, 04.35, 04.71, 05.05, 08.08, 08.31, 08.71, 09.31, 22.071, 23.002, 23.003, 23.007, 23.008, 23.016, 23.018, 23.032, 23.171, 24.007, 24.008, 24.030, 24.080, 25.305, 25.306, 25.331, 25.413, 25.423, 29.002, 29.010
- 3302: CAMEL is a network feature providing mechanisms to support services of operators which are not covered by standardised services, even when roaming outside the HPLMN. / Text3: 22.101, 23.008, 23.012, 23.016, 23.018, 23.060, 23.072, 23.078, 23.079, 23.082, 23.093, 29.002, 29.078
- 3303: - / Text3: 22.078, 23.078, 29.078
- 3304: MSP is an optional service enabling mobile subscribers to have several profiles associated with a single IMSI, with each profile being a subscription option. Each profile may be used for mobile originated and mobile terminated calls. / Text3: 22.097 (Advanced Addressing)
- 3305: SMS for 3G terminals compatible with GSM SMS. Added Enhanced Messaging Service (EMS) allowing small pictures, sounds, animations to be transferred via SMS. / Text3: 23.038, 23.039, 23.040, 23.042
- 3306: MExE provides a standardized MS execution environment and ability to negotiate its supported capabilities with a MExE SP. R99 enhances SIM MExE certificate management, security clarifications, QoS and defines two MExE classmarks WAP/Personal-Java based. / Text3: 02.57, 22.057, 22.101, 23.057
- 3307: MExE classmark identifies a category of MExE UE supporting MExE functionality with a minimum level of processing, memory, display, and interactive capabilities. Several MExE classmarks may be defined. / Text3: 24.008

| ID | WBS | Task | Duration | Start | Finish | Complete | Baseline start | Baseline finish | Baseline duration | Constraint | Resources | Work | Actual work | Text1 | Text6 | Text8 | Text12 |
| --- | --- | --- | --- | --- | --- | --- | --- | --- | --- | --- | --- | --- | --- | --- | --- | --- | --- |
| 3308 | 881.7 | **MultiCall** | 261d? | 1999-01-01 A | 1999-12-31 A | 100% | 1999-01-01 | 1999-12-31 | 261d? |  | S1,N1,N2,N4 | 4176h | 4176h | Multicall | R99 | Alain |  |
| 3309 | 881.7.1 | Stage 1 for Multicall | 261d? | 1999-01-01 A | 1999-12-31 A | 100% | 1999-01-01 | 1999-12-31 | 261d? | start no earlier than 1999-01-01 | S1 | 2088h | 2088h | Multicall | R99 | Alain |  |
| 3310 | 881.8 | Virtual Home Environment | 261d? | 1999-01-01 A | 1999-12-31 A | 100% | 1999-01-01 | 1999-12-31 | 261d? | start no earlier than 1999-01-01 | S1,SMG1,S2 | 2088h | 2088h | VHE | R99 | Alain |  |
| 3311 | 881.9 | Open Service Access | 261d? | 1999-01-01 A | 1999-12-31 A | 100% | 1999-01-01 | 1999-12-31 | 261d? | start no earlier than 1999-01-01 | S1,S2,N5 | 2088h | 2088h | OSA | R99 | Alain |  |
| 3312 | 881.10 | Super Charger mechanism for signalling traffic associated with mobility | 261d? | 1999-01-01 A | 1999-12-31 A | 100% | 1999-01-01 | 1999-12-31 | 261d? | start no earlier than 1999-01-01 | N2,N4 | 2088h | 2088h | Super_Charger | R99 | Kimmo |  |
| 3313 | 881.11 | Follow_Me service | 261d? | 1999-01-01 A | 1999-12-31 A | 100% | 1999-01-01 | 1999-12-31 | 261d? | start no earlier than 1999-01-01 | S1,N2,N4 | 2088h | 2088h | Follow_Me | R99 | Alain |  |
| 3314 | 881.12 | Wide area network Synchronization and object exchange | 261d? | 1999-01-01 A | 1999-12-31 A | 100% | 1999-01-01 | 1999-12-31 | 261d? | start no earlier than 1999-01-01 | T2 | 2088h | 2088h | SYNC | R99 |  |  |
| 3315 | 881.13 | **R99 Terminal Interfaces** | 261d? | 1999-01-01 A | 1999-12-31 A | 100% | 1999-01-01 | 1999-12-31 | 261d? |  | T2 | 8352h | 8352h |  | R99 |  |  |
| 3316 | 881.13.1 | AT commands for 3GPP | 261d? | 1999-01-01 A | 1999-12-31 A | 100% | 1999-01-01 | 1999-12-31 | 261d? | start no earlier than 1999-01-01 | T2 | 2088h | 2088h |  | R99 |  |  |
| 3317 | 881.13.2 | Physical interfaces | 261d? | 1999-01-01 A | 1999-12-31 A | 100% | 1999-01-01 | 1999-12-31 | 261d? | start no earlier than 1999-01-01 | T2 | 2088h | 2088h |  | R99 |  |  |
| 3318 | 881.13.3 | Multiplexer | 261d? | 1999-01-01 A | 1999-12-31 A | 100% | 1999-01-01 | 1999-12-31 | 261d? | start no earlier than 1999-01-01 | T2 | 2088h | 2088h | MUX MS-TE | R99 |  |  |
| 3319 | 881.14 | **Bearer Services** | 261d? | 1999-01-01 A | 1999-12-31 A | 100% | 1999-01-01 | 1999-12-31 | 261d? |  | S1,T2,N1,N3 | 27144h | 27144h |  | R99 | Alain |  |
| 3320 | 881.14.1 | **Circuit Switched Bearer Services** | 261d? | 1999-01-01 A | 1999-12-31 A | 100% | 1999-01-01 | 1999-12-31 | 261d? |  | S1,N3 | 14616h | 14616h | Circuit_switched_Bearer_Services | R99 | Alain |  |
| 3321 | 881.14.1.1 | Stage 1 for Circuit Switched Bearer Services | 261d? | 1999-01-01 A | 1999-12-31 A | 100% | 1999-01-01 | 1999-12-31 | 261d? | start no earlier than 1999-01-01 | S1 | 2088h | 2088h | CS_Bearerss_in_UMTS | R99 | Alain |  |
| 3322 | 881.14.1.2 | CS_Bearers | 261d? | 1999-01-01 A | 1999-12-31 A | 100% | 1999-01-01 | 1999-12-31 | 261d? | start no earlier than 1999-01-01 | N3 | 2088h | 2088h | CS_Bearers | R99 | Gwiho |  |
| 3323 | 881.14.1.3 | CS_Bearerss | 261d? | 1999-01-01 A | 1999-12-31 A | 100% | 1999-01-01 | 1999-12-31 | 261d? | start no earlier than 1999-01-01 | N3 | 2088h | 2088h | CS_Bearerss | R99 | Gwiho |  |
| 3324 | 881.14.1.4 | CS_Data | 261d? | 1999-01-01 A | 1999-12-31 A | 100% | 1999-01-01 | 1999-12-31 | 261d? | start no earlier than 1999-01-01 | N3 | 2088h | 2088h | CS_Data | R99 | Gwiho |  |
| 3325 | 881.14.1.5 | CS_Data_Bearers | 261d? | 1999-01-01 A | 1999-12-31 A | 100% | 1999-01-01 | 1999-12-31 | 261d? | start no earlier than 1999-01-01 | N3 | 2088h | 2088h | CS_Data_Bearers | R99 | Gwiho |  |
| 3326 | 881.14.1.6 | Deleted - CN3 poart of Circuit Switched Bearer Services | 261d? | 1999-01-01 A | 1999-12-31 A | 100% | 1999-01-01 | 1999-12-31 | 261d? | start no earlier than 1999-01-01 | N3 | 2088h | 2088h | CSBS | R99 | Gwiho | NP-06 |
| 3327 | 881.14.2 | Frame Tunnelling Mode | 261d? | 1999-01-01 A | 1999-12-31 A | 100% | 1999-01-01 | 1999-12-31 | 261d? | start no earlier than 1999-01-01 | T2,N1,N3 | 2088h | 2088h | FTM | R99 | Gwiho |  |
| 3328 | 881.14.3 | Access to ISPs and Intranets – Wireless/Remote access to LANs | 261d? | 1999-01-01 A | 1999-12-31 A | 100% | 1999-01-01 | 1999-12-31 | 261d? | start no earlier than 1999-01-01 | N3 | 2088h | 2088h | Interworking with PDN (DHCP) | R99 | Gwiho |  |
| 3329 | 881.14.4 | **PHS Internet Access Forum Specification** | 261d? | 1999-01-01 A | 1999-12-31 A | 100% | 1999-01-01 | 1999-12-31 | 261d? |  | S1,N3 | 6264h | 6264h | PIAFS | R99 | Alain |  |
| 3330 | 881.14.4.1 | Personal Handyphone System Internet Access Forum Standard (PIAFS) | 261d? | 1999-01-01 A | 1999-12-31 A | 100% | 1999-01-01 | 1999-12-31 | 261d? | start no earlier than 1999-01-01 | S1 | 2088h | 2088h | PIAFS | R99 | Alain |  |
| 3331 | 881.14.4.2 | Support_of_PIAFS_in_UMTS | 261d? | 1999-01-01 A | 1999-12-31 A | 100% | 1999-01-01 | 1999-12-31 | 261d? | start no earlier than 1999-01-01 | N3 | 2088h | 2088h | Support_of_PIAFS_in_UMTS | R99 | Gwiho |  |

Notes:
- 3308: Multicall allows several simultaneous CS calls with dedicated bearers of independent traffic and performance characteristics. R99 Multicall was defined as a supplementary service limited to one CS bearer to be used for speech at any time. / Text3: 22.030, 22.083, 22.087, 23.008, 23.009, 23.016, 23.018, 23.108, 23.135, 24.008, 24.080, 24.135, 29.002, 29.010
- 3309: - / Text3: 22.030, 22.083, 22.087
- 3310: Information exists in SP#5-8 reports & in SP-99416,SP-000095,SP 000155. OSA allows service development by operators and 3rd parties by making use of network functionality through open, standardised, secure, extensible and scalable interfaces. / Text3: 02.01, 22.105, 22.121,23.127
- 3311: Open Service Architecture became in later Releases Open Service Access. Produced by Parlay, ETSI SPAN (TISPAN), 3GPP SA1 (Stage 1), SA2 (Stage 2) and CN5 (Stage 3), resulting in a single set of standard OSA APIs for the whole development community. / Text3: 22.121, 23.127, 29.198, 29.998
- 3312: Super Charger reduces mobility management cost by reducing the volume of location update signalling. It changes subscriber data management associated with inter-VLR and SGSN location updates. It also applies to packet services (SGSN replaces VLR and … / Text3: 21.905, 23.007, 23.008, 23.012, 23.016, 23.018, 23.040, 23.060, 23.116, 23.912, 29.002
- 3313: Follow Me enables a mobile subscriber A to manipulate the Follow Me data of a party B in such a way that - under certain conditions - subsequent calls directed to party B will be forwarded to subscriber A. It is PLMN-specific and control based on USSD / Text3: 21.905, 22.004, 22.030, 22.082, 22.090, 22.094, 23.090, 24.090, 22.094, 23.011, 23.015, 23.082, 29.002
- 3314: Allows data stored in ME/USIM to be synchronized with the outside world. TS 27.103 defines protocols based upon IrMC level 4 and will evaluate new technologies (XML) for inclusion. From Rel-4 IrMC was replaced by SyncML in 27.103. / Text3: 27.103, 27.903
- 3315: -
- 3316: AT commands to control a 3G ME via an external Terminal Equipment (TE), fully compatible with GSM AT commands. R99 adds new AT commands e.g. to control Advanced Speech Call Items (ASCI) services. / Text3: 27.005, 27.007
- 3317: Conclusion: 3GPP should not produce any technical specification for terminal interfaces other than radio interface and USIM interface. SDOs could develop own optional physical connector specification based on market requirements / Text3: 27.901
- 3318: Multiplexing protocol allowing a number of simultaneous sessions between a MS and a terminal; used to send any data (voice, SMS, USSD, fax etc.). 27.010 describes the protocol, but not the commands or data transported with it. / Text3: 27.010
- 3319: -
- 3320: CS and real-time data services provided for interworking with PSTN/ISDN so that user is unaware of access network used (UMTS, GSM or handover between ANs). Transparent(constant delay) & non-transparent(zero error with flow control) services are supported / Text3: 22.002, 23.910, 27.001, 29.007
- 3321: CS and real-time data services provided for interworking with PSTN/ISDN so that user is unaware of access network used (UMTS, GSM or handover between ANs). Transparent(constant delay) & non-transparent(zero error with flow control) services are supported / Text3: 22.002
- 3322: - / Text3: 29.007
- 3323: - / Text3: 04.21, 23.910, 27.001, 29.007
- 3324: - / Text3: 27.001, 27.002, 27.003, 29.007
- 3325: - / Text3: 23.910, 27.001, 29.007
- 3326: No CR or new TS/TR approved under this WI / Text3: 23.910, 27.001, 29.007
- 3327: FTM is a type of async non-transparent CS bearer service (22.002). Generic term for HDLC and HDLC-related transmission protocols. Converts async non-transp data stream towards mobile side & sync data stream using X.31 flag stuffing on fixed network side. / Text3: 22.002, 27.001, 27.007, 29.007
- 3328: Access to an Intranet or ISP by running DHCP between the TE and a server in the Intranet/ISP domain. / Text3: 29.061
- 3329: PIAFS is one type of CS bearer data service (22.002). It refers to async CS tx protocol over ISDN 64 kbit/s unrestricted digital line. Facilitates interworking between PHS-MS and UMTS-UE & UMTS-UE and existing PIAFS TA (Terminal Adapter). / Text3: 22.002, 27.001, 27.007, 29.007
- 3330: PIAFS was originally standardised by the PHS Internet Access Forum in Japan. More information can be found at: http://www.infopro.or.jp/piaf / Text3: 22.002
- 3331: - / Text3: 27.001, 27.007, 29.007

| ID | WBS | Task | Duration | Start | Finish | Complete | Baseline start | Baseline finish | Baseline duration | Constraint | Resources | Work | Actual work | Text1 | Text6 | Text8 | Text12 |
| --- | --- | --- | --- | --- | --- | --- | --- | --- | --- | --- | --- | --- | --- | --- | --- | --- | --- |
| 3332 | 881.15 | **Universal Integrated Circuit Card (UICC) and Universal Subscriber Identity Module (USIM)** | 261d? | 1999-01-01 A | 1999-12-31 A | 100% | 1999-01-01 | 1999-12-31 | 261d? |  | T3 | 27144h | 27144h | UICC, USIM | R99 | Xavier |  |
| 3333 | 881.15.1 | UICC / Terminal interface; Physical and logical characteristics | 261d? | 1999-01-01 A | 1999-12-31 A | 100% | 1999-01-01 | 1999-12-31 | 261d? | start no earlier than 1999-01-01 | T3 | 2088h | 2088h | UICC | R99 | Xavier |  |
| 3334 | 881.15.2 | UICC/(U)SIM enhancements and interworking | 261d? | 1999-01-01 A | 1999-12-31 A | 100% | 1999-01-01 | 1999-12-31 | 261d? | start no earlier than 1999-01-01 | T3 | 2088h | 2088h | UICC1 | R99 | Xavier |  |
| 3335 | 881.15.3 | Characteristics of the USIM application | 261d? | 1999-01-01 A | 1999-12-31 A | 100% | 1999-01-01 | 1999-12-31 | 261d? | start no earlier than 1999-01-01 | T3 | 2088h | 2088h | USIM | R99 | Xavier |  |
| 3336 | 881.15.4 | UICC Application Identifiers | 261d? | 1999-01-01 A | 1999-12-31 A | 100% | 1999-01-01 | 1999-12-31 | 261d? | start no earlier than 1999-01-01 | T3 | 2088h | 2088h | AID, Application_Identifiers | R99 | Xavier |  |
| 3337 | 881.15.5 | SIM Application Toolkit | 261d? | 1999-01-01 A | 1999-12-31 A | 100% | 1999-01-01 | 1999-12-31 | 261d? | start no earlier than 1999-01-01 | S1,T3 | 2088h | 2088h | SAT | R99 | Alain |  |
| 3338 | 881.15.6 | USIM Application Toolkit | 261d? | 1999-01-01 A | 1999-12-31 A | 100% | 1999-01-01 | 1999-12-31 | 261d? | start no earlier than 1999-01-01 | T3 | 2088h | 2088h | USAT | R99 | Xavier |  |
| 3339 | 881.15.7 | Bearer Independent Protocol for SAT applications to exchange data over the GSM network | 261d? | 1999-01-01 A | 1999-12-31 A | 100% | 1999-01-01 | 1999-12-31 | 261d? | start no earlier than 1999-01-01 | T3 | 2088h | 2088h | BIP | R99 | Xavier |  |
| 3340 | 881.15.8 | Administrative commands and functions for IC cards | 261d? | 1999-01-01 A | 1999-12-31 A | 100% | 1999-01-01 | 1999-12-31 | 261d? | start no earlier than 1999-01-01 | T3 | 2088h | 2088h |  | R99 | Xavier |  |
| 3341 | 881.15.9 | USIM and UICC requirements | 261d? | 1999-01-01 A | 1999-12-31 A | 100% | 1999-01-01 | 1999-12-31 | 261d? | start no earlier than 1999-01-01 | T3 | 2088h | 2088h |  | R99 | Xavier |  |
| 3342 | 881.15.10 | SIM_API | 261d? | 1999-01-01 A | 1999-12-31 A | 100% | 1999-01-01 | 1999-12-31 | 261d? | start no earlier than 1999-01-01 | T3 | 2088h | 2088h | SIM_API | R99 | Xavier |  |
| 3343 | 881.15.11 | SIM_toolkit_API | 261d? | 1999-01-01 A | 1999-12-31 A | 100% | 1999-01-01 | 1999-12-31 | 261d? | start no earlier than 1999-01-01 | SMG9,T3 | 2088h | 2088h | SIM_toolkit | R99 | Xavier |  |
| 3344 | 881.15.12 | Deleted - 1.8 Volt SIM ME interface | 261d? | 1999-01-01 A | 1999-12-31 A | 100% | 1999-01-01 | 1999-12-31 | 261d? | start no earlier than 1999-01-01 | SMG9 | 2088h | 2088h | SMIME_1.8V | R99 | Xavier | TP-06 |
| 3345 | 881.16 | **USIM/UICC Testing** | 261d? | 1999-01-01 A | 1999-12-31 A | 100% | 1999-01-01 | 1999-12-31 | 261d? |  | T3 | 10440h | 10440h |  | R99 | Xavier |  |
| 3346 | 881.16.1 | Terminal tests for the UICC Interface | 261d? | 1999-01-01 A | 1999-12-31 A | 100% | 1999-01-01 | 1999-12-31 | 261d? | start no earlier than 1999-01-01 | T3 | 2088h | 2088h |  | R99 | Xavier |  |
| 3347 | 881.16.2 | USIM application test specification | 261d? | 1999-01-01 A | 1999-12-31 A | 100% | 1999-01-01 | 1999-12-31 | 261d? | start no earlier than 1999-01-01 | T3 | 2088h | 2088h |  | R99 | Xavier |  |
| 3348 | 881.16.3 | USIM conformance test specification | 261d? | 1999-01-01 A | 1999-12-31 A | 100% | 1999-01-01 | 1999-12-31 | 261d? | start no earlier than 1999-01-01 | T3 | 2088h | 2088h |  | R99 | Xavier |  |
| 3349 | 881.16.4 | SIM toolkit test specification | 261d? | 1999-01-01 A | 1999-12-31 A | 100% | 1999-01-01 | 1999-12-31 | 261d? | start no earlier than 1999-01-01 | T3 | 2088h | 2088h |  | R99 | Xavier |  |
| 3350 | 881.17 | **Security for UMTS and GSM Features** | 261d? | 1999-01-01 A | 1999-12-31 A | 100% | 1999-01-01 | 1999-12-31 | 261d? |  | S3,N2,N4 | 8352h | 8352h | Security | R99 | Dionisio |  |
| 3351 | 881.17.1 | Fraud Information Gathering Service (for connection-orientated services) | 261d? | 1999-01-01 A | 1999-12-31 A | 100% | 1999-01-01 | 1999-12-31 | 261d? | start no earlier than 1999-01-01 | S3 | 2088h | 2088h | FIGS | R99 | Dionisio |  |
| 3352 | 881.17.2 | Immediate Service Termination / SECurity Immediate Service Termination | 261d? | 1999-01-01 A | 1999-12-31 A | 100% | 1999-01-01 | 1999-12-31 | 261d? | start no earlier than 1999-01-01 | S3,N2,N4 | 2088h | 2088h | IST, SECIST | R99 | Dionisio |  |
| 3353 | 881.17.3 | Core_Network_Security | 261d? | 1999-01-01 A | 1999-12-31 A | 100% | 1999-01-01 | 1999-12-31 | 261d? | start no earlier than 1999-01-01 | N4 | 2088h | 2088h | Core_Network_Security | R99 | Kimmo |  |
| 3354 | 882 | **GSM Features** | 261d? | 1999-01-01 A | 1999-12-31 A | 100% | 1999-01-01 | 1999-12-31 | 261d? |  | S1,S2,SMG,T2,N1,N2,N3,N4 | 50112h | 50112h |  | R99 | Alain |  |
| 3355 | 882.1 | **Dual Transfer Mode within GSM and GPRS** | 261d? | 1999-01-01 A | 1999-12-31 A | 100% | 1999-01-01 | 1999-12-31 | 261d? |  | SMG,N1 | 6264h | 6264h | DTM | R99 | Frederic |  |
| 3356 | 882.1.1 | Class A Dual Transfer Mode | 261d? | 1999-01-01 A | 1999-12-31 A | 100% | 1999-01-01 | 1999-12-31 | 261d? | start no earlier than 1999-01-01 | SMG | 2088h | 2088h | Class_A_Dual_Transfer_Mode_(DTM) | R99 | Frederic |  |
| 3357 | 882.1.2 | Dual Transfer Mode | 261d? | 1999-01-01 A | 1999-12-31 A | 100% | 1999-01-01 | 1999-12-31 | 261d? | start no earlier than 1999-01-01 | SMG,N1 | 2088h | 2088h | DTM | R99 | Frederic |  |

Notes:
- 3332: For 3G, GSM 11.11 was divided into two parts: a platform comprised of basic physical, electrical and logical specification (31.101) and an application specification (31.102)
- 3333: Defines a generic Terminal/Integrated Circuit Card (ICC) interface. Is independent of 3G USIM application => platform for any IC card application. Ensures interoperability between ICC and terminal independently of manufacturer, card issuer or operator. / Text3: 31.101 (Since 10/2000, ETSI EP SCP is responsible for the generic Terminal/Integrated Circuit Card (ICC) interface TS 102 221)
- 3334: - / Text3: 31.102, 31.900
- 3335: Defines Universal Subscriber Identity Module (USIM) application for 3G telecom network operation & resides on UICC, an IC card specified in 31.101. UICC can be used as a multi-application card: several USIMs and/or other applications can co-exist / Text3: 31.102
- 3336: Defines and administers Application IDentifiers (AID) for UICC. AID is used to address an application in the card. Consists of Registered application provider ID (RID) & Proprietary application ID exception (PIX - according to ISO/IEC 7816-5). / Text3: 21.111, 31.110
- 3337: - / Text3: 11.14, 22.030, 22.100, 22.101
- 3338: Defines UICC - ME interface, and mandatory ME procedures for USAT. Based on GSM 11.14 (SIM Application Toolkit). Commands and procedures defined in USIM and 3G Terminal for using USAT. Service and security requirements defined in 22.100 and 22.101. / Text3: 31.111
- 3339: Defines at SIM-ME interface a basic protocol allowing SIM Toolkit applications to determine available bearers and to exchange data by selecting using the most appropriate bearer available (CS data, GPRS, SMS, Unstructured Supplementary Service Data (USSD) / Text3: 03.48, 11.10, 11.14
- 3340: Defines function and syntax of administrative commands for telecommunication IC Card used during installation, activation and de-activation of applications. Compliant to ISO/IEC 7816 series. Handed over to ETSI Project Smart Card Platform (SCP) in 2000. / Text3: ETSI TS 102 222
- 3341: High level requirements for 3GPP IC card and its interface to 3GPP terminal (USIM&UICC reqs). Service&security reqs in 322.01,22.00. USIM is a 3GPP application on an IC card. Inter-operates with 3GPP terminals and provides access to 3GPP services / Text3: 21.111
- 3342: - / Text3: 03.19
- 3343: - / Text3: 03.48, 11.11, 11.14
- 3344: No CR or new TS/TR approved under this WI / Text3: 11.18
- 3345: -
- 3346: Test spec for the interface between UICC and terminal (originally based GSM 11.10-1 clause 27). Ensures UICC - terminal interoperability independently of manufacturer, card issuer or operator. Tests for applications residing on UICC are in 31.121 / Text3: 31.120
- 3347: Application test spec originally based on GSM 11.17. Aspects related to UICC administrative management phase are not defined. Any internal technical realisation of either UICC or terminal is only specified where these are reflected over the interface. / Text3: 31.121
- 3348: Conformance Test specification for UICC defined in 31.101 with USIM defined in 31.102. / Text3: 31.122
- 3349: SIM Application Toolkit (SAT) has major impact on ME design and enhances SIM/ME interface. Contains tests for SIM/ME interface optional features (no network related signalling issues involved). Doesn't form basis for any type approval or regulatory tests. / Text3: 11.10-4
- 3350: - / Text3: 02.09, 03.20, 21.133, 22.022, 23.003, 23.007, 23.008, 23.012, 23.018, 24.007, 24.008, 24.010, 24.011, 29.002, 29.060, new (33.102, 33.103, 33.105, 33.107, 35.201)
- 3351: HPLMN can monitor its subscribers in VPLMN, which collects info on a defined set of monitored subscribers activities & sends it to HPLMN, which can perform service limitation control eg Operator Determined Barring (ODB) and IST to limit financial exposure / Text3: new 22.031, 23.031
- 3352: HPLMN can terminate all activities of its subscriber in VPLMN, if decides (based on info via eg FIGS) that a roaming subscriber is behaving in fraudulent/suspicious way. HPLMN can terminate all subscriber activities including calls in progress. / Text3: 03.35, 22.032, 23.008, 23.016, 23.035, 29.002
- 3353: - / Text3: 29.002
- 3354: -
- 3355: 2-99-1780 (2-99-H80 from SMG2#32) WID on BSS co-ordination of Radio Resource allocation for class A GPRS services - GSM Radio Access (R99) / Text3: 03.55, 03.64, 04.18, 04.60, 05.01, 05.02, 05.08, 08.08, 23.060, 24.007, 24.008
- 3356: - / Text3: 05.10
- 3357: - / Text3: 03.55, 03.64, 04.18, 05.01, 05.02, 05.08, 24.008

| ID | WBS | Task | Duration | Start | Finish | Complete | Baseline start | Baseline finish | Baseline duration | Constraint | Resources | Work | Actual work | Text1 | Text6 | Text8 | Text12 | Text4 | Text5 |
| --- | --- | --- | --- | --- | --- | --- | --- | --- | --- | --- | --- | --- | --- | --- | --- | --- | --- | --- | --- |
| 3358 | 882.2 | **General Packet Radio Service enahancements** | 261d? | 1999-01-01 A | 1999-12-31 A | 100% | 1999-01-01 | 1999-12-31 | 261d? |  | S1,S2,SMG1,SMG2,SMG7,N1,N2,N3,N4,T2 | 8352h | 8352h | GPRS enhancements | R99 | Alain |  |  |  |
| 3359 | 882.2.1 | General Packet Radio Service | 261d? | 1999-01-01 A | 1999-12-31 A | 100% | 1999-01-01 | 1999-12-31 | 261d? | start no earlier than 1999-01-01 | S1,S2,SMG1,SMG2,SMG7,N1,N2,N3,N4,T2 | 2088h | 2088h | GPRS | R99 | Alain |  |  |  |
| 3360 | 882.2.2 | GPRS2 | 261d? | 1999-01-01 A | 1999-12-31 A | 100% | 1999-01-01 | 1999-12-31 | 261d? | start no earlier than 1999-01-01 | SMG1,N2 | 2088h | 2088h | GPRS2 | R99 |  |  |  |  |
| 3361 | 882.2.3 | GPRS Tunnelling Protocol enhancement | 261d? | 1999-01-01 A | 1999-12-31 A | 100% | 1999-01-01 | 1999-12-31 | 261d? | start no earlier than 1999-01-01 | N4,N2 | 2088h | 2088h | GTP_enhancement | R99 | Kimmo |  |  |  |
| 3362 | 882.3 | **Enhanced Data rates for GSM Evolution - Phase 1** | 261d? | 1999-01-01 A | 1999-12-31 A | 100% | 1999-01-01 | 1999-12-31 | 261d? |  | SMG2,SMG1,SMG3,SMG4,SMG7,SMG9,SMG10,N1,N3,T2 | 25056h | 25056h | EDGE - Phase 1 | R99 | Maurice |  |  |  |
| 3363 | 882.3.1 | Enhanced Data rates for GSM Evolution | 261d? | 1999-01-01 A | 1999-12-31 A | 100% | 1999-01-01 | 1999-12-31 | 261d? | start no earlier than 1999-01-01 | SMG2,SMG1,SMG3,SMG4,SMG7,SMG9,SMG10,N1,N3,T2 | 2088h | 2088h | EDGE | R99 | Maurice |  |  |  |
| 3364 | 882.3.2 | EDGE-Layer1 | 261d? | 1999-01-01 A | 1999-12-31 A | 100% | 1999-01-01 | 1999-12-31 | 261d? | start no earlier than 1999-01-01 | SMG2 | 2088h | 2088h | EDGE-Layer1 | R99 |  |  |  |  |
| 3365 | 882.3.3 | High Speed Circuit Switched Data | 261d? | 1999-01-01 A | 1999-12-31 A | 100% | 1999-01-01 | 1999-12-31 | 261d? | start no earlier than 1999-01-01 | SMG1,SMG2,SMG7 | 2088h | 2088h | HSCSD | R99 |  |  |  |  |
| 3366 | 882.3.4 | Enhanced Circuit Switched Data - Phase 1 | 261d? | 1999-01-01 A | 1999-12-31 A | 100% | 1999-01-01 | 1999-12-31 | 261d? | start no earlier than 1999-01-01 | S1,SMG | 2088h | 2088h | ECSD | R99 | Alain |  |  |  |
| 3367 | 882.3.5 | EDGE-Enhanced Circuit Switched Data | 261d? | 1999-01-01 A | 1999-12-31 A | 100% | 1999-01-01 | 1999-12-31 | 261d? | start no earlier than 1999-01-01 | SMG2 | 2088h | 2088h | EDGE-ECSD | R99 |  |  |  |  |
| 3368 | 882.3.6 | Enhanced GPRS - Phase 1 | 261d? | 1999-01-01 A | 1999-12-31 A | 100% | 1999-01-01 | 1999-12-31 | 261d? | start no earlier than 1999-01-01 | SMG,N1 | 2088h | 2088h | EGPRS | R99 |  |  |  |  |
| 3369 | 882.3.7 | EDGE-EGPRS | 261d? | 1999-01-01 A | 1999-12-31 A | 100% | 1999-01-01 | 1999-12-31 | 261d? | start no earlier than 1999-01-01 | SMG2 | 2088h | 2088h | EDGE-EGPRS | R99 |  |  |  |  |
| 3370 | 882.3.8 | Packet Flow Context (PFC) | 261d? | 1999-01-01 A | 1999-12-31 A | 100% | 1999-01-01 | 1999-12-31 | 261d? | start no earlier than 1999-01-01 | SMG2 | 2088h | 2088h | PFC | R99 |  |  |  |  |
| 3371 | 882.3.9 | Support for EGPRS in ANSI-136 networks and EDGE COMPACT | 261d? | 1999-01-01 A | 1999-12-31 A | 100% | 1999-01-01 | 1999-12-31 | 261d? | start no earlier than 1999-01-01 | SMG | 2088h | 2088h | EDGE-Compact | R99 |  |  |  |  |
| 3372 | 882.3.10 | EGPRS COMPACT | 261d? | 1999-01-01 A | 1999-12-31 A | 100% | 1999-01-01 | 1999-12-31 | 261d? | start no earlier than 1999-01-01 | SMG | 2088h | 2088h | EGPRS-Compact | R99 |  |  |  |  |
| 3373 | 882.3.11 | COMPACT | 261d? | 1999-01-01 A | 1999-12-31 A | 100% | 1999-01-01 | 1999-12-31 | 261d? | start no earlier than 1999-01-01 | SMG,N1 | 2088h | 2088h | COMPACT | R99 |  |  |  |  |
| 3374 | 882.4 | GSM_400 | 261d? | 1999-01-01 A | 1999-12-31 A | 100% | 1999-01-01 | 1999-12-31 | 261d? | start no earlier than 1999-01-01 | SMG2,SMG7,T2 | 2088h | 2088h | GSM_400 | R99 | Paolo |  |  |  |
| 3375 | 882.5 | GSM_450 | 261d? | 1999-01-01 A | 1999-12-31 A | 100% | 1999-01-01 | 1999-12-31 | 261d? | start no earlier than 1999-01-01 | SMG2 | 2088h | 2088h | GSM_450 | R99 |  |  |  |  |
| 3376 | 882.6 | GSM_700 | 261d? | 1999-01-01 A | 1999-12-31 A | 100% | 1999-01-01 | 1999-12-31 | 261d? | start no earlier than 1999-01-01 | SMG2 | 2088h | 2088h | GSM_700 | R99 |  |  |  |  |
| 3377 | 882.7 | Deleted - GERAN | 261d? | 1999-01-01 A | 1999-12-31 A | 100% | 1999-01-01 | 1999-12-31 | 261d? | start no earlier than 1999-01-01 | SMG2,S2 | 2088h | 2088h | GERAN | R99 | Maurice | SP-06 |  |  |
| 3378 | 883 | **GSM Features transposed to UMTS** | 261d? | 1999-01-01 A | 1999-12-31 A | 100% | 1999-01-01 | 1999-12-31 | 261d? |  | S1,S3,T2,N2,N4 | 16704h | 16704h |  | R99 | Alain |  |  |  |
| 3379 | 883.1 | Cell Broadcast Service | 261d? | 1999-01-01 A | 1999-12-31 A | 100% | 1999-01-01 | 1999-12-31 | 261d? | start no earlier than 1999-01-01 | T2 | 2088h | 2088h | CBS | R99 |  |  |  |  |
| 3380 | 883.2 | **GSM mobile number portability euro MNP / North American MNP** | 261d? | 1999-01-01 A | 1999-12-31 A | 100% | 1999-01-01 | 1999-12-31 | 261d? |  | S1,N2,N4 | 4176h | 4176h | MNP | R99 | Alain |  |  |  |
| 3381 | 883.2.1 | Mobile Number Portability | 261d? | 1999-01-01 A | 1999-12-31 A | 100% | 1999-01-01 | 1999-12-31 | 261d? | start no earlier than 1999-01-01 | N2,N4 | 2088h | 2088h | MNP | R99 | Kimmo |  |  |  |
| 3382 | 883.3 | Automatic establishment of roaming relations | 261d? | 1999-01-01 A | 1999-12-31 A | 100% | 1999-01-01 | 1999-12-31 | 261d? | start no earlier than 1999-01-01 | S1 | 2088h | 2088h |  | R99 | Alain |  | Telecom Italia | enrico.scarrone@telecomitalia.it |
| 3383 | 883.4 | Advanced addressing | 261d? | 1999-01-01 A | 1999-12-31 A | 100% | 1999-01-01 | 1999-12-31 | 261d? | start no earlier than 1999-01-01 | S1 | 2088h | 2088h |  | R99 | Alain |  |  |  |
| 3384 | 883.5 | UMTS numbering, addressing and identities | 261d? | 1999-01-01 A | 1999-12-31 A | 100% | 1999-01-01 | 1999-12-31 | 261d? | start no earlier than 1999-01-01 | S1 | 2088h | 2088h |  | R99 | Alain |  |  |  |
| 3385 | 883.6 | Lawful Interception for GSM Features transposed to UMTS | 261d? | 1999-01-01 A | 1999-12-31 A | 100% | 1999-01-01 | 1999-12-31 | 261d? | start no earlier than 1999-01-01 | S3 | 2088h | 2088h | LI | R99 | Dionisio |  |  |  |

Notes:
- 3358: GPRS was introduced in Release 97. Release 99 brings a number of essential corrections e.g. on Downlink Power Control, Timing Advance procedure, Cell reselection delay time, PBCCH scheduling, PTCCH mapping, etc. / Text3: 05.02, 05.05, 05.08, 05.10, 05.50, 11.21, 23.064, 24.008, 24.060
- 3359: - / Text3: 02.60, 03.22, 03.64, 04.18, 04.60, 04.64, 04.65, 05.01, 05.02, 05.05, 05.08, 05.10, 08.08, 08.18, 11.10-1, 11.21, 22.041, 22.060, 23.003, 23.007, 23.060, 23.107, 23.122, 24.007, 24.008, 27.007, 27.060, 29.002, 29.016, 29.018, 29.060, 29.061
- 3360: Introduction of EGPRS (S1) + Introduction of Reserved Service Labels in the APN (N2) / Text3: 02.60, 23.003
- 3361: - / Text3: 23.003, 23.008, 29.060
- 3362: EDGE is independent of the frequency bands, so it can be deployed e.g. in 900 and 1900 MHz bands. The new physical layer based on 8-PSK modulation is introduced and EGPRS and ECSD facilitate the new modulation in single and multi slot constellation. / Text3: 10.59, 02.34, 02.60, 03.30, 05.10, 05.50, 11.26
- 3363: WID in SMG2 331/97, SMG 1147/97, SMG 1148/97 / Text3: 02.34, 03.10, 03.20, 03.64, 04.03, 04.04, 04.06, 04.08, 04.18, 04.21, 04.22, 04.60, 04.64, 05.01, 05.02, 05.03, 05.04, 05.05, 05.08, 05.10, 05.50, 07.01, 07.02, 07.03, 08.08, 08.20, 08.58, 08.60, 09.07, 09.18, 11.10-1, 11.11, 11.21, 11.26, 23.034, 24.008,
- 3364: WID in SMG2 331/97, SMG 1147/97, SMG 1148/97 / Text3: 05.05, 05.10, 05.50
- 3365: No additional features for R99. / Text3: 02.34, 04.18, 11.10-1
- 3366: ECSD supports both transparent and non-transparent services, up to 64 kbit/s and 57.6 kbit/s respectively. See Tdoc SMG2 670/99 ECSD Concept Evaluation for more info / Text3: 05.02, 08.58, 22.034
- 3367: - / Text3: 05.03
- 3368: - / Text3: 02.07, 03.64, 04.14, 04.18, 04.60, 05.05, 05.08, 24.008
- 3369: - / Text3: 05.03, 05.05, 05.08
- 3370: - / Text3: 04.18
- 3371: Support for EGPRS in ANSI-136 networks and EDGE Compact (for ANSI-136 networks only). COMPACT = Deployment of services in spectrum below 1 MHz / Text3: 03.22, 03.30, 03.64, 05.01, 05.02, 05.03, 05.05, 05.08, 05.10
- 3372: COMPACT = Deployment of services in spectrum below 1 MHz / Text3: 04.18, 05.02
- 3373: COMPACT = Deployment of services in spectrum below 1 MHz / Text3: 03.22, 04.18, 04.60, 05.08, 23.122, 24.008
- 3374: GSM in the 400 MHz bands allows to deploy GSM within frequency bands in the range 450 to 500 MHz, previously used for analogue cellular systems. See Tdoc SMG2 190/99 and 595/99 for further info. / Text3: 02.17, 03.22, 03.30, 04.04, 04.18, 04.60, 05.01, 05.02, 05.05, 05.08, 05.10, 05.50, 08.18, 08.58, 11.21, 24.008, 27.007
- 3375: - / Text3: 03.22, 03.30, 05.01, 05.05, 05.08
- 3376: - / Text3: 05.05
- 3377: No CR or new TS/TR approved under this WI / Text3: G2: 04.18 CR#A248 , 04.60 CR#B090
- 3378: -
- 3379: Moved to CT1 at TSG-T closure. Applicability of the Cell Broadcast Service (as defined for GSM network) to 3G networks / Text3: 23.041
- 3380: R98 MNP: mobile subscriber ability to change PLMN operator within the same country whilst retaining its original MS ISDN number (MSISDN). IMSI is changed, only MSISDN is kept. R99 adds requirements for North American Service Provider Number Portability. / Text3: 22.066
- 3381: - / Text3: 23.018, 23.066, 29.002
- 3382: framework for commercial and technical interworking between UMTS Home Environments and Serving Networks who have no direct prior commercial agreements with each other. / Text3: 22.101, 22.971
- 3383: - / Text3: 22.101, 22.75U, 22.975
- 3384: Also new requirements for Single and Multiple Numbering scheme was added (CR#20 and 21). Deleted the term International Mobile User Identifier (IMUI) and changed IMSI (International Mobile Station Identifier=>International Mobile Subscriber Identity. / Text3: 22.101
- 3385: Defines an interception system in UMTS that supports a number of regional interception regulations. Regional interception requirements shall be met in using specific (regional) mediation functions allowing only required information to be transported. / Text3: new 33.106, 33.107

| ID | WBS | Task | Duration | Start | Finish | Complete | Baseline start | Baseline finish | Baseline duration | Constraint | Resources | Work | Actual work | Text1 | Text6 | Text8 |
| --- | --- | --- | --- | --- | --- | --- | --- | --- | --- | --- | --- | --- | --- | --- | --- | --- |
| 3386 | 884 | **Charging** | 261d? | 1999-01-01 A | 1999-12-31 A | 100% | 1999-01-01 | 1999-12-31 | 261d? |  | S1,S5 | 6264h | 6264h | CH | R99 | Alain |
| 3387 | 884.1 | R99 Charging | 261d? | 1999-01-01 A | 1999-12-31 A | 100% | 1999-01-01 | 1999-12-31 | 261d? | start no earlier than 1999-01-01 | S1 | 2088h | 2088h | Charging | R99 | Alain |
| 3388 | 884.2 | R99 OAM Charging Management | 261d? | 1999-01-01 A | 1999-12-31 A | 100% | 1999-01-01 | 1999-12-31 | 261d? | start no earlier than 1999-01-01 | S5 | 2088h | 2088h | OAMCH, CH | R99 | Dionisio |
| 3389 | 885 | **Operations, Administration, Maintenance and Provisioning (OAM&P)** | 261d? | 1999-01-01 A | 1999-12-31 A | 100% | 1999-01-01 | 1999-12-31 | 261d? |  | S5 | 12528h | 12528h | OAM | R99 | Dionisio |
| 3390 | 885.1 | OAM Principles and High-level Requirements | 261d? | 1999-01-01 A | 1999-12-31 A | 100% | 1999-01-01 | 1999-12-31 | 261d? | start no earlier than 1999-01-01 | S5 | 2088h | 2088h | PR, Princs_&_Reqs_(PR) | R99 | Dionisio |
| 3391 | 885.2 | OAM Architecture | 261d? | 1999-01-01 A | 1999-12-31 A | 100% | 1999-01-01 | 1999-12-31 | 261d? | start no earlier than 1999-01-01 | S5 | 2088h | 2088h | OAMAR, AR, Telecom_Management_Arch_(AR) | R99 | Dionisio |
| 3392 | 885.3 | OAM Configuration Management | 261d? | 1999-01-01 A | 1999-12-31 A | 100% | 1999-01-01 | 1999-12-31 | 261d? | start no earlier than 1999-01-01 | S5 | 2088h | 2088h | OAMCM, CM | R99 | Dionisio |
| 3393 | 885.4 | OAM Fault Management | 261d? | 1999-01-01 A | 1999-12-31 A | 100% | 1999-01-01 | 1999-12-31 | 261d? | start no earlier than 1999-01-01 | S5 | 2088h | 2088h | OAMFM | R99 | Dionisio |
| 3394 | 885.5 | OAM Performance Management | 261d? | 1999-01-01 A | 1999-12-31 A | 100% | 1999-01-01 | 1999-12-31 | 261d? | start no earlier than 1999-01-01 | S5 | 2088h | 2088h | OAMPM, PM | R99 | Dionisio |
| 3395 | 886 | Vocabulary | 261d? | 1999-01-01 A | 1999-12-31 A | 100% | 1999-01-01 | 1999-12-31 | 261d? | start no earlier than 1999-01-01 | S1 | 2088h | 2088h | Vocabulary | R99 | Alain |
| 3396 | 887 | Emergency | 261d? | 1999-01-01 A | 1999-12-31 A | 100% | 1999-01-01 | 1999-12-31 | 261d? | start no earlier than 1999-01-01 | S1 | 2088h | 2088h | Emergency | R99 | Alain |
| 3397 | 888 | GSM General Bearer Services (GBS) and interworking scenarios support in UMTS | 261d? | 1999-01-01 A | 1999-12-31 A | 100% | 1999-01-01 | 1999-12-31 | 261d? | start no earlier than 1999-01-01 | S1 | 2088h | 2088h | GSM_to_UMTS_Evol | R99 | Alain |
| 3398 | 889 | GPRS_Mobile_IP_interworking | 261d? | 1999-01-01 A | 1999-12-31 A | 100% | 1999-01-01 | 1999-12-31 | 261d? | start no earlier than 1999-01-01 | N3 | 2088h | 2088h | GPRS_Mobile_IP_interworking | R99 |  |
| 3399 | 890 | GSM/UMTS interworking | 261d? | 1999-01-01 A | 1999-12-31 A | 100% | 1999-01-01 | 1999-12-31 | 261d? | start no earlier than 1999-01-01 | N1,N2,N4,R3,S1,SMG | 2088h | 2088h | 2G3Ginterworking | R99 | Frederic |
| 3400 | 891 | Handover | 261d? | 1999-01-01 A | 1999-12-31 A | 100% | 1999-01-01 | 1999-12-31 | 261d? | start no earlier than 1999-01-01 | S1,SMG2,N1,N2,N4 | 2088h | 2088h | Handover | R99 | Alain |
| 3401 | 892 | 2G3Ghandover | 261d? | 1999-01-01 A | 1999-12-31 A | 100% | 1999-01-01 | 1999-12-31 | 261d? | start no earlier than 1999-01-01 | SMG2 | 2088h | 2088h | 2G3Ghandover | R99 |  |
| 3402 | 893 | Service Provider Name Indication | 261d? | 1999-01-01 A | 1999-12-31 A | 100% | 1999-01-01 | 1999-12-31 | 261d? | start no earlier than 1999-01-01 | S1 | 2088h | 2088h | SPANME | R99 | Alain |
| 3403 | 894 | Data & Data_CleanUp | 261d? | 1999-01-01 A | 1999-12-31 A | 100% | 1999-01-01 | 1999-12-31 | 261d? | start no earlier than 1999-01-01 | SMG1 | 2088h | 2088h | Data, Data_CleanUp | R99 |  |
| 3404 | 895 | Unstructured Supplementary Service Data | 261d? | 1999-01-01 A | 1999-12-31 A | 100% | 1999-01-01 | 1999-12-31 | 261d? | start no earlier than 1999-01-01 | SMG1,N4 | 2088h | 2088h | USSD | R99 | Kimmo |
| 3405 | 896 | Man-Machine Interface (MMI) of the User Equipment (UE) | 261d? | 1999-01-01 A | 1999-12-31 A | 100% | 1999-01-01 | 1999-12-31 | 261d? | start no earlier than 1999-01-01 | S1 | 2088h | 2088h | MMI | R99 | Alain |
| 3406 | 897 | Network Identity and Timezone (NITZ) | 261d? | 1999-01-01 A | 1999-12-31 A | 100% | 1999-01-01 | 1999-12-31 | 261d? | start no earlier than 1999-01-01 | SMG1,SMG3 | 2088h | 2088h | NITZ | R99 | Alain |
| 3407 | 898 | Deleted - Operator Determined Barring for Packet Oriented Services | 261d? | 1999-01-01 A | 1999-12-31 A | 100% | 1999-01-01 | 1999-12-31 | 261d? | start no earlier than 1999-01-01 | S1 | 2088h | 2088h | ODB_Enh. | R99 | Alain |
| 3408 | 899 | Packet Flow Management | 261d? | 1999-01-01 A | 1999-12-31 A | 100% | 1999-01-01 | 1999-12-31 | 261d? | start no earlier than 1999-01-01 | SMG2 | 2088h | 2088h | Packet_Flow_Management | R99 |  |
| 3409 | 900 | GPRS_Point-To-Multipoint Group call | 261d? | 1999-01-01 A | 1999-12-31 A | 100% | 1999-01-01 | 1999-12-31 | 261d? | start no earlier than 1999-01-01 | SMG1 | 2088h | 2088h | GPRS_PTMG | R99 |  |

Notes:
- 3386: -
- 3387: - / Text3: 22.115, 23.121
- 3388: - / Text3: 32.005, 32.015
- 3389: -
- 3390: - / Text3: 32.101
- 3391: - / Text3: 32.101, 32.102
- 3392: - / Text3: 32.106, 32.106-1, 32.106-2, 32.106-3, 32.106-4, 32.106-5, 32.106-6, 32.106-7, 32.106-8
- 3393: - / Text3: 32.111, 32.111-1, 32.111-2, 32.111-3, 32.111-4
- 3394: - / Text3: 12.04, 32.104
- 3395: - / Text3: 21.905
- 3396: - / Text3: 22.101
- 3397: UMTS shall support GSM General Bearer Services (GBS) and interworking scenarios as specified in 02.02 / Text3: 22.105
- 3398: - / Text3: 29.061
- 3399: - / Text3: 03.22, 04.18, 04.60, 05.02, 05.08, 05.10, 08.08, 08.18, 08.58, 09.08, 22.011, 23.003, 23.009, 23.014, 23.034, 23.122, 24.007, 24.008, 24.011, 24.080, 29.108
- 3400: - / Text3: 04.18, 08.08, 08.58, 22.129, 23.009, 29.002, 29.010
- 3401: - / Text3: 04.18, 04.60, 05.02, 05.08, 05.10, 08.08, 29.010
- 3402: Service Provider Name Indication included in R98 (02.07) was not carried into R99 (22.101), but is in the SIM/USIM specification for R99 / Text3: 22.101
- 3403: - / Text3: 02.01, 02.02, 02.04, 02.34
- 3404: No additional features for R99. / Text3: 02.04, 02.90, 23.090, 29.002
- 3405: Data services streamlining + Support for Anonymous Call Rejection / Text3: 22.030
- 3406: - / Text3: 02.42, 04.08
- 3407: Remove ODB for Packet Oriented Services from R99 / Text3: 22.041
- 3408: - / Text3: 08.18
- 3409: - / Text3: 02.60

| ID | WBS | Task | Duration | Start | Finish | Complete | Baseline start | Baseline finish | Baseline duration | Constraint | Resources | Work | Actual work | Text6 | Text8 |
| --- | --- | --- | --- | --- | --- | --- | --- | --- | --- | --- | --- | --- | --- | --- | --- |
| 3410 | 901 | **Call Forwarding** | 261d? | 1999-01-01 A | 1999-12-31 A | 100% | 1999-01-01 | 1999-12-31 | 261d? |  | SMG1,N2,N4 | 8352h | 8352h | R99 | Kimmo |
| 3411 | 901.1 | Call Forwarding enhancements | 261d? | 1999-01-01 A | 1999-12-31 A | 100% | 1999-01-01 | 1999-12-31 | 261d? | start no earlier than 1999-01-01 | N4,N2 | 2088h | 2088h | R99 | Kimmo |
| 3412 | 901.2 | Call_Forwarding | 261d? | 1999-01-01 A | 1999-12-31 A | 100% | 1999-01-01 | 1999-12-31 | 261d? | start no earlier than 1999-01-01 | SMG1,N2 | 2088h | 2088h | R99 | Kimmo |
| 3413 | 901.3 | Call_Forwarding_Enhancements | 261d? | 1999-01-01 A | 1999-12-31 A | 100% | 1999-01-01 | 1999-12-31 | 261d? | start no earlier than 1999-01-01 | N4 | 2088h | 2088h | R99 | Kimmo |
| 3414 | 902 | **Quality of Service** | 261d? | 1999-01-01 A | 1999-12-31 A | 100% | 1999-01-01 | 1999-12-31 | 261d? |  | S2,T2,N1,N2,N4 | 10440h | 10440h | R99 | Maurice |
| 3415 | 902.1 | End-to-end UMTS Quality of Service management | 261d? | 1999-01-01 A | 1999-12-31 A | 100% | 1999-01-01 | 1999-12-31 | 261d? | start no earlier than 1999-01-01 | S2,T2,N1,N2,N4 | 2088h | 2088h | R99 | Maurice |
| 3416 | 902.2 | End-to-end QoS for PS Domain including IMS | 261d? | 1999-01-01 A | 1999-12-31 A | 100% | 1999-01-01 | 1999-12-31 | 261d? | start no earlier than 1999-01-01 | S2 | 2088h | 2088h | R99 | Maurice |
| 3417 | 902.3 | GPRS-enhanced_QoS | 261d? | 1999-01-01 A | 1999-12-31 A | 100% | 1999-01-01 | 1999-12-31 | 261d? | start no earlier than 1999-01-01 | T2 | 2088h | 2088h | R99 |  |
| 3418 | 902.4 | QoS_enhancements | 261d? | 1999-01-01 A | 1999-12-31 A | 100% | 1999-01-01 | 1999-12-31 | 261d? | start no earlier than 1999-01-01 | N2,N1,N4 | 2088h | 2088h | R99 | Kimmo |
| 3419 | 903 | Support of Localised Service Area | 261d? | 1999-01-01 A | 1999-12-31 A | 100% | 1999-01-01 | 1999-12-31 | 261d? | start no earlier than 1999-01-01 | SMG2,SMG3,SMG7,N2 | 2088h | 2088h | R99 | Maurice |
| 3420 | 904 | Transcoder_location | 261d? | 1999-01-01 A | 1999-12-31 A | 100% | 1999-01-01 | 1999-12-31 | 261d? | start no earlier than 1999-01-01 | S2 | 2088h | 2088h | R99 | Maurice |
| 3421 | 905 | Antenna_test_methods | 261d? | 1999-01-01 A | 1999-12-31 A | 100% | 1999-01-01 | 1999-12-31 | 261d? | start no earlier than 1999-01-01 | SMG2 | 2088h | 2088h | R99 |  |
| 3422 | 906 | WBAMR / high quality speech in UMTS Phase 1 but not in R99 | 261d? | 1999-01-01 A | 1999-12-31 A | 100% | 1999-01-01 | 1999-12-31 | 261d? | start no earlier than 1999-01-01 | S1 | 2088h | 2088h | R99 | Alain |
| 3423 | 907 | **Codec** | 261d? | 1999-01-01 A | 1999-12-31 A | 100% | 1999-01-01 | 1999-12-31 | 261d? |  | S4 | 14616h | 14616h | R99 | Paolo |
| 3424 | 907.1 | Codec(s)_for_Multimedia_Telephony_Service | 261d? | 1999-01-01 A | 1999-12-31 A | 100% | 1999-01-01 | 1999-12-31 | 261d? | start no earlier than 1999-01-01 | S4 | 2088h | 2088h | R99 | Paolo |
| 3425 | 907.2 | QoS for Speech and Multimedia Codec | 261d? | 1999-01-01 A | 1999-12-31 A | 100% | 1999-01-01 | 1999-12-31 | 261d? | start no earlier than 1999-01-01 | S4 | 2088h | 2088h | R99 | Paolo |
| 3426 | 907.3 | Tandem Free Operation - Adaptive Multi-Rate codec types | 261d? | 1999-01-01 A | 1999-12-31 A | 100% | 1999-01-01 | 1999-12-31 | 261d? | start no earlier than 1999-01-01 | S4 | 2088h | 2088h | R99 | Paolo |
| 3427 | 907.4 | Noise Suppression for AMR | 261d? | 1999-01-01 A | 1999-12-31 A | 100% | 1999-01-01 | 1999-12-31 | 261d? | start no earlier than 1999-01-01 | S4 | 2088h | 2088h | R99 | Paolo |
| 3428 | 907.5 | Out-of-Band Transcoder | 261d? | 1999-01-01 A | 1999-12-31 A | 100% | 1999-01-01 | 1999-12-31 | 261d? | start no earlier than 1999-01-01 | N1 | 2088h | 2088h | R99 | Frederic |
| 3429 | 907.6 | Out-of-Band Transcoder Control | 261d? | 1999-01-01 A | 1999-12-31 A | 100% | 1999-01-01 | 1999-12-31 | 261d? | start no earlier than 1999-01-01 | N1 | 2088h | 2088h | R99 | Frederic |
| 3430 | 908 | Advanced Speech Call Items enhancements | 261d? | 1999-01-01 A | 1999-12-31 A | 100% | 1999-01-01 | 1999-12-31 | 261d? | start no earlier than 1999-01-01 | SMG1,SMG2,SMG3,SMG7,SMG9,N1,N4,S1,T2 | 2088h | 2088h | R99 | Alain |
| 3431 | 909 | Call Control improvements | 261d? | 1999-01-01 A | 1999-12-31 A | 100% | 1999-01-01 | 1999-12-31 | 261d? | start no earlier than 1999-01-01 | N1 | 2088h | 2088h | R99 | Frederic |
| 3432 | 910 | Multimedia | 261d? | 1999-01-01 A | 1999-12-31 A | 100% | 1999-01-01 | 1999-12-31 | 261d? | start no earlier than 1999-01-01 | N1,N3 | 2088h | 2088h | R99 | Frederic |
| 3433 | 911 | Sub-System Number allocation for RANAP, RNSAP | 261d? | 1999-01-01 A | 1999-12-31 A | 100% | 1999-01-01 | 1999-12-31 | 261d? | start no earlier than 1999-01-01 | N2 | 2088h | 2088h | R99 | Frederic |
| 3434 | 912 | Intranet / ISP access with DHCP end-to-end | 261d? | 1999-01-01 A | 1999-12-31 A | 100% | 1999-01-01 | 1999-12-31 | 261d? | start no earlier than 1999-01-01 | N3 | 2088h | 2088h | R99 | Gwiho |
| 3435 | 913 | Point_to_Multipoint_Services | 261d? | 1999-01-01 A | 1999-12-31 A | 100% | 1999-01-01 | 1999-12-31 | 261d? | start no earlier than 1999-01-01 | N3 | 2088h | 2088h | R99 | Gwiho |
| 3436 | 914 | Facsimile | 261d? | 1999-01-01 A | 1999-12-31 A | 100% | 1999-01-01 | 1999-12-31 | 261d? | start no earlier than 1999-01-01 | S1 | 2088h | 2088h | R99 | Alain |
| 3437 | 915 | Realtime_NT_FAX_in_UMTS | 261d? | 1999-01-01 A | 1999-12-31 A | 100% | 1999-01-01 | 1999-12-31 | 261d? | start no earlier than 1999-01-01 | N3 | 2088h | 2088h | R99 | Gwiho |
| 3438 | 916 | Gateway Location Register (GLR) - Mobile Application Part (MAP) specification | 261d? | 1999-01-01 A | 1999-12-31 A | 100% | 1999-01-01 | 1999-12-31 | 261d? | start no earlier than 1999-01-01 | N4 | 2088h | 2088h | R99 | Kimmo |
| 3439 | 917 | Multiple Subscriber Profile phase 2 | 261d? | 1999-01-01 A | 1999-12-31 A | 100% | 1999-01-01 | 1999-12-31 | 261d? | start no earlier than 1999-01-01 | S1,N4 | 2088h | 2088h | R99 | Alain |
| 3440 | 918 | Prepaging | 261d? | 1999-01-01 A | 1999-12-31 A | 100% | 1999-01-01 | 1999-12-31 | 261d? | start no earlier than 1999-01-01 | N2,N4 | 2088h | 2088h | R99 | Kimmo |
| 3441 | 919 | Re-definition of channel quality measure used for AMR link adaptation for Downlink Advanced Receiver Performance (DARP) MS | 261d? | 1999-01-01 A | 1999-12-31 A | 100% | 1999-01-01 | 1999-12-31 | 261d? | start no earlier than 1999-01-01 | SMG | 2088h | 2088h | R99 |  |
| 3442 | 920 | Harmonized Standard | 261d? | 1999-01-01 A | 1999-12-31 A | 100% | 1999-01-01 | 1999-12-31 | 261d? | start no earlier than 1999-01-01 | SMG2 | 2088h | 2088h | R99 |  |
| 3443 | 921 | Streamlining of specifications | 261d? | 1999-01-01 A | 1999-12-31 A | 100% | 1999-01-01 | 1999-12-31 | 261d? | start no earlier than 1999-01-01 | N3 | 2088h | 2088h | R99 | Gwiho |
| 3444 | 922 | R99_Service_Clean_up | 261d? | 1999-01-01 A | 1999-12-31 A | 100% | 1999-01-01 | 1999-12-31 | 261d? | start no earlier than 1999-01-01 | N3 | 2088h | 2088h | R99 | Gwiho |

Notes:
- 3410: -
- 3411: No additional features for R99. / Text1: CF_enhancements / Text3: 23.078, 23.079, 23.082, 29.002, 29.078
- 3412: - / Text1: Call_Forwarding / Text3: 02.82, 29.002
- 3413: - / Text1: Call_Forwarding_Enhancements / Text3: 23.082
- 3414: WID SMG 98-0781 End To End UMTS QoS Management
- 3415: WID SMG 98-0781 End To End UMTS QoS Management / Text1: QoS / Text3: 23.107, 23.907, 24.008
- 3416: - / Text1: E2EQoS / Text3: 23.060, 23.170
- 3417: AT-commands for Enhanced QoS Support management / Text1: GPRS-enhanced_QoS / Text3: 27.007
- 3418: - / Text1: QoS_enhancements / Text3: 23.008, 23.016, 24.008, 29.002, 29.060
- 3419: Mechanism which can be used as a platform for providing special tariffs and/or special set of service features for certain subscribers within a regionally restricted area or areas. No additional features for R99. / Text1: SoLSA / Text3: 04.08, 04.18, 08.08, 11.10-1, 29.002
- 3420: UE location identification: background information and associated primitives 2. Transcoder location at the core network and source depending coding belonging to the non-access stratum. / Text1: Transcoder_location / Text3: 23.110
- 3421: - / Text1: Antenna_test_methods / Text3: 03.30
- 3422: Add requirement for high quality speech in UMTS Phase 1 but not in R99 / Text1: WBAMR / Text3: 22.105
- 3423: -
- 3424: - / Text1: Multimedia_Codec, CSM, WI2MMC, Codec(s)_for_CS_MM_Tel._Serv, Codec(s)_for_MM_Tel_Service, Codec_for_Multimedia_Telephony / Text3: 26.911, 26.104, 26.111
- 3425: - / Text1: QoS_for_Speech_&_MM_Codecs_/_AMR / Text3: 26.102, 26.912
- 3426: UMTS_AMR2 is default Codec Type in R99 dual_mode terminals / Text1: TFOAMR / Text3: 26.103
- 3427: Combination of the AMR speech codec and the Noise Suppression function. TS 06.77 and TR 06.78 only apply to GSM. They apply to UMTS from Rel-4 onwards, when they were converted to TS 26.077 and TR 26.078. / Text1: AMRNS / Text3: 06.77, 06.78
- 3428: Transcoder handling in the CN at inter-system handover and relocation + Introduction of UMTS AMR / Text1: OoBT / Text3: 23.009, 24.008
- 3429: 24.008 CR#0572 in NP-020220 was approved under this WI / Text1: OoBTC / Text3: 24.008 CR#0572 in NP-020220
- 3430: - / Text1: ASCI / Text3: 02.30, 02.68, 03.68, 03.69, 04.18, 08.08, 11.10-1, 11.11, 23.067, 23.094, 24.008, 24.067, 27.007, 29.002
- 3431: Minor improvements to 24.007 and 24.008 to increase the number of simultaneous calls/sessions from the present 7: the TI value is increased (NP-99441). / Text1: CC_Related_items / Text3: 24.007, 24.008
- 3432: - / Text1: Multimedia / Text3: 24.008, 27.001, 29.007
- 3433: Sub-System Number allocation for Radio Access Network Application Part, Radio Network Subsystem Application Part / Text1: SSN_allocation / Text3: 23.003
- 3434: Access to an Intranet/ISP with DHCP end to end / Text1: ISPaccess / Text3: 29.061
- 3435: Support for the IP-Multicast protocol / Text1: Point_to_Multipoint_Services / Text3: 29.061
- 3436: - / Text1: FAX / Text3: 22.003, 22.100
- 3437: Asynchronous Interface for real-time NT Fax + Introduction of Asynchronous interface for Real-time non-transparent FAX / Text1: Realtime_NT_FAX_in_UMTS / Text3: 27.001, 27.003
- 3438: - / Text1: GLR / Text3: 29.120
- 3439: - / Text1: MSP2 / Text3: 22.097, 23.072, 23.083, 23.084, 23.091, 23.093, 23.097
- 3440: - / Text1: Prepaging / Text3: 23.018, 23.082, 29.002
- 3441: Re-definition of channel quality measure used for AMR link adaptation for DARP MS / Text3: 05.09
- 3442: - / Text1: HS / Text3: 13.21
- 3443: - / Text1: Streamlining / Text3: 27.060, 29.061
- 3444: - / Text1: R99_Service_Clean_up / Text3: 03.10, 27.001, 27.002, 27.003, 27.060, 29.007, 29.061

| ID | WBS | Task | Type | Duration | Start | Finish | Complete | Baseline start | Baseline finish | Baseline duration | Constraint | Resources | Work | Actual work | Text1 | Text6 | Text8 | Text3 | Text12 | Text4 | Text5 |
| --- | --- | --- | --- | --- | --- | --- | --- | --- | --- | --- | --- | --- | --- | --- | --- | --- | --- | --- | --- | --- | --- |
| 3445 | 923 | **(Small) Technical Enhancements and Improvements for R99** |  | 261d? | 1999-01-01 A | 1999-12-31 A | 100% | 1999-01-01 | 1999-12-31 | 261d? |  | N3 | 6264h | 6264h | TEI | R99 | Gwiho |  |  |  |  |
| 3446 | 923.1 | TEI_[CS_Data] |  | 261d? | 1999-01-01 A | 1999-12-31 A | 100% | 1999-01-01 | 1999-12-31 | 261d? | start no earlier than 1999-01-01 | N3 | 2088h | 2088h | TEI_[CS_Data] | R99 | Gwiho |  |  |  |  |
| 3447 | 923.2 | TEI_[GPRS] |  | 261d? | 1999-01-01 A | 1999-12-31 A | 100% | 1999-01-01 | 1999-12-31 | 261d? | start no earlier than 1999-01-01 | N3 | 2088h | 2088h | TEI_[GPRS] | R99 | Gwiho |  |  |  |  |
| 3448 | 924 | **R99 UE Conformance Testing** |  | 261d? | 1999-01-01 A | 1999-12-31 A | 100% | 1999-01-01 | 1999-12-31 | 261d? |  | R5,T1 | 4176h | 4176h | TEI_Test | R99 | Ingbert | 34.108, 34.121, 34.122, 34.123-1, 34.123-2, 34.123-3 |  |  |  |
| 3449 | 924.1 | Deleted - RTEI |  | 261d? | 1999-01-01 A | 1999-12-31 A | 100% | 1999-01-01 | 1999-12-31 | 261d? | start no earlier than 1999-01-01 | T1 | 2088h | 2088h | RTEI | R99 | Ingbert | 34.123-1 CR#0650, 0651, 34.123-3 CR#0148, 0149, 0150 | TP-06 |  |  |
| 3450 | 924.2 | Common test environments for User Equipment (UE); Conformance testing | milestone | 0d? | 1999-01-01 A | 1999-01-01 A | 100% | 1999-01-01 | 1999-01-01 | 0d? | start no earlier than 1999-01-01 | R5,T1 |  |  | TEI_Test | R99 | Ingbert | 34.108 |  |  |  |
| 3451 | 924.3 | Terminal conformance specification, Radio transmission and reception (FDD) | milestone | 0d? | 1999-01-01 A | 1999-01-01 A | 100% | 1999-01-01 | 1999-01-01 | 0d? | start no earlier than 1999-01-01 | R5,T1 |  |  | TEI_Test | R99 | Ingbert | 34.121 |  |  |  |
| 3452 | 924.4 | Terminal conformance specification, Radio transmission and reception (TDD) | milestone | 0d? | 1999-01-01 A | 1999-01-01 A | 100% | 1999-01-01 | 1999-01-01 | 0d? | start no earlier than 1999-01-01 | R5,T1 |  |  | TEI_Test | R99 | Ingbert | 34.122 |  |  |  |
| 3453 | 924.5 | UE conformance specification; Part 1: Protocol conformance specification | milestone | 0d? | 1999-01-01 A | 1999-01-01 A | 100% | 1999-01-01 | 1999-01-01 | 0d? | start no earlier than 1999-01-01 | R5,T1 |  |  | TEI_Test | R99 | Ingbert | 34.123-1 |  |  |  |
| 3454 | 924.6 | UE conformance specification; Part 2: Implementation Conformance Statement (ICS) specification | milestone | 0d? | 1999-01-01 A | 1999-01-01 A | 100% | 1999-01-01 | 1999-01-01 | 0d? | start no earlier than 1999-01-01 | R5,T1 |  |  | TEI_Test | R99 | Ingbert | 34.123-2 |  |  |  |
| 3455 | 924.7 | UE conformance specification; Part 3: Abstract test suites (ATSs) | milestone | 0d? | 1999-01-01 A | 1999-01-01 A | 100% | 1999-01-01 | 1999-01-01 | 0d? | start no earlier than 1999-01-01 | R5,T1 |  |  | TEI_Test | R99 | Ingbert | 34.123-3 |  |  |  |
| 3456 | 925 | Deleted - Dual Tone Multi-Frequency signalling : Support in the whole 3GPP system |  | 261d? | 1999-01-01 A | 1999-12-31 A | 100% | 1999-01-01 | 1999-12-31 | 261d? | start no earlier than 1999-01-01 | N1 | 2088h | 2088h | DTMF | R99 | Frederic | 23.014 CR#0004 | NP-06 |  |  |
| 3457 | 926 | Deleted - Intersystem_Change |  | 261d? | 1999-01-01 A | 1999-12-31 A | 100% | 1999-01-01 | 1999-12-31 | 261d? | start no earlier than 1999-01-01 | SMG | 2088h | 2088h | Intersystem_Change | R99 |  | 04.18 CR#A243 | SMG |  |  |
| 3458 | 927 | Deleted - Long_Forwardedto_Numbers |  | 261d? | 1999-01-01 A | 1999-12-31 A | 100% | 1999-01-01 | 1999-12-31 | 261d? | start no earlier than 1999-01-01 | N2 | 2088h | 2088h | Long_Forwardedto_Numbers | R99 | Kimmo | 29.002 | NP-06 |  |  |
| 3459 | 928 | Deleted - RANimp-FSEarlyUE |  | 261d? | 1999-01-01 A | 1999-12-31 A | 100% | 1999-01-01 | 1999-12-31 | 261d? | start no earlier than 1999-01-01 | R3 | 2088h | 2088h | RANimp-FSEarlyUE | R99 | Juha | 25.413 CR#0520, 0538, 0565, 0563, 0541, 0540, 0539, 0547 | RP-06 |  |  |
| 3460 | 929 | Release 1999 Studies |  | 261d? | 1999-01-01 A | 1999-12-31 A | 100% | 1999-01-01 | 1999-12-31 | 261d? |  | S1,T2 | 2088h | 2088h |  | R99 | Alain |  |  |  |  |
| 3461 | 930 | Advanced Addressing/Numbering |  | 261d? | 1999-01-01 A | 1999-12-31 A | 100% | 1999-01-01 | 1999-12-31 | 261d? | start no earlier than 1999-01-01 | S1 | 2088h | 2088h | Numbering | R99 | Alain | 22.975 |  | Vodafone | mona.mustapha@vodafone.com |
| 3462 | 931 | Combined GSM and Mobile IP mobility handling in UMTS IP CN |  | 261d? | 1999-01-01 A | 1999-12-31 A | 100% | 1999-01-01 | 1999-12-31 | 261d? | start no earlier than 1999-01-01 | S2 | 2088h | 2088h |  | R99 | Maurice | 23.923 |  |  |  |
| 3463 | 932 | UE Capabilities Requirements |  | 261d? | 1999-01-01 A | 1999-12-31 A | 100% | 1999-01-01 | 1999-12-31 | 261d? | start no earlier than 1999-01-01 | T2 | 2088h | 2088h | UCR | R99 |  | 21.904 |  |  |  |
| 3464 | 933 | Electrical safety requirements and regulations |  | 261d? | 1999-01-01 A | 1999-12-31 A | 100% | 1999-01-01 | 1999-12-31 | 261d? | start no earlier than 1999-01-01 | T2 | 2088h | 2088h |  | R99 |  | 34.907 |  |  |  |
| 3465 | 934 | Specific Absorbtion Rate (SAR) requirements and regulations in different regions |  | 261d? | 1999-01-01 A | 1999-12-31 A | 100% | 1999-01-01 | 1999-12-31 | 261d? | start no earlier than 1999-01-01 | T2 | 2088h | 2088h |  | R99 |  | 34.925 |  |  |  |
| 3466 | 935 | Multi-mode UE issues |  | 261d? | 1999-01-01 A | 1999-12-31 A | 100% | 1999-01-01 | 1999-12-31 | 261d? | start no earlier than 1999-01-01 | T2 | 2088h | 2088h |  | R99 |  | 21.810, 21.910 |  |  |  |
| 3467 | 936 | Provision of fax service in GSM and UMTS |  | 261d? | 1999-01-01 A | 1999-12-31 A | 100% | 1999-01-01 | 1999-12-31 | 261d? | start no earlier than 1999-01-01 | T2 | 2088h | 2088h |  | R99 |  | 22.945 |  | Ericsson | peter.bleckert@ericsson.com |
| 3468 | 937 | Separating Radio Resources and Mobility Management specific parts of the MS Classmark |  | 1d | 2000-01-03 A | 2000-01-03 A | 100% | 2000-01-03 | 2000-01-03 | 1d |  | T2 | 8h | 8h |  | R99 |  | 23.814 |  |  |  |

Notes:
- 3445: -
- 3446: -
- 3447: -
- 3448: Specifies Conformance Tests for a 3G UE to be recognised as 3GPP-standard compliant. A 3GPP-external body, GCF (Global Certification Forum), delivers certificates to prove that a UE has correctly passed tests and is then conform to the 3GPP standard.
- 3449: No CR or new TS/TR approved under this WI
- 3450: -
- 3451: measurement procedures for the conformance test of the UE that contain transmitting characteristics, receiving characteristics and performance requirements in addition to requirements for support of RRM (Radio Resource Management) in FDD mode.
- 3452: measurement procedures for the conformance test of the UE that contain transmitting characteristics, receiving characteristics and performance requirements in addition to requirements for support of RRM (Radio Resource Management) in TDD mode.
- 3453: TS 34.123, composed of three parts, actually specifies the protocol conformance testing for the 3G UE. Part 1 describes the overall test structure.
- 3454: Part 2 contains the applicability of each test case defined as the Implementation Conformance Statement (ICS) proforma, in compliance with the relevant requirements, and in accordance with the relevant guidance given in ISO/IEC 9646-7 and ETS 300 406.
- 3455: Part 3 specifies the protocol conformance testing in TTCN for the 3G UE at the Uu interface. It defines the TTCN test specification and design considerations in Abstract Test Suites based on the test cases specified in prose in part 1.
- 3456: No CR or new TS/TR approved under this WI
- 3457: No CR or new TS/TR approved under this WI
- 3458: -
- 3459: No CR or new TS/TR approved under this WI
- 3460: -
- 3461: Study on requirements for numbering and addressing for UMTS
- 3462: -
- 3463: Moved to CT1 at TSG-T closure
- 3464: Moved to RAN4 at TSG-T closure. TR summarizes differences between international and national standards relevant to IEC60950 and refers to regulations for conformity assessment due to different regulatory environments in different countries / regions.
- 3465: Moved to RAN4 at TSG-T closure.
- 3466: Moved to CT1 at TSG-T closure. Consequences on roaming capabilities and service availability (e.g. handover) of multi-mode UEs while roaming in various regions with various network configurations. Case studies for each of the possible scenarios in specs
- 3467: CP#27: Moved to C1 on closure of T2; see TP-050062. CP#28: C1->C3
- 3468: CP#27: change of WG as a result of closure of CN and T.
